# Outline ELEXON Plan_kc

How a schedule from MS Project changed from version to version. A marks actual dates.

## Version 1 (data date 2024-08-07, saved 2024-08-08, file MHHS-DEL1139 - MHHS Plan v5.30.mpp)

| ID | WBS | Task | Duration | Start | Finish | Predecessors | Complete | Total float | Constraint |
| --- | --- | --- | --- | --- | --- | --- | --- | --- | --- |
| 1 | 1 | **PROGRAMME PLAN** | 1195d | 2022-10-31 A | 2027-05-28 |  | 53% | 0d |  |
| 2 |  | MHHS Programme Start | 0d | 2022-10-31 A | 2022-10-31 A |  | 100% |  |  |
| 3 | 1.2 | **PROGRAMME MANAGEMENT** | 1089d | 2022-10-31 A | 2026-12-31 |  | 42% | 106d |  |
| 4 | 1.2.1 | **Programme Management** | 1089d | 2022-10-31 A | 2026-12-31 |  | 41% | 106d |  |
| 5 |  | Sprint-based prioritisation planning and execution | 1089d | 2022-10-31 A | 2026-12-31 |  | 41% | 106d | finish no earlier than 2026-12-31 |
| 6 |  | Programme governance secretariat | 1089d | 2022-10-31 A | 2026-12-31 |  | 41% | 106d |  |
| 7 |  | RAID management and reporting | 1089d | 2022-10-31 A | 2026-12-31 |  | 41% | 106d |  |
| 8 |  | Tracking against Programme outcomes and KPIs | 1089d | 2022-10-31 A | 2026-12-31 |  | 41% | 106d |  |
| 9 |  | Change control and reporting | 1089d | 2022-10-31 A | 2026-12-31 |  | 41% | 106d |  |
| 10 |  | Ongoing identification of lessons learned relating to the PMO and implementation of improvements | 1089d | 2022-10-31 A | 2026-12-31 |  | 41% | 106d |  |
| 11 | 1.2.2 | **Programme Internal Assurance Reviews** | 1089d | 2022-10-31 A | 2026-12-31 |  | 41% | 106d |  |
| 12 |  | Programme Internal Assurance Reviews | 1089d | 2022-10-31 A | 2026-12-31 |  | 41% | 106d |  |
| 13 | 1.2.3 | **Engagement with PPs** | 1089d | 2022-10-31 A | 2026-12-31 |  | 41% | 106d |  |
| 14 |  | Ongoing PP liaison activities | 1089d | 2022-10-31 A | 2026-12-31 |  | 41% | 106d |  |
| 15 |  | Milestone and Control Point objective setting | 1089d | 2022-10-31 A | 2026-12-31 |  | 41% | 106d |  |
| 16 |  | Reporting | 1089d | 2022-10-31 A | 2026-12-31 |  | 41% | 106d |  |
| 17 | 1.2.3.4 | **PP Engagement Events** | 1089d | 2022-10-31 A | 2026-12-31 |  | 41% | 106d |  |
| 18 |  | Bilateral meetings | 1089d | 2022-10-31 A | 2026-12-31 |  | 41% | 106d |  |
| 19 |  | Monthly webinars | 1089d | 2022-10-31 A | 2026-12-31 |  | 41% | 106d |  |
| 20 |  | Open days | 1089d | 2022-10-31 A | 2026-12-31 |  | 41% | 106d |  |
| 21 | 1.2.3.5 | **PP Communications** | 1088d | 2022-10-31 A | 2026-12-30 |  | 41% | 107d |  |
| 22 |  | The Clock updates (weekly) | 1088d | 2022-10-31 A | 2026-12-30 |  | 41% | 107d |  |
| 23 |  | Maintain and update content on public-facing Portal (and ongoing feedback reviews to identify and implement Portal improvements) | 1088d | 2022-10-31 A | 2026-12-30 |  | 41% | 107d |  |
| 24 | 1.2.4 | **Code Change Support / Other Programme Alignment** | 1089d | 2022-10-31 A | 2026-12-31 |  | 41% | 106d |  |
| 25 |  | Support DCC/BEIS on SEC change | 1089d | 2022-10-31 A | 2026-12-31 |  | 41% | 106d |  |
| 26 |  | Support on Smart Meters Act changes | 1089d | 2022-10-31 A | 2026-12-31 |  | 41% | 106d |  |
| 27 |  | Support DCC/RECCo on CSS change | 1089d | 2022-10-31 A | 2026-12-31 |  | 41% | 106d |  |
| 28 |  | Support Elexon on BSC change | 1089d | 2022-10-31 A | 2026-12-31 |  | 41% | 106d |  |
| 29 |  | Support code change inside & outside CCIAG | 1089d | 2022-10-31 A | 2026-12-31 |  | 41% | 106d |  |
| 30 |  | Support code change inside & outside CCAG | 1089d | 2022-10-31 A | 2026-12-31 |  | 41% | 106d |  |
| 31 | 1.2.5 | **Programme Replan Baseline** | 163d | 2022-10-31 A | 2023-06-14 A |  | 100% |  |  |
| 32 |  | Round 3 consultation preparation | 32d | 2022-10-31 A | 2022-12-13 A |  | 100% |  |  |
| 33 |  | PSG decision to launch Round 3 consultation | 0d | 2022-12-07 A | 2022-12-07 A | 32FS-5d | 100% |  |  |
| 34 |  | Round 3 consultation (incl. walkthroughs and Q&A) | 35d | 2022-12-14 A | 2023-01-31 A | 33FS+5d | 100% |  |  |
| 35 |  | Review and uplift of foundational testing documents to align with replan approach | 92d | 2022-12-14 A | 2023-04-20 A | 34SS | 100% |  |  |
| 36 |  | Round 3 consultation responses analysis (incl. identification of SIT volunteers) | 10d | 2023-02-01 A | 2023-02-14 A | 34 | 100% |  |  |
| 37 |  | Replan re-drafting and supporting artefact updates (incl. engagement with Ofgem) | 26d | 2023-02-15 A | 2023-03-22 A | 36 | 100% |  |  |
| 38 |  | Draft Replan Change Request | 31d | 2023-02-15 A | 2023-03-29 A | 36 | 100% |  |  |
| 39 |  | PSG decision to issue CR for industry impact assessment | 0d | 2023-04-05 A | 2023-04-05 A | 38FS+5d | 100% |  |  |
| 40 |  | Industry impact assessment | 10d | 2023-04-06 A | 2023-04-19 A | 39 | 100% |  |  |
| 41 |  | Replan playbacks (to assist PPs in impact assessment) | 5d | 2023-04-11 A | 2023-04-17 A | 40SS+3d | 100% |  |  |
| 42 |  | Industry impact assessment responses analysis | 5d | 2023-04-20 A | 2023-04-26 A | 40 | 100% |  |  |
| 43 |  | Extraordinary PSG decision to agree baseline recommendation | 0d | 2023-05-03 A | 2023-05-03 A | 42FS+5d | 100% |  |  |
| 44 |  | Plan Rebaselined (subject to Ofgem decision) | 0d | 2023-06-08 A | 2023-06-08 A | 43FS+25d | 100% |  | start no earlier than 2023-06-08 |
| 45 |  | Programme Replan playbacks and drop-in sessions | 5d | 2023-06-08 A | 2023-06-14 A | 44 | 100% |  |  |
| 46 | 1.3 | **DESIGN, BUILD & TEST (PIT)** | 1101d | 2022-10-31 A | 2027-01-18 |  | 81% | 94d |  |
| 47 | 1.3.1 | **Design Baseline & Enduring PP Support** | 1101d | 2022-10-31 A | 2027-01-18 |  | 71% | 94d |  |
| 48 |  | Physical design baselined (M5) | 0d | 2022-10-31 A | 2022-10-31 A |  | 100% |  |  |
| 49 | 1.3.1.2 | **M5 Design Work-Off Plan Implementation & Approval** | 79d | 2022-10-31 A | 2023-02-16 A |  | 100% |  |  |
| 50 |  | Implementation of M5 design Work-Off Plan | 74d | 2022-10-31 A | 2023-02-09 A | 48 | 100% |  |  |
| 51 |  | M5 design Work-Off Plan completion approved | 0d | 2023-02-16 A | 2023-02-16 A | 50FS+5d | 100% |  |  |
| 52 | 1.3.1.3 | **Enduring PP Design Support** | 1089d | 2022-10-31 A | 2026-12-31 A |  | 100% |  |  |
| 53 |  | Design playbacks and drop-in sessions | 45d | 2022-10-31 A | 2022-12-30 A | 48 | 100% |  |  |
| 54 |  | Support participants on E2E MHHS Design | 1089d | 2022-10-31 A | 2026-12-31 A | 48 | 100% |  |  |
| 55 |  | DIP Onboarding Support | 70d | 2022-11-14 A | 2023-02-17 A |  | 100% |  | must start on 2022-11-14 |
| 56 |  | iServer Launch | 0d | 2023-02-16 A | 2023-02-16 A | 51 | 100% |  |  |
| 57 | 1.3.1.4 | **Establish Design Change Management Processes** | 1101d | 2022-10-31 A | 2027-01-18 |  | 36% | 94d |  |
| 58 |  | Internal review of internal change management processes | 35d | 2022-10-31 A | 2022-12-16 A |  | 100% |  |  |
| 59 |  | SRO approval of internal change management processes | 0d | 2022-12-16 A | 2022-12-16 A | 58FF | 100% |  |  |
| 60 |  | Change Process Webinar | 0d | 2023-01-16 A | 2023-01-16 A |  | 100% |  | must start on 2023-01-16 |
| 61 |  | Enduring change management process approved | 0d | 2023-02-16 A | 2023-02-16 A | 51FF | 100% |  |  |
| 62 |  | Maintain E2E MHHS Design (post-M5 design change management processes operational) | 1022d | 2023-02-17 A | 2027-01-18 | 61 | 34% | 94d |  |
| 63 | 1.3.1.5 | **Design Authority Mobilisation** | 29d | 2022-12-14 A | 2023-01-23 A |  | 100% |  |  |
| 64 |  | Design Authority ToR approved | 0d | 2022-12-14 A | 2022-12-14 A |  | 100% |  | must start on 2022-12-14 |
| 65 |  | Inaugural Design Authority | 0d | 2023-01-23 A | 2023-01-23 A | 64FS+29d | 100% |  |  |
| 66 | 1.3.1.6 | **Network Operation Services Adaptor Procurement** | 0d | 2023-05-23 A | 2023-05-23 A |  | 100% |  |  |
| 67 |  | All SIT LDSOs have procured their adapter providers | 0d | 2023-05-23 A | 2023-05-23 A | 524SS | 100% |  |  |
| 68 | 1.3.2 | **PP Mobilisation** | 67d | 2022-10-31 A | 2023-01-31 A |  | 100% |  |  |
| 69 |  | Set up governance | 67d | 2022-10-31 A | 2023-01-31 A |  | 100% |  |  |
| 70 |  | Set up reporting | 67d | 2022-10-31 A | 2023-01-31 A |  | 100% |  |  |

| ID | WBS | Task | Duration | Start | Finish | Predecessors | Complete | Total float | Constraint |
| --- | --- | --- | --- | --- | --- | --- | --- | --- | --- |
| 71 |  | Obtain funding | 67d | 2022-10-31 A | 2023-01-31 A |  | 100% |  |  |
| 72 |  | Earmark resources | 67d | 2022-10-31 A | 2023-01-31 A |  | 100% |  |  |
| 73 |  | Mobilise initial team | 67d | 2022-10-31 A | 2023-01-31 A |  | 100% |  |  |
| 74 | 1.3.3 | **PIT Stub Specification and Delivery** | 435d | 2022-10-31 A | 2024-06-28 A |  | 100% |  |  |
| 75 | 1.3.3.1 | **DIP Simulator** | 108d | 2022-10-31 A | 2023-03-29 A |  | 100% |  |  |
| 76 |  | Build & Test | 95d | 2022-10-31 A | 2023-03-10 A | 48 | 100% |  |  |
| 77 |  | UAT | 85d | 2022-11-14 A | 2023-03-10 A | 76SS+10d | 100% |  |  |
| 78 |  | Beta test | 95d | 2022-10-31 A | 2023-03-10 A | 76SS | 100% |  |  |
| 79 |  | Prepare for release | 18d | 2023-03-06 A | 2023-03-29 A | 78FS-5d | 100% |  |  |
| 80 |  | DIP Simulator released | 0d | 2023-03-29 A | 2023-03-29 A | 79FF | 100% |  | start no earlier than 2023-01-30 |
| 81 | 1.3.3.2 | **DIP Simulator Uplifts** | 257d | 2023-07-06 A | 2024-06-28 A |  | 100% |  |  |
| 82 |  | DIP Simulator uplifted to align with design releases - design/build/test | 27d | 2023-07-06 A | 2023-08-11 A | 118 | 100% |  |  |
| 83 |  | DIP Simulator uplifted to align with Interim Release 2 | 0d | 2023-08-11 A | 2023-08-11 A | 82 | 100% |  |  |
| 84 |  | DIP Simulator uplifted to align with design releases - design/build/test | 20d | 2023-10-09 A | 2023-11-03 A | 127FS+2d | 100% |  |  |
| 85 |  | DIP Simulator uplifted to align with Interim Release 5 | 0d | 2023-11-03 A | 2023-11-03 A | 84 | 100% |  |  |
| 86 |  | DIP Simulator uplifted to align with design releases - design/build/test | 37d | 2024-02-01 A | 2024-03-22 A | 135 | 100% |  |  |
| 87 |  | DIP Simulator uplifted to align with Interim Release 7 | 0d | 2024-03-22 A | 2024-03-22 A | 86 | 100% |  |  |
| 88 |  | DIP Simulator uplifted to align with design releases - design/build/test | 57d | 2024-04-04 A | 2024-06-21 A | 139 | 100% |  |  |
| 89 |  | DIP Simulator uplifted to align with Interim Release 8 | 0d | 2024-06-28 A | 2024-06-28 A | 88FS+5d | 100% |  |  |
| 90 | 1.3.3.3 | **Data Generator** | 130d | 2022-12-01 A | 2023-05-31 A |  | 100% |  |  |
| 91 |  | Design | 15d | 2022-12-01 A | 2022-12-21 A |  | 100% |  |  |
| 92 |  | Build & Test | 50d | 2023-02-16 A | 2023-04-26 A | 91FS+40d | 100% |  |  |
| 93 |  | UAT | 10d | 2023-04-27 A | 2023-05-10 A | 92 | 100% |  |  |
| 94 |  | Beta test | 45d | 2023-03-30 A | 2023-05-31 A | 92FS-20d, 96FF | 100% |  |  |
| 95 |  | Prepare for release | 24d | 2023-04-27 A | 2023-05-30 A | 93SS | 100% |  |  |
| 96 |  | Data Generator released | 0d | 2023-05-31 A | 2023-05-31 A | 95FS+1d | 100% |  |  |
| 97 | 1.3.4 | **Design Artefact Releases** | 398d | 2023-02-22 A | 2024-08-30 |  | 97% | 5d |  |
| 98 | 1.3.4.1 | **Interim release 1** | 79d | 2023-02-22 A | 2023-06-12 A |  | 100% |  |  |
| 99 |  | Prioritise DINs and CR | 1d | 2023-02-22 A | 2023-02-22 A |  | 100% |  | must start on 2023-02-22 |
| 100 | 1.3.4.1.2 | **Industry input session** | 7d | 2023-02-23 A | 2023-03-03 A |  | 100% |  |  |
| 101 |  | Raise a CR covering prioritized assessment cluster | 1d | 2023-02-23 A | 2023-02-23 A | 99 | 100% |  |  |
| 102 |  | Organize Industry Input session to go through significant items to reach consensus | 1d | 2023-02-23 A | 2023-02-23 A | 101SS | 100% |  |  |
| 103 |  | Conduct Meeting | 1d | 2023-03-03 A | 2023-03-03 A | 102FS+5d | 100% |  |  |
| 104 |  | Update baselined artefacts | 10d | 2023-03-24 A | 2023-04-06 A |  | 100% |  |  |
| 105 | 1.3.4.1.4 | **Participant review and impact assess changes** | 18d | 2023-04-14 A | 2023-05-09 A |  | 100% |  |  |
| 106 |  | Issue Redline Version of documents | 1d | 2023-04-14 A | 2023-04-14 A | 104FS+5d | 100% |  |  |
| 107 |  | Participants provide review comments to common log | 17d | 2023-04-17 A | 2023-05-09 A | 106 | 100% |  |  |
| 108 | 1.3.4.1.5 | **Assurance review** | 19d | 2023-05-10 A | 2023-06-05 A |  | 100% |  |  |
| 109 |  | SI Design Review and Respond to Comments | 5d | 2023-05-10 A | 2023-05-16 A | 107 | 100% |  |  |
| 110 |  | Prep for Assurance Review Meeting | 7d | 2023-05-17 A | 2023-05-25 A | 109 | 100% |  |  |
| 111 |  | Conduct Assurance Review Meeting | 1d | 2023-05-26 A | 2023-05-26 A | 110 | 100% |  |  |
| 112 |  | Update Artefacts following Assurance Review | 6d | 2023-05-29 A | 2023-06-05 A | 111 | 100% |  |  |
| 113 |  | PSG Approval of interim release plan | 1d | 2023-06-08 A | 2023-06-08 A |  | 100% |  | must start on 2023-06-08 |
| 114 |  | Publish updated baselined artefacts | 0d | 2023-06-06 A | 2023-06-12 A | 112 | 100% |  |  |
| 115 |  | Interim release 1 Go live | 0d | 2023-06-12 A | 2023-06-12 A | 114 | 100% |  |  |
| 116 | 1.3.4.2 | **Interim release 2** | 27d | 2023-05-30 A | 2023-07-05 A |  | 100% |  |  |
| 117 |  | Update baselined artefacts | 27d | 2023-05-30 A | 2023-07-05 A |  | 100% |  | must start on 2023-05-30 |
| 118 |  | Interim release 2 Go live | 0d | 2023-07-05 A | 2023-07-05 A | 117 | 100% |  |  |
| 119 | 1.3.4.3 | **Interim release 3** | 35d | 2023-06-15 A | 2023-08-02 A |  | 100% |  |  |
| 120 |  | Update baselined artefacts | 35d | 2023-06-15 A | 2023-08-02 A |  | 100% |  | must start on 2023-06-15 |
| 121 |  | Interim release 3 Go live | 0d | 2023-08-02 A | 2023-08-02 A | 120 | 100% |  |  |
| 122 | 1.3.4.4 | **Interim release 4** | 36d | 2023-07-12 A | 2023-08-30 A |  | 100% |  |  |
| 123 |  | Update baselined artefacts | 36d | 2023-07-12 A | 2023-08-30 A |  | 100% |  | must start on 2023-07-12 |
| 124 |  | Interim release 4 Go live | 0d | 2023-08-30 A | 2023-08-30 A | 123 | 100% |  |  |
| 125 | 1.3.4.5 | **Interim release 5** | 147d | 2023-08-17 A | 2024-03-08 A |  | 100% |  |  |
| 126 |  | Update baselined artefacts | 35d | 2023-08-17 A | 2023-10-04 A |  | 100% |  | must start on 2023-08-17 |
| 127 |  | Interim release 5 Go live | 0d | 2023-10-04 A | 2023-10-04 A | 126 | 100% |  |  |
| 128 |  | Interim Release 5 Deployed to SIT | 10d | 2024-02-26 A | 2024-03-08 A | 127FS+102d | 100% |  |  |
| 129 | 1.3.4.6 | **Interim release 6** | 192d | 2023-09-14 A | 2024-06-07 A |  | 100% |  |  |
| 130 |  | Update baselined artefacts | 35d | 2023-09-14 A | 2023-11-01 A |  | 100% |  | must start on 2023-09-14 |
| 131 |  | Interim release 6 Go live | 0d | 2023-11-01 A | 2023-11-01 A | 130 | 100% |  |  |
| 132 |  | Interim Release 6 Deployed to SIT | 10d | 2024-05-27 A | 2024-06-07 A | 131FS+147d | 100% |  |  |
| 133 | 1.3.4.7 | **Interim release 7** | 168d | 2023-10-18 A | 2024-06-07 A |  | 100% |  |  |
| 134 |  | Update baselined artefacts | 76d | 2023-10-18 A | 2024-01-31 A |  | 100% |  | start no earlier than 2023-10-18 |
| 135 |  | Interim release 7 Go live | 0d | 2024-01-31 A | 2024-01-31 A | 134 | 100% |  |  |
| 136 |  | Interim Release 7 Deployed to SIT | 10d | 2024-05-27 A | 2024-06-07 A | 135FS+82d | 100% |  |  |
| 137 | 1.3.4.8 | **Interim release 8** | 143d | 2024-02-14 A | 2024-08-30 |  | 78% | 5d |  |
| 138 |  | Update baselined artefacts | 36d | 2024-02-14 A | 2024-04-03 A |  | 100% |  | start no earlier than 2024-02-14 |
| 139 |  | Interim release 8 Go live | 0d | 2024-04-03 A | 2024-04-03 A | 138 | 100% |  | start no earlier than 2024-01-10 |
| 140 |  | Interim Release 8 Deployed to SIT | 10d | 2024-08-19 | 2024-08-30 | 139FS+97d |  | 5d |  |

| ID | WBS | Task | Duration | Start | Finish | Predecessors | Complete | Total float | Constraint |
| --- | --- | --- | --- | --- | --- | --- | --- | --- | --- |
| 141 | 1.3.5 | **Queries Support / Knowledgebase & Tool Roll-Out (Systems)** | 325d | 2023-01-03 A | 2024-04-01 A |  | 100% |  |  |
| 142 | 1.3.5.1 | **Query Management** | 325d | 2023-01-03 A | 2024-04-01 A |  | 100% |  |  |
| 143 |  | Respond to Participant Queries | 325d | 2023-01-03 A | 2024-04-01 A |  | 100% |  | must start on 2023-01-03 |
| 144 |  | Respond to Programme Queries | 325d | 2023-01-03 A | 2024-04-01 A | 143SS | 100% |  |  |
| 145 | 1.3.5.2 | **Query Support tooling (FreshDesk)** | 23d | 2023-06-01 A | 2023-07-03 A |  | 100% |  |  |
| 146 |  | Migrate to Standalone Freshdesk | 10d | 2023-06-01 A | 2023-06-14 A |  | 100% |  | must start on 2023-06-01 |
| 147 |  | Develop reporting dashboard | 5d | 2023-06-15 A | 2023-06-21 A | 146 | 100% |  |  |
| 148 |  | Issue to SRO for Review | 5d | 2023-06-22 A | 2023-06-28 A | 147 | 100% |  |  |
| 149 |  | Update following review | 2d | 2023-06-29 A | 2023-06-30 A | 148 | 100% |  |  |
| 150 |  | Sign off | 1d | 2023-07-03 A | 2023-07-03 A | 149 | 100% |  |  |
| 151 | 1.3.5.3 | **KnowledgeBase Development** | 72d | 2023-06-01 A | 2023-09-08 A |  | 100% |  |  |
| 152 |  | Define Scope of KB | 1d | 2023-06-01 A | 2023-06-01 A | 146SS | 100% |  |  |
| 153 |  | Capture Existing KB artefacts | 20d | 2023-06-02 A | 2023-06-29 A | 152 | 100% |  |  |
| 154 |  | Tag artefacts | 5d | 2023-06-30 A | 2023-07-06 A | 153 | 100% |  |  |
| 155 |  | Develop Participant Interfaces | 20d | 2023-07-07 A | 2023-08-03 A | 154 | 100% |  |  |
| 156 |  | Promote to Collaboration Portal | 21d | 2023-08-04 A | 2023-09-01 A | 155 | 100% |  |  |
| 157 |  | Link into FreshDesk | 5d | 2023-09-04 A | 2023-09-08 A | 156 | 100% |  |  |
| 158 | 1.3.6 | **PP Design, Build & Test (DBT)** | 495d | 2022-10-31 A | 2024-09-20 |  | 97% | 0d |  |
| 159 | 1.3.6.1 | **PP Impact Assessment, Planning & Procurement** | 110d | 2022-10-31 A | 2023-03-31 A |  | 100% |  |  |
| 160 | 1.3.6.1.1 | **PP Impact Assessment** | 67d | 2022-10-31 A | 2023-01-31 A |  | 100% |  |  |
| 161 |  | Develop heatmap for impact of MHHS | 67d | 2022-10-31 A | 2023-01-31 A | 48 | 100% |  |  |
| 162 |  | Develop detailed impact assessment | 67d | 2022-10-31 A | 2023-01-31 A | 48 | 100% |  |  |
| 163 | 1.3.6.1.2 | **PP Planning** | 67d | 2022-10-31 A | 2023-01-31 A |  | 100% |  |  |
| 164 |  | Develop detailed short-term plan | 23d | 2022-10-31 A | 2022-11-30 A | 48 | 100% |  |  |
| 165 |  | Develop overall project plan for implementation | 67d | 2022-10-31 A | 2023-01-31 A | 48 | 100% |  |  |
| 166 |  | Develop procurement plan | 67d | 2022-10-31 A | 2023-01-31 A | 48 | 100% |  |  |
| 167 | 1.3.6.1.3 | **PP Software/Service Procurement** | 110d | 2022-10-31 A | 2023-03-31 A |  | 100% |  |  |
| 168 |  | Run tender process | 67d | 2022-10-31 A | 2023-01-31 A | 48 | 100% |  |  |
| 169 |  | Select provider & sign commercials | 43d | 2023-02-01 A | 2023-03-31 A | 168 | 100% |  |  |
| 170 | 1.3.6.2 | **Central Systems DBT** | 325d | 2022-10-31 A | 2024-01-26 A |  | 100% |  |  |
| 171 | 1.3.6.2.1 | **Elexon Central Systems DBT CIT (Entering at Interval 1)** | 248d | 2022-10-31 A | 2023-10-11 A |  | 100% |  |  |
| 172 | 1.3.6.2.1.1 | **Design and Build** | 235d | 2022-10-31 A | 2023-09-22 A |  | 100% |  |  |
| 173 |  | Helix Design and Build | 235d | 2022-10-31 A | 2023-09-22 A | 2 | 100% |  |  |
| 174 | 1.3.6.2.1.2 | **Test Approach & Plan** | 235d | 2022-10-31 A | 2023-09-22 A |  | 100% |  |  |
| 175 |  | Develop Test Approach & Plan | 180d | 2022-10-31 A | 2023-07-07 A |  | 100% |  |  |
| 176 |  | Elexon Central Systems Test Approach & Plan (PIT) submitted to Programme for assurance | 0d | 2023-07-13 A | 2023-07-13 A | 175FF+4d | 100% |  |  |
| 177 |  | Elexon Central Systems Test Approach & Plan (PIT) V2 resubmitted to Programme for assurance | 0d | 2023-07-27 A | 2023-07-27 A | 176FS+9d | 100% |  |  |
| 178 |  | Elexon Central Systems Test Approach & Plan (PIT) V3 resubmitted to Programme for assurance | 0d | 2023-08-18 A | 2023-08-18 A | 177FS+17d | 100% |  |  |
| 179 |  | Elexon Central Systems Test approach and plan MHHS Review Completed | 0d | 2023-09-22 A | 2023-09-22 A | 178FS+25d | 100% |  |  |
| 180 | 1.3.6.2.1.3 | **Test Readiness Report** | 16d | 2023-07-28 A | 2023-08-18 A |  | 100% |  |  |
| 181 |  | Test readiness reporting | 16d | 2023-07-28 A | 2023-08-18 A | 176FS+10d | 100% |  |  |
| 182 | 1.3.6.2.1.4 | **Requirements to test Traceability Matrix (RTTM)** | 35d | 2023-08-04 A | 2023-09-22 A |  | 100% |  |  |
| 183 |  | Elexon Central Systems RTTM submitted to Programme for assurance | 0d | 2023-08-04 A | 2023-08-04 A | 176 | 100% |  | start no earlier than 2023-04-28 |
| 184 |  | Elexon Central Systems RTTM MHHS Review Completed | 0d | 2023-09-22 A | 2023-09-22 A | 183FS+35d | 100% |  |  |
| 185 | 1.3.6.2.1.5 | **Test Scenarios** | 35d | 2023-08-04 A | 2023-09-22 A |  | 100% |  |  |
| 186 |  | Elexon Central Systems test scenarios submitted to Programme for assurance | 0d | 2023-08-04 A | 2023-08-04 A | 176 | 100% |  |  |
| 187 |  | Elexon Central Systems Test scenarios MHHS Review Completed | 0d | 2023-09-22 A | 2023-09-22 A | 186FS+35d | 100% |  |  |
| 188 | 1.3.6.2.1.6 | **PIT Execution** | 38d | 2023-08-21 A | 2023-10-11 A |  | 100% |  |  |
| 189 |  | PIT Test Execution Progress Report | 18d | 2023-09-04 A | 2023-09-27 A | 181FS+10d | 100% |  |  |
| 190 |  | Elexon Central Systems PIT Execution | 28d | 2023-08-21 A | 2023-09-27 A | 181 | 100% |  |  |
| 191 |  | Elexon Central Systems PIT Completion Report submitted to Programme for assurance | 0d | 2023-09-27 A | 2023-09-27 A | 190 | 100% |  |  |
| 192 |  | Elexon Central Systems PIT Completion Report MHHS Review Completed | 0d | 2023-10-11 A | 2023-10-11 A | 184, 187, 189, 191FS+10d, 179 | 100% |  |  |
| 193 | 1.3.6.2.2 | **DIP DBT CIT (Entering at Interval 1)** | 221d | 2023-01-02 A | 2023-11-06 A |  | 100% |  |  |
| 194 |  | Design | 80d | 2023-01-02 A | 2023-04-21 A |  | 100% |  | must start on 2023-01-02 |
| 195 |  | Build | 155d | 2023-01-09 A | 2023-08-11 A | 194SS+5d | 100% |  |  |
| 196 | 1.3.6.2.2.3 | **Test Approach & Plan** | 9d | 2023-07-07 A | 2023-07-20 A |  | 100% |  |  |
| 197 |  | DIP Test Approach & Plan (PIT) submitted to Programme for assurance | 0d | 2023-07-07 A | 2023-07-07 A |  | 100% |  |  |
| 198 |  | DIP Test Approach & Plan (PIT) MHHS Review Completed | 0d | 2023-07-20 A | 2023-07-20 A | 197FS+9d | 100% |  |  |
| 199 | 1.3.6.2.2.4 | **PIT Test Readiness Report** | 31d | 2023-07-21 A | 2023-09-01 A |  | 100% |  |  |
| 200 |  | Test readiness reporting | 31d | 2023-07-21 A | 2023-09-01 A | 197FS+9d | 100% |  |  |
| 201 | 1.3.6.2.2.5 | **Requirements to test Traceability Matrix (RTTM)** | 18d | 2023-08-04 A | 2023-08-30 A |  | 100% |  |  |
| 202 |  | DIP RTTM submitted to Programme for assurance | 0d | 2023-08-04 A | 2023-08-04 A | 197FS+15d | 100% |  |  |
| 203 |  | DIP RTTM MHHS Review Completed | 0d | 2023-08-30 A | 2023-08-30 A | 202FS+18d | 100% |  |  |
| 204 | 1.3.6.2.2.6 | **Test Scenarios** | 22d | 2023-07-31 A | 2023-08-30 A |  | 100% |  |  |
| 205 |  | DIP PIT test scenarios submitted to Programme for assurance | 0d | 2023-07-31 A | 2023-07-31 A | 197FS+15d | 100% |  |  |
| 206 |  | DIP Test scenarios MHHS Review Completed | 0d | 2023-08-30 A | 2023-08-30 A | 205FS+22d | 100% |  |  |
| 207 | 1.3.6.2.2.7 | **PIT execution** | 50d | 2023-08-29 A | 2023-11-06 A |  | 100% |  |  |
| 208 |  | PIT Test Execution Progress Report | 37d | 2023-09-01 A | 2023-10-23 A | 209FF, 200 | 100% |  | start no earlier than 2023-08-29 |
| 209 |  | PIT Execution (Interim Release 1) | 30d | 2023-08-29 A | 2023-10-09 A |  | 100% |  | start no earlier than 2023-08-29 |
| 210 |  | PIT Execution (Interim Release 2) | 10d | 2023-10-10 A | 2023-10-23 A | 209 | 100% |  |  |

| ID | WBS | Task | Duration | Start | Finish | Predecessors | Complete | Total float | Constraint |
| --- | --- | --- | --- | --- | --- | --- | --- | --- | --- |
| 211 |  | DIP PIT Completion Report (Interim Release 1) submitted to Programme for assurance | 0d | 2023-10-09 A | 2023-10-09 A | 209 | 100% |  |  |
| 212 |  | DIP PIT Completion Report (Interim Release 1) MHHS Review Completed | 0d | 2023-10-23 A | 2023-10-23 A | 211FS+10d | 100% |  |  |
| 213 |  | DIP PIT Completion Report (Interim Release 2) submitted to Programme for assurance | 0d | 2023-10-23 A | 2023-10-23 A | 210, 208 | 100% |  |  |
| 214 |  | DIP PIT Completion Report (Interim Release 2) MHHS Review Completed | 0d | 2023-11-06 A | 2023-11-06 A | 213FS+10d | 100% |  |  |
| 215 | 1.3.6.2.3 | **DCC (DSP) DBT SIT Functional (Entering at SIT Functional)** | 325d | 2022-10-31 A | 2024-01-26 A |  | 100% |  |  |
| 216 |  | Design | 67d | 2022-10-31 A | 2023-01-31 A |  | 100% |  |  |
| 217 | 1.3.6.2.3.2 | **Test Approach & Plan** | 20d | 2023-11-17 A | 2023-12-15 A |  | 100% |  |  |
| 218 |  | DCC Test Approach & Plan (PIT) submitted to Programme for assurance | 0d | 2023-11-17 A | 2023-11-17 A | 216FS+208d | 100% |  |  |
| 219 |  | DCC Test Approach & Plan (PIT) MHHS Review Completed | 0d | 2023-12-15 A | 2023-12-15 A | 218FS+20d | 100% |  |  |
| 220 | 1.3.6.2.3.3 | **Test Readiness Report** | 22d | 2023-12-04 A | 2024-01-02 A |  | 100% |  |  |
| 221 |  | Test readiness reporting | 22d | 2023-12-04 A | 2024-01-02 A | 218FS+10d | 100% |  |  |
| 222 | 1.3.6.2.3.4 | **Requirements to test Traceability Matrix (RTTM)** | 30d | 2023-12-15 A | 2024-01-26 A |  | 100% |  |  |
| 223 |  | DCC RTTM submitted to Programme for assurance | 0d | 2023-12-15 A | 2023-12-15 A | 218FS+20d | 100% |  | start no earlier than 2023-04-28 |
| 224 |  | DCC RTTM MHHS Review Completed | 0d | 2024-01-26 A | 2024-01-26 A | 223FS+30d | 100% |  |  |
| 225 | 1.3.6.2.3.5 | **Test Scenarios** | 30d | 2023-12-15 A | 2024-01-26 A |  | 100% |  |  |
| 226 |  | DCC test scenarios submitted to Programme for assurance | 0d | 2023-12-15 A | 2023-12-15 A | 218FS+20d | 100% |  |  |
| 227 |  | DCC Test Scenarios MHHS Review Completed | 0d | 2024-01-26 A | 2024-01-26 A | 226FS+30d | 100% |  |  |
| 228 | 1.3.6.2.4 | **RECCo (EES) DBT CIT (Entering at Interval 6)** | 71d | 2023-10-13 A | 2024-01-19 A |  | 100% |  |  |
| 229 | 1.3.6.2.4.1 | **Test Approach & Plan** | 20d | 2023-10-13 A | 2023-11-09 A |  | 100% |  |  |
| 230 |  | EES Test Approach & Plan (PIT) submitted to Programme for assurance | 0d | 2023-10-13 A | 2023-10-13 A |  | 100% |  | start no earlier than 2023-10-13 |
| 231 |  | EES Test approach and plan (PIT) MHHS Review Completed | 0d | 2023-11-09 A | 2023-11-09 A | 230FS+20d | 100% |  |  |
| 232 | 1.3.6.2.4.2 | **Test Readiness Report** | 10d | 2023-10-27 A | 2023-11-09 A |  | 100% |  |  |
| 233 |  | Test readiness reporting | 10d | 2023-10-27 A | 2023-11-09 A | 230FS+10d | 100% |  |  |
| 234 | 1.3.6.2.4.3 | **Requirements to test Traceability Matrix (RTTM)** | 20d | 2023-11-02 A | 2023-11-30 A |  | 100% |  |  |
| 235 |  | EES RTTM submitted to Programme for assurance | 0d | 2023-11-02 A | 2023-11-02 A | 230FS+15d | 100% |  |  |
| 236 |  | EES RTTM MHHS Review Completed | 0d | 2023-11-30 A | 2023-11-30 A | 235FS+20d | 100% |  |  |
| 237 | 1.3.6.2.4.4 | **Test Scenarios** | 20d | 2023-11-02 A | 2023-11-30 A |  | 100% |  |  |
| 238 |  | EES test scenarios submitted to Programme for assurance | 0d | 2023-11-02 A | 2023-11-02 A | 230FS+15d | 100% |  |  |
| 239 |  | EES Test scenarios MHHS Review Completed | 0d | 2023-11-30 A | 2023-11-30 A | 238FS+20d | 100% |  |  |
| 240 | 1.3.6.2.4.5 | **PIT execution** | 51d | 2023-11-10 A | 2024-01-19 A |  | 100% |  |  |
| 241 |  | PIT Test Execution Progress Report | 41d | 2023-11-10 A | 2024-01-05 A | 233 | 100% |  |  |
| 242 |  | PIT Execution | 41d | 2023-11-10 A | 2024-01-05 A | 238FS+5d | 100% |  |  |
| 243 |  | EES PIT Completion Report submitted to Programme for assurance | 0d | 2024-01-05 A | 2024-01-05 A | 241, 242 | 100% |  |  |
| 244 |  | EES PIT Completion Report MHHS Review Completed | 0d | 2024-01-19 A | 2024-01-19 A | 231, 236, 239, 243FS+10d | 100% |  |  |
| 245 | 1.3.6.2.5 | **Registration Services DBT CIT (Entering at Interval 2)** | 70d | 2023-07-28 A | 2023-11-03 A |  | 100% |  |  |
| 246 | 1.3.6.2.5.1 | **Test Approach & Plan** | 40d | 2023-07-28 A | 2023-09-22 A |  | 100% |  |  |
| 247 |  | Registration Services Test Approach & Plan (PIT) submitted to Programme for assurance | 0d | 2023-07-28 A | 2023-07-28 A |  | 100% |  |  |
| 248 |  | Registration Services Test approach and plan MHHS Review Completed | 0d | 2023-09-22 A | 2023-09-22 A | 247FS+40d | 100% |  |  |
| 249 | 1.3.6.2.5.2 | **Test Readiness Report** | 20d | 2023-08-14 A | 2023-09-08 A |  | 100% |  |  |
| 250 |  | Test readiness reporting | 20d | 2023-08-14 A | 2023-09-08 A | 247FS+10d | 100% |  |  |
| 251 | 1.3.6.2.5.3 | **Requirements to test Traceability Matrix (RTTM)** | 20d | 2023-09-01 A | 2023-09-29 A |  | 100% |  |  |
| 252 |  | Registration Services RTTM submitted to Programme for assurance | 0d | 2023-09-01 A | 2023-09-01 A | 247FS+15d | 100% |  | start no earlier than 2023-04-28 |
| 253 |  | Registration Services RTTM MHHS Review Completed | 0d | 2023-09-29 A | 2023-09-29 A | 252FS+20d | 100% |  |  |
| 254 | 1.3.6.2.5.4 | **Test Scenarios** | 20d | 2023-09-01 A | 2023-09-29 A |  | 100% |  |  |
| 255 |  | Registration Services test scenarios submitted to Programme for assurance | 0d | 2023-09-01 A | 2023-09-01 A | 247FS+15d | 100% |  |  |
| 256 |  | Registration Services Test scenarios MHHS Review Completed | 0d | 2023-09-29 A | 2023-09-29 A | 255FS+20d | 100% |  |  |
| 257 | 1.3.6.2.5.5 | **PIT execution** | 40d | 2023-09-11 A | 2023-11-03 A |  | 100% |  |  |
| 258 |  | PIT Test Execution Progress Report | 33d | 2023-09-11 A | 2023-10-25 A | 250 | 100% |  |  |
| 259 |  | PIT Execution | 30d | 2023-09-11 A | 2023-10-20 A | 255FS+5d | 100% |  |  |
| 260 |  | Registration Services PIT (CIT interval 2) Completion Report submitted to Programme for assurance | 0d | 2023-10-25 A | 2023-10-25 A | 258, 259 | 100% |  |  |
| 261 |  | Registration Services PIT (CIT interval 2) Completion Report MHHS Review Completed | 0d | 2023-11-03 A | 2023-11-03 A | 248, 253, 256, 260FS+7d | 100% |  |  |
| 262 | 1.3.6.3 | **SIT Participants DBT** | 291d | 2023-08-11 A | 2024-09-20 |  | 92% | 0d |  |
| 263 | 1.3.6.3.1 | **All Data Services DBT CIT (Entering at Interval 3)** | 71d | 2023-08-11 A | 2023-11-17 A |  | 100% |  |  |
| 264 | 1.3.6.3.1.1 | **Test Approach & Plan** | 30d | 2023-08-11 A | 2023-09-21 A |  | 100% |  |  |
| 265 |  | All Data Services Test Approach & Plans (PIT) submitted to Programme for assurance | 0d | 2023-08-11 A | 2023-08-11 A |  | 100% |  | start no earlier than 2023-08-11 |
| 266 |  | All Data Services Test approach and plans MHHS Review Completed | 0d | 2023-09-21 A | 2023-09-21 A | 265FS+30d | 100% |  |  |
| 267 | 1.3.6.3.1.2 | **Test Readiness Report** | 11d | 2023-08-25 A | 2023-09-08 A |  | 100% |  |  |
| 268 |  | Test readiness reporting | 11d | 2023-08-25 A | 2023-09-08 A | 265FS+10d | 100% |  |  |
| 269 | 1.3.6.3.1.3 | **Requirements to test Traceability Matrix (RTTM)** | 7d | 2023-09-20 A | 2023-09-29 A |  | 100% |  |  |
| 270 |  | All Data Services RTTMs submitted to Programme for assurance | 0d | 2023-09-20 A | 2023-09-20 A | 265FS+29d | 100% |  |  |
| 271 |  | All Data Services RTTMs MHHS Review Completed | 0d | 2023-09-29 A | 2023-09-29 A | 270FS+7d | 100% |  |  |
| 272 | 1.3.6.3.1.4 | **Test Scenarios** | 6d | 2023-09-20 A | 2023-09-28 A |  | 100% |  |  |
| 273 |  | All Data Services test scenarios' submitted to Programme for assurance | 0d | 2023-09-20 A | 2023-09-20 A | 265FS+29d | 100% |  |  |
| 274 |  | All Data Services Test scenarios' MHHS Review Completed | 0d | 2023-09-28 A | 2023-09-28 A | 273FS+6d | 100% |  |  |
| 275 | 1.3.6.3.1.5 | **PIT execution** | 50d | 2023-09-11 A | 2023-11-17 A |  | 100% |  |  |
| 276 |  | PIT Test Execution Progress Report | 40d | 2023-09-11 A | 2023-11-03 A | 268 | 100% |  |  |
| 277 |  | PIT Execution | 27d | 2023-09-28 A | 2023-11-03 A | 273FS+5d | 100% |  |  |
| 278 |  | All Data Services PIT Completion Reports submitted to Programme for assurance | 0d | 2023-11-03 A | 2023-11-03 A | 276, 277 | 100% |  |  |
| 279 |  | All Data Services PIT Completion Reports MHHS Review Completed | 0d | 2023-11-17 A | 2023-11-17 A | 266, 271, 274, 278FS+10d | 100% |  |  |
| 280 | 1.3.6.3.2 | **All Metering Services DBT CIT (Entering at Interval 4)** | 70d | 2023-08-25 A | 2023-12-01 A |  | 100% |  |  |

| ID | WBS | Task | Duration | Start | Finish | Predecessors | Complete | Total float | Constraint |
| --- | --- | --- | --- | --- | --- | --- | --- | --- | --- |
| 281 | 1.3.6.3.2.1 | **Test Approach & Plan** | 40d | 2023-08-25 A | 2023-10-20 A |  | 100% |  |  |
| 282 |  | All Metering Services Test Approach & Plans (PIT) submitted to Programme for assurance | 0d | 2023-08-25 A | 2023-08-25 A |  | 100% |  |  |
| 283 |  | All Metering Services Test approach and plans MHHS Review Completed | 0d | 2023-10-20 A | 2023-10-20 A | 282FS+40d | 100% |  |  |
| 284 | 1.3.6.3.2.2 | **Test Readiness Report** | 11d | 2023-09-11 A | 2023-09-25 A |  | 100% |  |  |
| 285 |  | Test readiness reporting | 11d | 2023-09-11 A | 2023-09-25 A | 282FS+10d | 100% |  |  |
| 286 | 1.3.6.3.2.3 | **Requirements to test Traceability Matrix (RTTM)** | 30d | 2023-09-15 A | 2023-10-27 A |  | 100% |  |  |
| 287 |  | All Metering Services RTTMs submitted to Programme for assurance | 0d | 2023-09-15 A | 2023-09-15 A | 282FS+15d | 100% |  |  |
| 288 |  | All Metering Services MHHS Reviews Completed | 0d | 2023-10-27 A | 2023-10-27 A | 287FS+30d | 100% |  |  |
| 289 | 1.3.6.3.2.4 | **Test Scenarios** | 30d | 2023-09-15 A | 2023-10-27 A |  | 100% |  |  |
| 290 |  | All Metering Services test scenarios' submitted to Programme for assurance | 0d | 2023-09-15 A | 2023-09-15 A | 282FS+15d | 100% |  |  |
| 291 |  | All Metering Services Test scenarios' MHHS Review Completed | 0d | 2023-10-27 A | 2023-10-27 A | 290FS+30d | 100% |  |  |
| 292 | 1.3.6.3.2.5 | **PIT execution** | 50d | 2023-09-25 A | 2023-12-01 A |  | 100% |  |  |
| 293 |  | PIT Test Execution Progress Report | 39d | 2023-09-26 A | 2023-11-17 A | 285 | 100% |  |  |
| 294 |  | PIT Execution | 40d | 2023-09-25 A | 2023-11-17 A | 290FS+5d | 100% |  |  |
| 295 |  | All Metering Services PIT Completion Reports submitted to Programme for assurance | 0d | 2023-11-17 A | 2023-11-17 A | 293, 294 | 100% |  |  |
| 296 |  | All Metering Services PIT Completion Reports MHHS Review Completed | 0d | 2023-12-01 A | 2023-12-01 A | 283, 288, 291, 295FS+10d | 100% |  |  |
| 297 | 1.3.6.3.3 | **All SIT Programme Participants PIT (SIT Functional)** | 221d | 2023-11-17 A | 2024-09-20 |  | 82% | 0d |  |
| 298 | 1.3.6.3.3.1 | **Test Approach & Plans** | 40d | 2023-11-17 A | 2024-01-11 A |  | 100% |  |  |
| 299 |  | SIT Functional PIT Test Approach & Plan (PIT) submitted to Programme for assurance | 0d | 2023-11-17 A | 2023-11-17 A |  | 100% |  | start no earlier than 2023-11-17 |
| 300 |  | All SIT Functional Test approach and plans MHHS Reviews Completed | 0d | 2024-01-11 A | 2024-01-11 A | 299FS+40d | 100% |  |  |
| 301 | 1.3.6.3.3.2 | **Test Readiness Reports** | 11d | 2023-12-01 A | 2023-12-15 A |  | 100% |  |  |
| 302 |  | Test readiness reporting | 11d | 2023-12-01 A | 2023-12-15 A | 299FS+10d | 100% |  |  |
| 303 | 1.3.6.3.3.3 | **Requirements to test Traceability Matrices (RTTM)** | 30d | 2023-12-07 A | 2024-01-18 A |  | 100% |  |  |
| 304 |  | SIT Functional PIT RTTM submitted to Programme for assurance | 0d | 2023-12-07 A | 2023-12-07 A | 299FS+15d | 100% |  |  |
| 305 |  | All SIT Functional RTTMs MHHS Reviews Completed | 0d | 2024-01-18 A | 2024-01-18 A | 304FS+30d | 100% |  |  |
| 306 | 1.3.6.3.3.4 | **Test Scenarios** | 30d | 2023-12-07 A | 2024-01-18 A |  | 100% |  |  |
| 307 |  | SIT Functional PIT test scenarios submitted to Programme for assurance | 0d | 2023-12-07 A | 2023-12-07 A | 299FS+15d | 100% |  |  |
| 308 |  | All SIT Functional Test scenarios' MHHS Reviews Completed | 0d | 2024-01-18 A | 2024-01-18 A | 307FS+30d | 100% |  |  |
| 309 | 1.3.6.3.3.5 | **PIT execution** | 51d | 2023-12-15 A | 2024-02-23 A |  | 100% |  |  |
| 310 |  | PIT Test Execution Progress Reports | 40d | 2023-12-18 A | 2024-02-09 A | 302 | 100% |  |  |
| 311 |  | PIT Execution | 41d | 2023-12-15 A | 2024-02-09 A | 307FS+5d | 100% |  |  |
| 312 |  | All SIT Functional PIT Completion Reports submitted to Programme for Assurance | 0d | 2024-02-09 A | 2024-02-09 A | 310, 311 | 100% |  |  |
| 313 |  | All SIT Functional PIT Completion Reports MHHS Review Completed | 0d | 2024-02-23 A | 2024-02-23 A | 300, 305, 308, 312FS+10d | 100% |  |  |
| 314 | 1.3.6.3.3.6 | **All SIT Programme Participants PIT (SIT Migration)** | 71d | 2024-02-16 A | 2024-05-24 A |  | 100% |  |  |
| 315 | 1.3.6.3.3.6.1 | **Test Approach & Plans** | 40d | 2024-02-16 A | 2024-04-11 A |  | 100% |  |  |
| 316 |  | All SIT Migration PIT Test Approach & Plans submitted to Programme for assurance | 0d | 2024-02-16 A | 2024-02-16 A |  | 100% |  | start no earlier than 2024-02-16 |
| 317 |  | All SIT Migration PIT Test approach and plans MHHS Reviews Completed | 0d | 2024-04-11 A | 2024-04-11 A | 316FS+40d | 100% |  |  |
| 318 | 1.3.6.3.3.6.2 | **Test Readiness Reports** | 11d | 2024-03-01 A | 2024-03-15 A |  | 100% |  |  |
| 319 |  | Test readiness reporting | 11d | 2024-03-01 A | 2024-03-15 A | 316FS+10d | 100% |  |  |
| 320 | 1.3.6.3.3.6.3 | **Requirements to test Traceability Matrices (RTTM)** | 30d | 2024-03-07 A | 2024-04-18 A |  | 100% |  |  |
| 321 |  | All SIT Migration PIT RTTMs submitted to Programme for assurance | 0d | 2024-03-07 A | 2024-03-07 A | 316FS+15d | 100% |  |  |
| 322 |  | All SIT Migration RTTMs MHHS Reviews Completed | 0d | 2024-04-18 A | 2024-04-18 A | 321FS+30d | 100% |  |  |
| 323 | 1.3.6.3.3.6.4 | **Test Scenarios** | 30d | 2024-03-07 A | 2024-04-18 A |  | 100% |  |  |
| 324 |  | All SIT Migration PIT test scenarios submitted to Programme for assurance | 0d | 2024-03-07 A | 2024-03-07 A | 316FS+15d | 100% |  |  |
| 325 |  | All SIT Migration Test scenarios MHHS Reviews Completed | 0d | 2024-04-18 A | 2024-04-18 A | 324FS+30d | 100% |  |  |
| 326 | 1.3.6.3.3.6.5 | **PIT execution** | 51d | 2024-03-15 A | 2024-05-24 A |  | 100% |  |  |
| 327 |  | PIT Test Execution Progress Reports | 40d | 2024-03-18 A | 2024-05-10 A | 319 | 100% |  |  |
| 328 |  | PIT Execution | 41d | 2024-03-15 A | 2024-05-10 A | 324FS+5d | 100% |  |  |
| 329 |  | All SIT Migration PIT Completion Reports submitted to Programme for assurance | 0d | 2024-05-10 A | 2024-05-10 A | 327, 328 | 100% |  |  |
| 330 |  | All SIT Migration PIT Completion Reports MHHS Review Completed | 0d | 2024-05-24 A | 2024-05-24 A | 317, 322, 325, 329FS+10d | 100% |  |  |
| 331 | 1.3.6.3.3.7 | **All SIT Programme Participants PIT (SIT Non Functional)** | 71d | 2024-05-10 A | 2024-08-16 |  | 75% | 11d |  |
| 332 | 1.3.6.3.3.7.1 | **Test Approach & Plan** | 40d | 2024-05-10 A | 2024-07-04 A |  | 100% |  |  |
| 333 |  | SIT Non-Functional PIT Test Approach & Plan (PIT) submitted to Programme for assurance | 0d | 2024-05-10 A | 2024-05-10 A |  | 100% |  | start no earlier than 2024-05-10 |
| 334 |  | SIT Non-Functional Test approach and plan MHHS Review Completed | 0d | 2024-07-04 A | 2024-07-04 A | 333FS+40d | 100% |  |  |
| 335 | 1.3.6.3.3.7.2 | **Test Readiness Report** | 11d | 2024-05-24 A | 2024-06-07 A |  | 100% |  |  |
| 336 |  | Test readiness reporting | 11d | 2024-05-24 A | 2024-06-07 A | 333FS+10d | 100% |  |  |
| 337 | 1.3.6.3.3.7.3 | **Requirements to test Traceability Matrix (RTTM)** | 30d | 2024-05-30 | 2024-07-11 |  |  | 37d |  |
| 338 |  | SIT Non-Functional PIT RTTM submitted to Programme for assurance | 0d | 2024-05-30 | 2024-05-30 | 333FS+15d |  | 37d |  |
| 339 |  | SIT Non-Functional RTTM MHHS Review Completed | 0d | 2024-07-11 | 2024-07-11 | 338FS+30d |  | 37d |  |
| 340 | 1.3.6.3.3.7.4 | **Test Scenarios** | 30d | 2024-05-30 | 2024-07-11 |  |  | 29d |  |
| 341 |  | SIT Non-Functional PIT test scenarios submitted to Programme for assurance | 0d | 2024-05-30 | 2024-05-30 | 333FS+15d |  | 29d |  |
| 342 |  | SIT Non-Functional Test scenarios MHHS Review Completed | 0d | 2024-07-11 | 2024-07-11 | 341FS+30d |  | 37d |  |
| 343 | 1.3.6.3.3.7.5 | **PIT execution** | 51d | 2024-06-07 A | 2024-08-16 |  | 71% | 11d |  |
| 344 |  | PIT Test Execution Progress Report | 39d | 2024-06-10 A | 2024-08-01 | 336 | 72% | 12d |  |
| 345 |  | PIT Execution | 41d | 2024-06-07 A | 2024-08-02 | 341FS+5d | 71% | 11d |  |
| 346 |  | SIT Non-Functional PIT Completion Report submitted to Programme for assurance | 0d | 2024-08-02 | 2024-08-02 | 344, 345 |  | 11d |  |
| 347 |  | SIT Non-Functional PIT Completion Report MHHS Review Completed | 0d | 2024-08-16 | 2024-08-16 | 334, 339, 342, 346FS+10d |  | 11d |  |
| 348 | 1.3.6.3.3.8 | **All SIT Programme Participants PIT (SIT Operational)** | 71d | 2024-06-14 A | 2024-09-20 |  | 52% | 0d |  |
| 349 | 1.3.6.3.3.8.1 | **Test Approach & Plan** | 40d | 2024-06-14 | 2024-08-08 |  |  | 19d |  |
| 350 |  | SIT Operational PIT Test Approach & Plan (PIT) submitted to Programme for assurance | 0d | 2024-06-14 | 2024-06-14 |  |  | 19d | start no earlier than 2024-06-14 |

| ID | WBS | Task | Duration | Start | Finish | Predecessors | Complete | Total float | Constraint |
| --- | --- | --- | --- | --- | --- | --- | --- | --- | --- |
| 351 |  | SIT Operational Test approach and plan MHHS Review Completed | 0d | 2024-08-08 | 2024-08-08 | 350FS+40d |  | 31d |  |
| 352 | 1.3.6.3.3.8.2 | **Test Readiness Report** | 11d | 2024-06-28 A | 2024-07-12 A |  | 100% |  |  |
| 353 |  | Test readiness reporting | 11d | 2024-06-28 A | 2024-07-12 A | 350FS+10d | 100% |  |  |
| 354 | 1.3.6.3.3.8.3 | **Requirements to test Traceability Matrix (RTTM)** | 30d | 2024-07-04 | 2024-08-15 |  |  | 26d |  |
| 355 |  | SIT Operational PIT RTTM submitted to Programme for assurance | 0d | 2024-07-04 | 2024-07-04 | 350FS+15d |  | 26d |  |
| 356 |  | SIT Operational RTTM MHHS Review Completed | 0d | 2024-08-15 | 2024-08-15 | 355FS+30d |  | 26d |  |
| 357 | 1.3.6.3.3.8.4 | **Test Scenarios** | 30d | 2024-07-04 | 2024-08-15 |  |  | 19d |  |
| 358 |  | SIT Operational PIT test scenarios submitted to Programme for assurance | 0d | 2024-07-04 | 2024-07-04 | 350FS+15d |  | 19d |  |
| 359 |  | SIT Operational Test scenarios MHHS Review Completed | 0d | 2024-08-15 | 2024-08-15 | 358FS+30d |  | 26d |  |
| 360 | 1.3.6.3.3.8.5 | **PIT execution** | 51d | 2024-07-12 A | 2024-09-20 |  | 46% | 0d |  |
| 361 |  | PIT Test Execution Progress Report | 40d | 2024-07-15 A | 2024-09-06 | 353 | 45% | 0d |  |
| 362 |  | PIT Execution | 41d | 2024-07-12 A | 2024-09-06 | 358FS+5d | 46% | 0d |  |
| 363 |  | SIT Operational PIT Completion Report submitted to Programme for assurance | 0d | 2024-09-06 | 2024-09-06 | 361, 362 |  | 0d |  |
| 364 |  | SIT Operational PIT Completion Report MHHS Review Completed | 0d | 2024-09-20 | 2024-09-20 | 351, 356, 359, 363FS+10d |  | 0d |  |
| 365 | 1.3.6.3.4 | **All Suppliers DBT CIT (Entering at Interval 5)** | 71d | 2023-09-15 A | 2023-12-22 A |  | 100% |  |  |
| 366 | 1.3.6.3.4.1 | **Test Approach & Plan** | 20d | 2023-09-15 A | 2023-10-12 A |  | 100% |  |  |
| 367 |  | All SIT Suppliers Test Approach & Plans (PIT) submitted to Programme for assurance | 0d | 2023-09-15 A | 2023-09-15 A |  | 100% |  | start no earlier than 2023-09-15 |
| 368 |  | All SIT Suppliers Test Approach & Plans MHHS Review Completed | 0d | 2023-10-12 A | 2023-10-12 A | 367FS+20d | 100% |  |  |
| 369 | 1.3.6.3.4.2 | **Test Readiness Report** | 11d | 2023-09-29 A | 2023-10-13 A |  | 100% |  |  |
| 370 |  | Test readiness reporting | 11d | 2023-09-29 A | 2023-10-13 A | 367FS+10d | 100% |  |  |
| 371 | 1.3.6.3.4.3 | **Requirements to test Traceability Matrix (RTTM)** | 20d | 2023-10-06 A | 2023-11-03 A |  | 100% |  |  |
| 372 |  | All SIT Suppliers RTTMs submitted to Programme for assurance | 0d | 2023-10-06 A | 2023-10-06 A | 367FS+16d | 100% |  |  |
| 373 |  | All SIT Suppliers RTTMs MHHS Review Completed | 0d | 2023-11-03 A | 2023-11-03 A | 372FS+20d | 100% |  |  |
| 374 | 1.3.6.3.4.4 | **Test Scenarios** | 20d | 2023-10-05 A | 2023-11-02 A |  | 100% |  |  |
| 375 |  | All SIT Suppliers test scenarios' submitted to Programme for assurance | 0d | 2023-10-05 A | 2023-10-05 A | 367FS+15d | 100% |  |  |
| 376 |  | All SIT Suppliers Test scenarios' MHHS Review Completed | 0d | 2023-11-02 A | 2023-11-02 A | 375FS+20d | 100% |  |  |
| 377 | 1.3.6.3.4.5 | **PIT execution** | 51d | 2023-10-13 A | 2023-12-22 A |  | 100% |  |  |
| 378 |  | PIT Test Execution Progress Report | 40d | 2023-10-16 A | 2023-12-08 A | 375FS+5d, 370 | 100% |  |  |
| 379 |  | PIT Execution | 41d | 2023-10-13 A | 2023-12-08 A | 375FS+5d | 100% |  |  |
| 380 |  | All SIT Suppliers PIT Completion Reports submitted to Programme for assurance | 0d | 2023-12-08 A | 2023-12-08 A | 379, 378 | 100% |  |  |
| 381 |  | All SIT Suppliers PIT Completion Reports MHHS Review Completed | 0d | 2023-12-22 A | 2023-12-22 A | 380FS+10d, 368, 373, 376 | 100% |  |  |
| 382 | 1.3.6.3.5 | **All LDSO Network Operations DBT CIT (Entering at Interval 5)** | 71d | 2023-09-15 A | 2023-12-22 A |  | 100% |  |  |
| 383 | 1.3.6.3.5.1 | **Test Approach & Plan** | 71d | 2023-09-15 A | 2023-12-22 A |  | 100% |  |  |
| 384 |  | All Network Operation Test Approach & Plans (PIT) submitted to Programme for assurance | 0d | 2023-09-15 A | 2023-09-15 A |  | 100% |  | start no earlier than 2023-09-15 |
| 385 |  | All Network Operation Test Approach & Plans MHHS Review Completed | 0d | 2023-10-12 A | 2023-10-12 A | 384FS+20d | 100% |  |  |
| 386 | 1.3.6.3.5.1.3 | **Test Readiness Report** | 11d | 2023-09-29 A | 2023-10-13 A |  | 100% |  |  |
| 387 |  | Test readiness reporting | 11d | 2023-09-29 A | 2023-10-13 A | 384FS+10d | 100% |  |  |
| 388 | 1.3.6.3.5.1.4 | **Requirements to test Traceability Matrix (RTTM)** | 20d | 2023-10-05 A | 2023-11-02 A |  | 100% |  |  |
| 389 |  | All Network Operation RTTMs submitted to Programme for assurance | 0d | 2023-10-05 A | 2023-10-05 A | 384FS+15d | 100% |  | start no earlier than 2023-04-28 |
| 390 |  | All Network Operation RTTMs MHHS Review Completed | 0d | 2023-11-02 A | 2023-11-02 A | 389FS+20d | 100% |  |  |
| 391 | 1.3.6.3.5.1.5 | **Test Scenarios** | 20d | 2023-10-05 A | 2023-11-02 A |  | 100% |  |  |
| 392 |  | All Network Operation test scenarios' submitted to Programme for assurance | 0d | 2023-10-05 A | 2023-10-05 A | 384FS+15d | 100% |  |  |
| 393 |  | All Network Operation test scenarios' MHHS Review Completed | 0d | 2023-11-02 A | 2023-11-02 A | 392FS+20d | 100% |  |  |
| 394 | 1.3.6.3.5.1.6 | **PIT execution** | 51d | 2023-10-13 A | 2023-12-22 A |  | 100% |  |  |
| 395 |  | PIT Test Execution Progress Report | 40d | 2023-10-16 A | 2023-12-08 A | 392FS+5d, 387 | 100% |  |  |
| 396 |  | PIT Execution | 41d | 2023-10-13 A | 2023-12-08 A | 392FS+5d | 100% |  |  |
| 397 |  | All Network Operation PIT (CIT interval 5) Completion Reports submitted to Programme for assurance | 0d | 2023-12-08 A | 2023-12-08 A | 396, 395 | 100% |  |  |
| 398 |  | All Network Operation PIT (CIT interval 5) Completion Reports MHHS Review Completed | 0d | 2023-12-22 A | 2023-12-22 A | 397FS+10d, 385, 390, 393 | 100% |  |  |
| 399 | 1.3.6.3.6 | **All UMSO DBT CIT (Entering at Interval 6)** | 81d | 2023-09-29 | 2024-01-19 A |  | 100% |  |  |
| 400 | 1.3.6.3.6.1 | **Test Approach & Plan** | 20d | 2023-10-13 A | 2023-11-09 A |  | 100% |  |  |
| 401 |  | All UMSO Test Approach & Plans (PIT) submitted to Programme for assurance | 0d | 2023-10-13 A | 2023-10-13 A |  | 100% |  | start no earlier than 2023-10-13 |
| 402 |  | All UMSO Test Approach & Plans MHHS Review Completed | 0d | 2023-11-09 A | 2023-11-09 A | 401FS+20d | 100% |  |  |
| 403 | 1.3.6.3.6.2 | **Test Readiness Report** | 11d | 2023-09-29 | 2023-10-13 |  | 100% |  |  |
| 404 |  | Test readiness reporting | 11d | 2023-10-27 A | 2023-11-10 A | 401FS+10d | 100% |  |  |
| 405 | 1.3.6.3.6.3 | **Requirements to test Traceability Matrix (RTTM)** | 20d | 2023-10-05 | 2023-11-01 |  | 100% |  |  |
| 406 |  | All UMSO RTTMs submitted to Programme for assurance | 0d | 2023-11-02 A | 2023-11-02 A | 401FS+15d | 100% |  |  |
| 407 |  | All UMSO RTTMs MHHS Review Completed | 0d | 2023-11-30 A | 2023-11-30 A | 406FS+20d | 100% |  |  |
| 408 | 1.3.6.3.6.4 | **Test Scenarios** | 20d | 2023-10-05 | 2023-11-01 |  | 100% |  |  |
| 409 |  | All UMSO test scenarios' submitted to Programme for assurance | 0d | 2023-11-02 A | 2023-11-02 A | 401FS+15d | 100% |  |  |
| 410 |  | All UMSO Test scenarios' MHHS Review Completed | 0d | 2023-11-30 A | 2023-11-30 A | 409FS+20d | 100% |  |  |
| 411 | 1.3.6.3.6.5 | **PIT execution** | 51d | 2023-11-10 A | 2024-01-19 A |  | 100% |  |  |
| 412 |  | PIT Test Execution Progress Report | 40d | 2023-11-13 A | 2024-01-05 A | 409FS+5d, 404 | 100% |  |  |
| 413 |  | PIT Execution | 40d | 2023-11-10 A | 2024-01-04 A | 409FS+5d | 100% |  |  |
| 414 |  | All UMSO PIT (CIT interval 6) Completion Reports submitted to Programme for assurance | 0d | 2024-01-05 A | 2024-01-05 A | 413, 412 | 100% |  |  |
| 415 |  | All UMSO PIT (CIT interval 6) Completion Reports MHHS Review Completed | 0d | 2024-01-19 A | 2024-01-19 A | 402, 407, 410, 414FS+10d | 100% |  |  |
| 416 | 1.3.7 | **DBT Monitoring and Assurance** | 842d | 2022-10-31 A | 2026-01-20 |  | 64% | 353d |  |
| 417 | 1.3.7.1 | **Planning and DBT Progress Monitoring of PPs** | 696d | 2022-10-31 A | 2025-06-30 |  | 67% | 499d |  |
| 418 |  | Monitor Non-SIT PPs Planning and DBT1 progress (to inform confirmation of Qualification Testing Tranche participants milestones) | 696d | 2022-10-31 A | 2025-06-30 | 164SS | 67% | 499d |  |
| 419 | 1.3.7.2 | **DBT Progress Monitoring of Consequential Change** | 774d | 2023-02-02 A | 2026-01-20 |  | 51% | 353d |  |
| 420 |  | Monitor & report data cleanse progress | 774d | 2023-02-02 A | 2026-01-20 |  | 51% | 353d |  |

| ID | WBS | Task | Duration | Start | Finish | Predecessors | Complete | Total float | Constraint |
| --- | --- | --- | --- | --- | --- | --- | --- | --- | --- |
| 421 | 1.3.7.3 | **Design Assurance** | 713d | 2022-11-14 A | 2025-08-06 |  | 71% | 472d |  |
| 422 | 1.3.7.3.1 | **Design Assurance Readiness Assessment Preparation** | 39d | 2023-02-28 A | 2023-04-21 A |  | 100% |  |  |
| 423 |  | Set up FTIG | 15d | 2023-04-03 A | 2023-04-21 A |  | 100% |  | must start on 2023-04-03 |
| 424 |  | Produce Draft Questions | 10d | 2023-02-28 A | 2023-03-13 A |  | 100% |  | must start on 2023-02-28 |
| 425 |  | Pilot with SRO | 1d | 2023-03-14 A | 2023-03-14 A | 424 | 100% |  |  |
| 426 |  | Finalise questions | 10d | 2023-03-15 A | 2023-03-28 A | 425 | 100% |  |  |
| 427 |  | Prepare on-line RA tooling | 10d | 2023-03-29 A | 2023-04-11 A | 426 | 100% |  |  |
| 428 |  | Prepare webinar content | 5d | 2023-03-20 A | 2023-03-24 A | 424FS+4d | 100% |  |  |
| 429 |  | Conduct webinar | 1d | 2023-03-30 A | 2023-03-30 A | 428FS+3d | 100% |  |  |
| 430 | 1.3.7.3.2 | **Participant Design Assurance Approach** | 43d | 2022-11-14 A | 2023-01-11 A |  | 100% |  |  |
| 431 |  | Develop document | 20d | 2022-11-14 A | 2022-12-09 A | 48FS+10d | 100% |  | start no earlier than 2022-11-14 |
| 432 |  | Review document | 18d | 2022-12-12 A | 2023-01-04 A | 431 | 100% |  |  |
| 433 |  | Participant Design Assurance Approach approved | 0d | 2023-01-11 A | 2023-01-11 A | 432FF+5d | 100% |  |  |
| 434 | 1.3.7.3.3 | **Phase 1 - SIT Volunteers (Core Providers)** | 145d | 2023-04-10 A | 2023-10-27 A |  | 100% |  |  |
| 435 |  | Send on-line questionnaire to core capability providers and current SIT volunteers (from Round 3 consultation) | 1d | 2023-04-10 A | 2023-04-10 A |  | 100% |  | must start on 2023-04-10 |
| 436 |  | Participants Provide Responses to questionnaires | 15d | 2023-04-11 A | 2023-05-01 A | 435 | 100% |  |  |
| 437 |  | Assess on-line responses and provided evidence | 5d | 2023-05-02 A | 2023-05-08 A | 436 | 100% |  |  |
| 438 |  | Bi-lateral meeting with each responder, to walk and navigate through provided materials | 31d | 2023-05-09 A | 2023-06-20 A | 437 | 100% |  |  |
| 439 |  | Plan for, create and execute deep dive assurance interviews based on agreed priorities (participants, design areas) | 62d | 2023-06-07 A | 2023-08-31 A | 438FS-10d | 100% |  |  |
| 440 |  | SI endorsement of participants’ design – assurance reports | 43d | 2023-08-02 A | 2023-09-29 A | 439FS-22d | 100% |  |  |
| 441 |  | Post-assurance review of recommendations take-up by assured participants | 44d | 2023-08-29 A | 2023-10-27 A | 440SS+19d | 100% |  |  |
| 442 |  | Phase 1 - SIT Volunteers (Core Providers) complete | 0d | 2023-10-27 A | 2023-10-27 A | 441 | 100% |  |  |
| 443 | 1.3.7.3.4 | **Phase 2 - SIT all other participants** | 143d | 2023-05-08 A | 2023-11-22 A |  | 100% |  |  |
| 444 |  | Send on-line questionnaire to core capability providers and current SIT volunteers (from Round 3 consultation) | 1d | 2023-05-08 A | 2023-05-08 A |  | 100% |  | must start on 2023-05-08 |
| 445 |  | Participants Provide Responses to questionnaires | 15d | 2023-05-09 A | 2023-05-29 A | 444 | 100% |  |  |
| 446 |  | Assess on-line responses and provided evidence | 5d | 2023-05-30 A | 2023-06-05 A | 445 | 100% |  |  |
| 447 |  | Bi-lateral meeting with each responder, to walk and navigate through provided materials | 84d | 2023-06-06 A | 2023-09-29 A | 446 | 100% |  |  |
| 448 |  | Plan for, create and execute deep dive assurance interviews based on agreed priorities (participants, design areas) | 69d | 2023-06-27 A | 2023-09-29 A | 447SS+15d | 100% |  |  |
| 449 |  | SI endorsement of participants’ design – assurance reports | 54d | 2023-07-18 A | 2023-09-29 A | 448SS+15d | 100% |  |  |
| 450 |  | Post-assurance review of recommendations take-up by assured participants | 73d | 2023-08-14 A | 2023-11-22 A | 449SS+19d | 100% |  |  |
| 451 |  | SIT PPs design assurance (excl Migration/Reverse Migration) complete | 0d | 2023-11-22 A | 2023-11-22 A | 450 | 100% |  |  |
| 452 | 1.3.7.3.5 | **Non-SIT PPs design assurance** | 445d | 2023-11-23 A | 2025-08-06 |  | 33% | 472d |  |
| 453 |  | Non-SIT PPs design assurance (risk-based sample) | 445d | 2023-11-23 A | 2025-08-06 | 451 | 33% | 472d |  |
| 454 | 1.3.7.4 | **Test Assurance** | 629d | 2023-02-01 A | 2025-06-30 |  | 63% | 499d |  |
| 455 |  | Non-SIT PPs test assurance | 629d | 2023-02-01 A | 2025-06-30 |  | 63% | 499d |  |
| 456 | 1.3.7.5 | **Pre-Qualification Guidance (PIT Guidance)** | 67d | 2022-10-31 A | 2023-01-31 A |  | 100% |  |  |
| 457 |  | Develop document (incl. collaboration with code bodies, as required) | 56d | 2022-10-31 A | 2023-01-16 A |  | 100% |  |  |
| 458 |  | Review, update and agree Pre-Qualification Guidance internally | 11d | 2023-01-17 A | 2023-01-31 A | 457 | 100% |  |  |
| 459 | 1.3.7.6 | **External Programme Dependency Management** | 0d | 2022-11-03 A | 2022-11-03 A |  | 100% |  |  |
| 460 | 1.3.7.6.1 | **SLC47** | 0d | 2022-11-03 A | 2022-11-03 A |  | 100% |  |  |
| 461 |  | SLC47 implementation date | 0d | 2022-11-03 A | 2022-11-03 A |  | 100% |  | start no earlier than 2022-11-03 |
| 462 | 1.4 | **SYSTEMS INTEGRATION TESTING (SIT)** | 910d | 2022-10-31 A | 2026-04-24 |  | 66% | 285d |  |
| 463 | 1.4.1 | **SIT Preparation** | 520d | 2022-10-31 A | 2024-10-25 |  | 98% | 675d |  |
| 464 | 1.4.1.1 | **Test Artefact Development** | 472d | 2022-10-31 A | 2024-08-21 |  | 99% | 723d |  |
| 465 | 1.4.1.1.1 | **Environment Approach & Plan** | 460d | 2022-11-16 A | 2024-08-21 A |  | 100% |  |  |
| 466 |  | Environment Approach & Plan approved | 0d | 2022-11-16 A | 2022-11-16 A |  | 100% |  | start no earlier than 2022-11-16 |
| 467 |  | Environment Approach & Plan - Work Off | 157d | 2022-11-17 A | 2023-06-23 A | 466FS+1d | 100% |  |  |
| 468 |  | Environment Approach & Plan - Work Off Approved | 0d | 2023-08-16 A | 2023-08-16 A | 467FS+5d | 100% |  | start no earlier than 2023-08-16 |
| 469 |  | Environment Approach and Plan - SIT Functional | 0d | 2023-11-20 A | 2023-11-20 A |  | 100% |  | start no earlier than 2023-11-20 |
| 470 |  | Define Approach to Simulator for Non-SIT LDSO | 0d | 2023-11-15 A | 2023-11-15 A |  | 100% |  | start no earlier than 2023-11-15 |
| 471 |  | Environment Approach and Plan - Non SIT LDSO Testing | 0d | 2024-04-17 A | 2024-04-17 A |  | 100% |  | start no earlier than 2024-04-17 |
| 472 |  | Environment Approach and Plan - S and A Testing | 0d | 2024-07-17 A | 2024-07-17 A |  | 100% |  | start no earlier than 2024-07-17 |
| 473 |  | Environment Approach and Plan - SIT Non Functional | 0d | 2024-06-19 A | 2024-06-19 A |  | 100% |  | start no earlier than 2024-06-19 |
| 474 |  | Environment Approach and Plan - Sandbox | 0d | 2024-08-21 A | 2024-08-21 A |  | 100% |  | start no earlier than 2024-08-21 |
| 475 | 1.4.1.1.2 | **Overarching Test Scope (for all stages)** | 65d | 2022-10-31 A | 2023-01-27 A |  | 100% |  |  |
| 476 | 1.4.1.1.2.1 | **Overarching Test Scope (excl. Migration/Reverse Migration, NFT and Ops components)** | 65d | 2022-10-31 A | 2023-01-27 A |  | 100% |  |  |
| 477 |  | Develop document (excl Migration/Reverse Migration, NFT and Ops components) | 55d | 2022-10-31 A | 2023-01-13 A | 48 | 100% |  |  |
| 478 |  | Review, update & agree document (excl Migration/Reverse Migration, NFT and Ops components) | 10d | 2023-01-16 A | 2023-01-27 A | 477 | 100% |  |  |
| 479 | 1.4.1.1.3 | **Configuration and Release Management Approach & Plan** | 164d | 2022-11-01 A | 2023-06-16 A |  | 100% |  |  |
| 480 |  | Develop document | 69d | 2022-11-01 A | 2023-06-16 A |  | 100% |  | start no earlier than 2022-11-01 |
| 481 |  | Review, update and agree Configuration and Release Management Approach & Plan internally | 63d | 2023-02-01 A | 2023-04-28 A | 480 | 100% |  |  |
| 482 | 1.4.1.1.4 | **Test Data Overarching Approach & Plan** | 179d | 2022-11-14 A | 2023-07-20 A |  | 100% |  |  |
| 483 |  | Develop document | 20d | 2022-11-14 A | 2022-12-09 A |  | 100% |  | start no earlier than 2022-11-14 |
| 484 |  | Document review and update | 155d | 2022-12-12 A | 2023-07-14 A | 483 | 100% |  |  |
| 485 |  | Test Data Overarching Approach & Plan approved by TMAG | 0d | 2023-07-19 A | 2023-07-19 A | 484FS+3d | 100% |  |  |
| 486 |  | Document publication final version | 1d | 2023-07-20 A | 2023-07-20 A | 485 | 100% |  |  |
| 487 | 1.4.1.1.5 | **Interface Code of Connection (dates subject to DIP Service Provider's plan)** | 48d | 2023-03-01 A | 2023-05-05 A |  | 100% |  |  |
| 488 |  | Develop Interface Code of Connection with DIP Service Provider | 43d | 2023-03-01 A | 2023-04-28 A |  | 100% |  | must start on 2023-03-01 |
| 489 |  | Interface Code of Connection approved at SDWG | 0d | 2023-05-05 A | 2023-05-05 A | 488FS+5d | 100% |  |  |
| 490 | 1.4.1.1.6 | **Test Traceability** | 165d | 2023-06-01 A | 2024-01-17 |  | 98% | 877d |  |

| ID | WBS | Task | Duration | Start | Finish | Predecessors | Complete | Total float | Constraint |
| --- | --- | --- | --- | --- | --- | --- | --- | --- | --- |
| 491 |  | RTM containing Method Statement Implied Requirements into Azure DevOps | 22d | 2023-06-01 A | 2023-06-30 A |  | 100% |  | must start on 2023-06-01 |
| 492 |  | RTM Containing Interface Catalogue Implied Requirements | 27d | 2023-06-01 A | 2023-07-07 A |  | 100% |  | must start on 2023-06-01 |
| 493 |  | SIT CIT Full Traceability & Coverage complete | 118d | 2023-07-10 A | 2023-12-20 A | 492, 491 | 100% |  |  |
| 494 |  | SIT Functional Full Traceability & Coverage complete | 138d | 2023-07-10 A | 2024-01-17 | 492, 491 | 96% | 877d |  |
| 495 | 1.4.1.2 | **Test Tool Development** | 256d | 2022-10-31 A | 2023-10-23 |  | 99% | 939d |  |
| 496 | 1.4.1.2.1 | **Test Management Tool** | 256d | 2022-10-31 A | 2023-10-23 A |  | 100% |  |  |
| 497 | 1.4.1.2.1.1 | **Test Management Tool Implementation** | 256d | 2022-10-31 A | 2023-10-23 A |  | 100% |  |  |
| 498 |  | Requirements identification | 40d | 2022-10-31 A | 2022-12-23 A |  | 100% |  |  |
| 499 |  | Development | 125d | 2023-01-02 A | 2023-06-23 A | 498FS+5d | 100% |  |  |
| 500 |  | Testing | 125d | 2023-01-02 A | 2023-06-23 A | 499FF | 100% |  |  |
| 501 |  | Accept tool | 0d | 2023-06-23 A | 2023-06-23 A | 500FF | 100% |  |  |
| 502 |  | Implementation | 1d | 2023-10-23 A | 2023-10-23 A | 501FS+85d | 100% |  |  |
| 503 | 1.4.1.2.1.2 | **Test Management Tool User Guide** | 115d | 2023-01-02 A | 2023-06-09 A |  | 100% |  |  |
| 504 |  | Develop document | 100d | 2023-01-02 A | 2023-05-19 A | 499SS, 500SS | 100% |  | start no earlier than 2023-01-02 |
| 505 |  | Review, update and agree Test Management Tool User Guide internally | 15d | 2023-05-22 A | 2023-06-09 A | 504 | 100% |  |  |
| 506 | 1.4.1.2.1.3 | **Test Management Tool Configuration Guide** | 60d | 2023-01-02 A | 2023-03-24 A |  | 100% |  |  |
| 507 |  | Develop document | 45d | 2023-01-02 A | 2023-03-03 A | 498 | 100% |  | start no earlier than 2023-01-02 |
| 508 |  | Review, update and agree Test Management Tool Configuration Guide internally | 15d | 2023-03-06 A | 2023-03-24 A | 507 | 100% |  |  |
| 509 | 1.4.1.2.2 | **Test Query Tool** | 0d | 2022-10-31 | 2022-10-31 |  |  | 1195d |  |
| 510 | 1.4.1.2.2.1 | **Test Query Tool Implementation** | 130d | 2022-10-31 | 2023-04-28 |  |  | 96d |  |
| 511 |  | Requirements identification | 20d | 2022-10-31 | 2022-11-25 |  |  | 96d |  |
| 512 |  | Development | 10d | 2023-04-11 | 2023-04-24 | 511 |  | 0d | must start on 2023-04-11 |
| 513 |  | Testing | 5d | 2023-04-18 | 2023-04-24 | 512FF |  | 1065d |  |
| 514 |  | Accept tool | 0d | 2023-04-24 | 2023-04-24 | 513FF |  | 1065d |  |
| 515 |  | Implementation | 1d | 2023-04-28 | 2023-04-28 | 514FS+3d |  | 1065d |  |
| 516 | 1.4.1.2.2.2 | **Test Query Tool User Guide** | 14d | 2023-04-11 | 2023-04-28 |  |  | 1065d |  |
| 517 |  | Develop document | 10d | 2023-04-11 | 2023-04-24 | 512SS |  | 1065d | start no earlier than 2022-11-28 |
| 518 |  | Review, update and agree Test Query Tool User Guide internally | 4d | 2023-04-25 | 2023-04-28 | 517 |  | 1065d |  |
| 519 | 1.4.1.3 | **SIT Participation** | 147d | 2022-10-31 A | 2023-05-23 A |  | 100% |  |  |
| 520 |  | PPs decide whether to volunteer to participate in SIT and inform Programme of decision via Round 3 Replan consultation | 67d | 2022-10-31 A | 2023-01-31 A | 34FF | 100% |  |  |
| 521 |  | Assurance of SIT volunteers' plans (submitted via Round 3 Replan Consultation) | 10d | 2023-02-01 A | 2023-02-14 A | 520, 34 | 100% |  |  |
| 522 |  | SIT Participant Volunteers Identified | 0d | 2023-02-14 A | 2023-02-14 A | 521FF | 100% |  |  |
| 523 |  | Engagement with SIT volunteers | 147d | 2022-10-31 A | 2023-05-23 A |  | 100% |  |  |
| 524 |  | SIT Participants Agreed | 0d | 2023-05-23 A | 2023-05-23 A | 523, 581FS-74d | 100% |  |  |
| 525 | 1.4.1.4 | **Data Protection Impact Assessment (DPIA)** | 32d | 2023-06-01 A | 2023-07-14 A |  | 100% |  |  |
| 526 |  | Conduct DPIA on Overall Test Data Approach | 22d | 2023-06-01 A | 2023-06-30 A | 485 | 100% |  | start no earlier than 2023-06-01 |
| 527 |  | Revise Overarching Test Data Approach & plan for DPIA (if required), including engagement with DWG | 9d | 2023-07-03 A | 2023-07-13 A | 526 | 100% |  |  |
| 528 |  | Review (internal), update and approve revised Overarching Test Data Approach & Plan (if required) | 1d | 2023-07-14 A | 2023-07-14 A | 527 | 100% |  |  |
| 529 | 1.4.1.5 | **Data Sharing Agreements** | 44d | 2023-07-17 A | 2023-09-14 A |  | 100% |  |  |
| 530 |  | Produce Data Sharing Agreement for Industry Review | 15d | 2023-07-17 A | 2023-08-04 A | 528 | 100% |  |  |
| 531 |  | Manage Participant Queries and Contract Agreement Execution | 29d | 2023-08-07 A | 2023-09-14 A | 530 | 100% |  |  |
| 532 |  | Data Sharing Agreements Complete | 0d | 2023-09-14 A | 2023-09-14 A | 531 | 100% |  |  |
| 533 | 1.4.1.6 | **Production Data Cut & Data Obfuscation** | 109d | 2023-04-04 A | 2023-09-01 A |  | 100% |  |  |
| 534 | 1.4.1.6.1 | **SI Data Cut Preparation & Infrastructure** | 99d | 2023-04-04 A | 2023-08-18 A |  | 100% |  |  |
| 535 |  | SI Data Cut Planning activities (incl. pre-cut and post-cut cleansing and population approach) | 55d | 2023-04-04 A | 2023-06-19 A |  | 100% |  | must start on 2023-04-04 |
| 536 |  | Set up SI database and transmission structure | 44d | 2023-06-19 A | 2023-08-17 A | 535 | 100% |  | must start on 2023-06-19 |
| 537 |  | Mechanism for transfer of data in place | 1d | 2023-08-18 A | 2023-08-18 A | 536 | 100% |  |  |
| 538 |  | SI Data Cut Preparation & Infrastructure Complete | 0d | 2023-08-18 A | 2023-08-18 A | 537 | 100% |  |  |
| 539 | 1.4.1.6.2 | **Production Data Cut** | 55d | 2023-06-19 A | 2023-09-01 A |  | 100% |  |  |
| 540 |  | Notification of Production Data Cut issued to relevant participants | 0d | 2023-06-19 A | 2023-06-19 A | 485 | 100% |  |  |
| 541 |  | Coordinate relevant participants taking data cut from production systems | 40d | 2023-06-19 A | 2023-08-11 A | 540 | 100% |  |  |
| 542 |  | Production data cut GONG decision | 0d | 2023-08-16 A | 2023-08-16 A | 541FS+3d | 100% |  |  |
| 543 |  | Relevant participants take data cut from production systems (Saturday 19 August) | 1d | 2023-08-21 A | 2023-08-21 A | 542FS+2d | 100% |  |  |
| 544 |  | EES transmit request data to SI | 5d | 2023-08-21 A | 2023-08-25 A | 543SS | 100% |  |  |
| 545 |  | Check data alignment and integrity of data cut | 5d | 2023-08-28 A | 2023-09-01 A | 544 | 100% |  |  |
| 546 |  | Data cut from relevant participants' production systems completed (Saturday 19 August) | 0d | 2023-08-21 A | 2023-08-21 A | 543, 526 | 100% |  |  |
| 547 |  | Production Data Cut Complete | 0d | 2023-08-21 A | 2023-08-21 A | 546 | 100% |  |  |
| 548 | 1.4.1.7 | **SIT Stage-Specific Preparation** | 520d | 2022-10-31 A | 2024-10-25 |  | 97% | 675d |  |
| 549 | 1.4.1.7.1 | **SIT Component Integration Preparation** | 320d | 2022-10-31 A | 2024-01-19 A |  | 100% |  |  |
| 550 | 1.4.1.7.1.1 | **Test Approach & Plan** | 188d | 2022-10-31 A | 2023-07-19 A |  | 100% |  |  |
| 551 |  | Develop document with SITWG | 159d | 2022-10-31 A | 2023-06-08 A |  | 100% |  |  |
| 552 |  | Industry consultation | 10d | 2023-06-09 A | 2023-06-22 A | 551 | 100% |  |  |
| 553 |  | Artefact review (via TMAG) and updates | 19d | 2023-06-23 A | 2023-07-19 A | 552 | 100% |  | finish no earlier than 2023-07-06 |
| 554 |  | SIT Component Integration Testing Test Approach & Plan approved | 0d | 2023-07-19 A | 2023-07-19 A | 553 | 100% |  | finish no earlier than 2023-07-19 |
| 555 | 1.4.1.7.1.2 | **Test Data Approach & Plan** | 29d | 2023-06-09 A | 2023-07-19 A |  | 100% |  |  |
| 556 |  | Industry consultation | 10d | 2023-06-09 A | 2023-06-22 A | 552SS | 100% |  |  |
| 557 |  | Artefact review (via TMAG) and updates | 19d | 2023-06-23 A | 2023-07-19 A | 556 | 100% |  |  |
| 558 |  | SIT Component Integration Testing Test Data Approach & Plan approved | 0d | 2023-07-19 A | 2023-07-19 A | 557 | 100% |  |  |
| 559 | 1.4.1.7.1.3 | **Test scenarios** | 173d | 2023-01-02 A | 2023-08-30 A |  | 100% |  |  |
| 560 |  | Development of test scenarios | 0d | 2023-01-02 A | 2023-04-28 A | 551SS+45d | 100% |  |  |

| ID | WBS | Task | Duration | Start | Finish | Predecessors | Complete | Constraint |
| --- | --- | --- | --- | --- | --- | --- | --- | --- |
| 561 |  | Review test scenarios with SIT Working Group | 11d | 2023-02-01 A | 2023-08-09 A | 560SS+22d | 100% |  |
| 562 |  | SIT Component Integration Testing Test scenarios approved | 0d | 2023-08-30 A | 2023-08-30 A | 561FS+15d | 100% |  |
| 563 | 1.4.1.7.1.4 | **Test cases** | 160d | 2023-05-01 A | 2023-12-08 A |  | 100% |  |
| 564 | 1.4.1.7.1.4.1 | **SI Test cases** | 160d | 2023-05-01 A | 2023-12-08 A |  | 100% |  |
| 565 | 1.4.1.7.1.4.1.1 | **Batch 1 (CIT Intervals 1 and 2)** | 110d | 2023-05-01 A | 2023-09-29 A |  | 100% |  |
| 566 |  | Develop Test cases | 100d | 2023-05-01 A | 2023-09-15 A | 560 | 100% |  |
| 567 |  | Review Test cases with SIT Working Group | 9d | 2023-09-18 A | 2023-09-28 A | 566 | 100% |  |
| 568 |  | SIT Component Integration Testing Test cases Batch 1 (CIT Intervals 1 and 2) approved at ETMAG | 0d | 2023-09-29 A | 2023-09-29 A | 567FS+1d | 100% |  |
| 569 | 1.4.1.7.1.4.1.2 | **Batch 2 (CIT Intervals 3 and 4)** | 25d | 2023-10-02 A | 2023-11-03 A |  | 100% |  |
| 570 |  | Develop Test cases | 15d | 2023-10-02 A | 2023-10-20 A | 568 | 100% |  |
| 571 |  | Review Test cases with SIT Working Group | 9d | 2023-10-23 A | 2023-11-02 A | 570 | 100% |  |
| 572 |  | SIT Component Integration Testing Test cases Batch 2 (CIT Intervals 3 and 4) approved at ETMAG | 0d | 2023-11-03 A | 2023-11-03 A | 571FS+1d | 100% |  |
| 573 | 1.4.1.7.1.4.1.3 | **Batch 3 (CIT Intervals 5 and 6)** | 25d | 2023-11-03 A | 2023-12-08 A |  | 100% |  |
| 574 |  | Develop Test cases | 15d | 2023-11-03 A | 2023-11-24 A | 572 | 100% |  |
| 575 |  | Review Test cases with SIT Working Group | 9d | 2023-11-27 A | 2023-12-07 A | 574 | 100% |  |
| 576 |  | SIT Component Integration Testing Test cases Batch 3 (CIT Intervals 5 and 6) approved at ETMAG | 0d | 2023-12-08 A | 2023-12-08 A | 575FS+1d | 100% |  |
| 577 | 1.4.1.7.1.5 | **CIT Interval 1 Preparation** | 283d | 2022-11-16 A | 2023-12-15 A |  | 100% |  |
| 578 | 1.4.1.7.1.5.1 | **Environments (SIT A)** | 246d | 2022-11-16 A | 2023-10-25 A |  | 100% |  |
| 579 |  | PPs register PKI Officers and request PKI certificates | 5d | 2023-10-09 A | 2023-10-13 A |  | 100% | start no earlier than 2023-10-09 |
| 580 |  | PPs register PKI Officers and request PKI certificates Complete - Interval 1 | 0d | 2023-10-25 A | 2023-10-25 A | 579FS+8d | 100% |  |
| 581 |  | PP SIT A environment preparation (incl. security certificates and security compliance) | 238d | 2022-11-16 A | 2023-10-13 A | 466 | 100% |  |
| 582 |  | SI coordinate SIT Participants' SIT A environment preparation | 238d | 2022-11-16 A | 2023-10-13 A | 581SS | 100% |  |
| 583 |  | PP submit self-declaration of environment preparation complete (incl. security certificates and security compliance) to Programme for assurance | 0d | 2023-10-13 A | 2023-10-13 A | 581FF | 100% | start no earlier than 2023-10-13 |
| 584 |  | SI assure PPs' self-declaration of environment preparation complete (incl. security certificates and security compliance) | 5d | 2023-10-16 A | 2023-10-20 A | 583FF+5d | 100% |  |
| 585 |  | SIT Participants' SIT A environments ready to start connectivity proving CIT Interval 1 | 0d | 2023-09-01 A | 2023-09-01 A | 583SS | 100% |  |
| 586 |  | PP SIT A environment connectivity proving | 10d | 2023-09-04 A | 2023-09-15 A | 585 | 100% |  |
| 587 |  | SI coordinate SIT Participants' SIT A environment connectivity proving | 10d | 2023-09-04 A | 2023-09-15 A | 586SS | 100% |  |
| 588 |  | PP deployment of MHHS solution code to SIT A environments | 10d | 2023-09-25 A | 2023-10-06 A | 629FF | 100% |  |
| 589 |  | SI coordinate deployment of MHHS solution code to SIT Participants' SIT A environments | 10d | 2023-09-25 A | 2023-10-06 A | 629FF | 100% |  |
| 590 |  | PP submit evidence of SIT A environment connectivity proving and code deployment completion to Programme for assurance | 30d | 2023-09-04 A | 2023-10-13 A | 586SS | 100% |  |
| 591 |  | SI assurance of SIT Participants' SIT A environment connectivity proving and code deployment completion | 25d | 2023-09-18 A | 2023-10-20 A | 590FF+5d | 100% |  |
| 592 | 1.4.1.7.1.5.2 | **Test Data - ISD Creation** | 9d | 2023-08-22 A | 2023-09-01 A |  | 100% |  |
| 593 |  | Set-up Market Participants and DIP ID Data | 8d | 2023-08-22 A | 2023-08-31 A | 547 | 100% |  |
| 594 |  | Distribute ISD Data to Participants | 1d | 2023-09-01 A | 2023-09-01 A | 593 | 100% |  |
| 595 |  | Test Data - ISD Creation Complete | 0d | 2023-09-01 A | 2023-09-01 A | 594 | 100% |  |
| 596 | 1.4.1.7.1.5.3 | **Test Data - SFTP Onboarding** | 70d | 2023-08-21 A | 2023-11-24 A |  | 100% |  |
| 597 |  | Create Containers and Keys for Participants | 3d | 2023-08-21 A | 2023-08-23 A | 538 | 100% |  |
| 598 |  | Share SFTP Access with Participants | 5d | 2023-08-24 A | 2023-08-30 A | 597 | 100% |  |
| 599 |  | Test SFTP Connectivity | 5d | 2023-08-31 A | 2023-09-06 A | 598 | 100% |  |
| 600 |  | Test Data - SFTP Onboarding Complete | 0d | 2023-11-24 A | 2023-11-24 A | 599FS+57d | 100% |  |
| 601 | 1.4.1.7.1.5.4 | **Test Data - Provide Sample Files** | 10d | 2023-08-21 A | 2023-09-01 A |  | 100% |  |
| 602 |  | Generate Sample Files off IF Messages | 8d | 2023-08-21 A | 2023-08-30 A | 538 | 100% |  |
| 603 |  | Transmit Sample Files off IF Messages to Participants (More detail needs to be planned for a POC) | 2d | 2023-08-31 A | 2023-09-01 A | 602 | 100% |  |
| 604 |  | Test Data - Provide Sample Files Complete | 0d | 2023-09-01 A | 2023-09-01 A | 603 | 100% |  |
| 605 | 1.4.1.7.1.5.5 | **Test Data - Detailed SIT Data Load Guidance** | 65d | 2023-09-07 A | 2023-12-06 A |  | 100% |  |
| 606 |  | Document Guidance | 21d | 2023-09-07 A | 2023-10-05 A | 604FS+3d | 100% |  |
| 607 |  | Provide Guidance to PPs | 1d | 2023-10-06 A | 2023-10-06 A | 606 | 100% |  |
| 608 |  | Test Data - Detailed SIT Functional Data Load Guidance Complete | 0d | 2023-12-06 A | 2023-12-06 A | 607FS+43d | 100% |  |
| 609 | 1.4.1.7.1.5.6 | **Test Data - Population of Data Items for Testing Guidance - Draft** | 80d | 2023-08-17 A | 2023-12-06 A |  | 100% |  |
| 610 |  | Document Guidance - Draft | 11d | 2023-08-17 A | 2023-08-31 A | 798 | 100% |  |
| 611 |  | Provide Guidance to PPs - Draft | 1d | 2023-09-01 A | 2023-09-01 A | 610 | 100% |  |
| 612 |  | Test Data - Population of Data Items for Testing Guidance - Draft Complete | 0d | 2023-12-06 A | 2023-12-06 A | 611FS+68d | 100% |  |
| 613 | 1.4.1.7.1.5.7 | **Test Data - Population of Data Items for Testing Guidance - Final** | 87d | 2023-08-17 A | 2023-12-15 A |  | 100% |  |
| 614 |  | Update Document Guidance With PPS Feedback | 81d | 2023-08-17 A | 2023-12-07 A | 610SS | 100% |  |
| 615 |  | Provide Final Guidance to PPs | 1d | 2023-12-08 A | 2023-12-08 A | 614 | 100% |  |
| 616 |  | Test Data - Population of Data Items for Testing Guidance - Final Complete | 0d | 2023-12-15 A | 2023-12-15 A | 615FS+5d | 100% |  |
| 617 | 1.4.1.7.1.5.8 | **Test Data (SIT A) Interval 1** | 40d | 2023-09-04 A | 2023-10-27 A |  | 100% |  |
| 618 |  | Run data allocation | 4d | 2023-09-04 A | 2023-09-07 A | 545, 558, 547, 595 | 100% |  |
| 619 |  | Cleanse, anonymise and populate data post cut | 4d | 2023-09-08 A | 2023-09-13 A | 618 | 100% |  |
| 620 |  | Transmit data sets to PPs | 3d | 2023-09-15 A | 2023-09-19 A | 619, 532 | 100% |  |
| 621 |  | PP - Load test data to test environments | 7d | 2023-09-20 A | 2023-09-28 A | 620, 604 | 100% |  |
| 622 |  | PP Check data integrity on test environment | 1d | 2023-09-29 A | 2023-09-29 A | 621 | 100% |  |
| 623 |  | PP submit self-declaration to Programme to confirm loading & verification of test data | 0d | 2023-09-29 A | 2023-09-29 A | 622FF | 100% |  |
| 624 |  | Test Data (SIT A) Interval 1 Complete | 0d | 2023-10-27 A | 2023-10-27 A | 623FS+20d | 100% |  |
| 625 | 1.4.1.7.1.5.9 | **Other Preparation** | 45d | 2023-07-03 A | 2023-09-01 A |  | 100% |  |
| 626 |  | Onboarding of Test Participants to Test Management Tool (Azure DevOps) | 45d | 2023-07-03 A | 2023-09-01 A | 585SF | 100% |  |
| 627 |  | Test Management Tool onboarding | 45d | 2023-07-03 A | 2023-09-01 A | 585SF | 100% |  |
| 628 | 1.4.1.7.1.5.10 | **SIT Component Integration Test Readiness Report** | 28d | 2023-09-14 A | 2023-10-23 A |  | 100% |  |
| 629 |  | PP submit Test Readiness Report to Programme for assurance | 0d | 2023-10-20 A | 2023-10-20 A | 627, 568, 624 | 100% | start no earlier than 2023-10-09 |
| 630 |  | SI assure Test Participants' Test Readiness Reports | 1d | 2023-10-23 A | 2023-10-23 A | 629SS | 100% |  |

| ID | WBS | Task | Duration | Start | Finish | Predecessors | Complete | Constraint |
| --- | --- | --- | --- | --- | --- | --- | --- | --- |
| 631 |  | SI develop Overarching SIT Component Integration Test Readiness Report | 23d | 2023-09-14 A | 2023-10-16 A | 554FS+40d | 100% |  |
| 632 |  | Artefact review (via TMAG) and updates | 4d | 2023-10-17 A | 2023-10-20 A | 631 | 100% |  |
| 633 |  | SIT Component Integration Testing 1 Preparation Complete (incl. approval of SI SIT Component Integration Test Readiness Report) | 0d | 2023-10-27 A | 2023-10-27 A | 632FS+1d, 629, 585, 627, 624, 198, 203, 192, 212, 213, 630 | 100% |  |
| 634 | 1.4.1.7.1.6 | **CIT Interval 2 Preparation** | 103d | 2023-07-03 A | 2023-11-22 A |  | 100% |  |
| 635 | 1.4.1.7.1.6.1 | **Environments (SIT A)** | 43d | 2023-09-22 A | 2023-11-22 A |  | 100% |  |
| 636 |  | SIT Participants' SIT A environments ready to start connectivity proving CIT Interval 2 | 0d | 2023-09-22 A | 2023-09-22 A |  | 100% |  |
| 637 |  | Programme Participants Ready to Start Connectivity Proving | 0d | 2023-09-22 A | 2023-09-22 A |  | 100% | finish no earlier than 2023-09-22 |
| 638 |  | Internal Connectivity Proving Phase | 10d | 2023-09-25 A | 2023-10-06 A | 637 | 100% |  |
| 639 |  | Internal Connectivity Proving Phase Complete | 0d | 2023-10-06 A | 2023-10-06 A | 638 | 100% | start no earlier than 2023-10-06 |
| 640 |  | DIP Onboarding Activity (1. PKI Officers and Certificates, 2. Set-up Validation, 3. End Point Creation, 4. Controlled Smoke Test ) | 28d | 2023-10-16 A | 2023-11-22 A | 639FS+5d | 100% |  |
| 641 |  | DIP Onboarding Complete | 0d | 2023-11-22 A | 2023-11-22 A | 640 | 100% |  |
| 642 |  | PPs Register PKI Officers and request PKI certificates Complete - Interval 2 | 0d | 2023-11-22 A | 2023-11-22 A | 641 | 100% |  |
| 643 |  | PP Code Deployment | 0d | 2023-10-20 A | 2023-10-20 A |  | 100% | start no earlier than 2023-10-20 |
| 644 | 1.4.1.7.1.6.2 | **Test Data (SIT A) Interval 2** | 43d | 2023-09-20 A | 2023-11-17 A |  | 100% |  |
| 645 |  | Run data allocation | 7d | 2023-09-20 A | 2023-09-28 A | 621SS | 100% |  |
| 646 |  | Cleanse and populate data post cut | 2d | 2023-09-29 A | 2023-10-02 A | 645 | 100% |  |
| 647 |  | Transmit data sets to PPs | 1d | 2023-10-03 A | 2023-10-03 A | 646 | 100% |  |
| 648 |  | PP - Load test data to test environments | 33d | 2023-10-04 A | 2023-11-17 A | 647 | 100% |  |
| 649 |  | PP Check data integrity on test environment | 15d | 2023-10-23 A | 2023-11-17 A | 648FF | 100% |  |
| 650 |  | PP submit self-declaration to Programme to confirm loading & verification of test data | 0d | 2023-11-17 A | 2023-11-17 A | 649FF | 100% |  |
| 651 |  | Test Data (SIT A) Interval 2 Complete | 0d | 2023-11-17 A | 2023-11-17 A | 650 | 100% |  |
| 652 | 1.4.1.7.1.6.3 | **Other Preparation** | 87d | 2023-07-03 A | 2023-10-31 A |  | 100% |  |
| 653 |  | Onboarding of Test Participants to Test Management Tool (Azure DevOps) | 60d | 2023-07-03 A | 2023-09-22 A | 636SF | 100% |  |
| 654 |  | Test Management Tool onboarding | 27d | 2023-09-25 A | 2023-10-31 A | 653 | 100% |  |
| 655 | 1.4.1.7.1.6.4 | **SIT Component Integration Test Readiness Report** | 25d | 2023-10-02 A | 2023-11-03 A |  | 100% |  |
| 656 |  | PP submit Test Readiness Report to Programme for assurance | 0d | 2023-10-25 A | 2023-10-25 A | 568FS+18d | 100% |  |
| 657 |  | SI assure Test Participants' Test Readiness Reports | 2d | 2023-10-26 A | 2023-10-27 A | 656 | 100% |  |
| 658 |  | SI develop Overarching SIT Component Integration Test Readiness Report | 20d | 2023-10-02 A | 2023-10-27 A | 657FF | 100% |  |
| 659 |  | Artefact review (via TMAG) and updates | 5d | 2023-10-30 A | 2023-11-03 A | 658 | 100% |  |
| 660 |  | SIT Component Integration Testing 2 Preparation Complete (incl. approval of SI SIT Component Integration Test Readiness Report) | 0d | 2023-11-06 A | 2023-11-06 A | 654, 659FS+1d, 636, 261 | 100% |  |
| 661 | 1.4.1.7.1.7 | **CIT Interval 3 Preparation** | 54d | 2023-10-03 A | 2023-12-15 A |  | 100% |  |
| 662 | 1.4.1.7.1.7.1 | **PIT Test Completion Report (incl. evidence)** | 26d | 2023-10-13 A | 2023-11-17 A |  | 100% |  |
| 663 |  | Submit draft PIT Test Completion Report (incl. evidence) and submit to Programme for assurance | 11d | 2023-10-13 A | 2023-10-27 A |  | 100% | must start on 2023-10-13 |
| 664 |  | Finalise PIT Test Completion Report (incl. evidence) | 5d | 2023-10-30 A | 2023-11-03 A | 663 | 100% |  |
| 665 |  | PP PIT Completion Report (excl. Migration/Reverse Migration) submitted to Programme for assurance CIT Interval 3 | 0d | 2023-11-03 A | 2023-11-03 A | 664, 80, 96 | 100% |  |
| 666 |  | PP Final PIT Completion Reports assured by SI | 10d | 2023-11-06 A | 2023-11-17 A | 665 | 100% |  |
| 667 | 1.4.1.7.1.7.2 | **Environments (SIT A)** | 51d | 2023-10-06 A | 2023-12-15 A |  | 100% |  |
| 668 |  | Programme Participants Ready to Start Connectivity Proving | 0d | 2023-10-06 A | 2023-10-06 A |  | 100% | start no earlier than 2023-10-06 |
| 669 |  | SIT Participants' SIT A environments ready to start connectivity proving CIT Interval 3 | 0d | 2023-10-06 A | 2023-10-06 A | 668 | 100% |  |
| 670 |  | Internal Connectivity Proving Phase | 10d | 2023-10-09 A | 2023-10-20 A | 668FS+1d | 100% |  |
| 671 |  | Internal Connectivity Proving Phase Complete | 0d | 2023-10-20 A | 2023-10-20 A | 670 | 100% |  |
| 672 |  | DIP Onboarding Activity (1. PKI Officers and Certificates, 2. Set-up Validation, 3. End Point Creation, 4. Controlled Smoke Test ) | 35d | 2023-10-30 A | 2023-12-15 A | 671FS+5d | 100% |  |
| 673 |  | DIP Onboarding Complete | 0d | 2023-12-15 A | 2023-12-15 A | 672 | 100% |  |
| 674 |  | PPs Register PKI Officers and Request PKI certificates Complete - Interval 3 | 0d | 2023-12-15 A | 2023-12-15 A | 673FF | 100% |  |
| 675 |  | PP Code Deployment | 0d | 2023-11-10 A | 2023-11-10 A | 671FS+15d | 100% | start no earlier than 2023-10-20 |
| 676 | 1.4.1.7.1.7.3 | **Test Data (SIT A) Interval 3** | 34d | 2023-10-03 A | 2023-11-17 A |  | 100% |  |
| 677 |  | Run data allocation | 4d | 2023-10-03 A | 2023-10-06 A | 647SS | 100% |  |
| 678 |  | Cleanse and populate data post cut | 5d | 2023-10-09 A | 2023-10-13 A | 677 | 100% |  |
| 679 |  | Transmit data sets to PPs | 2d | 2023-10-16 A | 2023-10-17 A | 678 | 100% |  |
| 680 |  | PP - Load test data to test environments | 8d | 2023-10-18 A | 2023-10-27 A | 679 | 100% |  |
| 681 |  | PP Check data integrity on test environment | 15d | 2023-10-30 A | 2023-11-17 A | 680 | 100% |  |
| 682 |  | PP submit self-declaration to Programme to confirm loading & verification of test data | 0d | 2023-11-17 A | 2023-11-17 A | 681FF | 100% |  |
| 683 |  | Test Data (SIT A) Interval 3 Complete | 0d | 2023-11-17 A | 2023-11-17 A | 682 | 100% |  |
| 684 | 1.4.1.7.1.7.4 | **Other Preparation** | 25d | 2023-10-16 A | 2023-11-17 A |  | 100% |  |
| 685 |  | Onboarding of Test Participants to Test Management Tool (Azure DevOps) | 25d | 2023-10-16 A | 2023-11-17 A |  | 100% | start no earlier than 2023-10-16 |
| 686 |  | Test Management Tool onboarding | 25d | 2023-10-16 A | 2023-11-17 A |  | 100% | start no earlier than 2023-10-16 |
| 687 | 1.4.1.7.1.7.5 | **SIT Component Integration Test Readiness Report** | 25d | 2023-10-16 A | 2023-11-17 A |  | 100% |  |
| 688 |  | PP submit Test Readiness Report to Programme for assurance | 0d | 2023-11-03 A | 2023-11-03 A | 572 | 100% |  |
| 689 |  | SI assure Test Participants' Test Readiness Reports | 5d | 2023-11-06 A | 2023-11-10 A | 688FF+5d | 100% |  |
| 690 |  | SI develop Overarching SIT Component Integration Test Readiness Report | 20d | 2023-10-16 A | 2023-11-10 A | 689FF | 100% |  |
| 691 |  | Artefact review (via TMAG) and updates | 5d | 2023-11-13 A | 2023-11-17 A | 690 | 100% |  |
| 692 |  | SIT Component Integration Testing 3 Preparation Complete (incl. approval of SI SIT Component Integration Test Readiness Report) | 0d | 2023-11-20 A | 2023-11-20 A | 691FS+1d, 665, 669, 688, 686, 683, 279 | 100% |  |
| 693 | 1.4.1.7.1.8 | **CIT Interval 4 Preparation** | 36d | 2023-10-16 A | 2023-12-04 A |  | 100% |  |
| 694 | 1.4.1.7.1.8.1 | **PIT Test Completion Report (incl. evidence)** | 21d | 2023-10-27 A | 2023-11-24 A |  | 100% |  |
| 695 |  | Submit draft PIT Test Completion Report (incl. evidence) and submit to Programme for assurance | 1d | 2023-10-27 A | 2023-10-27 A |  | 100% | must start on 2023-10-27 |
| 696 |  | Finalise PIT Test Completion Report (incl. evidence) | 15d | 2023-10-30 A | 2023-11-17 A | 695 | 100% |  |
| 697 |  | PP PIT Completion Report (excl. Migration/Reverse Migration) submitted to Programme for assurance CIT Interval 4 | 0d | 2023-11-17 A | 2023-11-17 A | 696, 80, 96 | 100% |  |
| 698 |  | PP Final PIT Completion Reports assured by SI | 5d | 2023-11-20 A | 2023-11-24 A | 697 | 100% |  |
| 699 | 1.4.1.7.1.8.2 | **Environments (SIT A)** | 25d | 2023-10-23 A | 2023-11-24 A |  | 100% |  |
| 700 |  | Programme Participants Ready to Start Connectivity Proving | 0d | 2023-10-23 A | 2023-10-23 A |  | 100% | start no earlier than 2023-10-23 |

| ID | WBS | Task | Duration | Start | Finish | Predecessors | Complete | Constraint |
| --- | --- | --- | --- | --- | --- | --- | --- | --- |
| 701 |  | SIT Participants' SIT A environments ready to start connectivity proving CIT Interval 4 | 0d | 2023-10-23 A | 2023-10-23 A | 700 | 100% |  |
| 702 |  | Internal Connectivity Proving Phase | 10d | 2023-10-23 A | 2023-11-03 A | 701 | 100% |  |
| 703 |  | Internal Connectivity Proving Phase Complete | 0d | 2023-11-03 A | 2023-11-03 A | 702 | 100% |  |
| 704 |  | DIP Onboarding Activity (1. PKI Officers and Certificates, 2. Set-up Validation, 3. End Point Creation, 4. Controlled Smoke Test ) | 10d | 2023-11-13 A | 2023-11-24 A | 703FS+5d | 100% |  |
| 705 |  | DIP Onboarding Complete | 0d | 2023-11-24 A | 2023-11-24 A | 704 | 100% |  |
| 706 |  | PPs register PKI Officers and Request PKI Certificates Complete - Interval 4 | 0d | 2023-11-24 A | 2023-11-24 A | 705 | 100% |  |
| 707 |  | PP Code Deployment | 0d | 2023-11-17 A | 2023-11-17 A |  | 100% | start no earlier than 2023-11-17 |
| 708 | 1.4.1.7.1.8.3 | **Test Data (SIT A) Interval 4** | 30d | 2023-10-23 A | 2023-12-01 A |  | 100% |  |
| 709 |  | Run data allocation | 5d | 2023-10-23 A | 2023-10-27 A | 678FS+5d | 100% |  |
| 710 |  | Cleanse and populate data post cut | 2d | 2023-10-30 A | 2023-10-31 A | 709 | 100% |  |
| 711 |  | Transmit data sets to PPs | 5d | 2023-11-01 A | 2023-11-07 A | 710 | 100% |  |
| 712 |  | PP - Load test data to test environments | 5d | 2023-11-08 A | 2023-11-14 A | 711 | 100% |  |
| 713 |  | PP Check data integrity on test environment | 13d | 2023-11-15 A | 2023-12-01 A | 712 | 100% |  |
| 714 |  | PP submit self-declaration to Programme to confirm loading & verification of test data | 0d | 2023-12-01 A | 2023-12-01 A | 713FF | 100% |  |
| 715 |  | Test Data (SIT A) Interval 4 Complete | 0d | 2023-12-01 A | 2023-12-01 A | 714 | 100% |  |
| 716 | 1.4.1.7.1.8.4 | **Other Preparation** | 25d | 2023-10-30 A | 2023-12-01 A |  | 100% |  |
| 717 |  | Onboarding of Test Participants to Test Management Tool (Azure DevOps) | 25d | 2023-10-30 A | 2023-12-01 A |  | 100% | start no earlier than 2023-10-30 |
| 718 |  | Test Management Tool onboarding | 25d | 2023-10-30 A | 2023-12-01 A |  | 100% | start no earlier than 2023-10-30 |
| 719 | 1.4.1.7.1.8.5 | **SIT Component Integration Test Readiness Report** | 27d | 2023-10-16 A | 2023-11-21 A |  | 100% |  |
| 720 |  | PP submit Test Readiness Report to Programme for assurance | 0d | 2023-11-03 A | 2023-11-03 A | 572 | 100% |  |
| 721 |  | SI assure Test Participants' Test Readiness Reports | 5d | 2023-11-06 A | 2023-11-10 A | 720FF+5d | 100% |  |
| 722 |  | SI develop Overarching SIT Component Integration Test Readiness Report | 20d | 2023-10-16 A | 2023-11-10 A | 721FF | 100% |  |
| 723 |  | Artefact review (via SITAG) and updates | 7d | 2023-11-13 A | 2023-11-21 A | 722 | 100% |  |
| 724 |  | SIT Component Integration Testing 4 Preparation Complete (incl. approval of SI SIT Component Integration Test Readiness Report) | 0d | 2023-12-04 A | 2023-12-04 A | 723FS+2d, 697, 701, 720, 715, 296FS+1d | 100% |  |
| 725 | 1.4.1.7.1.9 | **CIT Interval 5 Preparation** | 53d | 2023-11-01 A | 2024-01-12 A |  | 100% |  |
| 726 | 1.4.1.7.1.9.1 | **PIT Test Completion Report (incl. evidence)** | 21d | 2023-11-17 A | 2023-12-15 A |  | 100% |  |
| 727 |  | Submit draft PIT Test Completion Report (incl. evidence) and submit to Programme for assurance | 1d | 2023-11-17 A | 2023-11-17 A |  | 100% | must start on 2023-11-17 |
| 728 |  | Finalise PIT Test Completion Report (incl. evidence) | 15d | 2023-11-20 A | 2023-12-08 A | 727 | 100% |  |
| 729 |  | PP PIT Completion Report (excl. Migration/Reverse Migration) submitted to Programme for assurance CIT Interval 5 | 0d | 2023-12-08 A | 2023-12-08 A | 728, 80, 96 | 100% |  |
| 730 |  | PP Final PIT Completion Reports assured by SI | 5d | 2023-12-11 A | 2023-12-15 A | 729 | 100% |  |
| 731 | 1.4.1.7.1.9.2 | **Environments (SIT A)** | 21d | 2023-11-10 A | 2023-12-08 A |  | 100% |  |
| 732 |  | Programme Participants Ready to Start Connectivity Proving | 0d | 2023-11-10 A | 2023-11-10 A |  | 100% | start no earlier than 2023-11-10 |
| 733 |  | SIT Participants' SIT A environments ready to start connectivity proving CIT Interval 5 | 0d | 2023-11-10 A | 2023-11-10 A | 732 | 100% |  |
| 734 |  | Internal Connectivity Proving Phase | 10d | 2023-11-13 A | 2023-11-24 A | 732FS+1d | 100% |  |
| 735 |  | Internal Connectivity Proving Phase Complete | 0d | 2023-11-24 A | 2023-11-24 A | 734 | 100% |  |
| 736 |  | DIP Onboarding Activity (1. PKI Officers and Certificates, 2. Set-up Validation, 3. End Point Creation, 4. Controlled Smoke Test ) | 10d | 2023-11-27 A | 2023-12-08 A | 735 | 100% |  |
| 737 |  | DIP Onboarding Complete | 0d | 2023-12-08 A | 2023-12-08 A | 736 | 100% |  |
| 738 |  | PPs register PKI Officers and Request PKI Certificates Complete - Interval 5 | 0d | 2023-12-08 A | 2023-12-08 A | 737 | 100% |  |
| 739 |  | PP Code Deployment | 0d | 2023-12-08 A | 2023-12-08 A | 738 | 100% | start no earlier than 2023-10-20 |
| 740 | 1.4.1.7.1.9.3 | **Test Data (SIT A) Interval 5** | 33d | 2023-11-01 A | 2023-12-15 A |  | 100% |  |
| 741 |  | Run data allocation | 5d | 2023-11-01 A | 2023-11-07 A | 711SS | 100% |  |
| 742 |  | Cleanse and populate data post cut | 8d | 2023-11-08 A | 2023-11-17 A | 741 | 100% |  |
| 743 |  | Transmit data sets to PPs | 2d | 2023-11-20 A | 2023-11-21 A | 742 | 100% |  |
| 744 |  | PP - Load test data to test environments | 8d | 2023-11-22 A | 2023-12-01 A | 743 | 100% |  |
| 745 |  | PP Check data integrity on test environment | 10d | 2023-12-04 A | 2023-12-15 A | 744 | 100% |  |
| 746 |  | PP submit self-declaration to Programme to confirm loading & verification of test data | 0d | 2023-12-15 A | 2023-12-15 A | 745FF | 100% |  |
| 747 |  | Test Data (SIT A) Interval 5 Complete | 0d | 2023-12-15 A | 2023-12-15 A | 746 | 100% |  |
| 748 | 1.4.1.7.1.9.4 | **Other Preparation** | 40d | 2023-11-20 A | 2024-01-12 A |  | 100% |  |
| 749 |  | Onboarding of Test Participants to Test Management Tool (Azure DevOps) | 40d | 2023-11-20 A | 2024-01-12 A |  | 100% | start no earlier than 2023-11-20 |
| 750 |  | Test Management Tool onboarding | 36d | 2023-11-20 A | 2024-01-08 A |  | 100% | start no earlier than 2023-11-20 |
| 751 | 1.4.1.7.1.9.5 | **SIT Component Integration Test Readiness Report** | 35d | 2023-11-20 A | 2024-01-05 A |  | 100% |  |
| 752 |  | PP submit Test Readiness Report to Programme for assurance | 0d | 2023-12-08 A | 2023-12-08 A | 576 | 100% |  |
| 753 |  | SI assure Test Participants' Test Readiness Reports | 5d | 2023-12-11 A | 2023-12-15 A | 752FF+5d | 100% |  |
| 754 |  | SI develop Overarching SIT Component Integration Test Readiness Report | 20d | 2023-11-20 A | 2023-12-15 A | 753FF | 100% |  |
| 755 |  | Artefact review (via SITAG) and updates | 15d | 2023-12-18 A | 2024-01-05 A | 754 | 100% |  |
| 756 |  | SIT Component Integration Testing 5 Preparation Complete (incl. approval of SI SIT Component Integration Test Readiness Report) | 0d | 2024-01-08 A | 2024-01-08 A | 755FS+1d, 729, 733, 750, 752, 747, 398, 381 | 100% |  |
| 757 | 1.4.1.7.1.10 | **CIT Interval 6 Preparation** | 45d | 2023-11-20 A | 2024-01-19 A |  | 100% |  |
| 758 | 1.4.1.7.1.10.1 | **PIT Test Completion Report (incl. evidence)** | 31d | 2023-12-01 A | 2024-01-12 A |  | 100% |  |
| 759 |  | Submit draft PIT Test Completion Report (incl. evidence) and submit to Programme for assurance | 1d | 2023-12-01 A | 2023-12-01 A |  | 100% | must start on 2023-12-01 |
| 760 |  | Finalise PIT Test Completion Report (incl. evidence) | 25d | 2023-12-04 A | 2024-01-05 A | 759 | 100% |  |
| 761 |  | PP PIT Completion Report (excl. Migration/Reverse Migration) submitted to Programme for assurance CIT Interval 6 | 0d | 2024-01-05 A | 2024-01-05 A | 760, 80, 96, 218, 223, 226 | 100% |  |
| 762 |  | PP Final PIT Completion Reports assured by SI | 5d | 2024-01-08 A | 2024-01-12 A | 761 | 100% |  |
| 763 | 1.4.1.7.1.10.2 | **Environments (SIT A)** | 30d | 2023-11-24 A | 2024-01-05 A |  | 100% |  |
| 764 |  | Programme Participants Ready to Start Connectivity Proving | 0d | 2023-11-24 A | 2023-11-24 A |  | 100% | start no earlier than 2023-11-24 |
| 765 |  | SIT Participants' SIT A environments ready to start connectivity proving CIT Interval 6 | 0d | 2023-11-24 A | 2023-11-24 A | 764 | 100% |  |
| 766 |  | Internal Connectivity Proving Phase | 10d | 2023-11-27 A | 2023-12-08 A | 765FS+1d | 100% |  |
| 767 |  | Internal Connectivity Proving Phase Complete | 0d | 2023-12-08 A | 2023-12-08 A | 766 | 100% |  |
| 768 |  | DIP Onboarding Activity (1. PKI Officers and Certificates, 2. Set-up Validation, 3. End Point Creation, 4. Controlled Smoke Test ) | 5d | 2023-12-04 A | 2023-12-08 A | 765FS+6d | 100% |  |
| 769 |  | DIP Onboarding Complete | 0d | 2023-12-08 A | 2023-12-08 A | 768 | 100% |  |
| 770 |  | PPs register PKI Officers and Request PKI Certificates Complete - Interval 6 | 0d | 2023-12-08 A | 2023-12-08 A | 769 | 100% | start no earlier than 2023-12-08 |

| ID | WBS | Task | Duration | Start | Finish | Predecessors | Complete | Total float | Constraint |
| --- | --- | --- | --- | --- | --- | --- | --- | --- | --- |
| 771 |  | PP Code Deployment | 0d | 2024-01-05 A | 2024-01-05 A |  | 100% |  | start no earlier than 2024-01-05 |
| 772 | 1.4.1.7.1.10.3 | **Test Data (SIT A) Interval 6** | 25d | 2023-11-20 A | 2023-12-22 A |  | 100% |  |  |
| 773 |  | Run data allocation | 10d | 2023-11-20 A | 2023-12-01 A | 743SS | 100% |  |  |
| 774 |  | Cleanse and populate data post cut | 1d | 2023-12-04 A | 2023-12-04 A | 773 | 100% |  |  |
| 775 |  | Transmit data sets to PPs | 1d | 2023-12-05 A | 2023-12-05 A | 774 | 100% |  |  |
| 776 |  | PP - Load test data to test environments | 8d | 2023-12-06 A | 2023-12-15 A | 775 | 100% |  |  |
| 777 |  | PP Check data integrity on test environment | 5d | 2023-12-18 A | 2023-12-22 A | 776 | 100% |  |  |
| 778 |  | PP submit self-declaration to Programme to confirm loading & verification of test data | 0d | 2023-12-22 A | 2023-12-22 A | 777FF | 100% |  |  |
| 779 |  | Test Data (SIT A) Interval 6 Complete | 0d | 2023-12-22 A | 2023-12-22 A | 778 | 100% |  |  |
| 780 | 1.4.1.7.1.10.4 | **Other Preparation** | 31d | 2023-12-04 A | 2024-01-15 A |  | 100% |  |  |
| 781 |  | Onboarding of Test Participants to Test Management Tool (Azure DevOps) | 31d | 2023-12-04 A | 2024-01-15 A |  | 100% |  | start no earlier than 2023-12-04 |
| 782 |  | Test Management Tool onboarding | 31d | 2023-12-04 A | 2024-01-15 A |  | 100% |  | start no earlier than 2023-12-04 |
| 783 | 1.4.1.7.1.10.5 | **SIT Component Integration Test Readiness Report** | 25d | 2023-11-20 A | 2023-12-22 A |  | 100% |  |  |
| 784 |  | PP submit Test Readiness Report to Programme for assurance | 0d | 2023-12-08 A | 2023-12-08 A | 576 | 100% |  |  |
| 785 |  | SI assure Test Participants' Test Readiness Reports | 5d | 2023-12-11 A | 2023-12-15 A | 784FF+5d | 100% |  |  |
| 786 |  | SI develop Overarching SIT Component Integration Test Readiness Report | 20d | 2023-11-20 A | 2023-12-15 A | 785FF | 100% |  |  |
| 787 |  | Artefact review (via TMAG) and updates | 5d | 2023-12-18 A | 2023-12-22 A | 786 | 100% |  |  |
| 788 |  | SIT Component Integration Testing 6 Preparation Complete (incl. approval of SI SIT Component Integration Test Readiness Report) | 0d | 2024-01-19 A | 2024-01-19 A | 787FS+1d, 761, 765, 782, 784, 779, 244, 415 | 100% |  |  |
| 789 | 1.4.1.7.2 | **SIT Functional Preparation** | 520d | 2022-10-31 A | 2024-10-25 |  | 93% | 17d |  |
| 790 | 1.4.1.7.2.1 | **Test Approach & Plan** | 208d | 2022-10-31 A | 2023-08-16 A |  | 100% |  |  |
| 791 |  | Develop document with SITWG | 179d | 2022-10-31 A | 2023-07-06 A |  | 100% |  | finish no earlier than 2023-07-06 |
| 792 |  | Industry Consultation | 10d | 2023-07-07 A | 2023-07-20 A | 791 | 100% |  |  |
| 793 |  | Artefact review (via TMAG) and updates | 19d | 2023-07-21 A | 2023-08-16 A | 792 | 100% |  | finish no earlier than 2023-08-03 |
| 794 |  | SIT Functional Testing Test Approach & Plan approved | 0d | 2023-08-16 A | 2023-08-16 A |  | 100% |  | finish no earlier than 2023-08-16 |
| 795 | 1.4.1.7.2.2 | **Test Data Approach & Plan** | 29d | 2023-07-07 A | 2023-08-16 A |  | 100% |  |  |
| 796 |  | Industry Consultation | 10d | 2023-07-07 A | 2023-07-20 A | 792SS | 100% |  |  |
| 797 |  | Artefact review (via TMAG) and updates | 19d | 2023-07-21 A | 2023-08-16 A | 796 | 100% |  |  |
| 798 |  | SIT Functional Testing Test Data Approach & Plan approved | 0d | 2023-08-16 A | 2023-08-16 A | 797 | 100% |  |  |
| 799 | 1.4.1.7.2.3 | **Test scenarios** | 298d | 2023-01-02 A | 2024-02-21 A |  | 100% |  |  |
| 800 |  | Development of test scenarios | 85d | 2023-01-02 A | 2023-04-28 A | 791SS+45d | 100% |  |  |
| 801 |  | Review test scenarios with SIT Working Group | 65d | 2023-08-17 A | 2023-11-15 A | 800FS+78d | 100% |  |  |
| 802 |  | SIT Functional Testing Test scenarios (themes 1-5) approved | 0d | 2023-12-08 A | 2023-12-08 A | 801FS+17d | 100% |  |  |
| 803 |  | SIT Functional Testing Test scenarios (themes 6,7,9) approved | 0d | 2024-01-17 A | 2024-01-17 A | 802FS+28d | 100% |  |  |
| 804 |  | SIT Functional Testing Test scenarios (theme 8) approved | 0d | 2024-02-21 A | 2024-02-21 A | 803FS+25d | 100% |  |  |
| 805 | 1.4.1.7.2.4 | **Test cases** | 213d | 2023-05-01 A | 2024-02-21 A |  | 100% |  |  |
| 806 | 1.4.1.7.2.4.1 | **SI Test cases** | 213d | 2023-05-01 A | 2024-02-21 A |  | 100% |  |  |
| 807 |  | Development of Test cases | 150d | 2023-05-01 A | 2023-11-24 A | 800 | 100% |  |  |
| 808 |  | Review Test cases with SIT Working Group | 78d | 2023-09-25 A | 2024-01-10 A | 807SS+105d | 100% |  |  |
| 809 |  | SIT Functional Testing Test Cases (themes 1-5) approved | 0d | 2024-01-17 A | 2024-01-17 A | 808FS+5d | 100% |  |  |
| 810 |  | SIT Functional Testing Test cases (themes 6,7,9) approved | 0d | 2024-01-17 A | 2024-01-17 A | 809 | 100% |  |  |
| 811 |  | SIT Functional Testing Test cases (theme 8) approved | 0d | 2024-02-21 A | 2024-02-21 A | 810FS+25d | 100% |  |  |
| 812 | 1.4.1.7.2.5 | **Environments (SIT-Staging)** | 10d | 2023-12-04 A | 2023-12-15 A |  | 100% |  |  |
| 813 | 1.4.1.7.2.5.1 | **SIT Functional pre-requisites** | 10d | 2023-12-04 A | 2023-12-15 A |  | 100% |  |  |
| 814 | 1.4.1.7.2.5.1.1 | **DCC** | 10d | 2023-12-04 A | 2023-12-15 A |  | 100% |  |  |
| 815 | 1.4.1.7.2.5.1.1.1 | **CSS** | 10d | 2023-12-04 A | 2023-12-15 A |  | 100% |  |  |
| 816 |  | SIT participants have requested DCC CSS PKI certificates for access to UIT-B environment | 10d | 2023-12-04 A | 2023-12-15 A |  | 100% |  | start no earlier than 2023-12-04 |
| 817 |  | SIT participants have received DCC CSS PKI certificates for UIT-B environment | 0d | 2023-12-15 A | 2023-12-15 A | 816 | 100% |  |  |
| 818 | 1.4.1.7.2.5.1.1.2 | **DSP** | 10d | 2023-12-04 A | 2023-12-15 A |  | 100% |  |  |
| 819 |  | SIT participants have requested DCC DSP PKI certificates for access to UIT-B environment | 10d | 2023-12-04 A | 2023-12-15 A |  | 100% |  | start no earlier than 2023-12-04 |
| 820 |  | SIT participants have received DCC DSP PKI certificates for UIT-B environment | 0d | 2023-12-15 A | 2023-12-15 A | 819 | 100% |  |  |
| 821 | 1.4.1.7.2.6 | **Environments (SIT A)** | 25d | 2024-02-05 A | 2024-03-08 A |  | 100% |  |  |
| 822 | 1.4.1.7.2.6.1 | **SIT Functional Connectivity Proving** | 15d | 2024-02-12 A | 2024-03-01 A |  | 100% |  |  |
| 823 |  | SIT Functional Connectivity Proving Period | 15d | 2024-02-12 A | 2024-03-01 A |  | 100% |  | start no earlier than 2024-01-08 |
| 824 |  | SIT Functional Connectivity Proving Complete | 0d | 2024-03-01 A | 2024-03-01 A | 823 | 100% |  | start no earlier than 2024-03-01 |
| 825 | 1.4.1.7.2.6.2 | **PP Environments (SIT A)** | 25d | 2024-02-05 A | 2024-03-08 A |  | 100% |  |  |
| 826 |  | Deployment of MHHS solution code to SIT A environments | 25d | 2024-02-05 A | 2024-03-08 A |  | 100% |  | start no earlier than 2024-02-05 |
| 827 | 1.4.1.7.2.6.3 | **SI Environments (SIT A)** | 25d | 2024-02-05 A | 2024-03-08 A |  | 100% |  |  |
| 828 |  | Coordinate deployment of MHHS solution code to SIT Participants' SIT A environments | 25d | 2024-02-05 A | 2024-03-08 A | 826SS | 100% |  |  |
| 829 | 1.4.1.7.2.7 | **Test data (SIT A)** | 225d | 2023-12-18 A | 2024-10-25 |  | 61% | 17d |  |
| 830 | 1.4.1.7.2.7.1 | **Cycle 1 Test data (SIT A)** | 55d | 2023-12-18 A | 2024-03-01 A |  | 100% |  |  |
| 831 |  | Prepare, Generate and Allocate Test Data | 28d | 2023-12-18 A | 2024-01-24 A | 608, 616 | 100% |  | start no earlier than 2023-12-11 |
| 832 |  | Transmit Data Sets to PPs | 4d | 2024-01-26 A | 2024-01-31 A | 831FS+1d | 100% |  |  |
| 833 |  | PP's Iterative load and data integrity check | 22d | 2024-02-01 A | 2024-03-01 A | 832 | 100% |  |  |
| 834 |  | Cycle 1 - PP's confirmation that test data is ready for SIT Functional | 0d | 2024-03-01 A | 2024-03-01 A | 833 | 100% |  |  |
| 835 | 1.4.1.7.2.7.2 | **Cycle 2 Test data (SIT A)** | 57d | 2024-03-28 A | 2024-06-14 A |  | 100% |  |  |
| 836 |  | Prepare, Generate and Allocate Test Data | 31d | 2024-03-28 A | 2024-05-09 A | 834FS+18d | 100% |  |  |
| 837 |  | Transmit Data Sets to PPs | 3d | 2024-05-10 A | 2024-05-14 A | 836 | 100% |  |  |
| 838 |  | PP's Iterative load and data integrity check | 13d | 2024-05-15 A | 2024-05-31 A | 837 | 100% |  |  |
| 839 |  | Cycle 2 - PP's confirmation that test data is ready for SIT Functional | 0d | 2024-06-14 A | 2024-06-14 A | 838FS+10d | 100% |  |  |
| 840 | 1.4.1.7.2.7.3 | **Cycle 3 Test data (SIT A)** | 41d | 2024-06-24 A | 2024-08-19 |  | 32% | 17d |  |

| ID | WBS | Task | Duration | Start | Finish | Predecessors | Complete | Total float | Constraint |
| --- | --- | --- | --- | --- | --- | --- | --- | --- | --- |
| 841 |  | Prepare, Generate and Allocate Test Data | 18d | 2024-06-24 A | 2024-07-17 | 839FS+5d | 72% | 17d |  |
| 842 |  | Transmit Data Sets to PPs | 2d | 2024-07-18 | 2024-07-19 | 841 |  | 17d |  |
| 843 |  | PP's Iterative load and data integrity check | 21d | 2024-07-22 | 2024-08-19 | 842 |  | 17d |  |
| 844 |  | Cycle 3 - PP's confirmation that test data is ready for SIT Functional | 0d | 2024-08-19 | 2024-08-19 | 843 |  | 17d |  |
| 845 | 1.4.1.7.2.7.4 | **Regression Test data (SIT A)** | 45d | 2024-08-26 | 2024-10-25 |  |  | 17d |  |
| 846 |  | Prepare, Generate and Allocate Test Data | 23d | 2024-08-26 | 2024-09-25 | 844FS+4d |  | 17d |  |
| 847 |  | Transmit Data Sets to PPs | 2d | 2024-09-26 | 2024-09-27 | 846 |  | 17d |  |
| 848 |  | PP's Iterative load and data integrity check | 20d | 2024-09-30 | 2024-10-25 | 847 |  | 17d |  |
| 849 |  | Regression - PP's confirmation that test data is ready for SIT Functional | 0d | 2024-10-25 | 2024-10-25 | 848 |  | 17d |  |
| 850 | 1.4.1.7.2.8 | **SIT Functional Test Readiness Report** | 44d | 2024-01-01 A | 2024-02-29 A |  | 100% |  |  |
| 851 | 1.4.1.7.2.8.1 | **PP SIT Functional Test Readiness Report** | 44d | 2024-01-01 A | 2024-02-29 A |  | 100% |  |  |
| 852 |  | Develop draft Test Readiness Report and submit to Programme for assurance | 21d | 2024-01-01 A | 2024-01-29 A |  | 100% |  | start no earlier than 2024-01-01 |
| 853 |  | Placing Reliance Stage 2 Review | 34d | 2024-01-15 A | 2024-02-29 A | 852SS+10d | 100% |  |  |
| 854 |  | Finalise Test Readiness Report and submit to Programme for assurance | 9d | 2024-01-30 A | 2024-02-09 A | 852 | 100% |  |  |
| 855 | 1.4.1.7.2.8.2 | **SI SIT Functional Test Readiness Report** | 40d | 2024-01-01 A | 2024-02-23 A |  | 100% |  |  |
| 856 |  | Assure Test Participants' Test Readiness Reports | 35d | 2024-01-01 A | 2024-02-16 A | 852SS, 854FF+5d | 100% |  |  |
| 857 |  | Develop Overarching SIT Functional Test Readiness Report | 20d | 2024-01-22 A | 2024-02-16 A | 856FF | 100% |  |  |
| 858 |  | Artefact review (via TMAG) and updates | 5d | 2024-02-19 A | 2024-02-23 A | 857 | 100% |  |  |
| 859 |  | SIT Functional Testing Preparation Complete | 0d | 2024-03-01 A | 2024-03-01 A | 858FF+5d, 794, 313, 853, 802, 809, 834 | 100% |  |  |
| 860 | 1.4.1.7.3 | **SIT Migration Testing Preparation** | 435d | 2022-10-31 A | 2024-06-28 A |  | 100% |  |  |
| 861 | 1.4.1.7.3.1 | **Test Approach & Plan** | 75d | 2023-09-07 A | 2023-12-20 A |  | 100% |  |  |
| 862 |  | Develop document with SITWG | 32d | 2023-09-07 A | 2023-10-20 A | 1905 | 100% |  | finish no earlier than 2023-10-11 |
| 863 |  | Draft document review with Code Bodies | 8d | 2023-10-23 A | 2023-11-01 A | 862 | 100% |  |  |
| 864 |  | Industry Consultation | 10d | 2023-11-02 A | 2023-11-15 A | 863 | 100% |  |  |
| 865 |  | Artefact review (via TMAG) and updates | 25d | 2023-11-16 A | 2023-12-20 A | 864 | 100% |  |  |
| 866 |  | SIT Migration Testing Test Approach & Plan approved | 0d | 2023-12-20 A | 2023-12-20 A | 865 | 100% |  | finish no earlier than 2023-12-20 |
| 867 | 1.4.1.7.3.2 | **Test Data Approach & Plan** | 35d | 2023-11-02 A | 2023-12-20 A |  | 100% |  |  |
| 868 |  | Industry Consultation | 10d | 2023-11-02 A | 2023-11-15 A | 864SS | 100% |  |  |
| 869 |  | Artefact review (via TMAG) and updates | 25d | 2023-11-16 A | 2023-12-20 A | 868 | 100% |  |  |
| 870 |  | SIT Migration Test Data Test Approach & Plan approved | 0d | 2023-12-20 A | 2023-12-20 A | 869 | 100% |  |  |
| 871 | 1.4.1.7.3.3 | **Test scenarios & Test Cases** | 85d | 2023-12-21 A | 2024-04-17 A |  | 100% |  |  |
| 872 | 1.4.1.7.3.3.1 | **Theme 1** | 65d | 2023-12-21 A | 2024-03-20 A |  | 100% |  |  |
| 873 |  | Develop Test Scenarios & Test Cases | 25d | 2023-12-21 A | 2024-01-24 A | 866 | 100% |  |  |
| 874 |  | Industry Review Workshop | 1d | 2024-01-25 A | 2024-01-25 A | 873 | 100% |  |  |
| 875 |  | Industry Consultation Review | 6d | 2024-02-05 A | 2024-02-12 A | 874FS+6d | 100% |  |  |
| 876 |  | Review with SIT Working Group | 5d | 2024-02-29 A | 2024-03-06 A | 875FS+12d | 100% |  |  |
| 877 |  | SIT Migration Test scenarios & Test Cases Approved - Theme 1 | 0d | 2024-03-20 A | 2024-03-20 A | 876FS+10d | 100% |  |  |
| 878 | 1.4.1.7.3.3.2 | **Theme 2** | 85d | 2023-12-21 A | 2024-04-17 A |  | 100% |  |  |
| 879 |  | Develop Test Scenarios & Test Cases | 40d | 2023-12-21 A | 2024-02-14 A | 866 | 100% |  |  |
| 880 |  | Industry Review Workshop | 1d | 2024-02-15 A | 2024-02-15 A | 879 | 100% |  |  |
| 881 |  | Industry Consultation Review | 6d | 2024-02-26 A | 2024-03-04 A | 880FS+6d | 100% |  |  |
| 882 |  | Review with SIT Working Group | 5d | 2024-03-28 A | 2024-04-03 A | 881FS+17d | 100% |  |  |
| 883 |  | SIT Migration Test scenarios & Test Cases Approved - Theme 2 | 0d | 2024-04-17 A | 2024-04-17 A | 882FS+10d | 100% |  |  |
| 884 | 1.4.1.7.3.3.3 | **Theme 3** | 85d | 2023-12-21 A | 2024-04-17 A |  | 100% |  |  |
| 885 |  | Develop Test Scenarios & Test Cases | 55d | 2023-12-21 A | 2024-03-06 A | 866 | 100% |  |  |
| 886 |  | Industry Review Workshop | 1d | 2024-03-07 A | 2024-03-07 A | 885 | 100% |  |  |
| 887 |  | Industry Consultation Review | 6d | 2024-03-13 A | 2024-03-20 A | 886FS+3d | 100% |  |  |
| 888 |  | Review with SIT Working Group | 5d | 2024-03-28 A | 2024-04-03 A | 887FS+5d | 100% |  |  |
| 889 |  | SIT Migration Test scenarios & Test Cases Approved - Theme 3 | 0d | 2024-04-17 A | 2024-04-17 A | 888FS+10d | 100% |  |  |
| 890 | 1.4.1.7.3.4 | **Environments (SIT B)** | 435d | 2022-10-31 A | 2024-06-28 A |  | 100% |  |  |
| 891 | 1.4.1.7.3.4.1 | **PP Environments (SIT B)** | 41d | 2024-05-03 A | 2024-06-28 A |  | 100% |  |  |
| 892 |  | PP Environments available | 0d | 2024-05-03 A | 2024-05-03 A | 466 | 100% |  | start no earlier than 2024-05-03 |
| 893 |  | PP Onboarding / Smoke test | 35d | 2024-05-13 A | 2024-06-28 A | 892FS+6d | 100% |  |  |
| 894 |  | DTN Connectivity Proving Complete | 5d | 2024-06-10 A | 2024-06-14 A | 892FS+26d | 100% |  |  |
| 895 |  | PP Code Deployment | 0d | 2024-06-14 A | 2024-06-14 A | 894 | 100% |  |  |
| 896 | 1.4.1.7.3.4.2 | **SI Environments (SIT B)** | 425d | 2022-10-31 A | 2024-06-14 A |  | 100% |  |  |
| 897 |  | Coordinate SIT Participants' SIT B environment preparation | 420d | 2022-10-31 A | 2024-06-07 A |  | 100% |  |  |
| 898 |  | Assure PPs' self-declaration of environment preparation complete (incl. security certificates and security compliance) | 0d | 2024-06-07 A | 2024-06-07 A | 897 | 100% |  |  |
| 899 |  | SIT Participants' SIT B environments ready to start connectivity proving (incl. certificates and security compliance) | 0d | 2024-06-05 A | 2024-06-05 A | 892FS+24d | 100% |  |  |
| 900 |  | Coordinate SIT Participants' SIT B environment connectivity proving | 2d | 2024-06-06 A | 2024-06-07 A | 899 | 100% |  |  |
| 901 |  | Coordinate deployment of MHHS solution code to SIT Participants' SIT B environments | 0d | 2024-06-14 A | 2024-06-14 A | 895 | 100% |  |  |
| 902 | 1.4.1.7.3.5 | **SIT Migration Test Readiness Report** | 44d | 2024-04-02 A | 2024-05-31 A |  | 100% |  |  |
| 903 | 1.4.1.7.3.5.1 | **PP SIT Migration Test Readiness Report** | 44d | 2024-04-02 A | 2024-05-31 A |  | 100% |  |  |
| 904 |  | Develop draft Test Readiness Report and submit to Programme for assurance | 20d | 2024-04-02 A | 2024-04-29 A |  | 100% |  | start no earlier than 2024-04-02 |
| 905 |  | Placing Reliance Stage 2 Review | 35d | 2024-04-15 A | 2024-05-31 A | 904SS+9d | 100% |  |  |
| 906 |  | Finalise Test Readiness Report and submit to Programme for assurance | 10d | 2024-04-30 A | 2024-05-13 A | 904 | 100% |  |  |
| 907 | 1.4.1.7.3.5.2 | **SI SIT Migration Test Readiness Report** | 40d | 2024-04-02 A | 2024-05-27 A |  | 100% |  |  |
| 908 |  | Assure Test Participants' Test Readiness Reports | 35d | 2024-04-02 A | 2024-05-20 A | 904SS, 906FF+5d | 100% |  |  |
| 909 |  | Develop Overarching SIT Migration Test Readiness Report | 20d | 2024-04-23 A | 2024-05-20 A | 908FF | 100% |  |  |
| 910 |  | Artefact review (via SITAG) and updates | 5d | 2024-05-21 A | 2024-05-27 A | 909 | 100% |  |  |

| ID | WBS | Task | Duration | Start | Finish | Predecessors | Complete | Total float | Constraint |
| --- | --- | --- | --- | --- | --- | --- | --- | --- | --- |
| 911 |  | SIT Migration Testing Preparation Complete | 0d | 2024-06-03 A | 2024-06-03 A | 910FF+5d, 866, 330, 905, 877, 883, 889 | 100% |  |  |
| 912 | 1.4.1.7.4 | **SIT Non-Functional Preparation** | 193d | 2023-11-30 A | 2024-08-27 |  | 89% | 719d |  |
| 913 | 1.4.1.7.4.1 | **Test Approach & Plan** | 120d | 2023-11-30 A | 2024-05-15 A |  | 100% |  |  |
| 914 |  | Develop document with SITWG | 67d | 2023-11-30 A | 2024-03-01 A |  | 100% |  | must start on 2023-11-30 |
| 915 |  | Draft document review with Code Bodies | 10d | 2024-03-04 A | 2024-03-15 A | 914 | 100% |  |  |
| 916 |  | Industry Consultation | 10d | 2024-03-18 A | 2024-03-29 A | 915 | 100% |  |  |
| 917 |  | Industry Assurance Review | 5d | 2024-04-11 A | 2024-04-17 A | 916FS+8d | 100% |  |  |
| 918 |  | SIT Non-Functional Testing Test Approach & Plan approved | 0d | 2024-05-15 A | 2024-05-15 A | 917FS+20d | 100% |  |  |
| 919 | 1.4.1.7.4.2 | **Test Data Approach & Plan** | 41d | 2024-03-20 A | 2024-05-15 A |  | 100% |  |  |
| 920 |  | Industry Consultation | 14d | 2024-03-20 A | 2024-04-08 A | 916SS+2d | 100% |  |  |
| 921 |  | Artefact review (via SITAG) and updates | 27d | 2024-04-09 A | 2024-05-15 A | 920 | 100% |  |  |
| 922 |  | SIT Non-Functional Testing Test Data Approach & Plan approved | 0d | 2024-05-15 A | 2024-05-15 A | 918FF, 921 | 100% |  |  |
| 923 | 1.4.1.7.4.3 | **Test scenarios & Test Cases** | 123d | 2024-03-04 A | 2024-08-21 |  | 97% | -9d |  |
| 924 | 1.4.1.7.4.3.1 | **Theme 1** | 78d | 2024-03-04 A | 2024-06-19 A |  | 100% |  |  |
| 925 |  | Develop Test Scenarios & Test Cases | 33d | 2024-03-04 A | 2024-04-17 A | 914 | 100% |  |  |
| 926 |  | Industry Review Workshop | 1d | 2024-04-18 A | 2024-04-18 A | 925 | 100% |  |  |
| 927 |  | Industry Consultation Review | 7d | 2024-05-02 A | 2024-05-10 A | 926FS+9d | 100% |  |  |
| 928 |  | Review with NFT Working Group | 5d | 2024-05-31 A | 2024-06-06 A | 927FS+14d | 100% |  |  |
| 929 |  | SIT NFT Scenarios & Test Cases Approved - Theme 1 | 0d | 2024-06-19 A | 2024-06-19 A | 928FS+9d | 100% |  |  |
| 930 | 1.4.1.7.4.3.2 | **Theme 2** | 98d | 2024-03-04 A | 2024-07-17 A |  | 100% |  |  |
| 931 |  | Develop Test Scenarios & Test Cases | 53d | 2024-03-04 A | 2024-05-15 A | 914 | 100% |  |  |
| 932 |  | Industry Review Workshop | 1d | 2024-05-16 A | 2024-05-16 A | 931 | 100% |  |  |
| 933 |  | Industry Consultation Review | 7d | 2024-05-20 A | 2024-05-28 A | 932FS+1d | 100% |  |  |
| 934 |  | Review with NFT Working Group | 5d | 2024-06-28 A | 2024-07-04 A | 933FS+22d | 100% |  |  |
| 935 |  | SIT NFT Scenarios & Test Cases Approved - Theme 2 | 0d | 2024-07-17 A | 2024-07-17 A | 934FS+9d | 100% |  |  |
| 936 | 1.4.1.7.4.3.3 | **Theme 3** | 123d | 2024-03-04 A | 2024-08-21 |  | 94% | -9d |  |
| 937 |  | Develop Test Scenarios & Test Cases | 63d | 2024-03-04 A | 2024-05-29 A | 914 | 100% |  |  |
| 938 |  | Industry Review Workshop | 1d | 2024-05-30 A | 2024-05-30 A | 937 | 100% |  |  |
| 939 |  | Industry Consultation Review | 6d | 2024-06-10 A | 2024-06-17 A | 938FS+6d | 100% |  |  |
| 940 |  | Review with NFT Working Group | 30d | 2024-06-28 A | 2024-08-08 | 939FS+8d | 80% | -42d |  |
| 941 |  | SIT NFT Scenarios & Test Cases Approved - Theme 3 | 0d | 2024-08-21 | 2024-08-21 | 940FS+9d |  | -42d |  |
| 942 | 1.4.1.7.4.4 | **Environments (SIT B)** | 0d | 2024-08-27 | 2024-08-27 |  |  | 719d |  |
| 943 | 1.4.1.7.4.4.1 | **PP Environments (SIT B)** | 0d | 2024-08-27 | 2024-08-27 |  |  | 719d |  |
| 944 |  | Deployment of MHHS solution code to SIT B environments | 0d | 2024-08-27 | 2024-08-27 |  |  | 719d | start no earlier than 2024-08-27 |
| 945 | 1.4.1.7.4.4.2 | **SI Environments (SIT B)** | 0d | 2024-08-27 | 2024-08-27 |  |  | 719d |  |
| 946 |  | Coordinate deployment of MHHS solution code to SIT Participants' SIT B environments | 0d | 2024-08-27 | 2024-08-27 | 944SS |  | 719d |  |
| 947 | 1.4.1.7.4.5 | **SIT Non-Functional Test Readiness Report** | 44d | 2024-06-25 A | 2024-08-23 |  | 65% | 6d |  |
| 948 | 1.4.1.7.4.5.1 | **PP SIT Non-Functional Test Readiness Report** | 44d | 2024-06-25 A | 2024-08-23 |  | 79% | 6d |  |
| 949 |  | Develop draft Test Readiness Report and submit to Programme for assurance | 20d | 2024-06-25 A | 2024-07-22 A |  | 100% |  | start no earlier than 2024-06-25 |
| 950 |  | Placing Reliance Stage 2 Review | 40d | 2024-07-01 A | 2024-08-23 | 949SS+4d | 70% | 6d |  |
| 951 |  | Finalise Test Readiness Report and submit to Programme for assurance | 10d | 2024-07-23 A | 2024-08-05 | 949 | 70% | 5d |  |
| 952 | 1.4.1.7.4.5.2 | **SI SIT Non-Functional Test Readiness Report** | 40d | 2024-06-25 A | 2024-08-19 |  | 48% | 5d |  |
| 953 |  | Assure Test Participants' Test Readiness Reports | 35d | 2024-06-25 A | 2024-08-12 | 949SS, 951FF+5d | 63% | 5d |  |
| 954 |  | Develop Overarching SIT Non-Functional Test Readiness Report | 20d | 2024-07-16 A | 2024-08-12 | 953FF | 35% | 5d |  |
| 955 |  | Artefact review (via SITAG) and updates | 5d | 2024-08-13 | 2024-08-19 | 954 |  | 5d |  |
| 956 |  | SIT Non-Functional Testing Preparation Complete | 0d | 2024-08-26 | 2024-08-26 | 955FF+5d, 794, 347, 950, 929, 935, 941 |  | 5d |  |
| 957 | 1.4.1.7.5 | **SIT Operational Preparation** | 170d | 2024-02-01 A | 2024-09-25 |  | 92% | 697d |  |
| 958 | 1.4.1.7.5.1 | **Test Approach & Plan** | 75d | 2024-02-01 A | 2024-05-15 A |  | 100% |  |  |
| 959 |  | Develop document with SITWG | 25d | 2024-02-01 A | 2024-03-06 A |  | 100% |  | must start on 2024-02-01 |
| 960 |  | Draft document review with Code Bodies | 4d | 2024-03-21 A | 2024-03-26 A | 959FS+10d | 100% |  |  |
| 961 |  | Industry Consultation | 10d | 2024-03-27 A | 2024-04-09 A | 960 | 100% |  |  |
| 962 |  | Artefact review (via SITAG) and updates | 26d | 2024-04-10 A | 2024-05-15 A | 961 | 100% |  |  |
| 963 |  | SIT Operational Testing Test Approach & Plan approved | 0d | 2024-05-15 A | 2024-05-15 A | 962 | 100% |  |  |
| 964 | 1.4.1.7.5.2 | **Test Data Approach & Plan** | 36d | 2024-03-27 A | 2024-05-15 A |  | 100% |  |  |
| 965 |  | Industry Consultation | 10d | 2024-03-27 A | 2024-04-09 A | 961SS | 100% |  |  |
| 966 |  | Artefact review (via SITAG) and updates | 26d | 2024-04-10 A | 2024-05-15 A | 965 | 100% |  |  |
| 967 |  | SIT Operational Testing Test Data Approach & Plan approved | 0d | 2024-05-15 A | 2024-05-15 A | 966 | 100% |  |  |
| 968 | 1.4.1.7.5.3 | **Test scenarios & Test Cases** | 116d | 2024-04-10 A | 2024-09-18 |  | 96% | -20d |  |
| 969 | 1.4.1.7.5.3.1 | **Theme 1** | 96d | 2024-04-10 A | 2024-08-21 |  | 99% | -35d |  |
| 970 |  | Develop Test Scenarios & Test Cases | 16d | 2024-04-10 A | 2024-05-01 A | 961 | 100% |  |  |
| 971 |  | Industry Review Workshop | 1d | 2024-05-02 A | 2024-05-02 A | 970 | 100% |  |  |
| 972 |  | Industry Consultation Review | 6d | 2024-05-28 A | 2024-06-04 A | 971FS+17d | 100% |  |  |
| 973 |  | Review with SIT Working Group | 5d | 2024-06-27 A | 2024-07-03 A | 972FS+16d | 100% |  |  |
| 974 |  | SIT Operational Scenarios & Test Cases Approved - Theme 1 | 0d | 2024-08-21 | 2024-08-21 | 973FS+35d |  | -62d |  |
| 975 | 1.4.1.7.5.3.2 | **Theme 2** | 71d | 2024-04-10 A | 2024-07-17 A |  | 100% |  |  |
| 976 |  | Develop Test Scenarios & Test Cases | 31d | 2024-04-10 A | 2024-05-22 A | 961 | 100% |  |  |
| 977 |  | Industry Review Workshop | 1d | 2024-05-23 A | 2024-05-23 A | 976 | 100% |  |  |
| 978 |  | Industry Consultation Review | 6d | 2024-06-04 A | 2024-06-11 A | 977FS+7d | 100% |  |  |
| 979 |  | Review with SIT Working Group | 5d | 2024-06-27 A | 2024-07-03 A | 978FS+11d | 100% |  |  |
| 980 |  | SIT Operational Scenarios & Test Cases Approved - Theme 2 | 0d | 2024-07-17 A | 2024-07-17 A | 979FS+10d | 100% |  |  |

| ID | WBS | Task | Duration | Start | Finish | Predecessors | Complete | Total float | Constraint |
| --- | --- | --- | --- | --- | --- | --- | --- | --- | --- |
| 981 | 1.4.1.7.5.3.3 | **Theme 3** | 116d | 2024-04-10 A | 2024-09-18 |  | 91% | -20d |  |
| 982 |  | Develop Test Scenarios & Test Cases | 46d | 2024-04-10 A | 2024-06-12 A | 961 | 100% |  |  |
| 983 |  | Industry Review Workshop | 1d | 2024-06-13 A | 2024-06-13 A | 982 | 100% |  |  |
| 984 |  | Industry Consultation Review | 5d | 2024-07-15 A | 2024-07-19 A | 983FS+21d | 100% |  |  |
| 985 |  | Review with SIT Working Group | 5d | 2024-07-25 | 2024-07-31 | 984FS+3d |  | -20d |  |
| 986 |  | SIT Operational Scenarios & Test Cases Approved - Theme 3 | 0d | 2024-09-18 | 2024-09-18 | 985FS+35d |  | -20d |  |
| 987 | 1.4.1.7.5.4 | **Environments (SIT B)** | 0d | 2024-08-27 | 2024-08-27 |  |  | 719d |  |
| 988 | 1.4.1.7.5.4.1 | **PP Environments (SIT B)** | 0d | 2024-08-27 | 2024-08-27 |  |  | 719d |  |
| 989 |  | Deployment of MHHS solution code to SIT B environments | 0d | 2024-08-27 | 2024-08-27 |  |  | 719d | start no earlier than 2024-08-27 |
| 990 | 1.4.1.7.5.4.2 | **SI Environments (SIT B)** | 0d | 2024-08-27 | 2024-08-27 |  |  | 719d |  |
| 991 |  | Coordinate deployment of MHHS solution code to SIT Participants' SIT B environments | 0d | 2024-08-27 | 2024-08-27 | 989SS |  | 719d |  |
| 992 | 1.4.1.7.5.5 | **SIT Operational Test Readiness Report** | 19d | 2024-08-30 | 2024-09-25 |  |  | -3d |  |
| 993 | 1.4.1.7.5.5.1 | **PP SIT Operational Test Readiness Report** | 0d | 2024-08-30 | 2024-08-30 |  |  | -3d |  |
| 994 |  | Test Readiness Report submitted to Programme for assurance | 0d | 2024-08-30 | 2024-08-30 |  |  | -3d | start no earlier than 2024-08-30 |
| 995 | 1.4.1.7.5.5.2 | **SI SIT Operational Test Readiness Report** | 19d | 2024-08-30 | 2024-09-25 |  |  | -3d |  |
| 996 |  | Assure Test Participants' Test Readiness Reports | 5d | 2024-08-30 | 2024-09-05 | 994 |  | -3d |  |
| 997 |  | Develop Overarching SIT Operational Test Readiness Report | 4d | 2024-09-13 | 2024-09-18 | 996SS+10d |  | -3d |  |
| 998 |  | Artefact review (via SITAG) and updates | 5d | 2024-09-19 | 2024-09-25 | 997 |  | -3d |  |
| 999 |  | SIT Operational Testing Preparation Complete | 0d | 2024-09-25 | 2024-09-25 | 998, 364, 974, 980, 986 |  | -3d |  |
| 1000 | 1.4.2 | **SIT Execution** | 390d | 2023-10-30 A | 2025-04-25 |  | 22% | 545d |  |
| 1001 |  | System Integration Testing Start (M9) | 0d | 2023-10-30 A | 2023-10-30 A | 633FS+5d, 524, 547 | 100% |  | must start on 2023-10-30 |
| 1002 | 1.4.2.2 | **SIT Component Integration Testing** | 96d | 2023-10-30 A | 2024-03-11 A |  | 100% |  |  |
| 1003 |  | SIT Component Integration Testing Start | 0d | 2023-10-30 A | 2023-10-30 A | 1001 | 100% |  |  |
| 1004 |  | Component Integration Testing Interval 1 Start | 0d | 2023-10-30 A | 2023-10-30 A | 633SS+1d, 554, 558, 562, 115 | 100% |  |  |
| 1005 |  | Component Integration Testing Interval 2 Start | 0d | 2023-11-13 A | 2023-11-13 A | 660SS+5d, 554, 562, 558, 115 | 100% |  |  |
| 1006 |  | Component Integration Testing Interval 3 Start | 0d | 2023-11-27 A | 2023-11-27 A | 692SS+5d, 554, 558, 562, 115 | 100% |  |  |
| 1007 |  | Component Integration Testing Interval 4 Start | 0d | 2023-12-11 A | 2023-12-11 A | 724SS+5d, 554, 558, 562, 115 | 100% |  |  |
| 1008 |  | Component Integration Testing Interval 5 Start | 0d | 2024-01-15 A | 2024-01-15 A | 756SS+5d, 554, 558, 562, 115 | 100% |  |  |
| 1009 |  | Component Integration Testing Interval 6 Start | 0d | 2024-01-29 A | 2024-01-29 A | 554, 558, 562, 788, 115, 600 | 100% |  | must start on 2024-01-29 |
| 1010 |  | SIT Component Integration Testing Execution | 85d | 2023-10-30 A | 2024-02-23 A | 1004SS | 100% |  | must start on 2023-10-30 |
| 1011 |  | SIT Component Integration Testing End (incl. confirmation that PPs have submitted their Test Completion Reports to Programme for assurance) | 0d | 2024-02-23 A | 2024-02-23 A | 1010FF | 100% |  |  |
| 1012 |  | Assurance of PPs Test Completion Reports | 30d | 2024-01-22 A | 2024-03-01 A | 1011FF+5d | 100% |  |  |
| 1013 | 1.4.2.2.11 | **SIT CI Test Completion Report** | 18d | 2024-02-07 A | 2024-03-01 A |  | 100% |  |  |
| 1014 |  | Develop document | 13d | 2024-02-07 A | 2024-02-23 A | 1011FF | 100% |  |  |
| 1015 |  | Review & agree document | 5d | 2024-02-26 A | 2024-03-01 A | 1014, 1012FF | 100% |  |  |
| 1016 |  | SIT Component Integration Testing Test Completion Report Approved | 0d | 2024-03-11 A | 2024-03-11 A | 1015FS+6d | 100% |  |  |
| 1017 | 1.4.2.3 | **SIT - Minimum Viable Cohort (MVC)** | 240d | 2024-03-11 A | 2025-02-07 |  | 18% | 600d |  |
| 1018 | 1.4.2.3.1 | **SIT Functional Testing (MVC)** | 225d | 2024-03-11 A | 2025-01-17 |  | 37% | 615d |  |
| 1019 |  | SIT Functional Testing Start | 0d | 2024-03-11 A | 2024-03-11 A | 1016, 859FS+5d, 794, 802, 803, 804, 811 | 100% |  |  |
| 1020 | 1.4.2.3.1.2 | **SIT Functional Testing Execution (Minimum Viable Cohort)** | 225d | 2024-03-11 A | 2025-01-17 |  | 37% | 615d |  |
| 1021 | 1.4.2.3.1.2.1 | **Cycle 1 (Full Cycle)** | 70d | 2024-03-11 A | 2024-06-14 A |  | 100% |  |  |
| 1022 |  | Test Execution | 55d | 2024-03-11 A | 2024-05-24 A | 1019SS-1d, 834 | 100% |  |  |
| 1023 |  | Defect resolution, assurance, review, data & environments maintenance | 15d | 2024-05-27 A | 2024-06-14 A | 1022 | 100% |  |  |
| 1024 | 1.4.2.3.1.2.2 | **Cycle 2 (Defect retests and targeted regression testing)** | 55d | 2024-06-17 A | 2024-08-30 |  | 60% | 12d |  |
| 1025 |  | Test Execution | 45d | 2024-06-17 A | 2024-08-16 | 1023, 839 | 73% | 11d |  |
| 1026 |  | Defect resolution, assurance, review, data & environments maintenance | 10d | 2024-08-19 | 2024-08-30 | 1025 |  | 12d |  |
| 1027 | 1.4.2.3.1.2.3 | **SIT Functional Testing back-up progress risk-assessment** | 20d | 2024-09-02 | 2024-09-27 |  |  | 695d |  |
| 1028 |  | Back-up risk-assessment of SIT Functional progress to assess whether Qualification Execution can start early | 15d | 2024-09-02 | 2024-09-20 | 1026 |  | 695d |  |
| 1029 |  | Back-up SITAG decision on early Qualification Testing Execution start | 0d | 2024-09-27 | 2024-09-27 | 1028FS+5d |  | 695d |  |
| 1030 | 1.4.2.3.1.2.4 | **Cycle 3 (Defect retests and targeted regression testing)** | 45d | 2024-09-02 | 2024-11-01 |  |  | 12d |  |
| 1031 |  | Test Execution | 35d | 2024-09-02 | 2024-10-18 | 1026, 844 |  | 12d |  |
| 1032 |  | Defect resolution, assurance, review, data & environments maintenance | 10d | 2024-10-21 | 2024-11-01 | 1031 |  | 12d |  |
| 1033 |  | Core Systems Code Freeze | 0d | 2024-11-01 | 2024-11-01 | 1032FF |  | 669d |  |
| 1034 |  | Regression Testing (code freeze) | 45d | 2024-11-04 | 2025-01-03 | 1032, 849 |  | 12d |  |
| 1035 |  | SIT Functional Testing End (Minimum Viable Cohort) (incl. confirmation that PPs have submitted their Test Completion Reports to Programme for assurance) | 0d | 2025-01-03 | 2025-01-03 | 1034FF |  | 12d |  |
| 1036 |  | Assurance of PPs Test Completion Reports | 30d | 2024-12-02 | 2025-01-10 | 1035FF+5d |  | 12d |  |
| 1037 | 1.4.2.3.1.2.9 | **SIT Functional Test Completion Report (Minimum Viable Cohort)** | 20d | 2024-12-16 | 2025-01-10 |  |  | 12d |  |
| 1038 |  | Develop document | 15d | 2024-12-16 | 2025-01-03 | 1035FF |  | 12d |  |
| 1039 |  | Review & agree document | 5d | 2025-01-06 | 2025-01-10 | 1038, 1036FF |  | 12d |  |
| 1040 |  | SIT Functional Testing Test Completion Report (Minimum Viable Cohort) Approved | 0d | 2025-01-17 | 2025-01-17 | 1039FF+5d |  | 12d |  |
| 1041 | 1.4.2.3.2 | **SIT Migration Testing (MVC)** | 152d | 2024-06-17 A | 2025-01-15 |  | 16% | 14d |  |
| 1042 |  | SIT Migration Testing Start | 0d | 2024-06-17 A | 2024-06-17 A | 911FS+10d, 866, 870, 877, 883, 889 | 100% |  |  |
| 1043 |  | SIT Migration Testing Execution (Minimum Viable Cohort) | 89d | 2024-06-18 A | 2024-10-18 | 1042SS | 36% | 14d |  |
| 1044 |  | Defect resolution, assurance, review, data & environments maintenance | 10d | 2024-10-21 | 2024-11-01 | 1043 |  | 14d |  |
| 1045 |  | Regression Testing (code freeze) | 45d | 2024-11-04 | 2025-01-03 | 1044 |  | 14d |  |
| 1046 |  | SIT Migration Testing End (Minimum Viable Cohort) (incl. confirmation that PPs have submitted their Test Completion Reports to Programme for assurance) | 0d | 2025-01-03 | 2025-01-03 | 1043FF, 1045 |  | 14d |  |
| 1047 |  | Assurance of PPs Test Completion Reports | 30d | 2024-12-02 | 2025-01-10 | 1046FF+5d |  | 14d |  |
| 1048 | 1.4.2.3.2.7 | **SIT Migration Testing Test Completion Report (Minimum Viable Cohort)** | 20d | 2024-12-16 | 2025-01-10 |  |  | 14d |  |
| 1049 |  | Develop document | 15d | 2024-12-16 | 2025-01-03 | 1046FF |  | 14d |  |
| 1050 |  | Review & agree document | 5d | 2025-01-06 | 2025-01-10 | 1049, 1047FF |  | 14d |  |

| ID | WBS | Task | Duration | Start | Finish | Predecessors | Complete | Total float |
| --- | --- | --- | --- | --- | --- | --- | --- | --- |
| 1051 |  | SIT Migration Testing Test Completion Report (Minimum Viable Cohort) Approved | 0d | 2025-01-15 | 2025-01-15 | 1050FF+3d |  | 14d |
| 1052 | 1.4.2.3.3 | **SIT Non-Functional Testing (MVC)** | 99d | 2024-09-02 | 2025-01-17 |  |  | 5d |
| 1053 |  | SIT Non-Functional Testing Start | 0d | 2024-09-02 | 2024-09-02 | 956FS+5d, 1025FS+5d, 918, 922, 929, 935, 941 |  | 5d |
| 1054 |  | SIT Non-Functional Testing Execution (Minimum Viable Cohort) | 89d | 2024-09-03 | 2025-01-03 | 1053SS |  | 12d |
| 1055 |  | SIT Non-Functional Testing End (Minimum Viable Cohort) (incl. confirmation that PPs have submitted their Test Completion Reports to Programme for assurance) | 0d | 2025-01-03 | 2025-01-03 | 1054FF |  | 12d |
| 1056 |  | Assurance of PPs Test Completion Reports | 30d | 2024-12-02 | 2025-01-10 | 1055FF+5d |  | 12d |
| 1057 | 1.4.2.3.3.5 | **SIT Non-Functional Testing Test Completion Report (Minimum Viable Cohort)** | 20d | 2024-12-16 | 2025-01-10 |  |  | 12d |
| 1058 |  | Develop document | 15d | 2024-12-16 | 2025-01-03 | 1055FF |  | 12d |
| 1059 |  | Review & agree document | 5d | 2025-01-06 | 2025-01-10 | 1058, 1056FF |  | 12d |
| 1060 |  | SIT Non-Functional Testing Test Completion Report (Minimum Viable Cohort) Approved | 0d | 2025-01-17 | 2025-01-17 | 1059FF+5d |  | 12d |
| 1061 | 1.4.2.3.4 | **SIT Operational Testing (MVC)** | 89d | 2024-10-07 | 2025-02-07 |  |  | -3d |
| 1062 |  | SIT Operational Testing Start | 0d | 2024-10-07 | 2024-10-07 | 999FS+8d, 963, 967, 974, 980, 986 |  | -3d |
| 1063 |  | SIT Operational Testing Execution (Minimum Viable Cohort) | 79d | 2024-10-08 | 2025-01-24 | 1062SS |  | -3d |
| 1064 |  | SIT Operational Testing End (Minimum Viable Cohort) (incl. confirmation that PPs have submitted their Test Completion Reports to Programme for assurance) | 0d | 2025-01-24 | 2025-01-24 | 1063FF |  | -3d |
| 1065 |  | Assurance of PPs Test Completion Reports | 30d | 2024-12-23 | 2025-01-31 | 1064FF+5d |  | -3d |
| 1066 | 1.4.2.3.4.5 | **SIT Operational Testing Test Completion Report (Minimum Viable Cohort)** | 20d | 2025-01-06 | 2025-01-31 |  |  | -3d |
| 1067 |  | Develop document | 15d | 2025-01-06 | 2025-01-24 | 1064FF |  | -3d |
| 1068 |  | Review & agree document | 5d | 2025-01-27 | 2025-01-31 | 1067, 1065FF |  | -3d |
| 1069 |  | SIT Operational Testing Test Completion Report (Minimum Viable Cohort) Approved | 0d | 2025-02-07 | 2025-02-07 | 1068FF+5d |  | -3d |
| 1070 | 1.4.2.3.5 | **SIT MVC Test Exit Report** | 20d | 2025-01-06 | 2025-01-31 |  |  | -3d |
| 1071 |  | Develop document | 15d | 2025-01-06 | 2025-01-24 | 1067FF |  | -3d |
| 1072 |  | Review & agree document | 5d | 2025-01-27 | 2025-01-31 | 1071 |  | -3d |
| 1073 |  | SIT Minimum Viable Cohort Complete (SIT Minimum Viable Cohort Test Exit Report Approved) | 0d | 2025-02-07 | 2025-02-07 | 1072FS+5d, 1016, 1040, 1051, 1060, 1069 |  | -3d |
| 1074 | 1.4.2.4 | **SIT - Other Participants** | 295d | 2024-03-11 A | 2025-04-25 |  | 14% | 5d |
| 1075 | 1.4.2.4.1 | **SIT Functional Testing (Other Participants)** | 295d | 2024-03-11 A | 2025-04-25 |  | 34% | 5d |
| 1076 | 1.4.2.4.1.1 | **SIT Functional Testing Execution (Other Participants)** | 280d | 2024-03-11 A | 2025-04-04 |  | 37% | 5d |
| 1077 | 1.4.2.4.1.1.1 | **Cycle 1 (Full Cycle)** | 70d | 2024-03-11 A | 2024-06-14 A |  | 100% |  |
| 1078 |  | Test Execution | 55d | 2024-03-11 A | 2024-05-24 A | 1022SS, 128 | 100% |  |
| 1079 |  | Defect resolution, assurance, review, data & environments maintenance | 15d | 2024-05-27 A | 2024-06-14 A | 1078 | 100% |  |
| 1080 | 1.4.2.4.1.1.2 | **Cycle 2 (Defect retests and targeted regression testing)** | 55d | 2024-06-17 A | 2024-08-30 |  | 60% | 5d |
| 1081 |  | Test Execution | 45d | 2024-06-17 A | 2024-08-16 | 1079, 132, 136 | 73% | 5d |
| 1082 |  | Defect resolution, assurance, review, data & environments maintenance | 10d | 2024-08-19 | 2024-08-30 | 1081 |  | 5d |
| 1083 | 1.4.2.4.1.1.3 | **Cycle 3 (Defect retests and targeted regression testing)** | 45d | 2024-09-02 | 2024-11-01 |  |  | 5d |
| 1084 |  | Test Execution | 35d | 2024-09-02 | 2024-10-18 | 1082, 140 |  | 5d |
| 1085 |  | Defect resolution, assurance, review, data & environments maintenance | 10d | 2024-10-21 | 2024-11-01 | 1084 |  | 5d |
| 1086 |  | Regression Testing (code freeze) | 45d | 2024-11-04 | 2025-01-03 | 1085 |  | 5d |
| 1087 |  | SIT Other PPs continued support | 65d | 2025-01-06 | 2025-04-04 | 1086 |  | 5d |
| 1088 |  | SIT Functional Testing End (Other Participants) (incl. confirmation that PPs have submitted their Test Completion Reports to Programme for assurance) | 0d | 2025-04-04 | 2025-04-04 | 1087FF |  | 5d |
| 1089 |  | Assurance of PPs Test Completion Reports | 5d | 2025-04-14 | 2025-04-18 | 1088FS+5d |  | 5d |
| 1090 | 1.4.2.4.1.4 | **SIT Functional Testing Test Completion Report (Other Participants)** | 25d | 2025-03-17 | 2025-04-18 |  |  | 5d |
| 1091 |  | Develop document | 15d | 2025-03-17 | 2025-04-04 | 1088FF |  | 10d |
| 1092 |  | Review & agree document | 5d | 2025-04-14 | 2025-04-18 | 1091, 1089FF |  | 5d |
| 1093 |  | SIT Functional Testing Test Completion Report (Other Participants) Approved | 0d | 2025-04-25 | 2025-04-25 | 1092FF+5d |  | 5d |
| 1094 | 1.4.2.4.2 | **SIT Migration Testing (Other Participants)** | 224d | 2024-06-18 A | 2025-04-25 |  | 12% | 5d |
| 1095 |  | SIT Migration Testing Execution (Other Participants) | 209d | 2024-06-18 A | 2025-04-04 | 1042SS | 13% | 5d |
| 1096 |  | SIT Migration Testing End (Other Participants) (incl. confirmation that PPs have submitted their Test Completion Reports to Programme for assurance) | 0d | 2025-04-04 | 2025-04-04 | 1095FF |  | 5d |
| 1097 |  | Assurance of PPs Test Completion Reports | 5d | 2025-04-14 | 2025-04-18 | 1096FS+5d |  | 5d |
| 1098 | 1.4.2.4.2.4 | **SIT Migration Testing Test Completion Report (Other Participants)** | 25d | 2025-03-17 | 2025-04-18 |  |  | 5d |
| 1099 |  | Develop document | 15d | 2025-03-17 | 2025-04-04 | 1096FF |  | 10d |
| 1100 |  | Review & agree document | 5d | 2025-04-14 | 2025-04-18 | 1099, 1097FF |  | 5d |
| 1101 |  | SIT Migration Testing Test Completion Report (Other Participants) Approved | 0d | 2025-04-25 | 2025-04-25 | 1100FF+5d |  | 5d |
| 1102 | 1.4.2.4.3 | **SIT Non-Functional Testing (Other Participants)** | 169d | 2024-09-03 | 2025-04-25 |  |  | 5d |
| 1103 |  | SIT Non-Functional Testing Execution (Other Participants) | 154d | 2024-09-03 | 2025-04-04 | 1053SS |  | 5d |
| 1104 |  | SIT Non-Functional Testing End (Other Participants) (incl. confirmation that PPs have submitted their Test Completion Reports to Programme for assurance) | 0d | 2025-04-04 | 2025-04-04 | 1103FF |  | 5d |
| 1105 |  | Assurance of PPs Test Completion Reports | 5d | 2025-04-14 | 2025-04-18 | 1104FS+5d |  | 5d |
| 1106 | 1.4.2.4.3.4 | **SIT Non-Functional Testing Test Completion Report (Other Participants)** | 25d | 2025-03-17 | 2025-04-18 |  |  | 5d |
| 1107 |  | Develop document | 15d | 2025-03-17 | 2025-04-04 | 1104FF |  | 10d |
| 1108 |  | Review & agree document | 5d | 2025-04-14 | 2025-04-18 | 1107, 1105FF |  | 5d |
| 1109 |  | SIT Non-Functional Testing Test Completion Report (Other Participants) Approved | 0d | 2025-04-25 | 2025-04-25 | 1108FF+5d |  | 5d |
| 1110 | 1.4.2.4.4 | **SIT Operational Testing (Other Participants)** | 144d | 2024-10-08 | 2025-04-25 |  |  | 5d |
| 1111 |  | SIT Operational Testing Execution (Other Participants) | 129d | 2024-10-08 | 2025-04-04 | 1062SS |  | 5d |
| 1112 |  | SIT Operational Testing End (Other Participants) (incl. confirmation that PPs have submitted their Test Completion Reports to Programme for assurance) | 0d | 2025-04-04 | 2025-04-04 | 1111FF |  | 5d |
| 1113 |  | Assurance of PPs Test Completion Reports | 10d | 2025-04-07 | 2025-04-18 | 1112 |  | 5d |
| 1114 | 1.4.2.4.4.4 | **SIT Operational Testing Test Completion Report (Other Participants)** | 25d | 2025-03-17 | 2025-04-18 |  |  | 5d |
| 1115 |  | Develop document | 15d | 2025-03-17 | 2025-04-04 | 1112FF |  | 10d |
| 1116 |  | Review & agree document | 5d | 2025-04-14 | 2025-04-18 | 1115, 1113FF |  | 5d |
| 1117 |  | SIT Operational Testing Test Completion Report (Other Participants) Approved | 0d | 2025-04-25 | 2025-04-25 | 1116FF+5d |  | 5d |
| 1118 | 1.4.2.4.5 | **SIT Other Participants Test Exit Report** | 20d | 2025-03-17 | 2025-04-11 |  |  | 11d |
| 1119 |  | Develop document | 15d | 2025-03-17 | 2025-04-04 | 1115FF |  | 11d |
| 1120 |  | Review & agree document | 5d | 2025-04-07 | 2025-04-11 | 1119 |  | 11d |

| ID | WBS | Task | Duration | Start | Finish | Predecessors | Complete | Total float | Constraint |
| --- | --- | --- | --- | --- | --- | --- | --- | --- | --- |
| 1121 |  | SIT - Other Participants Complete | 0d | 2025-04-25 | 2025-04-25 | 1120FS+4d, 1093, 1101, 1109, 1117 |  | 5d |  |
| 1122 | 1.4.3 | **UIT Environment Preparation** | 700d | 2022-10-31 A | 2025-07-04 |  | 44% | 495d |  |
| 1123 | 1.4.3.1 | **Test Artefact Development** | 361d | 2023-03-01 A | 2024-07-18 |  |  | 747d |  |
| 1124 | 1.4.3.1.1 | **E2E Sandbox Guidance** | 361d | 2023-03-01 A | 2024-07-18 |  |  | 747d |  |
| 1125 |  | Develop document | 83d | 2023-03-01 | 2023-06-23 |  |  | 995d | start no earlier than 2023-03-01 |
| 1126 |  | Artefact review (via SITAG) and updates | 25d | 2023-06-26 | 2023-07-28 | 1125 |  | 1000d |  |
| 1127 |  | E2E Sandbox Guidance approved | 0d | 2024-07-18 A | 2024-07-18 A | 1126FF+5d | 100% |  | start no earlier than 2024-07-18 |
| 1128 | 1.4.3.1.2 | **E2E Sandbox Test Data Approach & Plan** | 93d | 2023-03-29 | 2023-08-04 |  |  | 995d |  |
| 1129 |  | Develop document | 68d | 2023-03-29 | 2023-06-30 | 1125SS+20d |  | 995d |  |
| 1130 |  | Review, update & agree document internally | 25d | 2023-07-03 | 2023-08-04 | 1129 |  | 995d |  |
| 1131 | 1.4.3.2 | **UIT Stub Specification and Delivery** | 190d | 2023-12-04 A | 2024-08-23 |  | 88% | 694d |  |
| 1132 | 1.4.3.2.1 | **Qualification Test Stubs** | 190d | 2023-12-04 A | 2024-08-23 |  | 88% | 694d |  |
| 1133 |  | Specify | 44d | 2023-12-04 A | 2024-02-01 A | 470FS+13d | 100% |  |  |
| 1134 |  | Build & Test | 141d | 2024-02-02 A | 2024-08-16 | 1133 | 88% | 694d |  |
| 1135 |  | Prepare for release | 5d | 2024-08-19 | 2024-08-23 | 1134 |  | 694d |  |
| 1136 |  | Non-SIT LDSO Test Harness Released | 0d | 2024-08-23 | 2024-08-23 | 1135 |  | 694d |  |
| 1137 | 1.4.3.3 | **Environments (UIT)** | 700d | 2022-10-31 A | 2025-07-04 |  | 44% | 495d |  |
| 1138 | 1.4.3.3.1 | **Central Party (Avenade) Environments (UIT)** | 488d | 2022-11-16 A | 2024-09-27 |  | 97% | 695d |  |
| 1139 |  | Central Party (Avendae) environment preparation (incl. security certificates and security compliance) | 447d | 2022-11-16 A | 2024-08-01 A | 466 | 100% |  |  |
| 1140 |  | Submit self-declaration of environment preparation complete (incl. security certificates and security compliance) to Programme for assurance | 447d | 2022-11-16 A | 2024-08-01 A | 1139SS | 100% |  |  |
| 1141 |  | Central Party (Avenade) UIT environment connectivity proving | 25d | 2024-08-26 | 2024-09-27 | 1153 |  | 694d |  |
| 1142 |  | Deployment of MHHS solution code to UIT environments | 2d | 2024-07-29 | 2024-07-30 |  |  | 737d | start no earlier than 2024-07-29 |
| 1143 |  | Central Party (Avenade) UIT environment Regression Testing | 1d | 2024-07-31 | 2024-07-31 | 1142 |  | 737d |  |
| 1144 | 1.4.3.3.2 | **E2E Sandbox Participants (UIT)** | 680d | 2022-10-31 | 2025-06-06 |  |  | 0d |  |
| 1145 |  | E2E Sandbox Participants environment preparation (incl. security certificates and security compliance) | 660d | 2022-10-31 | 2025-05-09 |  |  | 0d | must finish on 2025-05-09 |
| 1146 |  | Submit self-declaration of environment preparation complete (incl. security certificates and security compliance) to Programme for assurance | 660d | 2022-10-31 | 2025-05-09 |  |  | 515d |  |
| 1147 |  | E2E Sandbox Participants UIT environment connectivity proving | 20d | 2025-05-12 | 2025-06-06 | 1146 |  | 515d |  |
| 1148 |  | Deployment of MHHS solution code to UIT environments | 10d | 2025-05-26 | 2025-06-06 | 1147FF |  | 515d |  |
| 1149 |  | Coordinate E2E Sandbox Participants' UIT environment preparation (for E2E Sandbox Testing Start) | 463d | 2022-10-31 | 2024-08-07 | 1145SS |  | 732d |  |
| 1150 | 1.4.3.3.3 | **SI Environments (UIT)** | 688d | 2022-11-16 A | 2025-07-04 |  | 69% | 495d |  |
| 1151 |  | Coordinate Central Parties' UIT environment preparation | 447d | 2022-11-16 A | 2024-08-01 A | 1139SS | 100% |  |  |
| 1152 |  | Assure Central Parties' self-declaration of environment preparation complete (incl. security certificates and security compliance) | 463d | 2022-11-16 A | 2024-08-23 | 1140SS | 97% | 720d |  |
| 1153 |  | Central Parties' UIT environments ready to start connectivity proving (incl. certificates and security compliance) | 0d | 2024-08-23 | 2024-08-23 | 1136 |  | 694d |  |
| 1154 |  | Coordinate Central Parties' UIT environment connectivity proving | 26d | 2024-08-26 | 2024-09-30 | 1141SS |  | 694d |  |
| 1155 |  | Coordinate deployment of MHHS solution code to Central Parties' UIT environments | 2d | 2024-07-29 A | 2024-07-30 A | 1142SS | 100% |  |  |
| 1156 |  | Coordinate Central Parties' UIT environment Regression Testing | 1d | 2024-07-31 | 2024-07-31 | 1155 |  | 737d |  |
| 1157 | 1.4.3.3.3.7 | **Environments (Non-SIT LDSO)** | 43d | 2024-08-01 | 2024-09-30 |  |  | 694d |  |
| 1158 |  | Coordinate Qualification Participants' environment preparation | 17d | 2024-08-01 | 2024-08-23 |  |  | 720d | start no earlier than 2024-08-01 |
| 1159 |  | Coordinate deployment of MHHS solution code to Qualification Participants' UIT environments | 17d | 2024-08-01 | 2024-08-23 |  |  | 694d | start no earlier than 2024-08-01 |
| 1160 |  | Qualification Testing Tranche 1 Participants' UIT environments ready to start connectivity proving (incl. certificates and security compliance) | 0d | 2024-08-26 | 2024-08-26 | 1159FS+1d |  | 694d |  |
| 1161 | 1.4.3.3.3.7.4 | **Coordinate Qualification Participants' connectivity proving (Non-SIT LDSO)** | 25d | 2024-08-27 | 2024-09-30 |  |  | 694d |  |
| 1162 |  | Assurance of Qualification Participants' connectivity proving | 25d | 2024-08-27 | 2024-09-30 | 1160 |  | 694d |  |
| 1163 | 1.4.3.3.3.8 | **Environments (S&A) Wave 1** | 41d | 2024-08-01 | 2024-09-26 |  |  |  |  |
| 1164 |  | Coordinate Qualification Participants' environment preparation | 20d | 2024-09-02 | 2024-09-27 |  |  | 695d | start no earlier than 2024-09-02 |
| 1165 |  | Coordinate deployment of MHHS solution code to Qualification Participants' UIT environments | 10d | 2024-10-21 | 2024-11-01 |  |  | 625d | start no earlier than 2024-10-21 |
| 1166 |  | Qualification Testing Wave 1 Participants' UIT environments ready to start connectivity proving (incl. certificates and security compliance) | 19d | 2024-11-05 | 2024-11-29 | 1165FS+1d |  | 625d |  |
| 1167 | 1.4.3.3.3.8.4 | **Coordinate Qualification Participants' connectivity proving (S&A)** | 25d | 2024-12-02 | 2025-01-03 |  |  | 625d |  |
| 1168 |  | Assurance of Qualification Participants' connectivity proving | 25d | 2024-12-02 | 2025-01-03 | 1166 |  | 625d |  |
| 1169 | 1.4.3.3.3.9 | **Environments (S&A) Wave 2** | 139d | 2024-08-27 | 2025-03-07 |  |  | 0d |  |
| 1170 |  | Coordinate Qualification Participants' environment preparation | 20d | 2024-11-18 | 2024-12-13 |  |  | 640d | start no earlier than 2024-11-18 |
| 1171 |  | Coordinate deployment of MHHS solution code to Qualification Participants' UIT environments | 20d | 2024-12-16 | 2025-01-10 |  |  | 580d | start no earlier than 2024-12-16 |
| 1172 |  | Qualification Testing Wave 2 Participants' UIT environments ready to start connectivity proving (incl. certificates and security compliance) | 15d | 2025-01-13 | 2025-01-31 | 1171 |  | 580d |  |
| 1173 | 1.4.3.3.3.9.4 | **Coordinate Qualification Participants' connectivity proving (S&A)** | 25d | 2024-08-27 | 2024-09-30 |  |  |  |  |
| 1174 |  | Assurance of Qualification Participants' connectivity proving | 25d | 2025-02-03 | 2025-03-07 | 1172 |  | 580d |  |
| 1175 | 1.4.3.3.3.10 | **Environments (S&A) Wave 3** | 80d | 2025-03-17 | 2025-07-04 |  |  | 495d |  |
| 1176 |  | Coordinate Qualification Participants' environment preparation | 30d | 2025-03-17 | 2025-04-25 |  |  | 545d | start no earlier than 2025-03-17 |
| 1177 |  | Coordinate deployment of MHHS solution code to Qualification Participants' UIT environments | 10d | 2025-04-28 | 2025-05-09 |  |  | 495d | start no earlier than 2025-04-28 |
| 1178 |  | Qualification Testing Wave 3 Participants' UIT environments ready to start connectivity proving (incl. certificates and security compliance) | 14d | 2025-05-13 | 2025-05-30 | 1177FS+1d |  | 495d |  |
| 1179 | 1.4.3.3.3.10.4 | **Coordinate Qualification Participants' connectivity proving (S&A)** | 25d | 2025-06-02 | 2025-07-04 |  |  | 495d |  |
| 1180 |  | Assurance of Qualification Participants' connectivity proving | 25d | 2025-06-02 | 2025-07-04 | 1178 |  | 495d |  |
| 1181 | 1.4.3.3.3.11 | **Environments (S&A) Wave 4** | 80d | 2025-03-17 | 2025-07-04 |  |  | 55d |  |
| 1182 |  | Coordinate Qualification Participants' environment preparation | 30d | 2025-03-17 | 2025-04-25 |  |  | 545d | finish no earlier than 2025-04-25 |
| 1183 |  | Coordinate deployment of MHHS solution code to Qualification Participants' UIT environments | 10d | 2025-04-28 | 2025-05-09 |  |  | 495d | finish no earlier than 2025-05-09 |
| 1184 |  | Qualification Testing Wave 4 Participants' UIT environments ready to start connectivity proving (incl. certificates and security compliance) | 14d | 2025-05-13 | 2025-05-30 | 1183FS+1d |  | 495d | finish no earlier than 2025-05-30 |
| 1185 | 1.4.3.3.3.11.4 | **Coordinate Qualification Participants' connectivity proving (S&A)** | 25d | 2025-06-02 | 2025-07-04 |  |  |  |  |
| 1186 |  | Assurance of Qualification Participants' connectivity proving | 25d | 2025-06-02 | 2025-07-04 | 1184 |  | 495d | start no earlier than 2025-06-02 |
| 1187 | 1.4.3.4 | **Test Data** | 30d | 2024-08-26 | 2024-10-04 |  |  | 670d |  |
| 1188 | 1.4.3.4.1 | **Central Parties (for E2E Sandbox & Qualification)** | 30d | 2024-08-26 | 2024-10-04 |  |  | 670d |  |
| 1189 |  | Central Parties' UIT environment test data loading & verification (& data cleansing, if required) | 30d | 2024-08-26 | 2024-10-04 |  |  | 670d | start no earlier than 2024-08-26 |
| 1190 |  | Submit self-declaration to Programme to confirm loading & verification of test data | 30d | 2024-08-26 | 2024-10-04 | 1189SS |  | 670d |  |

| ID | WBS | Task | Duration | Start | Finish | Predecessors | Complete | Total float | Constraint |
| --- | --- | --- | --- | --- | --- | --- | --- | --- | --- |
| 1191 | 1.4.3.4.2 | **E2E Sandbox Participants** | 30d | 2024-08-26 | 2024-10-04 |  |  | 690d |  |
| 1192 |  | E2E Sandbox Test Data Approach and Plan Approved | 0d | 2024-09-19 | 2024-09-19 |  |  | 702d | start no earlier than 2024-09-19 |
| 1193 |  | UIT environment test data loading and verification (and data cleansing, if required) (for E2E Sandbox Testing Start) | 30d | 2024-08-26 | 2024-10-04 | 1189FF |  | 690d |  |
| 1194 | 1.4.3.4.3 | **SI Test Data** | 30d | 2024-08-26 | 2024-10-04 |  |  | 690d |  |
| 1195 |  | Coordinate Central Parties' UIT environment test data loading and verification (and data cleansing, if required) | 30d | 2024-08-26 | 2024-10-04 | 1189SS |  | 690d |  |
| 1196 |  | Assure evidence of Central Parties' UIT environment test data load and verification | 30d | 2024-08-26 | 2024-10-04 | 1190SS |  | 690d |  |
| 1197 |  | Coordinate E2E Sandbox Participants' UIT environment test data loading and verification (and data cleansing, if required) (for E2E Sandbox Testing Start) | 30d | 2024-08-26 | 2024-10-04 | 1193SS |  | 690d |  |
| 1198 | 1.4.3.5 | **Other Preparation** | 496d | 2022-10-31 A | 2024-09-23 |  | 59% | 699d |  |
| 1199 | 1.4.3.5.1 | **SI Other Preparation** | 66d | 2022-10-31 | 2023-01-30 |  |  | 1129d |  |
| 1200 |  | Onboarding of UIT E2E Sandbox Participants to Test Management Tool for E2E Sandbox Testing Start (onboarding of participants will be ongoing hereafter) | 66d | 2022-10-31 | 2023-01-30 |  |  | 1129d |  |
| 1201 | 1.4.3.5.2 | **Other Preparation (for Central Parties & E2E Sandbox Participants)** | 484d | 2022-11-16 A | 2024-09-23 |  | 67% | 699d |  |
| 1202 |  | Test Management Tool onboarding for E2E Sandbox Testing Start (onboarding will be ongoing hereafter) | 66d | 2024-05-02 | 2024-08-01 | 1200SS |  | 736d | start no earlier than 2024-05-02 |
| 1203 |  | Other Preparation (incl. test execution planning) | 484d | 2022-11-16 A | 2024-09-23 | 1139SS, 1145SS | 76% | 699d |  |
| 1204 | 1.4.3.6 | **UIT E2E Sandbox Test Readiness Report** | 114d | 2024-08-26 | 2025-01-31 |  |  | 601d |  |
| 1205 | 1.4.3.6.1 | **Central Parties E2E Sandbox Test Readiness Report** | 30d | 2024-08-26 | 2024-10-04 |  |  | 670d |  |
| 1206 |  | Develop draft Test Readiness Report and submit to Programme for assurance | 20d | 2024-08-26 | 2024-09-20 | 1190FF-10d |  | 670d |  |
| 1207 |  | Finalise Test Readiness Report and submit to Programme for assurance | 10d | 2024-09-23 | 2024-10-04 | 1190FF |  | 670d |  |
| 1208 | 1.4.3.6.2 | **SI E2E Sandbox Test Readiness Report** | 40d | 2024-08-26 | 2024-10-18 |  |  | 670d |  |
| 1209 |  | Assure Central Parties' E2E Sandbox Test Readiness Reports | 35d | 2024-08-26 | 2024-10-11 | 1206SS, 1207FF+5d |  | 670d |  |
| 1210 |  | Develop Overarching E2E Sandbox Test Readiness Report | 20d | 2024-09-16 | 2024-10-11 | 1209FF |  | 670d |  |
| 1211 |  | Artefact review (via SITAG) and updates | 5d | 2024-10-14 | 2024-10-18 | 1210 |  | 670d |  |
| 1212 |  | UIT E2E Sandbox Preparation Complete | 0d | 2025-01-31 | 2025-01-31 | 1211FS+5d |  | 601d | start no earlier than 2025-01-31 |
| 1213 | 1.4.4 | **SIT PPs E2E Sandbox Testing Execution** | 316d | 2025-02-07 | 2026-04-24 |  |  | 285d |  |
| 1214 |  | SIT PPs E2E Sandbox Testing Start | 0d | 2025-02-10 | 2025-02-10 | 1033FS+1d, 1212FS+5d |  | 600d | start no earlier than 2025-02-10 |
| 1215 |  | SIT PPs E2E Sandbox Testing Execution | 316d | 2025-02-07 | 2026-04-24 | 1214SS-1d |  | 285d | start no earlier than 2024-11-04 |
| 1216 | 1.4.5 | **External Programme Dependency Management** | 174d | 2022-10-31 A | 2023-06-30 A |  | 100% |  |  |
| 1217 | 1.4.5.1 | **BSC CP1558** | 173d | 2022-10-31 A | 2023-06-29 A |  | 100% |  |  |
| 1218 |  | Monitor progress to implementation date | 173d | 2022-10-31 A | 2023-06-28 A |  | 100% |  |  |
| 1219 |  | BSC CP1558 Implementation Date | 0d | 2023-06-29 A | 2023-06-29 A | 1218 | 100% |  | must start on 2023-06-29 |
| 1220 | 1.4.5.2 | **REC CP R0032** | 174d | 2022-10-31 A | 2023-06-30 A |  | 100% |  |  |
| 1221 |  | Monitor progress to implementation date | 174d | 2022-10-31 A | 2023-06-29 A |  | 100% |  |  |
| 1222 |  | REC CP R0032 Implementation Date | 0d | 2023-06-30 A | 2023-06-30 A | 1221 | 100% |  | must start on 2023-06-30 |
| 1223 | 1.4.5.3 | **REC CP R0044** | 173d | 2022-10-31 A | 2023-06-29 A |  | 100% |  |  |
| 1224 |  | Monitor progress to implementation date | 173d | 2022-10-31 A | 2023-06-28 A |  | 100% |  |  |
| 1225 |  | REC CP R0044 Implementation Date | 0d | 2023-06-29 A | 2023-06-29 A | 1224 | 100% |  | must start on 2023-06-29 |
| 1226 | 1.5 | **NON SIT LDSO QUALIFICATION** | 339d | 2023-11-07 A | 2025-02-21 |  | 74% | -3d |  |
| 1227 | 1.5.1 | **Approach Planning** | 208d | 2023-11-07 A | 2024-08-22 |  | 96% | 25d |  |
| 1228 |  | Develop Draft Testing Approach & Plan | 61d | 2023-11-07 A | 2024-01-30 A |  | 100% |  | start no earlier than 2023-11-07 |
| 1229 |  | Draft Testing Approach & Plan Issued to LDSO for Review | 1d | 2024-01-31 A | 2024-01-31 A | 1228 | 100% |  |  |
| 1230 |  | LDSO Review Complete | 10d | 2024-02-01 A | 2024-02-14 A | 1229 | 100% |  |  |
| 1231 |  | Update Following LDSO Review | 14d | 2024-02-15 A | 2024-03-05 A | 1230 | 100% |  |  |
| 1232 |  | QWG Review of Approach & Plan | 1d | 2024-03-12 A | 2024-03-12 A | 1231FS+4d | 100% |  |  |
| 1233 |  | QAG Approval for Approach & Plan | 0d | 2024-03-21 A | 2024-03-21 A | 1232FS+7d | 100% |  |  |
| 1234 |  | Confirmation of Participants for Non-SIT LDSO Qualification Testing | 0d | 2024-03-21 A | 2024-03-21 A | 1233 | 100% |  |  |
| 1235 |  | Update to Annex 1 for internal review (NF, Not Operational) | 15d | 2024-03-18 A | 2024-04-05 A | 915 | 100% |  |  |
| 1236 |  | Non-Functional, Operational & Migration Approaches Socialised with Code Bodies & LDSO & Feedback Actioned | 86d | 2024-04-08 A | 2024-08-05 A | 1235 | 100% |  |  |
| 1237 |  | QWG Review Operational, Non-Functional & Migration Annexes of Approach & Plan | 1d | 2024-08-13 | 2024-08-13 | 1236FS+5d |  | 25d |  |
| 1238 |  | Update Following QWG Review | 6d | 2024-08-14 | 2024-08-21 | 1237 |  | 25d |  |
| 1239 |  | QAG Approval for Operational, Non-Functional & Migration Annexes of Approach & Plan | 0d | 2024-08-22 | 2024-08-22 | 1238FS+1d, 1234, 918 |  | 25d |  |
| 1240 | 1.5.2 | **Functional Test Cases & Scenarios** | 58d | 2024-01-30 A | 2024-04-18 A |  | 100% |  |  |
| 1241 | 1.5.2.1 | **Functional Test Cases & Scenarios Batch 1** | 8d | 2024-01-30 A | 2024-02-08 A |  | 100% |  |  |
| 1242 |  | Walkthrough Test Cases & Scenarios Batch 1 with Code Bodies | 1d | 2024-01-30 A | 2024-01-30 A | 1228SS+60d | 100% |  |  |
| 1243 |  | Walkthrough Test Cases & Scenarios Batch 1 with LDSO | 1d | 2024-02-01 A | 2024-02-01 A | 1242 | 100% |  |  |
| 1244 |  | Action Feedback on Test Cases & Scenarios Batch 1 | 5d | 2024-02-02 A | 2024-02-08 A | 1243 | 100% |  |  |
| 1245 | 1.5.2.2 | **Functional Test Cases & Scenarios Batch 2** | 14d | 2024-02-20 A | 2024-03-08 A |  | 100% |  |  |
| 1246 |  | Walkthrough Test Cases & Scenarios Batch 2 with Code Bodies | 1d | 2024-02-20 A | 2024-02-20 A | 1228SS+75d | 100% |  |  |
| 1247 |  | Walkthrough Test Cases & Scenarios Batch 2 with LDSO | 1d | 2024-03-01 A | 2024-03-01 A | 1246FS+7d | 100% |  |  |
| 1248 |  | Action Feedback on Test Cases & Scenarios Batch 2 | 5d | 2024-03-04 A | 2024-03-08 A | 1247 | 100% |  |  |
| 1249 | 1.5.2.3 | **Functional Test Cases & Scenarios Batch 3** | 13d | 2024-03-20 A | 2024-04-05 A |  | 100% |  |  |
| 1250 |  | Walkthrough Test Cases & Scenarios Batch 3 with Code Bodies | 1d | 2024-03-20 A | 2024-03-20 A | 1228SS+96d | 100% |  |  |
| 1251 |  | Walkthrough Test Cases & Scenarios Batch 3 with LDSO | 1d | 2024-03-28 A | 2024-03-28 A | 1250FS+5d | 100% |  |  |
| 1252 |  | Action Feedback on Test Cases & Scenarios Batch 3 | 6d | 2024-03-29 A | 2024-04-05 A | 1251 | 100% |  |  |
| 1253 |  | Test Cases & Scenarios Batch 1-3 Discussion at QWG | 1d | 2024-04-09 A | 2024-04-09 A | 1244, 1248, 1252FS+1d | 100% |  |  |
| 1254 |  | Action QWG Feedback on Test Cases & Scenarios Batch 1-3 | 2d | 2024-04-10 A | 2024-04-11 A | 1253 | 100% |  |  |
| 1255 |  | Batch 1-3 Non-SIT LDSO QT Functional Test Scenarios and Test Cases approved | 0d | 2024-04-18 A | 2024-04-18 A | 1254FS+5d | 100% |  |  |
| 1256 | 1.5.3 | **Test Execution Schedule** | 90d | 2024-04-19 A | 2024-08-22 |  | 99% | 25d |  |
| 1257 |  | Draft Test Delivery Schedule for Functional and Operational Testing | 20d | 2024-04-19 A | 2024-05-16 A | 1255 | 100% |  |  |
| 1258 |  | Socialise Test Delivery Schedule with Code Bodies & LDSO for Review & Action Feedback | 37d | 2024-05-17 A | 2024-07-08 A | 1257 | 100% |  |  |
| 1259 |  | Agree Test Execution Timetable Format at QWG, Including Anonymisation Requirements | 1d | 2024-07-09 A | 2024-07-09 A | 1258 | 100% |  |  |
| 1260 |  | Action QWG Feedback | 3d | 2024-07-10 A | 2024-07-12 A | 1259 | 100% |  |  |

| ID | WBS | Task | Duration | Start | Finish | Predecessors | Complete | Total float | Constraint |
| --- | --- | --- | --- | --- | --- | --- | --- | --- | --- |
| 1261 |  | Agree Test Execution Timetable Format at QAG, Including Anonymisation Requirements | 0d | 2024-07-18 A | 2024-07-18 A | 1260FS+4d | 100% |  |  |
| 1262 |  | Qualification Testing for Non-SIT LDSOs (Functional, Migration, NFT, Operational) Test Execution Schedule Complete | 0d | 2024-08-22 | 2024-08-22 | 1239 |  | 25d |  |
| 1263 | 1.5.4 | **Functional, Non-Functional, Operational & Migration Test Scenarios & Cases** | 110d | 2024-03-22 A | 2024-08-22 |  | 90% | 25d |  |
| 1264 |  | Test Scenarios & Cases - Functional - Drafted, Reviewed | 14d | 2024-04-01 A | 2024-04-18 A | 1233 | 100% |  |  |
| 1265 |  | Test Scenarios & Cases- Functional - Approved at QAG | 0d | 2024-04-18 A | 2024-04-18 A | 1264 | 100% |  |  |
| 1266 |  | Test Scenarios & Cases - Non-Functional - Drafted, Reviewed | 110d | 2024-03-22 A | 2024-08-22 | 1233, 935FF | 90% | 25d |  |
| 1267 |  | Test Scenarios & Cases - Non-Functional - Approved at QAG | 0d | 2024-08-22 | 2024-08-22 | 1266 |  | 25d |  |
| 1268 |  | Test Scenarios & Cases - Migration - Drafted, Reviewed | 45d | 2024-03-22 A | 2024-05-23 A | 1233 | 100% |  |  |
| 1269 |  | Test Scenarios & Cases - Migration - Approved at QAG | 0d | 2024-05-23 A | 2024-05-23 A | 1268 | 100% |  |  |
| 1270 |  | Test Scenarios & Cases - Operational - Drafted, Reviewed | 59d | 2024-06-03 A | 2024-08-22 | 1233FS+51d | 81% | 24d |  |
| 1271 |  | Test Scenarios & Cases - Operational - Approved at QAG | 0d | 2024-08-22 | 2024-08-22 | 1270, 935FF |  | 24d |  |
| 1272 | 1.5.5 | **Test Data** | 241d | 2024-01-22 A | 2024-12-23 |  | 61% | 41d |  |
| 1273 |  | Test Data Plan Drafted & Reviewed | 89d | 2024-01-22 A | 2024-05-23 A | 1228 | 100% |  |  |
| 1274 |  | Non-SIT LDSO QT Test Data Plan Approved by QAG | 0d | 2024-05-23 A | 2024-05-23 A | 1273 | 100% |  |  |
| 1275 |  | Develop Test Data Matrices | 10d | 2024-05-24 A | 2024-06-06 A | 1274 | 100% |  |  |
| 1276 |  | Test Data Cut | 17d | 2024-05-24 A | 2024-06-17 A | 1274 | 100% |  |  |
| 1277 |  | Test Data Cut Complete | 0d | 2024-06-17 A | 2024-06-17 A | 1276, 1275 | 100% |  |  |
| 1278 |  | Test Data Reviewed by the Programme | 39d | 2024-06-18 A | 2024-08-09 | 1277 | 95% | 41d |  |
| 1279 |  | Test Data Loaded | 17d | 2024-08-12 | 2024-09-03 | 1278 |  | 41d |  |
| 1280 |  | Test Data Signed Off | 0d | 2024-09-03 | 2024-09-03 | 1279 |  | 41d |  |
| 1281 |  | Test Execution Data Support | 79d | 2024-09-04 | 2024-12-23 | 1280 |  | 41d |  |
| 1282 | 1.5.6 | **Tooling** | 148d | 2024-01-31 A | 2024-08-23 |  | 96% | 24d |  |
| 1283 |  | Design Approach & Set-Up ADO Tool for Test & Defect Management Tool | 53d | 2024-01-31 A | 2024-04-12 A | 1228 | 100% |  |  |
| 1284 |  | Develop Training Requirements & Materials Inc. Day in the Life | 87d | 2024-04-15 A | 2024-08-13 | 1283 | 95% | 31d |  |
| 1285 |  | ADO Launch complete | 1d | 2024-08-23 | 2024-08-23 | 1284, 1265, 1269, 1271 |  | 24d |  |
| 1286 | 1.5.7 | **Pre-Integration Testing** | 174d | 2024-01-31 A | 2024-09-30 |  | 84% | 0d |  |
| 1287 |  | PIT Guidance & Templates & Approach & Plans Developed | 106d | 2024-02-05 A | 2024-07-01 A | 1228FS+3d | 100% |  |  |
| 1288 |  | PIT Test Approach & Plan Deadline for Submission for Non-SIT LDSO​ QT | 0d | 2024-07-01 A | 2024-07-01 A | 1287 | 100% |  |  |
| 1289 |  | Develop and agree PIT Test Scenarios | 20d | 2024-07-02 A | 2024-07-29 A | 1288 | 100% |  |  |
| 1290 |  | PIT Execution | 45d | 2024-07-30 A | 2024-09-30 | 1289 | 16% | -2d |  |
| 1291 |  | Non-SIT LDSO Participants have submitted PIT Test Completion Report & evidence for QT Entry​ | 0d | 2024-09-30 | 2024-09-30 | 1290 |  | -2d |  |
| 1292 | 1.5.7.6 | **Placing Reliance - Code Body & LDSO Functional and Migration** | 147d | 2024-01-31 A | 2024-08-22 |  | 93% | 25d |  |
| 1293 |  | Placing Reliance Submitted & Reviewed | 21d | 2024-01-31 A | 2024-02-28 A | 1228 | 100% |  |  |
| 1294 |  | Define & Agree QT Testing for Each LDSO | 22d | 2024-02-29 A | 2024-03-29 A | 1293 | 100% |  |  |
| 1295 |  | Develop Test Scope & Reliance Submissions | 20d | 2024-04-01 A | 2024-04-26 A | 1294 | 100% |  |  |
| 1296 |  | Review and Consultation | 84d | 2024-04-29 A | 2024-08-22 | 1295, 1239FF | 87% | 25d |  |
| 1297 | 1.5.7.7 | **Placing Reliance - Code Body & LDSO Non Functional and Operational** | 49d | 2024-06-17 A | 2024-08-22 |  | 78% | 25d |  |
| 1298 |  | Placing Reliance Submitted & Reviewed | 32d | 2024-06-17 A | 2024-07-30 A | 1237FF-10d | 100% |  |  |
| 1299 |  | Review and Consultation | 17d | 2024-07-31 A | 2024-08-22 | 1298 | 35% | 25d |  |
| 1300 |  | PP Test Scope Presented at QAG | 0d | 2024-08-22 | 2024-08-22 | 1299, 1296 |  | 25d |  |
| 1301 | 1.5.8 | **LDSO Test Readiness Reporting** | 118d | 2024-04-19 A | 2024-10-01 |  | 62% | -3d |  |
| 1302 |  | Interim Test Readiness Report & Plan Developed & Reviewed | 71d | 2024-04-19 A | 2024-07-26 A | 1255 | 100% |  |  |
| 1303 |  | Test Plan Submission to MHHS Programme For Review | 0d | 2024-07-26 A | 2024-07-26 A | 1302 | 100% |  |  |
| 1304 |  | Final Test Readiness Report Developed & Submitted | 44d | 2024-07-29 | 2024-09-26 | 1303 |  | -3d |  |
| 1305 |  | Non-SIT LDSO QT Test Execution Starts | 0d | 2024-10-01 | 2024-10-01 | 1304FS+3d, 1285, 1312, 1319, 1320, 1262, 1300 |  | -3d |  |
| 1306 | 1.5.9 | **Test Environment** | 111d | 2024-04-17 A | 2024-09-18 |  | 65% | 5d |  |
| 1307 |  | Define Test Harness Requirements and Sign-Off with SRO | 13d | 2024-04-17 A | 2024-05-03 A | 471 | 100% |  |  |
| 1308 |  | Central System (DIP Env & Helix Test Harness) Test Environment DBT | 104d | 2024-04-17 A | 2024-09-09 | 471 | 73% | 12d |  |
| 1309 |  | Coordinate LDSO Env Preparation | 42d | 2024-07-12 A | 2024-09-09 | 1308FF | 33% | 12d |  |
| 1310 |  | DIP available for Onboarding | 1d | 2024-08-01 A | 2024-08-01 A |  | 100% |  | start no earlier than 2024-08-01 |
| 1311 |  | Qualification Testing for Non-SIT LDSOs Participants' environments) Ready to start DIP onboarding (incl. certificates and security compliance) | 0d | 2024-08-05 A | 2024-08-05 A | 1310FS+2d | 100% |  |  |
| 1312 |  | LDSO Test Environments Connection Confirmed to UIT Environment | 0d | 2024-09-18 | 2024-09-18 | 1311FS+32d, 1309 |  | 5d |  |
| 1313 | 1.5.10 | **Test Readiness** | 65d | 2024-07-02 A | 2024-09-30 |  | 41% | -2d |  |
| 1314 |  | Preparation for Interim Test Readiness Report | 19d | 2024-07-02 A | 2024-07-26 A | 1288 | 100% |  |  |
| 1315 |  | Interim Test Readiness Report Submission to MHHS Programme for Review | 0d | 2024-07-26 | 2024-07-26 | 1314 |  | 8d |  |
| 1316 |  | LDSO Update Readiness Report & Final Assurance by Programme | 25d | 2024-07-29 A | 2024-08-30 | 1315 | 32% | -3d |  |
| 1317 |  | Final Test Readiness Report Submitted to MHHS Programme | 1d | 2024-09-02 | 2024-09-02 | 1316 |  | 5d |  |
| 1318 |  | Final Programme Assurance of LDSO Test Readiness | 21d | 2024-09-02 | 2024-09-30 | 1316 |  | -3d |  |
| 1319 |  | Qualification Testing for Non-SIT LDSOs (Functional, Migration, NFT, Operational) Programme Test Readiness confirmed | 0d | 2024-09-30 | 2024-09-30 | 1317FS+13d, 1291, 1265, 1267, 1269, 1307 |  | -2d |  |
| 1320 |  | Qualification Testing for Non-SIT LDSOs (Functional, Migration, NFT, Operational) Test Readiness Confirmed (Final Test Readiness Review for LDSO) | 0d | 2024-09-30 | 2024-09-30 | 1316, 1318 |  | -3d |  |
| 1321 | 1.5.11 | **Test Window** | 59d | 2024-10-01 | 2024-12-20 |  |  | -3d |  |
| 1322 |  | All Non-SIT LDSOs Qualification Testing | 59d | 2024-10-01 | 2024-12-20 | 1320, 1312 |  | -3d |  |
| 1323 | 1.5.12 | **Test Result Assurance** | 60d | 2024-11-04 | 2025-01-24 |  |  | -3d |  |
| 1324 |  | LDSOs Develop & Submit Test Report (QT Test Completion Report) | 19d | 2024-11-04 | 2024-11-28 | 1305FS+23d |  | -3d |  |
| 1325 |  | Test Reports Reviewed By MHHS & Code Bodies & Finalised | 16d | 2024-11-29 | 2024-12-20 | 1324 |  | -3d |  |
| 1326 |  | Non-SIT LDSOs submission deadline for their QT Test Completion Report to MHHS Programme | 0d | 2024-12-20 | 2024-12-20 | 1325, 1322 |  | -3d |  |
| 1327 |  | Qualification Testing for Non-SIT LDSOs (Functional, Migration, NFT, Operational) 1 End | 0d | 2025-01-24 | 2025-01-24 | 1326FS+25d, 1281 |  | 17d |  |
| 1328 | 1.5.13 | **Non-SIT LDSO Qualification Closure** | 45d | 2024-12-23 | 2025-02-21 |  |  | -3d |  |
| 1329 |  | Non-SIT LDSO Qualification Learned Captured | 15d | 2024-12-23 | 2025-01-10 | 1326 |  | -3d |  |
| 1330 |  | Non-SIT LDSO Qualification Closure Down | 5d | 2025-01-13 | 2025-01-17 | 1329 |  | -3d |  |

| ID | WBS | Task | Duration | Start | Finish | Predecessors | Complete | Total float | Constraint |
| --- | --- | --- | --- | --- | --- | --- | --- | --- | --- |
| 1331 |  | BSC PAB & REC Manager approval of Qualification for Non-SIT LDSOs (Start of Migration for Qualification Participants) | 0d | 2025-02-21 | 2025-02-21 | 1330FS+25d, 1327, 1420, 1421 |  | -3d |  |
| 1332 | 1.6 | **S & A QUALIFICATION** | 604d | 2023-11-07 A | 2026-02-27 |  | 33% | 325d |  |
| 1333 | 1.6.1 | **MHHS Qualification - Qualification Deliverables** | 349d | 2023-11-07 A | 2025-03-07 |  | 85% | 2d |  |
| 1334 | 1.6.1.1 | **BSC & REC Assessment Criteria** | 213d | 2023-11-07 A | 2024-08-29 |  | 99% | 56d |  |
| 1335 |  | Draft BSC Assessment Criteria (Functional) | 21d | 2023-11-07 A | 2023-12-05 A |  | 100% |  | finish no earlier than 2023-12-05 |
| 1336 |  | BSC PAB Review | 1d | 2023-12-14 A | 2023-12-14 A |  | 100% |  | start no earlier than 2023-12-14 |
| 1337 |  | Update BSC Assessment Criteria (Functional, Non-Functional, Migration) | 30d | 2024-02-07 A | 2024-03-19 A |  | 100% |  | finish no earlier than 2024-03-19 |
| 1338 |  | REC & BSC PAB Approval | 3d | 2024-03-26 A | 2024-03-28 A |  | 100% |  | start no earlier than 2024-03-28 |
| 1339 |  | Update BSC Assessment Criteria (Functional, Non-Functional, Migration, Operational) | 20d | 2024-07-24 A | 2024-08-20 A | 983FS+28d | 100% |  |  |
| 1340 |  | Assessment Criteria (Functional, Non-Functional, Migration, Operational) Approved by REC PAB and BSC PAB | 0d | 2024-08-29 | 2024-08-29 | 1339FS+7d |  | 56d |  |
| 1341 | 1.6.1.2 | **Qualification Approach and Plan** | 194d | 2023-12-04 A | 2024-08-29 |  | 97% | 88d |  |
| 1342 | 1.6.1.2.1 | **Qualification Approach and Plan v2** | 84d | 2023-12-04 A | 2024-03-28 A |  | 100% |  |  |
| 1343 |  | Draft Qualification Approach and Plan v2 | 30d | 2023-12-04 A | 2024-01-12 A |  | 100% |  | finish no earlier than 2024-01-12 |
| 1344 |  | Internal Review (Code Bodies and MHHSP) for Qualification Approach and Plan V2 | 10d | 2024-01-15 A | 2024-01-26 A | 1343 | 100% |  | finish no earlier than 2024-01-26 |
| 1345 |  | Industry consultation for Qualification Approach and Plan v2 | 11d | 2024-01-31 A | 2024-02-14 A | 1344 | 100% |  | start no earlier than 2024-01-31 |
| 1346 |  | Update Qualification Approach and Plan v2 post industry consultation | 10d | 2024-02-15 A | 2024-02-28 A | 1345 | 100% |  |  |
| 1347 |  | QWG Endorsement of Qualification Approach and Plan v2 | 1d | 2024-03-12 A | 2024-03-12 A |  | 100% |  | start no earlier than 2024-03-12 |
| 1348 |  | QAG Approval of Qualification Approach and Plan v2 | 1d | 2024-03-21 A | 2024-03-21 A |  | 100% |  | start no earlier than 2024-03-21 |
| 1349 |  | BSC and REC PAB Approval of Qualification Approach and Plan v2 | 3d | 2024-03-26 A | 2024-03-28 A |  | 100% |  | finish no earlier than 2024-03-28 |
| 1350 |  | Functional Testing elements of Qualification Approach & Plan v2 approvement by REC PAB and BSC PAB | 0d | 2024-03-28 A | 2024-03-28 A | 1349 | 100% |  |  |
| 1351 |  | Migration Testing elements of Qualification Approach & Plan v2 appoved by REC PAB and BSC PAB | 0d | 2024-03-28 A | 2024-03-28 A | 1349 | 100% |  |  |
| 1352 | 1.6.1.2.2 | **Qualification Approach and Plan v3** | 84d | 2024-05-06 A | 2024-08-29 |  | 94% | 88d |  |
| 1353 |  | Draft Qualification Approach and Plan v3 | 35d | 2024-05-06 A | 2024-06-21 A | 918 | 100% |  | finish no earlier than 2024-05-17 |
| 1354 |  | Internal Review (Code Bodies and MHHSP) of Qualification Approach and Plan v3 | 10d | 2024-06-24 A | 2024-07-05 A | 1353 | 100% |  |  |
| 1355 |  | Industry consultation for Qualification Approach and Plan v3 | 10d | 2024-07-08 A | 2024-07-19 A | 1354 | 100% |  |  |
| 1356 |  | Update Qualification Approach and Plan v3 Post-Consultation | 10d | 2024-07-22 A | 2024-08-02 A | 1355 | 100% |  |  |
| 1357 |  | QWG Endorsement of Qualification Approach and Plan v3 | 1d | 2024-08-13 | 2024-08-13 | 1356FS+6d |  | 88d |  |
| 1358 |  | QAG Approval of Qualification Approach and Plan v3 | 0d | 2024-08-22 | 2024-08-22 | 1357FS+7d |  | 88d |  |
| 1359 |  | BSC and REC PAB Approval of Qualification Approach and Plan v3 | 3d | 2024-08-27 | 2024-08-29 | 1358FS+2d |  | 88d |  |
| 1360 |  | Non-Functional Testing elements of Qualification Approach and Plan v3 approved by REC PAB and BSC PAB | 0d | 2024-08-29 | 2024-08-29 | 1359 |  | 88d |  |
| 1361 | 1.6.1.3 | **Qualification Assessment Document** | 316d | 2023-12-22 A | 2025-03-07 |  | 76% | 2d |  |
| 1362 | 1.6.1.3.1 | **Qualification Assessment Document v1** | 70d | 2023-12-22 A | 2024-03-28 A |  | 100% |  |  |
| 1363 |  | Draft Qualification Assessment Document v1 | 30d | 2023-12-22 A | 2024-02-01 A |  | 100% |  | finish no earlier than 2024-02-01 |
| 1364 |  | Internal Review (Code Bodies and MHHSP) of Qualification Assessment Document v1 | 10d | 2024-02-01 A | 2024-02-14 A |  | 100% |  | finish no earlier than 2024-02-14 |
| 1365 |  | Industry consultation for Qualification Assessment Document v1 | 11d | 2024-02-16 A | 2024-03-01 A |  | 100% |  | start no earlier than 2024-02-16 |
| 1366 |  | Update Post-Consultation for Qualification Assessment Document v1 | 10d | 2024-03-04 A | 2024-03-15 A | 1365 | 100% |  |  |
| 1367 |  | BSC and REC PAB Approval of Qualification Assessment Document v1 | 3d | 2024-03-26 A | 2024-03-28 A |  | 100% |  | start no earlier than 2024-03-26 |
| 1368 |  | Qualification Assessment Document v1 approved by REC PAB and BSC PAB | 0d | 2024-03-28 A | 2024-03-28 A | 1367 | 100% |  |  |
| 1369 | 1.6.1.3.2 | **Qualification Assessment Document v2** | 110d | 2024-03-29 A | 2024-08-29 |  | 94% | 62d |  |
| 1370 |  | Draft Qualification Assessment Document V1.1 | 26d | 2024-03-29 A | 2024-05-03 A | 1368 | 100% |  |  |
| 1371 |  | Industry Consultation for Qualification Assessment Document V1.1 | 12d | 2024-05-06 A | 2024-05-21 A | 1370 | 100% |  |  |
| 1372 |  | Draft Qualification Assessment Document v2 | 6d | 2024-06-14 A | 2024-06-21 A | 977, 983, 1371 | 100% |  |  |
| 1373 |  | Internal Review (Code Bodies and MHHSP) of Qualification Assessment Document v2 | 10d | 2024-06-24 A | 2024-07-05 A | 1372 | 100% |  |  |
| 1374 |  | Industry consultation for Qualification Assessment Document v2 | 10d | 2024-07-08 A | 2024-07-19 A | 1373 | 100% |  |  |
| 1375 |  | Update Post-Consultation for Qualification Assessment Document v2 | 10d | 2024-07-22 A | 2024-08-02 A | 1374 | 100% |  |  |
| 1376 |  | QWG Endorsement of Qualification Assessment Document v2 | 1d | 2024-08-13 | 2024-08-13 | 1375FS+6d |  | 62d |  |
| 1377 |  | QAG Endorsement of Qualification Assessment Document v2 | 1d | 2024-08-22 | 2024-08-22 | 1376FS+6d |  | 62d |  |
| 1378 |  | BSC and REC PAB Approval of Qualification Assessment Document v2 | 3d | 2024-08-27 | 2024-08-29 | 1377FS+2d |  | 62d |  |
| 1379 |  | Qualification Assessment Document v2 approved by REC PAB and BSC PAB | 0d | 2024-08-29 | 2024-08-29 | 1378 |  | 62d |  |
| 1380 | 1.6.1.3.3 | **Qualification Assessment Document Portal** | 285d | 2024-02-05 A | 2025-03-07 |  | 59% | 2d |  |
| 1381 |  | Design Completion | 30d | 2024-02-05 A | 2024-03-15 A |  | 100% |  | finish no earlier than 2024-03-15 |
| 1382 |  | Qualification Assessment Document Portal Build | 30d | 2024-03-18 A | 2024-04-26 A | 1381 | 100% |  |  |
| 1383 |  | Qualification Assessment Document Internal Testing | 20d | 2024-04-29 A | 2024-05-24 A | 1382 | 100% |  |  |
| 1384 |  | Qualification Assessment Document Portal Training and Onboarding Material Creation | 20d | 2024-05-27 A | 2024-06-21 A | 1383 | 100% |  |  |
| 1385 |  | Qualification Assessment Document Portal Webinar (Date TBC) | 1d | 2024-06-18 A | 2024-06-18 A |  | 100% |  | start no earlier than 2024-06-18 |
| 1386 |  | SIT Participant QAD Application Creation in Portal | 10d | 2024-08-12 | 2024-08-23 | 1384FS+35d |  | 1d |  |
| 1387 |  | Non-SIT LDSO Participant QAD Application Creation in Portal | 10d | 2024-08-12 | 2024-08-23 | 1384FS+35d |  | 7d |  |
| 1388 |  | QT Wave 1 Participant QAD Application Creation in Portal | 10d | 2024-09-23 | 2024-10-04 | 1384FS+65d |  | 1d |  |
| 1389 |  | QT Wave 2 Participant QAD Application Creation in Portal | 10d | 2024-10-28 | 2024-11-08 | 1384FS+90d |  | 1d |  |
| 1390 |  | QT Wave 3 Participant QAD Application Creation in Portal | 10d | 2024-12-30 | 2025-01-10 | 1384FS+135d |  | 2d |  |
| 1391 |  | QT Wave 4 Participant QAD Application Creation in Portal | 10d | 2025-02-24 | 2025-03-07 | 1384FS+175d |  | 2d |  |
| 1392 |  | Update to Qualification Assessment Document Portal post QAD V2 | 10d | 2024-08-30 | 2024-09-12 | 1379 |  | 62d |  |
| 1393 |  | Update to Qualification Assessment Document Portal post QAD V2 Complete | 0d | 2024-09-12 | 2024-09-12 | 1392 |  | 62d |  |
| 1394 | 1.6.2 | **MHHS Qualification - SIT Participants** | 194d | 2024-09-02 | 2025-05-30 |  |  | 1d |  |
| 1395 |  | Initial QAD Submission Window opens | 0d | 2024-09-02 | 2024-09-02 | 1386FS+6d |  | 1d |  |
| 1396 |  | SIT Participants submit Initial QAD | 28d | 2024-09-03 | 2024-10-10 | 1395 |  | 1d |  |
| 1397 |  | Code Bodies review Initial QAD | 36d | 2024-10-11 | 2024-11-29 | 1396 |  | 1d |  |
| 1398 |  | Completion of Code Bodies review of Initial QAD | 0d | 2024-11-29 | 2024-11-29 | 1397 |  | 1d |  |
| 1399 | 1.6.2.5 | **MHHS Qualification - SIT MVC Participants** | 65d | 2024-11-29 | 2025-02-28 |  |  | 1d |  |
| 1400 |  | Final QAD Submission Window (MVC) opens | 0d | 2024-11-29 | 2024-11-29 | 1397, 1393, 1398 |  | 6d |  |

| ID | WBS | Task | Duration | Start | Finish | Predecessors | Complete | Total float | Constraint |
| --- | --- | --- | --- | --- | --- | --- | --- | --- | --- |
| 1401 |  | SIT MVC Participants submit Final QAD | 26d | 2024-12-02 | 2025-01-06 | 1400 |  | 6d |  |
| 1402 |  | Completion of Code Bodies review of Final QAD (MVC) | 19d | 2025-01-07 | 2025-01-31 | 1401, 1064FF |  | 6d |  |
| 1403 |  | QAD Sign Off Deadline (MVC) | 0d | 2025-02-07 | 2025-02-07 | 1073, 1402 |  | 1d |  |
| 1404 |  | REC Code Manager / BSC PAB Approval of Qualification (MVC) | 0d | 2025-02-28 | 2025-02-28 | 1403FS+15d |  | 1d |  |
| 1405 | 1.6.2.6 | **MHHS Qualification - SIT Non-MVC Participants** | 129d | 2024-12-02 | 2025-05-30 |  |  | 1d |  |
| 1406 |  | Final QAD Submission Window (Non-MVC) opens | 0d | 2024-12-02 | 2024-12-02 | 1398FS+1d |  | 1d |  |
| 1407 |  | SIT Non-MVC Participants submit Final QAD | 85d | 2024-12-03 | 2025-03-31 | 1406SS |  | 1d |  |
| 1408 |  | Completion of Code Bodies review of Final QAD (Non-MVC) | 19d | 2025-04-01 | 2025-04-25 | 1407 |  | 1d |  |
| 1409 |  | QAD Sign Off Deadline (Non-MVC) | 1d | 2025-05-02 | 2025-05-02 | 1408FS+4d, 1121 |  | 1d |  |
| 1410 |  | REC Code Manager / BSC PAB Approval of Qualification (Non-MVC) | 0d | 2025-05-30 | 2025-05-30 | 1409FS+20d |  | 1d |  |
| 1411 | 1.6.3 | **MHHS Qualification - Non-SIT LDSO** | 114d | 2024-09-02 | 2025-02-07 |  |  | 7d |  |
| 1412 |  | Initial QAD Submission window opens | 0d | 2024-09-02 | 2024-09-02 | 1387FS+6d |  | 7d |  |
| 1413 |  | Non-SIT LDSO Participants submit initial QAD | 28d | 2024-09-03 | 2024-10-10 | 1412 |  | 7d |  |
| 1414 |  | Non-SIT LDSO QT Participants have submitted their initial QAD | 0d | 2024-10-10 | 2024-10-10 | 1413 |  | 7d |  |
| 1415 |  | Code Bodies review of Non-SIT LDSO participants Initial QAD | 36d | 2024-10-11 | 2024-11-29 | 1414 |  | 7d |  |
| 1416 |  | Completion of Code Bodies review of Initial QAD | 0d | 2024-11-29 | 2024-11-29 | 1415 |  | 7d |  |
| 1417 |  | Final QAD Submission window opens | 0d | 2024-12-02 | 2024-12-02 | 1416FS+1d |  | 7d |  |
| 1418 |  | Non-SIT LDSO Participants submit Final QAD | 25d | 2024-12-03 | 2025-01-06 | 1324SS, 1417SS |  | 7d |  |
| 1419 |  | Non-SIT LDSO QT Participants have submitted their final QAD | 0d | 2025-01-06 | 2025-01-06 | 1418 |  | 7d |  |
| 1420 |  | Completion of Code Bodies review of the Final QAD | 19d | 2025-01-07 | 2025-01-31 | 1419 |  | 7d |  |
| 1421 |  | QAD Sign Off Deadline | 0d | 2025-02-07 | 2025-02-07 | 1420FS+5d |  | 7d |  |
| 1422 | 1.6.4 | **MHHS Qualification - Qualification Waves** | 575d | 2023-12-18 A | 2026-02-27 |  | 28% | 325d |  |
| 1423 | 1.6.4.1 | **Qualification Wave Prep** | 424d | 2023-12-18 A | 2025-07-31 |  | 53% | 476d |  |
| 1424 | 1.6.4.1.1 | **Non-SIT Supplier and Agent Test Approach and Plan** | 119d | 2023-12-18 A | 2024-05-30 A |  | 100% |  |  |
| 1425 |  | Draft Non-SIT S&A Test Approach and Plan | 50d | 2023-12-18 A | 2024-02-23 A |  | 100% |  | finish no earlier than 2024-02-23 |
| 1426 |  | Internal Review of Non-SIT S&A Test Approach and Plan (Code Bodies and MHHSP) | 10d | 2024-02-26 A | 2024-03-08 A | 1425 | 100% |  |  |
| 1427 |  | Issue Non-SIT S&A Test Approach and Plan for Consultation | 15d | 2024-03-18 A | 2024-04-05 A | 1426 | 100% |  | start no earlier than 2024-03-18 |
| 1428 |  | Update Non-SIT S&A Test Approach and Plan Post-Consultation | 10d | 2024-04-08 A | 2024-04-19 A | 1427 | 100% |  |  |
| 1429 |  | QWG Endorsement of Non-SIT S&A Test Approach and Plan | 1d | 2024-05-14 A | 2024-05-14 A |  | 100% |  | finish no earlier than 2024-05-14 |
| 1430 |  | QAG Approval of Non-SIT S&A Test Approach and Plan | 0d | 2024-05-23 A | 2024-05-23 A | 1429FS+7d | 100% |  |  |
| 1431 |  | BSC & REC PAB Approval of Non-SIT S&A Test Approach and Plan | 0d | 2024-05-30 A | 2024-05-30 A | 1430FS+5d | 100% |  |  |
| 1432 | 1.6.4.1.2 | **QT Test Data Approach and Plan** | 64d | 2024-04-19 A | 2024-07-18 A |  | 100% |  |  |
| 1433 |  | QT Test Data Approach agreed as part of the Non-SIT Supplier and Agent Test Approach and Plan | 0d | 2024-04-19 A | 2024-04-19 A | 1428 | 100% |  |  |
| 1434 |  | Draft Test Data Approach and Plan for QT | 10d | 2024-05-06 A | 2024-05-17 A | 1433 | 100% |  |  |
| 1435 |  | Internal Review (Code Bodies and MHHSP) of QT Test Data Approach and Plan | 15d | 2024-05-20 A | 2024-06-07 A | 1434 | 100% |  |  |
| 1436 |  | Issue QT Test Data Approach and Plan for Industry Consultation | 10d | 2024-06-10 A | 2024-06-21 A | 1435 | 100% |  |  |
| 1437 |  | Update QT Test Approach and Plan Post Industry Consultation | 5d | 2024-06-24 A | 2024-06-28 A | 1436 | 100% |  |  |
| 1438 |  | QWG Endorsement of Test Data Approach and Plan | 1d | 2024-07-09 A | 2024-07-09 A | 1437FS+6d | 100% |  |  |
| 1439 |  | QAG Approval of QT Test Data Approach and Plan | 0d | 2024-07-18 A | 2024-07-18 A | 1438FS+7d | 100% |  |  |
| 1440 | 1.6.4.1.3 | **QT Functional Test Scenarios and Test Cases** | 59d | 2024-03-04 A | 2024-05-23 A |  | 100% |  |  |
| 1441 |  | Draft Test Scenarios and Test Case list - Batch 1 | 10d | 2024-03-04 A | 2024-03-15 A |  | 100% |  | finish no earlier than 2024-03-15 |
| 1442 |  | Issue Batch 1 for Consultation | 15d | 2024-03-18 A | 2024-04-05 A | 1441 | 100% |  | start no earlier than 2024-03-18 |
| 1443 |  | Gap analysis against QT Requirements | 8d | 2024-03-18 A | 2024-03-27 A | 1441 | 100% |  |  |
| 1444 |  | Update Test Scenarios and Test Case list - Batch 2 | 6d | 2024-03-28 A | 2024-04-04 A | 1443 | 100% |  |  |
| 1445 |  | Issue Batch 2 for consultation | 10d | 2024-04-05 A | 2024-04-18 A | 1444 | 100% |  |  |
| 1446 |  | Update Batch 2 post consultation | 10d | 2024-04-19 A | 2024-05-02 A | 1445 | 100% |  |  |
| 1447 |  | QWG Endorsement of Batch 1 and 2 | 1d | 2024-05-14 A | 2024-05-14 A |  | 100% |  | finish no earlier than 2024-05-14 |
| 1448 |  | QAG Approval of QT Functional Test Scenarios and Test Cases Batches 1 and 2 | 0d | 2024-05-23 A | 2024-05-23 A | 1447FS+7d | 100% |  |  |
| 1449 | 1.6.4.1.4 | **QT Migration Test Scenarios and Test Cases** | 54d | 2024-05-06 A | 2024-07-18 A |  | 100% |  |  |
| 1450 |  | Draft Test Scenarios and Test Case list - Batch 1 | 20d | 2024-05-06 A | 2024-05-31 A | 889FS+12d | 100% |  |  |
| 1451 |  | Issue Batch 1 for Consultation | 10d | 2024-06-03 A | 2024-06-14 A | 1450 | 100% |  |  |
| 1452 |  | Update Batch 1 Post Consultation | 10d | 2024-06-17 A | 2024-06-28 A | 1451 | 100% |  |  |
| 1453 |  | QWG Endorsement of Batch 1 | 0d | 2024-07-09 A | 2024-07-09 A | 1452FS+7d | 100% |  |  |
| 1454 |  | QAG Approval of QT Migration Test Scenarios and Test Cases Batches 1 | 0d | 2024-07-18 A | 2024-07-18 A | 1453FS+7d | 100% |  |  |
| 1455 | 1.6.4.1.5 | **QT Non-Functional Test Scenarios and Test Cases** | 61d | 2024-06-27 | 2024-09-19 |  |  | 0d |  |
| 1456 |  | Draft Test Scenarios and Test Case list - Batch 2 | 27d | 2024-06-27 | 2024-08-02 | 941FS+2d, 935FS+2d |  | -42d | must finish on 2024-08-02 |
| 1457 |  | Issue Batch 2 for Consultation | 10d | 2024-08-05 | 2024-08-16 | 1456 |  | 80d |  |
| 1458 |  | Update Batch 2 Post Consultation | 10d | 2024-08-19 | 2024-08-30 | 1457 |  | 80d |  |
| 1459 |  | QWG Endorsement of Batch 2 | 0d | 2024-09-10 | 2024-09-10 | 1458FS+7d, 1360 |  | 80d |  |
| 1460 |  | QAG Approval of QT Non-Functional Test Scenarios and Test Cases Batch 2 | 0d | 2024-09-19 | 2024-09-19 | 1459FS+7d |  | 80d |  |
| 1461 | 1.6.4.1.6 | **QT Operational Test Scenarios and Test Cases** | 101d | 2024-05-30 | 2024-10-17 |  |  | 0d |  |
| 1462 |  | Draft QT Operational Test Cases - Batch 1 | 47d | 2024-05-30 | 2024-08-02 | 974FS+2d, 1439 |  | -62d | must finish on 2024-08-02 |
| 1463 |  | Issue Batch 1 for Consultation | 10d | 2024-08-05 | 2024-08-16 | 1462 |  | 80d |  |
| 1464 |  | Update Batch 1 Post Consultation | 10d | 2024-08-19 | 2024-08-30 | 1463 |  | 80d |  |
| 1465 |  | QWG Endorsement of Batch 1 | 0d | 2024-09-10 | 2024-09-10 | 1464FS+7d |  | 80d |  |
| 1466 |  | QAG Approval of QT Operational Test Scenarios and Test Cases Batch 1 | 0d | 2024-09-19 | 2024-09-19 | 1465FS+7d |  | 80d |  |
| 1467 |  | Draft QT Operational Test Cases - Batch 2 | 10d | 2024-07-22 | 2024-08-02 | 980FS+2d |  | 80d |  |
| 1468 |  | Issue Batch 2 for Consultation | 10d | 2024-08-05 | 2024-08-16 | 1467 |  | 80d |  |
| 1469 |  | Update Batch 2 Post Consultation | 10d | 2024-08-19 | 2024-08-30 | 1468 |  | 80d |  |
| 1470 |  | QWG Endorsement of Batch 2 | 0d | 2024-09-10 | 2024-09-10 | 1469FS+7d |  | 80d |  |

| ID | WBS | Task | Duration | Start | Finish | Predecessors | Complete | Total float | Constraint |
| --- | --- | --- | --- | --- | --- | --- | --- | --- | --- |
| 1471 |  | QAG Approval of QT Operational Test Scenarios and Test Cases Batch 2 | 0d | 2024-09-19 | 2024-09-19 | 1470FS+7d |  | 80d |  |
| 1472 |  | Draft QT Operational Test Cases - Batch 3 | 10d | 2024-08-26 | 2024-09-06 | 986FS+2d |  | -20d | must finish on 2024-09-06 |
| 1473 |  | Issue Batch 3 for Consultation | 10d | 2024-09-09 | 2024-09-20 | 1472, 1340 |  | 50d |  |
| 1474 |  | Update Batch 3 Post Consultation | 5d | 2024-09-23 | 2024-09-27 | 1473 |  | 50d |  |
| 1475 |  | QWG Endorsement of Batch 3 | 0d | 2024-10-08 | 2024-10-08 | 1474FS+7d |  | 50d |  |
| 1476 |  | QAG Approval of QT Operational Test Scenarios and Test Cases Batch 3 | 0d | 2024-10-17 | 2024-10-17 | 1475FS+7d |  | 50d |  |
| 1477 | 1.6.4.1.7 | **Qualification Testing Framework (Test Stubs and Supporting UI)** | 394d | 2024-01-29 A | 2025-07-31 |  | 47% | 476d |  |
| 1478 |  | Proof of Concept for QTF Completion | 45d | 2024-01-29 A | 2024-03-29 A |  | 100% |  | start no earlier than 2024-01-22 |
| 1479 |  | Discovery and Mobilisation | 25d | 2024-04-01 A | 2024-05-03 A | 1478 | 100% |  |  |
| 1480 | 1.6.4.1.7.3 | **Agile DBT of Qualification Testing Framework** | 83d | 2024-04-24 A | 2024-08-16 |  | 96% | 725d |  |
| 1481 | 1.6.4.1.7.3.1 | **User Interface (UI)** | 48d | 2024-04-24 A | 2024-06-28 A |  | 100% |  |  |
| 1482 |  | UI Wireframe | 48d | 2024-04-24 A | 2024-06-28 A | 1428FS+2d | 100% |  |  |
| 1483 |  | UI Standards | 35d | 2024-05-13 A | 2024-06-28 A | 1482SS+13d | 100% |  |  |
| 1484 |  | Elexon Branding Sylesheet | 1d | 2024-05-17 A | 2024-05-20 A | 1479FS+10d | 100% |  |  |
| 1485 |  | Elexon Branding QTF Logo | 1d | 2024-05-31 A | 2024-06-03 A | 1479FS+20d | 100% |  |  |
| 1486 | 1.6.4.1.7.3.2 | **Design, Build, Test** | 70d | 2024-05-13 A | 2024-08-16 |  | 95% | 725d |  |
| 1487 |  | Core UI Screens | 60d | 2024-05-13 A | 2024-08-02 A | 1483SS | 100% |  |  |
| 1488 |  | Tooling (Trigger Files / Template Generators) | 70d | 2024-05-13 A | 2024-08-16 | 1482SS+13d | 83% | 725d |  |
| 1489 |  | Database Schema | 50d | 2024-05-13 A | 2024-07-19 A | 1482SS+13d | 100% |  |  |
| 1490 |  | Core API's | 60d | 2024-05-13 A | 2024-08-02 A | 1482SS+13d | 100% |  |  |
| 1491 |  | DIP (SIT-A) Onboarding for Development inc. Test Stubs | 1d | 2024-07-12 A | 2024-07-12 A | 1479FS+49d | 100% |  |  |
| 1492 |  | DTN Onboarding for Development inc. Test Stubs | 1d | 2024-07-15 A | 2024-07-15 A | 1491 | 100% |  |  |
| 1493 |  | QTF Test Cases DBT Refinement, Execution and Results Validation, Defect Management, Error Handling | 131d | 2024-05-02 | 2024-10-31 | 1454FF, 1460FF, 1466FF, 1471FF, 1476FF+10d |  | 50d |  |
| 1494 | 1.6.4.1.7.5 | **Environments** | 158d | 2024-04-15 A | 2024-11-20 |  | 49% | 657d |  |
| 1495 | 1.6.4.1.7.5.1 | **Azure Devops** | 120d | 2024-04-15 A | 2024-09-27 |  | 42% | 67d |  |
| 1496 | 1.6.4.1.7.5.1.1 | **QFT ADO Development Instance** | 15d | 2024-04-15 A | 2024-05-03 A |  | 100% |  |  |
| 1497 |  | Elexon Instance Setup for QTF Build | 5d | 2024-04-15 A | 2024-04-19 A | 1479SS+10d | 100% |  |  |
| 1498 |  | Configuration and User Access | 10d | 2024-04-22 A | 2024-05-03 A | 1497 | 100% |  |  |
| 1499 | 1.6.4.1.7.5.1.2 | **MHHSP ADO Instance** | 49d | 2024-07-23 A | 2024-09-27 |  | 24% | 67d |  |
| 1500 |  | MHHSP Instance Setup for QTF Production | 29d | 2024-07-23 A | 2024-08-30 | 1506SS+41d | 41% | 67d |  |
| 1501 |  | Configuration and User Access | 20d | 2024-09-02 | 2024-09-27 | 1500, 1557 |  | 67d |  |
| 1502 | 1.6.4.1.7.5.2 | **Temporary Development Environment** | 35d | 2024-04-15 A | 2024-05-31 A |  | 100% |  |  |
| 1503 |  | Design | 15d | 2024-04-15 A | 2024-05-03 A | 1479SS+10d | 100% |  |  |
| 1504 |  | Build and Deployment | 20d | 2024-05-06 A | 2024-05-31 A | 1498, 1503 | 100% |  |  |
| 1505 | 1.6.4.1.7.5.3 | **Dev, Test & Prod Environment Requirements + Design** | 105d | 2024-05-27 A | 2024-10-18 |  | 58% | 680d |  |
| 1506 |  | Design (including Security Review) | 70d | 2024-05-27 A | 2024-08-30 | 1479FS+15d | 76% | 715d |  |
| 1507 |  | Hub Deployment | 20d | 2024-06-10 A | 2024-07-05 A | 1506SS+10d | 100% |  |  |
| 1508 |  | Development Envn. Deployment | 40d | 2024-07-08 A | 2024-08-30 | 1507 | 58% | 59d |  |
| 1509 |  | Test Envn. Deployment | 10d | 2024-09-02 | 2024-09-13 | 1508 |  | 59d |  |
| 1510 |  | Production Envn. Deployment | 25d | 2024-09-16 | 2024-10-18 | 1509 |  | 59d |  |
| 1511 | 1.6.4.1.7.5.4 | **QTF Deployment into Production** | 14d | 2024-11-01 | 2024-11-20 |  |  | 50d |  |
| 1512 |  | App Deployment | 1d | 2024-11-01 | 2024-11-01 | 1493, 1510 |  | 50d |  |
| 1513 |  | Smoke Test | 2d | 2024-11-01 | 2024-11-04 | 1512SS |  | 50d |  |
| 1514 |  | PEN Test | 2d | 2024-11-05 | 2024-11-06 | 1513 |  | 50d |  |
| 1515 |  | Regresssion Test | 10d | 2024-11-07 | 2024-11-20 | 1514 |  | 50d |  |
| 1516 | 1.6.4.1.7.5.5 | **DIP Onboarding (UIT)** | 37d | 2024-08-05 | 2024-09-24 |  |  | 91d |  |
| 1517 |  | DIP available for Onboarding | 1d | 2024-08-05 | 2024-08-05 | 1503 |  | 91d | start no earlier than 2024-08-05 |
| 1518 |  | Qualification Testing for Non-SIT S&A Participants' environments) Ready to start DIP onboarding (incl. certificates and security compliance) | 15d | 2024-08-06 | 2024-08-26 | 1517 |  | 91d |  |
| 1519 |  | Non-SIT S&A QTF Environments Connection Confirmed to UIT Environment | 1d | 2024-08-27 | 2024-08-27 | 1518 |  | 91d |  |
| 1520 |  | DIP UIT Test Stubs | 20d | 2024-08-28 | 2024-09-24 | 1519 |  | 91d |  |
| 1521 | 1.6.4.1.7.5.6 | **DTN Onboarding** | 95d | 2024-05-20 A | 2024-09-27 |  | 47% | 88d |  |
| 1522 |  | DTN Request Raised for Onboarding | 25d | 2024-05-20 A | 2024-06-21 A | 1503FS+10d | 100% |  |  |
| 1523 |  | Setup, configuration of New Host and Test Flags | 5d | 2024-06-24 A | 2024-06-28 A | 1522 | 100% |  |  |
| 1524 |  | New VPN Connection | 30d | 2024-08-05 A | 2024-09-13 | 1523FS+25d | 10% | 88d |  |
| 1525 |  | DTN Test Stubs | 10d | 2024-09-16 | 2024-09-27 | 1524 |  | 88d |  |
| 1526 | 1.6.4.1.7.6 | **Test Data (MPANs, DIP Messages, Settlement, Consumption, Reference)** | 299d | 2024-06-10 A | 2025-07-31 |  | 14% | 476d |  |
| 1527 |  | Sample MPAN Data + Attributes from Suppliers | 15d | 2024-06-10 A | 2024-06-28 A | 1435 | 100% |  |  |
| 1528 |  | Test Data Templates and generator tools ready | 30d | 2024-06-24 A | 2024-08-02 | 1488SS+20d, 1527FF+25d | 93% | 735d |  |
| 1529 | 1.6.4.1.7.6.3 | **Industry Standing Data (ISD)** | 33d | 2024-07-26 A | 2024-09-10 |  | 6% | 101d |  |
| 1530 |  | Dependant on Receiving ISD Agreed Source Data from Helix | 1d | 2024-07-26 A | 2024-07-26 A |  | 100% |  | start no earlier than 2024-07-26 |
| 1531 |  | First View of Migrated ISD Data | 1d | 2024-08-19 | 2024-08-19 | 1530 |  | 101d | start no earlier than 2024-08-19 |
| 1532 |  | Final Cycle 3 Migrated ISD Data | 1d | 2024-08-20 | 2024-08-20 | 1531 |  | 101d |  |
| 1533 |  | Create ISD Template inc. DIP ID | 5d | 2024-08-21 | 2024-08-27 | 1532 |  | 101d |  |
| 1534 |  | Publish Qualification ISD | 10d | 2024-08-28 | 2024-09-10 | 1533 |  | 101d |  |
| 1535 | 1.6.4.1.7.6.4 | **Wave 1 Test Data** | 46d | 2024-11-29 | 2025-01-31 |  |  | 1d |  |
| 1536 |  | Test Data Request + Templates Completed | 16d | 2024-11-29 | 2024-12-20 | 1580 |  | 1d |  |
| 1537 |  | Test Data Generated | 10d | 2024-12-23 | 2025-01-03 | 1536 |  | 1d |  |
| 1538 |  | Test Data Loaded into QP Systems | 20d | 2025-01-06 | 2025-01-31 | 1537 |  | 1d |  |
| 1539 |  | Test Data Loaded into QTF + ADO | 20d | 2025-01-06 | 2025-01-31 | 1537 |  | 1d |  |
| 1540 | 1.6.4.1.7.6.5 | **Wave 2 Test Data** | 42d | 2025-01-31 | 2025-03-31 |  |  | 1d |  |

| ID | WBS | Task | Duration | Start | Finish | Predecessors | Complete | Total float | Constraint |
| --- | --- | --- | --- | --- | --- | --- | --- | --- | --- |
| 1541 |  | Test Data Request + Templates Completed | 16d | 2025-01-31 | 2025-02-21 | 1610 |  | 1d |  |
| 1542 |  | Test Data Generated | 10d | 2025-02-24 | 2025-03-07 | 1541 |  | 1d |  |
| 1543 |  | Test Data Loaded into QP Systems | 16d | 2025-03-10 | 2025-03-31 | 1542 |  | 1d |  |
| 1544 |  | Test Data Loaded into QTF + ADO | 16d | 2025-03-10 | 2025-03-31 | 1542 |  | 1d |  |
| 1545 | 1.6.4.1.7.6.6 | **Wave 3 Test Data** | 45d | 2025-03-31 | 2025-05-30 |  |  | 2d |  |
| 1546 |  | Test Data Request + Templates Completed | 15d | 2025-03-31 | 2025-04-18 | 1640 |  | 2d |  |
| 1547 |  | Test Data Generated | 10d | 2025-04-21 | 2025-05-02 | 1546 |  | 2d |  |
| 1548 |  | Test Data Loaded into QP Systems | 20d | 2025-05-05 | 2025-05-30 | 1547 |  | 2d |  |
| 1549 |  | Test Data Loaded into QTF + ADO | 20d | 2025-05-05 | 2025-05-30 | 1547 |  | 2d |  |
| 1550 | 1.6.4.1.7.6.7 | **Wave 4 Test Data** | 45d | 2025-05-30 | 2025-07-31 |  |  | 2d |  |
| 1551 |  | Test Data Request + Templates Completed | 15d | 2025-05-30 | 2025-06-19 | 1670 |  | 2d |  |
| 1552 |  | Test Data Generated | 10d | 2025-06-20 | 2025-07-03 | 1551 |  | 2d |  |
| 1553 |  | Test Data Loaded into QP Systems | 20d | 2025-07-04 | 2025-07-31 | 1552 |  | 2d |  |
| 1554 |  | Test Data Loaded into QTF + ADO | 20d | 2025-07-04 | 2025-07-31 | 1552 |  | 2d |  |
| 1555 | 1.6.4.1.7.7 | **Governance** | 130d | 2024-07-01 A | 2024-12-27 |  | 29% | 630d |  |
| 1556 |  | Onboarding Strategy and Develop Training Requirements & Materials Inc. Day in the Life | 65d | 2024-07-01 A | 2024-09-27 | 1482 | 43% | 695d |  |
| 1557 |  | Design Approach & Set-Up ADO Tool for Test & Defect Management Tool | 45d | 2024-07-01 A | 2024-08-30 | 1556SS | 62% | 67d |  |
| 1558 |  | Knowledge Transfer, Training, Demonstrations, Documentation, Governance | 85d | 2024-09-02 | 2024-12-27 | 1556SS+45d |  | 8d |  |
| 1559 |  | Qualification Testing Framework (Test Stubs and Supporting UI) Complete | 0d | 2025-01-17 | 2025-01-17 | 1487, 1489, 1490, 1491, 1492, 1493, 1515, 1525, 1534, 1520, 1558FS+15d |  | 8d |  |
| 1560 |  | Qualification Testing Wave Readiness Confirmed | 0d | 2025-01-23 | 2025-01-23 | 1559FS+4d, 1558 |  | 8d |  |
| 1561 | 1.6.4.1.8 | **Wave Allocation** | 129d | 2024-01-02 A | 2024-06-28 A |  | 100% |  |  |
| 1562 |  | Draft Pre-Qualification Submission (PQS) document | 20d | 2024-01-02 A | 2024-01-29 A |  | 100% |  | finish no earlier than 2024-01-26 |
| 1563 |  | Publish PQS document | 1d | 2024-01-31 A | 2024-01-31 A |  | 100% |  | start no earlier than 2024-01-31 |
| 1564 |  | PQS Submission window | 60d | 2024-02-05 A | 2024-04-26 A |  | 100% |  | start no earlier than 2024-02-05 |
| 1565 |  | Pre-Qualification Submission and PIT Test Plan Deadline for Submission​ | 0d | 2024-04-26 A | 2024-04-26 A | 1564 | 100% |  |  |
| 1566 |  | PQS Review by Code Bodies | 25d | 2024-04-29 A | 2024-05-31 A | 1564, 1565 | 100% |  |  |
| 1567 |  | Draft Wave Allocations | 15d | 2024-06-03 A | 2024-06-21 A | 1566 | 100% |  |  |
| 1568 |  | Confirmation of participant Qualification Wave allocation | 0d | 2024-06-28 A | 2024-06-28 A | 1567FS+5d | 100% |  |  |
| 1569 | 1.6.4.2 | **Qualification Wave 1** | 229d | 2024-10-14 | 2025-08-29 |  |  | 1d |  |
| 1570 | 1.6.4.2.1 | **Qualification Wave 1 QAD Prep** | 79d | 2024-10-14 | 2025-01-31 |  |  | 1d |  |
| 1571 |  | Initial QAD Submission window opens | 0d | 2024-10-14 | 2024-10-14 | 1568, 1388FS+6d |  | 1d |  |
| 1572 |  | Qualification Wave 1 Participants Submit Initial QAD | 49d | 2024-10-15 | 2024-12-20 | 1571 |  | 1d |  |
| 1573 |  | Qualification Wave 1 Participants have submitted their initial QAD | 0d | 2024-12-20 | 2024-12-20 | 1572 |  | 1d |  |
| 1574 |  | Code Bodies review of Wave 1 Participants Initial QAD | 30d | 2024-12-23 | 2025-01-31 | 1572, 1573 |  | 1d |  |
| 1575 |  | Completion of Code Bodies review of Initial QAD | 0d | 2025-01-31 | 2025-01-31 | 1574 |  | 1d |  |
| 1576 | 1.6.4.2.2 | **Qualification Wave 1 Test Prep** | 60d | 2024-11-01 | 2025-01-24 |  |  | 7d |  |
| 1577 |  | Confirmation from Qualification Wave 1 Participants that DIP onboarding has commenced | 0d | 2024-11-01 | 2024-11-01 |  |  | 26d | finish no earlier than 2024-11-01 |
| 1578 |  | Qualification Wave 1 Participants DIP Onboarding Window | 35d | 2024-11-04 | 2024-12-20 | 1577 |  | 26d |  |
| 1579 |  | Confirmation from Qualification Wave 1 Participants that DIP onboarding has completed | 0d | 2024-12-20 | 2024-12-20 | 1578 |  | 26d |  |
| 1580 |  | Qualification Wave 1 Participants' to provide status of PIT completion and submit QT Test Plan | 0d | 2024-11-29 | 2024-11-29 |  |  | 1d | start no earlier than 2024-11-29 |
| 1581 |  | Review of Participants' PIT Status and QT Test Plan | 15d | 2024-12-02 | 2024-12-20 | 1580FS+1d |  | 26d |  |
| 1582 |  | Qualification Test Plans for Wave 1 Participants approved | 0d | 2024-12-20 | 2024-12-20 | 1581 |  | 26d |  |
| 1583 |  | Qualification Wave 1 Participants have submitted PIT Test Completion Report and evidence for QT Entry | 0d | 2024-12-20 | 2024-12-20 |  |  | 1d | finish no earlier than 2024-12-20 |
| 1584 |  | Review of Participants PIT Test Completion Report | 25d | 2024-12-23 | 2025-01-24 | 1583 |  | 1d |  |
| 1585 |  | Onboarding to QTF & ADO | 25d | 2024-12-23 | 2025-01-24 | 1584SS, 1501 |  | 7d |  |
| 1586 | 1.6.4.2.3 | **Qualification Wave 1 QT Execution** | 100d | 2025-01-27 | 2025-06-13 |  |  | 1d |  |
| 1587 |  | Review Entry Criteria Evidence for each Wave 1 Participant | 5d | 2025-01-27 | 2025-01-31 | 1575FF, 1579, 1582, 1584 |  | 1d |  |
| 1588 |  | Qualification Wave 1 Participant Test Readiness Confirmed | 0d | 2025-01-31 | 2025-01-31 | 1574, 1575, 1587, 1538, 1539 |  | 1d |  |
| 1589 |  | Qualification Wave 1 QT Execution Start | 0d | 2025-02-03 | 2025-02-03 | 1588FS+1d, 1560, 1585, 1040 |  | 1d |  |
| 1590 |  | Qualification Wave 1 QT Execution Window | 95d | 2025-02-03 | 2025-06-13 | 1589FS-1d |  | 6d |  |
| 1591 |  | Qualification Wave 1 QT Projected Execution End | 0d | 2025-06-13 | 2025-06-13 | 1590 |  | 6d |  |
| 1592 | 1.6.4.2.4 | **Qualification Wave 1 Exit** | 149d | 2025-02-03 | 2025-08-29 |  |  | 1d |  |
| 1593 |  | Final QAD Submission window opens | 0d | 2025-02-03 | 2025-02-03 | 1589 |  | 1d |  |
| 1594 |  | Qualification Wave 1 Participants submit their Final QAD | 99d | 2025-02-04 | 2025-06-20 | 1593 |  | 1d |  |
| 1595 |  | Qualification Wave 1 Participants have submitted their final QAD | 0d | 2025-06-20 | 2025-06-20 | 1594, 1591 |  | 1d |  |
| 1596 |  | Completion of Code Bodies review of Final QAD | 20d | 2025-06-23 | 2025-07-18 | 1594, 1595 |  | 1d |  |
| 1597 |  | QAD Sign Off deadline | 1d | 2025-07-31 | 2025-07-31 | 1596FS+8d |  | 1d |  |
| 1598 |  | Qualification Wave 1 Participants Qualification approved by BSC PAB and REC Manager | 0d | 2025-08-29 | 2025-08-29 | 1597FS+21d |  | 1d |  |
| 1599 | 1.6.4.3 | **Qualification Wave 2** | 249d | 2024-11-18 | 2025-10-31 |  |  | 1d |  |
| 1600 | 1.6.4.3.1 | **Qualification Wave 2 QAD Prep** | 95d | 2024-11-18 | 2025-03-31 |  |  | 1d |  |
| 1601 |  | Initial QAD Submission window opens | 0d | 2024-11-18 | 2024-11-18 | 1389FS+6d |  | 1d |  |
| 1602 |  | Qualification Wave 2 Participants Submit Initial QAD | 69d | 2024-11-19 | 2025-02-21 | 1601 |  | 1d |  |
| 1603 |  | Qualification Wave 2 Participants have submitted their initial QAD | 0d | 2025-02-21 | 2025-02-21 | 1602 |  | 1d |  |
| 1604 |  | Code Bodies review of Wave 2 Participants' Initial QAD | 26d | 2025-02-24 | 2025-03-31 | 1603 |  | 1d |  |
| 1605 |  | Completion of Code Bodies review of Initial QAD | 0d | 2025-03-31 | 2025-03-31 | 1604 |  | 1d |  |
| 1606 | 1.6.4.3.2 | **Qualification Wave 2 Test Prep** | 60d | 2025-01-06 | 2025-03-28 |  |  | 17d |  |
| 1607 |  | Confirmation from Qualification Wave 2 Participants that DIP Onboarding has commenced | 0d | 2025-01-06 | 2025-01-06 |  |  | 17d | start no earlier than 2025-01-06 |
| 1608 |  | Qualification Wave 2 Participants DIP Onboarding Window | 40d | 2025-01-06 | 2025-02-28 | 1607 |  | 17d |  |
| 1609 |  | Confirmation from Qualificiation Wave 2 Participants that DIP onboarding has completed | 0d | 2025-02-28 | 2025-02-28 | 1608 |  | 17d |  |
| 1610 |  | Qualification Wave 2 Participants' to provide status of PIT completion and submit QT Test Plan | 0d | 2025-01-31 | 2025-01-31 |  |  | 1d | start no earlier than 2025-01-31 |

| ID | WBS | Task | Duration | Start | Finish | Predecessors | Total float | Constraint |
| --- | --- | --- | --- | --- | --- | --- | --- | --- |
| 1611 |  | Review of Participants' PIT Status and QT Test Plan | 15d | 2025-02-03 | 2025-02-21 | 1610FS+1d | 590d |  |
| 1612 |  | Qualification Test Plans for Wave 2 Participants approved | 0d | 2025-02-21 | 2025-02-21 | 1611 | 590d |  |
| 1613 |  | Qualification Wave 2 Participants have submitted PIT Test Completion Report and evidence for QT entry | 0d | 2025-02-21 | 2025-02-21 |  | 3d | finish no earlier than 2025-02-21 |
| 1614 |  | Review of Participants' PIT Test Completion Report | 25d | 2025-02-24 | 2025-03-28 | 1613 | 3d |  |
| 1615 |  | Onboarding to QTF & ADO | 25d | 2025-02-24 | 2025-03-28 | 1614SS | 3d |  |
| 1616 | 1.6.4.3.3 | **Qualification Wave 2 QT Execution** | 99d | 2025-03-25 | 2025-08-08 |  | 1d |  |
| 1617 |  | Review Entry Criteria Evidence for each Wave 2 Participant | 5d | 2025-03-25 | 2025-03-31 | 1605FF, 1609 | 1d |  |
| 1618 |  | Qualification Wave 2 Participant Test Readiness Confirmed | 0d | 2025-03-31 | 2025-03-31 | 1617, 1605, 1543, 1544 | 1d |  |
| 1619 |  | Qualification Wave 2 Execution Start | 0d | 2025-04-01 | 2025-04-01 | 1618FS+1d, 1615 | 1d |  |
| 1620 |  | Qualification Wave 2 QT Execution Window | 93d | 2025-04-02 | 2025-08-08 | 1619 | 6d |  |
| 1621 |  | Qualfication Wave 2 QT Execution End | 0d | 2025-08-08 | 2025-08-08 | 1620 | 6d |  |
| 1622 | 1.6.4.3.4 | **Qualification Wave 2 Exit** | 153d | 2025-04-01 | 2025-10-31 |  | 1d |  |
| 1623 |  | Final QAD Submission window opens | 0d | 2025-04-01 | 2025-04-01 | 1619 | 1d |  |
| 1624 |  | Qualification Wave 2 Participants submit their Final QAD | 98d | 2025-04-02 | 2025-08-15 | 1623 | 1d |  |
| 1625 |  | Qualification Wave 2 Participants have submitted their final QAD | 0d | 2025-08-15 | 2025-08-15 | 1624, 1621 | 1d |  |
| 1626 |  | Completion of Code Bodies review of Final QAD | 27d | 2025-08-18 | 2025-09-23 | 1625 | 1d |  |
| 1627 |  | QAD Sign Off deadline | 1d | 2025-09-30 | 2025-09-30 | 1626FS+4d | 1d |  |
| 1628 |  | Qualification Wave 2 Participants Qualification approved by BSC PAB and REC Manager | 0d | 2025-10-31 | 2025-10-31 | 1627FS+23d | 1d |  |
| 1629 | 1.6.4.4 | **Qualification Wave 3** | 239d | 2025-01-20 | 2025-12-19 |  | 2d |  |
| 1630 | 1.6.4.4.1 | **Qualification Wave 3 QAD Prep** | 94d | 2025-01-20 | 2025-05-30 |  | 2d |  |
| 1631 |  | Initial QAD Submission window opens | 0d | 2025-01-20 | 2025-01-20 | 1390FS+6d | 2d |  |
| 1632 |  | Qualification Wave 3 Participants Submit Initial QAD | 64d | 2025-01-21 | 2025-04-18 | 1631 | 2d |  |
| 1633 |  | Qualification Wave 3 Participants have submitted their initial QAD | 0d | 2025-04-18 | 2025-04-18 | 1632 | 2d |  |
| 1634 |  | Code Bodies review of Wave 3 Participants' Initial QAD | 30d | 2025-04-21 | 2025-05-30 | 1633 | 2d |  |
| 1635 |  | Completion of Code Bodies review of Initial QAD | 0d | 2025-05-30 | 2025-05-30 | 1634 | 2d |  |
| 1636 | 1.6.4.4.2 | **Qualification Wave 3 Test Prep** | 65d | 2025-03-03 | 2025-05-30 |  | 22d |  |
| 1637 |  | Qualification Wave 3 Participants' have started DIP Onboarding | 0d | 2025-03-03 | 2025-03-03 |  | 24d | start no earlier than 2025-03-03 |
| 1638 |  | Qualification Wave 3 Participants DIP Onboarding window | 40d | 2025-03-03 | 2025-04-25 | 1637 | 24d |  |
| 1639 |  | Confirmation from Qualification Wave 3 Participants that DIP onboarding has completed | 0d | 2025-04-25 | 2025-04-25 | 1638 | 24d |  |
| 1640 |  | Qualification Wave 3 Participants' to provide status of PIT completion and submit QT Test Plan | 0d | 2025-03-31 | 2025-03-31 |  | 2d | start no earlier than 2025-03-31 |
| 1641 |  | Review of Participants' PIT Status and QT Test Plan | 15d | 2025-03-31 | 2025-04-18 | 1640 | 550d |  |
| 1642 |  | Qualification Test Plans for Wave 3 Participants approved | 0d | 2025-04-18 | 2025-04-18 | 1641 | 550d |  |
| 1643 |  | Qualification Wave 3 Participants have submitted PIT Test Completion Report and evidence for QT Entry | 0d | 2025-04-18 | 2025-04-18 |  | 1d | finish no earlier than 2025-04-18 |
| 1644 |  | Review of Participants' PIT Test Completion Report | 30d | 2025-04-21 | 2025-05-30 | 1643 | 1d |  |
| 1645 |  | Onboarding to QTF & ADO | 30d | 2025-04-21 | 2025-05-30 | 1644SS | 1d |  |
| 1646 | 1.6.4.4.3 | **Qualification Wave 3 QT Execution** | 98d | 2025-05-28 | 2025-10-10 |  | 2d |  |
| 1647 |  | Review Entry Criteria Evidence for each Wave 3 Participant | 3d | 2025-05-28 | 2025-05-30 | 1639, 1635FF | 2d |  |
| 1648 |  | Qualification Wave 3 Participant Test Readiness confirmed | 0d | 2025-05-30 | 2025-05-30 | 1639, 1647, 1548, 1549 | 2d |  |
| 1649 |  | Qualification Wave 3 Execution Start | 0d | 2025-06-02 | 2025-06-02 | 1648, 1645FS+1d | 1d |  |
| 1650 |  | Qualification Wave 3 QT Execution Window | 94d | 2025-06-03 | 2025-10-10 | 1647, 1649 | 6d |  |
| 1651 |  | Qualification Wave 3 Projected Execution End | 0d | 2025-10-10 | 2025-10-10 | 1650 | 6d |  |
| 1652 | 1.6.4.4.4 | **Qualification Wave 3 Exit** | 144d | 2025-06-02 | 2025-12-19 |  | 1d |  |
| 1653 |  | Final QAD Submission window opens | 0d | 2025-06-02 | 2025-06-02 | 1649 | 1d |  |
| 1654 |  | Qualification Wave 3 Participants submit their Final QAD | 99d | 2025-06-03 | 2025-10-17 | 1653 | 1d |  |
| 1655 |  | Qualification Wave 3 Participants have submitted their Final QAD | 0d | 2025-10-17 | 2025-10-17 | 1654, 1651 | 1d |  |
| 1656 |  | Completion of Code Bodies review of Final QAD | 20d | 2025-10-20 | 2025-11-14 | 1655 | 1d |  |
| 1657 |  | QAD Sign Off deadline | 1d | 2025-11-21 | 2025-11-21 | 1656FS+4d | 1d |  |
| 1658 |  | Qualification Wave 3 Participants Qualification approved by BSC PAB and REC Manager | 0d | 2025-12-19 | 2025-12-19 | 1657FS+20d | 1d |  |
| 1659 | 1.6.4.5 | **Qualification Wave 4** | 249d | 2025-03-17 | 2026-02-27 |  | 2d |  |
| 1660 | 1.6.4.5.1 | **Qualification Wave 4 QAD Prep** | 98d | 2025-03-17 | 2025-07-31 |  | 2d |  |
| 1661 |  | Initial QAD Submission window opens | 0d | 2025-03-17 | 2025-03-17 | 1391FS+6d | 2d |  |
| 1662 |  | Qualification Wave 4 Participants Submit Initial QAD | 69d | 2025-03-18 | 2025-06-20 | 1661 | 2d |  |
| 1663 |  | Qualification Wave 4 Participants have submitted their Initial QAD | 0d | 2025-06-20 | 2025-06-20 | 1662 | 2d |  |
| 1664 |  | Code Bodies review of Wave 4 Participants' Initial QAD | 29d | 2025-06-23 | 2025-07-31 | 1663 | 2d |  |
| 1665 |  | Completion of Code Bodies review of Initial QAD | 0d | 2025-07-31 | 2025-07-31 | 1664 | 2d |  |
| 1666 | 1.6.4.5.2 | **Qualification Wave 4 Test Prep** | 67d | 2025-05-01 | 2025-08-01 |  | 21d |  |
| 1667 |  | Confirmation from Qualification 4 Participants that DIP Onboarding has commenced | 0d | 2025-05-01 | 2025-05-01 |  | 21d | start no earlier than 2025-05-01 |
| 1668 |  | Qualification Wave 4 Participants DIP Onboarding Window | 42d | 2025-05-01 | 2025-06-27 | 1667 | 21d |  |
| 1669 |  | Confirmation from Qualification Wave 4 Participants that DIP onboarding has completed | 0d | 2025-06-27 | 2025-06-27 | 1668 | 21d |  |
| 1670 |  | Qualification Wave 4 Participants' to provide status of PIT completion and submit QT Test Plan | 0d | 2025-05-30 | 2025-05-30 |  | 2d | start no earlier than 2025-05-30 |
| 1671 |  | Review of Participants' PIT Status and QT Test Plan | 16d | 2025-05-30 | 2025-06-20 | 1670 | 505d |  |
| 1672 |  | Qualification Test Plans for Qualification Wave 4 Participants approved | 0d | 2025-06-20 | 2025-06-20 | 1671 | 505d |  |
| 1673 |  | Qualification Wave 4 Participants have submitted PIT Test Completion Report and evidence for QT entry | 0d | 2025-06-20 | 2025-06-20 |  | 1d | finish no earlier than 2025-06-20 |
| 1674 |  | Review of Participants' PIT Test Completion Report | 29d | 2025-06-23 | 2025-07-31 | 1673 | 1d |  |
| 1675 |  | Onboarding to QTF & ADO | 30d | 2025-06-23 | 2025-08-01 | 1674SS | 1d |  |
| 1676 | 1.6.4.5.3 | **Qualification Wave 4 QT Execution** | 101d | 2025-07-25 | 2025-12-12 |  | 2d |  |
| 1677 |  | Review Entry Criteria Evidence for each Wave 4 Participant | 5d | 2025-07-25 | 2025-07-31 | 1665FF, 1669 | 2d |  |
| 1678 |  | Qualification Test Plans for Qualification Wave 4 Participants approved | 0d | 2025-07-31 | 2025-07-31 | 1669, 1677, 1553, 1554 | 2d |  |
| 1679 |  | Qualification Wave 4 QT Execution Start | 0d | 2025-08-01 | 2025-08-01 | 1678, 1675 | 1d |  |
| 1680 |  | Qualification Wave 4 QT Execution Window | 95d | 2025-08-04 | 2025-12-12 | 1679, 1677 | 6d |  |

| ID | WBS | Task | Duration | Start | Finish | Predecessors | Complete | Total float | Constraint |
| --- | --- | --- | --- | --- | --- | --- | --- | --- | --- |
| 1681 |  | Qualification Wave 4 Projected Execution End | 0d | 2025-12-12 | 2025-12-12 | 1680 |  | 6d |  |
| 1682 | 1.6.4.5.4 | **Qualification Wave 4 Exit** | 150d | 2025-08-01 | 2026-02-27 |  |  | 1d |  |
| 1683 |  | Final QAD Submission window opens | 0d | 2025-08-01 | 2025-08-01 | 1679 |  | 1d |  |
| 1684 |  | Qualification Wave 4 Participants submit their Final QAD | 100d | 2025-08-04 | 2025-12-19 | 1683 |  | 1d |  |
| 1685 |  | Qualification Wave 4 Participants have submitted their Final QAD | 0d | 2025-12-19 | 2025-12-19 | 1684, 1681 |  | 1d |  |
| 1686 |  | Completion of Code Bodies review of Final QAD | 25d | 2025-12-22 | 2026-01-23 | 1685 |  | 1d |  |
| 1687 |  | QAD Sign Off deadline | 1d | 2026-01-30 | 2026-01-30 | 1686FS+4d |  | 1d |  |
| 1688 |  | Qualification Wave 4 Participants Qualification approved by BSC PAB and REC Manager | 0d | 2026-02-27 | 2026-02-27 | 1687FS+20d |  | 1d |  |
| 1689 | 1.7 | **REGULATORY** | 680d | 2022-10-31 A | 2025-06-06 |  | 94% | 515d |  |
| 1690 | 1.7.1 | **Baseline MHHS Code Changes** | 475d | 2022-10-31 A | 2024-08-23 |  | 99% | 720d |  |
| 1691 | 1.7.1.1 | **Preparation and planning** | 35d | 2022-10-31 A | 2022-12-16 A |  | 100% |  |  |
| 1692 |  | Impact assessment of Programme design on codes to determine required changes | 20d | 2022-10-31 A | 2022-11-25 A | 48 | 100% |  |  |
| 1693 |  | Become 'code draft ready' | 35d | 2022-10-31 A | 2022-12-16 A |  | 100% |  |  |
| 1694 |  | Soft start drafting where possible | 35d | 2022-10-31 A | 2022-12-16 A |  | 100% |  |  |
| 1695 | 1.7.1.2 | **Code drafting** | 443d | 2022-12-12 A | 2024-08-21 |  | 99% | 722d |  |
| 1696 | 1.7.1.2.1 | **Data Services (BSC driven)** | 118d | 2022-12-12 A | 2023-05-24 A |  | 100% |  |  |
| 1697 |  | Pre Code Drafting activities | 5d | 2022-12-12 A | 2022-12-16 A |  | 100% |  | start no earlier than 2022-12-12 |
| 1698 |  | Code and subsidiary document drafting takes place offline | 19d | 2023-01-03 A | 2023-01-27 A | 1697FS+11d | 100% |  |  |
| 1699 |  | Internal review and cross-checking of drafting across code drafters | 11d | 2023-01-30 A | 2023-02-13 A | 1698 | 100% |  |  |
| 1700 |  | External industry review via consultation | 20d | 2023-02-14 A | 2023-03-13 A | 1699 | 100% |  |  |
| 1701 |  | Triage and action comments | 19d | 2023-03-10 A | 2023-04-05 A | 1700FS-2d | 100% |  |  |
| 1702 |  | CDWG review | 30d | 2023-04-06 A | 2023-05-17 A | 1701 | 100% |  |  |
| 1703 |  | CCAG review | 5d | 2023-05-18 A | 2023-05-24 A | 1702 | 100% |  |  |
| 1704 |  | Code drafting for Data Services topic area approved | 0d | 2023-05-24 A | 2023-05-24 A | 1703 | 100% |  |  |
| 1705 | 1.7.1.2.2 | **Metering (REC driven)** | 118d | 2022-12-12 A | 2023-05-24 A |  | 100% |  |  |
| 1706 |  | Pre Code Drafting activities | 5d | 2022-12-12 A | 2022-12-16 A | 1697SS | 100% |  |  |
| 1707 |  | Code and subsidiary document drafting takes place offline | 19d | 2023-01-03 A | 2023-01-27 A | 1706FS+11d | 100% |  |  |
| 1708 |  | Internal review and cross-checking of drafting across code drafters | 11d | 2023-01-30 A | 2023-02-13 A | 1707 | 100% |  |  |
| 1709 |  | External industry review via consultation | 20d | 2023-02-14 A | 2023-03-13 A | 1708 | 100% |  |  |
| 1710 |  | Triage and action comments | 19d | 2023-03-10 A | 2023-04-05 A | 1709FS-2d | 100% |  |  |
| 1711 |  | CDWG review | 30d | 2023-04-06 A | 2023-05-17 A | 1710 | 100% |  |  |
| 1712 |  | CCAG review | 5d | 2023-05-18 A | 2023-05-24 A | 1711 | 100% |  |  |
| 1713 |  | Code drafting for Metering topic area approved | 0d | 2023-05-24 A | 2023-05-24 A | 1712 | 100% |  |  |
| 1714 | 1.7.1.2.3 | **BSC Central Services (BSC driven)** | 156d | 2023-02-22 A | 2023-09-27 A |  | 100% |  |  |
| 1715 |  | Pre Code Drafting activities | 5d | 2023-02-22 A | 2023-02-28 A | 1716SS-5d | 100% |  |  |
| 1716 |  | Code Drafting (offline) | 80d | 2023-03-01 A | 2023-06-20 A | 1700SS | 100% |  | must start on 2023-03-01 |
| 1717 |  | Internal review and cross-checking of drafting across code drafters | 70d | 2023-03-15 A | 2023-06-20 A | 1716SS+10d | 100% |  |  |
| 1718 |  | External industry review via consultation | 15d | 2023-06-21 A | 2023-07-11 A | 1717 | 100% |  |  |
| 1719 |  | Triage and action comments | 19d | 2023-07-10 A | 2023-08-03 A | 1718FS-2d | 100% |  |  |
| 1720 |  | CDWG review | 28d | 2023-08-04 A | 2023-09-12 A | 1719 | 100% |  |  |
| 1721 |  | CCAG review | 11d | 2023-09-13 A | 2023-09-27 A | 1720 | 100% |  |  |
| 1722 |  | Code drafting for BSC Central Services topic area approved | 0d | 2023-09-27 A | 2023-09-27 A | 1721 | 100% |  |  |
| 1723 | 1.7.1.2.4 | **Registration (BSC & REC driven)** | 131d | 2023-02-22 A | 2023-08-23 A |  | 100% |  |  |
| 1724 |  | Pre Code Drafting activities | 5d | 2023-02-22 A | 2023-02-28 A | 1725SS-5d | 100% |  |  |
| 1725 |  | Code Drafting (offline) | 65d | 2023-03-01 A | 2023-05-30 A | 1699, 1708 | 100% |  | must start on 2023-03-01 |
| 1726 |  | Internal review and cross-checking of drafting across code drafters | 55d | 2023-03-15 A | 2023-05-30 A | 1725SS+10d | 100% |  |  |
| 1727 |  | External industry review via consultation | 15d | 2023-05-31 A | 2023-06-20 A | 1726 | 100% |  |  |
| 1728 |  | Triage and action comments | 19d | 2023-06-19 A | 2023-07-13 A | 1727FS-2d | 100% |  |  |
| 1729 |  | CDWG review | 18d | 2023-07-14 A | 2023-08-08 A | 1728 | 100% |  |  |
| 1730 |  | CCAG review | 11d | 2023-08-09 A | 2023-08-23 A | 1729 | 100% |  |  |
| 1731 |  | Code drafting for Registration topic area approved | 0d | 2023-08-23 A | 2023-08-23 A | 1730 | 100% |  |  |
| 1732 | 1.7.1.2.5 | **Governance and Qualification (BSC & REC driven)** | 130d | 2023-05-25 A | 2023-11-22 A |  | 100% |  |  |
| 1733 |  | Pre Code Drafting activities | 5d | 2023-05-25 A | 2023-05-31 A | 1734SS-5d | 100% |  |  |
| 1734 |  | Code Drafting (offline) | 55d | 2023-06-01 A | 2023-08-16 A | 1727SS+1d | 100% |  |  |
| 1735 |  | Internal review and cross-checking of drafting across code drafters | 45d | 2023-06-15 A | 2023-08-16 A | 1734SS+10d | 100% |  |  |
| 1736 |  | External industry review via consultation | 15d | 2023-08-18 A | 2023-09-07 A | 1735FS+1d | 100% |  |  |
| 1737 |  | Triage and action comments | 19d | 2023-09-06 A | 2023-10-02 A | 1736FS-2d | 100% |  |  |
| 1738 |  | CDWG review | 31d | 2023-10-03 A | 2023-11-14 A | 1737 | 100% |  |  |
| 1739 |  | CCAG review | 6d | 2023-11-15 A | 2023-11-22 A | 1738 | 100% |  |  |
| 1740 |  | Code drafting for Governance and Qualification topic areas approved | 0d | 2023-11-22 A | 2023-11-22 A | 1739 | 100% |  |  |
| 1741 | 1.7.1.2.6 | **Interfaces / Data Specification (REC driven)** | 174d | 2023-05-25 A | 2024-01-23 A |  | 100% |  |  |
| 1742 |  | Pre Code Drafting activities | 5d | 2023-05-25 A | 2023-05-31 A | 1743SS-5d | 100% |  |  |
| 1743 |  | Code Drafting (offline) | 94d | 2023-06-01 A | 2023-10-10 A | 1727SS+1d | 100% |  |  |
| 1744 |  | Internal review and cross-checking of drafting across code drafters | 84d | 2023-06-15 A | 2023-10-10 A | 1743SS+10d | 100% |  |  |
| 1745 |  | External industry review via consultation | 15d | 2023-10-11 A | 2023-10-31 A | 1744 | 100% |  |  |
| 1746 |  | Triage and action comments | 20d | 2023-10-30 A | 2023-11-24 A | 1745FS-2d | 100% |  |  |
| 1747 |  | CDWG review | 37d | 2023-11-27 A | 2024-01-16 A | 1746 | 100% |  |  |
| 1748 |  | CCAG review | 5d | 2024-01-17 A | 2024-01-23 A | 1747 | 100% |  |  |
| 1749 |  | Code drafting for Interfaces / Data Specification topic areas approved | 0d | 2024-01-23 A | 2024-01-23 A | 1748 | 100% |  |  |
| 1750 | 1.7.1.2.7 | **Migration (BSC & REC driven)** | 130d | 2023-05-25 A | 2023-11-22 A |  | 100% |  |  |

| ID | WBS | Task | Duration | Start | Finish | Predecessors | Complete | Total float | Constraint |
| --- | --- | --- | --- | --- | --- | --- | --- | --- | --- |
| 1751 |  | Pre Code Drafting activities | 5d | 2023-05-25 A | 2023-05-31 A | 1752SS-5d | 100% |  |  |
| 1752 |  | Code Drafting (offline) | 55d | 2023-06-01 A | 2023-08-16 A | 1727SS+1d | 100% |  |  |
| 1753 |  | Internal review and cross-checking of drafting across code drafters | 45d | 2023-06-15 A | 2023-08-16 A | 1752SS+10d | 100% |  |  |
| 1754 |  | External industry review via consultation | 15d | 2023-08-18 A | 2023-09-07 A | 1753FS+1d | 100% |  |  |
| 1755 |  | Triage and action comments | 19d | 2023-09-06 A | 2023-10-02 A | 1754FS-2d | 100% |  |  |
| 1756 |  | CDWG review | 31d | 2023-10-03 A | 2023-11-14 A | 1755 | 100% |  |  |
| 1757 |  | CCAG review | 6d | 2023-11-15 A | 2023-11-22 A | 1756 | 100% |  |  |
| 1758 |  | Code drafting for Migration topic area approved | 0d | 2023-11-22 A | 2023-11-22 A | 1757 | 100% |  |  |
| 1759 | 1.7.1.2.8 | **Consequential Code Change** | 109d | 2023-10-11 A | 2024-03-11 A |  | 100% |  |  |
| 1760 |  | External industry review via consultation - drop 1 (DCUSA) | 15d | 2023-10-11 A | 2023-10-31 A | 1766SS | 100% |  |  |
| 1761 |  | External industry review via consultation - drop 2 (Elexon) | 16d | 2024-02-19 A | 2024-03-11 A | 1776SS | 100% |  | start no earlier than 2024-02-19 |
| 1762 | 1.7.1.2.9 | **Transition Text (all codes)** | 118d | 2023-08-11 A | 2024-01-23 A |  | 100% |  |  |
| 1763 |  | Pre Code Drafting activities | 8d | 2023-08-11 A | 2023-08-22 A | 1764SS-5d | 100% |  |  |
| 1764 |  | Code Drafting (offline) | 38d | 2023-08-18 A | 2023-10-10 A | 1754SS | 100% |  |  |
| 1765 |  | Internal review and cross-checking of drafting across code drafters | 28d | 2023-09-01 A | 2023-10-10 A | 1764SS+10d | 100% |  |  |
| 1766 |  | External industry review via consultation | 15d | 2023-10-11 A | 2023-10-31 A | 1765 | 100% |  |  |
| 1767 |  | Triage and action comments | 20d | 2023-10-30 A | 2023-11-24 A | 1766FS-2d | 100% |  |  |
| 1768 |  | CDWG review | 37d | 2023-11-27 A | 2024-01-16 A | 1767 | 100% |  |  |
| 1769 |  | CCAG review | 5d | 2024-01-17 A | 2024-01-23 A | 1768 | 100% |  |  |
| 1770 |  | Code drafting for Transition Text topic area approved | 0d | 2024-01-23 A | 2024-01-23 A | 1769 | 100% |  |  |
| 1771 | 1.7.1.2.10 | **Final Code Drafting (mop-up) (all codes)** | 199d | 2023-08-18 A | 2024-05-22 A |  | 100% |  |  |
| 1772 |  | Forward look and confirm remaining plan | 15d | 2023-08-18 A | 2023-09-07 A | 1764SS | 100% |  |  |
| 1773 |  | Identify remaining or additional areas of code (e.g. consequential change requirements) to be completed | 15d | 2023-08-18 A | 2023-09-07 A | 1772SS | 100% |  |  |
| 1774 |  | Code Drafting (offline) Interim Consultation (1) | 60d | 2023-09-08 A | 2023-11-30 A | 1773 | 100% |  |  |
| 1775 |  | Internal review and cross-checking of drafting across code drafters Interim Consultation (1) | 50d | 2023-09-22 A | 2023-11-30 A | 1774SS+10d | 100% |  |  |
| 1776 |  | External industry review via consultation Interim Consultation (1) | 23d | 2023-12-01 A | 2024-01-02 A | 1775 | 100% |  |  |
| 1777 |  | Code Drafting (offline) Final Consultation (2) | 55d | 2023-12-01 A | 2024-02-15 A | 1775 | 100% |  |  |
| 1778 |  | Internal review and cross-checking of drafting across code drafters Final Consultation (2) | 45d | 2023-12-15 A | 2024-02-15 A | 1777SS+10d | 100% |  |  |
| 1779 |  | External industry review via consultation Final Consultation (2) | 16d | 2024-02-19 A | 2024-03-11 A | 1778FS+1d | 100% |  |  |
| 1780 |  | Triage and action comments | 18d | 2024-03-11 A | 2024-04-03 A | 1779FS-1d | 100% |  |  |
| 1781 |  | CDWG review | 29d | 2024-04-04 A | 2024-05-14 A | 1780 | 100% |  |  |
| 1782 |  | CCAG review | 6d | 2024-05-15 A | 2024-05-22 A | 1781 | 100% |  |  |
| 1783 |  | Final code drafting (mop-up) approved | 0d | 2024-05-22 A | 2024-05-22 A | 1782 | 100% |  |  |
| 1784 | 1.7.1.2.11 | **Final code review, consistency check and approval** | 100d | 2024-04-04 A | 2024-08-21 |  | 90% | 722d |  |
| 1785 |  | Gap analysis of final code against design artefacts (reverse process to code drafting) | 38d | 2024-04-04 A | 2024-05-27 A | 1781SS | 100% |  |  |
| 1786 |  | Outputs of gap analysis actioned offline | 11d | 2024-05-28 A | 2024-06-11 A | 1785 | 100% |  |  |
| 1787 |  | Final documentation collated for final consultation | 8d | 2024-06-12 A | 2024-06-21 A | 1786 | 100% |  |  |
| 1788 |  | External industry review via consultation | 15d | 2024-06-24 A | 2024-07-12 A | 1787 | 100% |  |  |
| 1789 |  | Triage and action comments | 10d | 2024-07-15 A | 2024-07-26 A | 1788 | 100% |  |  |
| 1790 |  | Final CDWG review | 8d | 2024-08-02 A | 2024-08-13 | 1789FS+4d | 50% | 586d |  |
| 1791 |  | Final CCAG review | 6d | 2024-08-14 | 2024-08-21 | 1790 |  | 586d |  |
| 1792 |  | CCAG recommend final code to PSG for baselining | 0d | 2024-08-21 | 2024-08-21 | 1791 |  | 722d |  |
| 1793 |  | Code changes baselined (M6) | 0d | 2024-08-23 | 2024-08-23 | 1791FS+2d, 1783, 1770, 1758, 1749, 1740, 1731, 1722, 1713, 1704 |  | 586d |  |
| 1794 | 1.7.2 | **Ofgem preparation and enactment of SCR powers** | 201d | 2024-02-05 A | 2024-11-11 |  | 77% | 664d |  |
| 1795 | 1.7.2.1 | **Preparation and enactment of SCR Powers** | 201d | 2024-02-05 A | 2024-11-11 |  | 77% | 664d |  |
| 1796 |  | Ofgem to keep Ofgem legal informed of process followed and nature of Code drafting to ensure that prepared for SCR go/no go decision | 101d | 2024-02-05 A | 2024-06-24 A | 1797SF | 100% |  |  |
| 1797 |  | OFGEM Legal to review Code Artefacts deliver policy intent and process followed and confirm that SCR powers are appropriate to use rather than SMAP - SCR go/no go | 14d | 2024-06-24 A | 2024-07-11 A | 1788SS | 100% |  |  |
| 1798 |  | Code Bodies to draft MOD proposal forms | 20d | 2024-07-12 A | 2024-08-08 A | 1797 | 100% |  |  |
| 1799 |  | Ofgem discuss and agree code mod timetable with code bodies (and MHHSP in relation to the dates for expected decisions) | 20d | 2024-07-12 A | 2024-08-08 A | 1797 | 100% |  |  |
| 1800 |  | Ofgem to draft open letter and direction to each code body specifying the timetable for each modification | 5d | 2024-08-09 A | 2024-08-15 | 1799 | 80% | 726d |  |
| 1801 |  | Ofgem to publish open letter | 1d | 2024-08-26 | 2024-08-26 | 1793, 1798 |  | 586d |  |
| 1802 |  | Ofgem to publish each Direction to each code body specifying the timetable for each modification | 1d | 2024-08-28 | 2024-08-28 | 1801FS+1d |  | 717d |  |
| 1803 |  | Formally submit (by separate email) Modification Proposal Forms and legal texts to each code body | 1d | 2024-08-28 | 2024-08-28 | 1801FS+1d |  | 586d |  |
| 1804 |  | Each Code Body publishes and issues Modification Proposal Forms | 3d | 2024-08-29 | 2024-09-02 | 1803 |  | 586d |  |
| 1805 |  | Each Code Body sends Modification Proposal Forms to Panel to approve Mod to go to consultation | 10d | 2024-09-03 | 2024-09-16 | 1804 |  | 586d |  |
| 1806 |  | Modification Proposal approved by Panel for Consultation | 1d | 2024-09-17 | 2024-09-17 | 1805 |  | 586d |  |
| 1807 |  | Draft Modification Report issued for consultation | 1d | 2024-09-18 | 2024-09-18 | 1806 |  | 586d |  |
| 1808 |  | Consultation Close-out for representations | 15d | 2024-09-19 | 2024-10-09 | 1807 |  | 586d |  |
| 1809 |  | Each Code Body reviews consultation response and drafts Modification Report | 10d | 2024-10-10 | 2024-10-23 | 1808 |  | 586d |  |
| 1810 |  | Final Modification Report sent to Panel for decision with recommendation to approve | 1d | 2024-10-24 | 2024-10-24 | 1809 |  | 586d |  |
| 1811 |  | Modification Panel decision | 1d | 2024-11-07 | 2024-11-07 | 1810FS+9d |  | 586d |  |
| 1812 |  | Panel make recommendation to OFGEM | 1d | 2024-11-11 | 2024-11-11 | 1811FS+1d |  | 586d |  |
| 1813 |  | SCR powers enabled (M7) | 0d | 2024-11-11 | 2024-11-11 | 1793, 1812 |  | 586d |  |
| 1814 | 1.7.3 | **Deliver MHHS Code Changes** | 149d | 2024-11-12 | 2025-06-06 |  |  | 515d |  |
| 1815 | 1.7.3.1 | **Releases** | 149d | 2024-11-12 | 2025-06-06 |  |  | 515d |  |
| 1816 |  | Impacted codes make resourcing provisions and prepare to implement new Code via internal code body change processes | 78d | 2024-11-12 | 2025-02-27 | 1813 |  | 586d |  |
| 1817 | 1.7.3.1.2 | **Main Code Release** | 71d | 2025-02-28 | 2025-06-06 |  |  | 515d |  |
| 1818 |  | Release preparation (e.g. preparing release documentation) | 6d | 2025-02-28 | 2025-03-07 | 1819SF |  | 580d |  |
| 1819 |  | Implement new code on day of code release | 0d | 2025-03-07 | 2025-03-07 | 1820SF |  | 580d |  |
| 1820 |  | Code changes delivered (M8) | 0d | 2025-03-07 | 2025-03-07 | 2084SS, 1813, 1793 |  | 515d |  |

| ID | WBS | Task | Duration | Start | Finish | Predecessors | Complete | Total float | Constraint |
| --- | --- | --- | --- | --- | --- | --- | --- | --- | --- |
| 1821 |  | Code changes delivered (M8*) late exit | 0d | 2025-06-06 | 2025-06-06 | 1820FS+65d |  | 515d |  |
| 1822 | 1.7.4 | **External Programme Dependency Management** | 38d | 2023-12-01 A | 2024-01-24 A |  | 100% |  |  |
| 1823 | 1.7.4.1 | **DCP397** | 38d | 2023-12-01 A | 2024-01-24 A |  | 100% |  |  |
| 1824 |  | Ensure DCP397 drafting included in mop-up code drafting activity (link to mop-up) | 20d | 2023-12-01 A | 2023-12-28 A | 1777SS, 1774SS | 100% |  |  |
| 1825 |  | Implementation of DCP397 | 0d | 2024-01-24 A | 2024-01-24 A |  | 100% |  | start no earlier than 2024-01-24 |
| 1826 | 1.8 | **MIGRATION** | 1091d | 2022-10-31 A | 2027-01-04 |  | 36% | 104d |  |
| 1827 |  | Migration Period Plan Review 1 Completed | 0d | 2025-01-31 | 2025-01-31 |  |  | 605d | finish no earlier than 2025-01-31 |
| 1828 | 1.8.2 | **Regulatory Governance** | 198d | 2024-04-01 A | 2025-01-01 |  | 47% | 627d |  |
| 1829 |  | Incentive Mods Created | 110d | 2024-04-01 A | 2024-08-30 |  | 85% | 627d | start no earlier than 2024-04-01 |
| 1830 |  | Incentives Implemented | 88d | 2024-09-02 | 2025-01-01 | 1829 |  | 627d | start no earlier than 2024-07-02 |
| 1831 | 1.8.3 | **Migration Framework Agreed and Implemented** | 214d | 2024-02-01 A | 2024-11-26 |  | 61% | 653d |  |
| 1832 | 1.8.3.1 | **Consultation 1 - Schedule** | 70d | 2024-02-01 A | 2024-05-08 A |  | 100% |  |  |
| 1833 |  | Prepare Artefacts for Consultation | 33d | 2024-02-01 A | 2024-03-18 A |  | 100% |  |  |
| 1834 |  | Industry Consultation | 16d | 2024-03-18 A | 2024-04-08 A |  | 100% |  |  |
| 1835 |  | Triage and Action Comments | 10d | 2024-04-08 A | 2024-04-19 A |  | 100% |  |  |
| 1836 |  | Industry Assurance Review | 6d | 2024-04-19 A | 2024-04-26 A |  | 100% |  |  |
| 1837 |  | MWG Recommendation | 1d | 2024-04-26 A | 2024-04-26 A |  | 100% |  |  |
| 1838 |  | MCAG Interim Approval Artefacts | 1d | 2024-05-08 A | 2024-05-08 A |  | 100% |  |  |
| 1839 | 1.8.3.2 | **Consultation 2 - Control** | 79d | 2024-04-08 A | 2024-07-25 A |  | 100% |  |  |
| 1840 |  | Prepare Artefacts for Consultation | 49d | 2024-04-08 A | 2024-06-13 A |  | 100% |  |  |
| 1841 |  | Industry Consultation | 11d | 2024-06-14 A | 2024-06-28 A | 1840 | 100% |  |  |
| 1842 |  | Triage and Action Comments | 9d | 2024-07-01 A | 2024-07-11 A | 1841 | 100% |  |  |
| 1843 |  | Industry Assurance Review | 5d | 2024-07-12 A | 2024-07-18 A | 1842 | 100% |  |  |
| 1844 |  | MWG Recommendation | 0d | 2024-07-18 A | 2024-07-18 A | 1843 | 100% |  |  |
| 1845 |  | Consultation 2 - Control - MCAG Approval of Interim Artefacts | 0d | 2024-07-25 A | 2024-07-25 A | 1844FS+5d | 100% |  |  |
| 1846 | 1.8.3.3 | **Consultation 3 - Parameters** | 76d | 2024-07-09 A | 2024-10-22 |  | 35% | 678d |  |
| 1847 |  | Prepare Artefacts (9) for Consultation | 36d | 2024-07-09 A | 2024-08-27 | 1861SS+6d | 61% | 678d |  |
| 1848 |  | Industry Consultation | 10d | 2024-08-28 | 2024-09-10 | 1847 |  | 678d |  |
| 1849 |  | Triage and Action Comments | 10d | 2024-09-11 | 2024-09-24 | 1848 |  | 678d |  |
| 1850 |  | Industry Assurance Review | 7d | 2024-09-25 | 2024-10-03 | 1849 |  | 678d |  |
| 1851 |  | MWG Recommendation | 0d | 2024-10-03 | 2024-10-03 | 1850 |  | 678d |  |
| 1852 |  | MCAG Approval of Migration Framework Artefacts (Baselined) | 0d | 2024-10-22 | 2024-10-22 | 1862, 1851FS+13d |  | 678d |  |
| 1853 | 1.8.3.4 | **Consultation 4 - Test** | 70d | 2024-08-21 | 2024-11-26 |  |  | 585d |  |
| 1854 |  | Prepare Artefacts for Consultation | 37d | 2024-08-21 | 2024-10-10 |  |  | 585d | start no earlier than 2024-08-21 |
| 1855 |  | Industry Consultation | 10d | 2024-10-11 | 2024-10-24 | 1854 |  | 585d |  |
| 1856 |  | Triage and Action Comments | 10d | 2024-10-25 | 2024-11-07 | 1855 |  | 585d |  |
| 1857 |  | Industry Assurance Review | 5d | 2024-11-08 | 2024-11-14 | 1856 |  | 585d |  |
| 1858 |  | MWG Recommendation | 0d | 2024-11-14 | 2024-11-14 | 1857 |  | 585d |  |
| 1859 |  | Consultation 4 - Test - MCAG Approval of Interim Artefacts | 0d | 2024-11-26 | 2024-11-26 | 1858FS+8d, 1862 |  | 585d |  |
| 1860 | 1.8.4 | **Migration Schedule Agreed and Maintained** | 207d | 2024-07-01 A | 2025-04-15 |  | 20% | 553d |  |
| 1861 |  | Indicative Envelopes Issued | 23d | 2024-07-01 A | 2024-07-31 A | 1838FS+37d | 100% |  |  |
| 1862 |  | Supplier Submissions | 45d | 2024-08-01 A | 2024-10-02 | 1861, 1845 | 11% | 573d |  |
| 1863 |  | Team Assess Responses | 10d | 2024-10-03 | 2024-10-16 | 1862 |  | 573d |  |
| 1864 |  | Discuss and Agree Approach with Participants where necessary | 4d | 2024-10-17 | 2024-10-22 | 1863 |  | 573d |  |
| 1865 |  | V1.0 of Migration Schedule Baseline Approved at MCAG | 0d | 2024-10-22 | 2024-10-22 | 1874, 1864 |  | 573d |  |
| 1866 |  | Sprint Planning (Cycle 1) | 20d | 2024-11-20 | 2024-12-17 | 1884, 1865 |  | 553d |  |
| 1867 |  | Sprint Planning (Cycle 2) | 20d | 2025-01-22 | 2025-02-18 | 1866FS+25d |  | 553d |  |
| 1868 |  | Sprint Planning (Cycle 3) | 20d | 2025-03-19 | 2025-04-15 | 1867FS+20d, 1886 |  | 553d |  |
| 1869 | 1.8.5 | **Migration Control Centre Tooling** | 182d | 2024-05-09 A | 2025-01-17 |  | 45% | 594d |  |
| 1870 |  | Data Source Definition | 60d | 2024-05-09 A | 2024-07-31 | 1838 | 92% | 575d |  |
| 1871 |  | Scheduling and Data Requirements | 60d | 2024-05-09 A | 2024-07-31 | 1838 | 92% | 575d |  |
| 1872 |  | Tool Phase 1 | 11d | 2024-08-01 | 2024-08-15 | 1871, 1870 |  | 575d |  |
| 1873 |  | Data Requirements | 21d | 2024-08-16 | 2024-09-13 | 1838, 1872 |  | 575d |  |
| 1874 |  | Tool Phase 2 | 25d | 2024-09-16 | 2024-10-18 | 1873 |  | 575d |  |
| 1875 |  | Data Source Provision | 7d | 2024-10-21 | 2024-10-29 | 1874, 1880 |  | 594d |  |
| 1876 |  | Tool - Internal and External Testing | 58d | 2024-10-30 | 2025-01-17 | 1875 |  | 594d |  |
| 1877 | 1.8.6 | **Data Arrangements** | 88d | 2024-05-09 A | 2024-09-09 |  | 63% | 623d |  |
| 1878 |  | Agree and Ratify Approach | 60d | 2024-05-09 A | 2024-07-31 | 1870SS | 92% | 623d |  |
| 1879 |  | Arrange for Data to be received | 4d | 2024-08-01 | 2024-08-06 | 1878 |  | 623d |  |
| 1880 |  | Test Data Being Received | 24d | 2024-08-07 | 2024-09-09 | 1879 |  | 623d |  |
| 1881 | 1.8.7 | **Migration Control Centre Mobilised and Ready** | 135d | 2024-07-30 A | 2025-02-03 |  | 2% | 584d |  |
| 1882 |  | Migration Control Centre TOM Definition | 29d | 2024-07-30 A | 2024-09-06 | 1845FS+2d | 7% | 553d |  |
| 1883 |  | Access to Data | 25d | 2024-09-13 | 2024-10-17 | 1882FS+4d |  | 553d |  |
| 1884 |  | Migration Control Centre Delegation of Authority | 12d | 2024-11-04 | 2024-11-19 | 1883FS+11d |  | 553d |  |
| 1885 |  | Recruit and Train | 65d | 2024-11-04 | 2025-01-31 | 1884SS |  | 584d |  |
| 1886 |  | Dress Rehearsal | 1d | 2025-02-03 | 2025-02-03 | 1876, 1885, 1890, 1891 |  | 584d |  |
| 1887 | 1.8.8 | **PP's Prepared for Migration** | 154d | 2024-07-01 A | 2025-01-30 |  | 23% | 585d |  |
| 1888 |  | Prep for Envelope Webinar | 26d | 2024-07-01 A | 2024-08-05 A | 1861SS | 100% |  |  |
| 1889 |  | Envelope/Submission Webinar | 1d | 2024-08-05 A | 2024-08-05 A | 1888FF | 100% |  |  |
| 1890 |  | Guides Creation | 45d | 2024-11-29 | 2025-01-30 | 1859FS+2d |  | 585d |  |

| ID | WBS | Task | Duration | Start | Finish | Predecessors | Complete | Total float |
| --- | --- | --- | --- | --- | --- | --- | --- | --- |
| 1891 |  | Support Channels | 45d | 2024-11-29 | 2025-01-30 | 1859FS+2d |  | 585d |
| 1892 | 1.8.9 | **Migration Artefact Development and Publication** | 635d | 2022-10-31 A | 2025-04-04 |  | 78% | 560d |
| 1893 | 1.8.9.1 | **Migration Approach** | 28d | 2022-10-31 A | 2022-12-07 A |  | 100% |  |
| 1894 |  | Option analysis (via MWG and PPIR) and recommendation | 23d | 2022-10-31 A | 2022-11-30 A |  | 100% |  |
| 1895 |  | Migration Approach approved | 0d | 2022-12-07 A | 2022-12-07 A | 1894FS+5d | 100% |  |
| 1896 | 1.8.9.2 | **Migration Design** | 100d | 2022-11-14 A | 2023-03-31 A |  | 100% |  |
| 1897 |  | Review and update existing design artefacts and socialise with participants ahead of MDSG | 10d | 2022-11-14 A | 2022-11-25 A |  | 100% |  |
| 1898 |  | Develop design artefacts and supporting technical documents in line with MDSG | 53d | 2022-11-30 A | 2023-02-10 A | 1897FS+2d | 100% |  |
| 1899 |  | Migration design artefacts issued for consultation | 0d | 2023-02-13 A | 2023-02-13 A | 1898FS+1d | 100% |  |
| 1900 |  | Industry consultation | 5d | 2023-02-14 A | 2023-02-20 A | 1899SS | 100% |  |
| 1901 |  | Review consultation feedback, address comments and update artefacts | 5d | 2023-02-21 A | 2023-02-27 A | 1900 | 100% |  |
| 1902 |  | Internal artefact review and comms preparation | 3d | 2023-02-28 A | 2023-03-02 A | 1901 | 100% |  |
| 1903 |  | Updated Migration Design artefacts issued to PPs for assurance review | 0d | 2023-03-03 A | 2023-03-03 A | 1902FS+1d | 100% |  |
| 1904 |  | Final Migration Design artefacts walkthrough with PPs | 0d | 2023-03-22 A | 2023-03-22 A | 1903FS+13d | 100% |  |
| 1905 |  | Migration Design approved | 0d | 2023-03-31 A | 2023-03-31 A | 1904FS+7d | 100% |  |
| 1906 | 1.8.9.3 | **Transition Design** | 186d | 2023-03-01 A | 2023-11-15 A |  | 100% |  |
| 1907 | 1.8.9.3.1 | **Tranche 1** | 56d | 2023-03-01 A | 2023-05-17 A |  | 100% |  |
| 1908 |  | Develop design artefacts and supporting technical details with participants | 50d | 2023-03-01 A | 2023-05-09 A |  | 100% |  |
| 1909 |  | Issue Material for DAG approval | 1d | 2023-05-10 A | 2023-05-10 A | 1908 | 100% |  |
| 1910 |  | Tranche 1 Transition Design approved | 0d | 2023-05-17 A | 2023-05-17 A | 1909FS+5d | 100% |  |
| 1911 | 1.8.9.3.2 | **Tranche 2** | 130d | 2023-05-18 A | 2023-11-15 A |  | 100% |  |
| 1912 |  | Develop Initial design artefacts and supporting technical details | 76d | 2023-05-18 A | 2023-08-31 A | 1910 | 100% |  |
| 1913 |  | Communicate Initial Design Artefacts with Industry (MTDSG) | 1d | 2023-09-01 A | 2023-09-01 A | 1912 | 100% |  |
| 1914 |  | Host MTDSG | 1d | 2023-09-11 A | 2023-09-11 A | 1913FS+5d | 100% |  |
| 1915 |  | Process MTDSG Feedback and Amend Design Artefacts | 4d | 2023-09-12 A | 2023-09-15 A | 1914 | 100% |  |
| 1916 |  | Communicate Amended Design Artefacts with Industry | 1d | 2023-09-15 A | 2023-09-15 A | 1915FF | 100% |  |
| 1917 |  | Host MTDSG | 1d | 2023-09-26 A | 2023-09-26 A | 1916FS+6d | 100% |  |
| 1918 |  | Make Final Amendments to Design Artefact | 5d | 2023-09-27 A | 2023-10-03 A | 1917 | 100% |  |
| 1919 |  | Request DAG Consultation | 1d | 2023-10-04 A | 2023-10-04 A | 1918 | 100% |  |
| 1920 |  | Consultation Period | 11d | 2023-10-04 A | 2023-10-18 A | 1919SS | 100% |  |
| 1921 |  | Action Consultation Comments | 5d | 2023-10-19 A | 2023-10-25 A | 1920 | 100% |  |
| 1922 |  | Post Consultation Industry Assurance | 5d | 2023-10-26 A | 2023-11-01 A | 1921 | 100% |  |
| 1923 |  | Request DAG Approval | 1d | 2023-11-01 A | 2023-11-01 A | 1922FF | 100% |  |
| 1924 |  | DAG Transition Design Approved | 1d | 2023-11-08 A | 2023-11-08 A | 1923FS+4d | 100% |  |
| 1925 |  | Update Transition Design Admin | 5d | 2023-11-09 A | 2023-11-15 A | 1924 | 100% |  |
| 1926 |  | Tranche 2 Transition Design Baselined | 0d | 2023-11-15 A | 2023-11-15 A | 1925 | 100% |  |
| 1927 | 1.8.9.4 | **Data Assessment Report** | 61d | 2022-12-06 A | 2023-02-28 A |  | 100% |  |
| 1928 |  | Develop document with MWG | 49d | 2022-12-06 A | 2023-02-10 A |  | 100% |  |
| 1929 |  | Artefact review (via TMAG) and updates | 25d | 2023-01-18 A | 2023-02-21 A | 1928FS-18d | 100% |  |
| 1930 |  | Data Assessment Report approved | 0d | 2023-02-28 A | 2023-02-28 A | 1929FS+5d | 100% |  |
| 1931 | 1.8.9.5 | **Migration, Cutover & Data Strategy (incl. Migration Entry Criteria)** | 102d | 2022-12-08 A | 2023-04-28 A |  | 100% |  |
| 1932 |  | Develop document with MWG | 67d | 2022-12-08 A | 2023-03-10 A | 1895 | 100% |  |
| 1933 |  | Artefact review (via TMAG) and updates | 28d | 2023-03-15 A | 2023-04-21 A | 1932FS+2d | 100% |  |
| 1934 |  | Migration, Cutover & Data Strategy approved | 0d | 2023-04-28 A | 2023-04-28 A | 1933FF+5d | 100% |  |
| 1935 | 1.8.9.6 | **Data Cleanse Plan** | 547d | 2023-03-02 A | 2025-04-04 |  | 63% | 560d |
| 1936 |  | Develop document with MWG | 50d | 2023-03-02 A | 2023-05-10 A |  | 100% |  |
| 1937 |  | Artefact review (via TMAG) and updates | 20d | 2023-05-11 A | 2023-06-07 A | 1936 | 100% |  |
| 1938 |  | Data Cleanse Plan approved | 0d | 2023-07-19 A | 2023-07-19 A | 1937FS+30d | 100% |  |
| 1939 |  | Monitor Programme Participant adherence to Data Cleanse Plan | 467d | 2023-06-15 A | 2025-03-28 | 1938 | 64% | 560d |
| 1940 | 1.8.9.6.5 | **MTDs** | 115d | 2024-08-16 | 2025-01-24 |  |  | 610d |
| 1941 | 1.8.9.6.5.1 | **ESME ID** | 90d | 2024-08-16 | 2024-12-20 |  |  | 635d |
| 1942 |  | DCC to extract ESME ID and share with LDSO | 0d | 2024-08-16 | 2024-08-16 | 1938FS+282d |  | 635d |
| 1943 |  | LDSO ‘full refresh’ between their Registration Service and the EES (ESME ID) | 16d | 2024-10-21 | 2024-11-11 | 1942FS+45d |  | 635d |
| 1944 |  | Suppliers complete investigation of exceptions and resolution of exceptions | 1d | 2024-12-20 | 2024-12-20 | 1943FS+28d |  | 635d |
| 1945 |  | ESME ID Complete | 0d | 2024-12-20 | 2024-12-20 | 1944 |  | 635d |
| 1946 | 1.8.9.6.5.2 | **Meter Location and Number of Displayed Register Digits** | 96d | 2024-09-13 | 2025-01-24 |  |  | 610d |
| 1947 |  | MEM to extract data and share with LDSO | 1d | 2024-09-13 | 2024-09-13 | 1938FS+301d |  | 610d |
| 1948 |  | LDSO ‘full refresh’ between their Registration Service and the EES (Meter Location and Number of Displayed Register Digits) | 16d | 2024-10-21 | 2024-11-11 | 1947FS+25d |  | 610d |
| 1949 |  | Suppliers complete investigation of exceptions and resolution of exceptions | 1d | 2025-01-24 | 2025-01-24 | 1948FS+53d |  | 610d |
| 1950 |  | Meter Location and Number of Displayed Register Digits Complete | 0d | 2025-01-24 | 2025-01-24 | 1949 |  | 610d |
| 1951 | 1.8.9.6.6 | **Registration Data** | 147d | 2024-09-06 | 2025-03-31 |  |  | 564d |
| 1952 | 1.8.9.6.6.1 | **Connection Type** | 47d | 2024-09-06 | 2024-11-11 |  |  | 664d |
| 1953 |  | Automated Population of Connection Type for Measurement Classes ‘B’, ‘D’, ‘F’ & ‘G’ | 0d | 2024-10-04 | 2024-10-04 | 1938FS+317d |  | 690d |
| 1954 |  | BAU Population of Connection Type for Site Specific LLFCs within Measurement Classes ‘C’ & ‘E’ | 0d | 2024-10-04 | 2024-10-04 | 1938FS+317d |  | 690d |
| 1955 |  | Automated Population of Connection Type for Smart Meters within Measurement Class ‘A’ | 0d | 2024-10-04 | 2024-10-04 | 1938FS+317d |  | 690d |
| 1956 |  | Population of Connection Type for Traditional and Advanced Meters within Measurement Class ‘A’ | 1d | 2024-09-06 | 2024-09-06 | 1938FS+296d |  | 710d |
| 1957 |  | Automated Population of Null Connection Type | 0d | 2024-10-04 | 2024-10-04 | 1938FS+317d |  | 690d |
| 1958 |  | Full MPAN refresh to ESS | 16d | 2024-10-21 | 2024-11-11 | 1938FS+327d |  | 664d |
| 1959 |  | Connection Type Complete | 0d | 2024-11-11 | 2024-11-11 | 1953, 1954, 1955, 1956, 1957, 1958 |  | 664d |
| 1960 | 1.8.9.6.6.2 | **Domestic Premises Indicator** | 17d | 2025-03-07 | 2025-03-31 |  |  | 564d |

| ID | WBS | Task | Duration | Start | Finish | Predecessors | Complete | Total float | Constraint |
| --- | --- | --- | --- | --- | --- | --- | --- | --- | --- |
| 1961 |  | The DCC to extract Domestic Premises Indicator from the CSS and provide a file to each LDSO and EES. | 1d | 2025-03-07 | 2025-03-07 | 1938FS+426d |  | 564d |  |
| 1962 |  | Each LDSO notifies the DCC of any exceptions | 1d | 2025-03-07 | 2025-03-07 | 1938FS+426d |  | 564d |  |
| 1963 |  | Each LDSO and DCC completes investigation and resolution of exceptions | 1d | 2025-03-31 | 2025-03-31 | 1961FS+15d, 1962FS+15d |  | 564d |  |
| 1964 |  | Domestic Premises Indicator Complete | 0d | 2025-03-31 | 2025-03-31 | 1963 |  | 564d |  |
| 1965 | 1.8.9.6.7 | **Export / Import MPANs** | 151d | 2024-03-22 A | 2024-10-18 |  | 67% | 680d |  |
| 1966 | 1.8.9.6.7.1 | **Linking of Export / Import MPANS** | 151d | 2024-03-22 A | 2024-10-18 |  | 67% | 680d |  |
| 1967 |  | LDSO utilises BAU processing (DB05s) to populate each import/export association | 1d | 2024-03-22 A | 2024-03-22 A | 1938FS+176d | 100% |  |  |
| 1968 |  | Each LDSO notifies the Registered Supplier of any exceptions | 1d | 2024-04-19 A | 2024-04-19 A | 1967FS+19d | 100% |  |  |
| 1969 |  | Each Supplier completes investigation and resolution of exceptions | 1d | 2024-08-23 | 2024-08-23 | 1968FS+89d |  | 680d |  |
| 1970 |  | Each LDSO has linked al relevant import/export MPANS | 0d | 2024-10-18 | 2024-10-18 | 1969FS+40d |  | 680d |  |
| 1971 |  | Linking of Export / Import MPANS Complete | 0d | 2024-10-18 | 2024-10-18 | 1970 |  | 680d |  |
| 1972 |  | Pre-migration data cleanse complete | 0d | 2025-04-04 | 2025-04-04 | 2088FS-20d, 2090FS-20d, 1939FS+5d, 1945, 1950, 1959, 1964, 1971 |  | 560d |  |
| 1973 | 1.8.10 | **Migration Period Planning** | 367d | 2023-07-03 A | 2024-11-26 |  | 77% | 529d |  |
| 1974 | 1.8.10.1 | **Migration Implementation Plan (incl. Migration Exit Criteria)** | 367d | 2023-07-03 A | 2024-11-26 |  | 77% | 529d |  |
| 1975 | 1.8.10.1.1 | **Migration Threshold Volumes** | 101d | 2023-07-03 A | 2023-11-20 A |  | 100% |  |  |
| 1976 |  | Threshold volumes reviewed by MWG | 54d | 2023-07-03 A | 2023-09-14 A |  | 100% |  |  |
| 1977 |  | Artefact review (via TMAG) and updates | 47d | 2023-09-15 A | 2023-11-20 A | 1976 | 100% |  |  |
| 1978 |  | Threshold volumes approved at TMAG | 0d | 2023-11-20 A | 2023-11-20 A | 1977 | 100% |  |  |
| 1979 | 1.8.10.1.2 | **Define acceptance criteria for M15** | 78d | 2023-09-04 A | 2023-12-20 A |  | 100% |  |  |
| 1980 |  | Review acceptance criteria and reporting requirements with MWG | 49d | 2023-09-04 A | 2023-11-09 A |  | 100% |  | start no earlier than 2023-09-04 |
| 1981 |  | Artefact review (via TMAG) and updates | 29d | 2023-11-10 A | 2023-12-20 A | 1980 | 100% |  | start no earlier than 2023-10-30 |
| 1982 |  | Acceptance criteria for M15 agreed at TMAG | 0d | 2023-12-20 A | 2023-12-20 A | 1981 | 100% |  | finish no earlier than 2023-11-30 |
| 1983 | 1.8.10.1.3 | **M10/M11 cut-over plan** | 119d | 2023-12-21 A | 2024-06-04 A |  | 100% |  |  |
| 1984 |  | Draft Document | 84d | 2023-12-21 A | 2024-04-16 A | 1982 | 100% |  |  |
| 1985 |  | Share Document with SRO | 1d | 2024-04-17 A | 2024-04-17 A | 1984 | 100% |  |  |
| 1986 |  | Industry Consultation | 11d | 2024-04-23 A | 2024-05-07 A | 1985FS+3d | 100% |  |  |
| 1987 |  | Assurance Meeting | 1d | 2024-05-21 A | 2024-05-21 A | 1986FS+9d | 100% |  |  |
| 1988 |  | MCAG Approval of M10/M11 Cut-over Plan | 0d | 2024-06-04 A | 2024-06-04 A | 1987FS+10d | 100% |  |  |
| 1989 | 1.8.10.1.4 | **M15/M16 cut-over plan** | 105d | 2024-06-05 A | 2024-10-29 |  | 52% | 504d |  |
| 1990 |  | Draft Document | 75d | 2024-06-05 A | 2024-09-17 | 1988 | 61% | 504d |  |
| 1991 |  | Share Document with SRO | 1d | 2024-09-18 | 2024-09-18 | 1990 |  | 504d |  |
| 1992 |  | Industry Consultation | 11d | 2024-09-24 | 2024-10-08 | 1991FS+3d |  | 504d |  |
| 1993 |  | Assurance Meeting | 1d | 2024-10-22 | 2024-10-22 | 1992FS+9d |  | 504d |  |
| 1994 |  | Approval of M15/M16 cut-over plan | 0d | 2024-10-29 | 2024-10-29 | 1993FS+5d |  | 504d |  |
| 1995 | 1.8.10.1.5 | **M16 Methodology** | 85d | 2024-07-31 A | 2024-11-26 |  | 10% | 529d |  |
| 1996 |  | Draft Document | 50d | 2024-07-31 A | 2024-10-08 | 1990SS+40d | 12% | 529d |  |
| 1997 |  | Share Document with SRO | 1d | 2024-10-09 | 2024-10-09 | 1996 |  | 529d |  |
| 1998 |  | Industry Consultation | 11d | 2024-10-15 | 2024-10-29 | 1997FS+3d |  | 529d |  |
| 1999 |  | Assurance Meeting | 1d | 2024-11-12 | 2024-11-12 | 1998FS+9d |  | 529d |  |
| 2000 |  | M16 methodology approved | 0d | 2024-11-26 | 2024-11-26 | 1999FS+10d |  | 529d |  |
| 2001 | 1.8.11 | **Go-Live Dress Rehearsals** | 114d | 2024-09-30 | 2025-03-06 |  |  | 581d |  |
| 2002 |  | Define dress rehearsal scenarios (incl. engagement with MWG) | 20d | 2024-09-30 | 2024-10-25 | 2088FS-135d, 2090FS-135d |  | 675d |  |
| 2003 |  | Set up, coordinate and conduct dress rehearsals | 9d | 2025-02-10 | 2025-02-20 | 1073 |  | 581d |  |
| 2004 |  | Evaluate dress rehearsals and identify lessons learned | 10d | 2025-02-21 | 2025-03-06 | 2003 |  | 581d |  |
| 2005 | 1.8.12 | **Preparation for Cutover to Live** | 635d | 2022-10-31 A | 2025-04-04 |  |  | 0d |  |
| 2006 | 1.8.12.1 | **Central Systems Prepare for Cutover to Live** | 620d | 2022-10-31 A | 2025-03-14 |  |  | 11d |  |
| 2007 |  | DCC (Functionality available June 2024) | 0d | 2024-06-28 A | 2024-06-28 A |  | 100% |  | start no earlier than 2024-06-28 |
| 2008 | 1.8.12.1.2 | **Development of Comms Approach and Declaration Guidance** | 79d | 2024-10-01 | 2025-01-17 |  |  | 35d |  |
| 2009 |  | Draft Cutover Comms Approach | 59d | 2024-10-01 | 2024-12-20 | 1988FS+84d |  | 35d |  |
| 2010 |  | Draft Cutover Comms Approach shared | 0d | 2024-12-20 | 2024-12-20 | 2009 |  | 35d |  |
| 2011 |  | Development of Implementation Group | 59d | 2024-10-01 | 2024-12-20 | 1988FS+84d |  | 35d |  |
| 2012 |  | Implementation Group Established | 0d | 2024-12-20 | 2024-12-20 | 2011 |  | 35d |  |
| 2013 |  | Finalised Cutover Comms Approach shared | 0d | 2025-01-17 | 2025-01-17 | 2010FS+20d, 2012FS+20d |  | 35d |  |
| 2014 | 1.8.12.1.3 | **Development of Cutover Plan requirements with Participants** | 113d | 2024-10-01 | 2025-03-06 |  |  | 1d |  |
| 2015 |  | Development of SIT Participant Cutover Plans | 59d | 2024-10-01 | 2024-12-20 | 1988FS+84d |  | 1d |  |
| 2016 |  | SIT Participant Cutover Plans Ready | 0d | 2024-12-20 | 2024-12-20 | 2015 |  | 1d |  |
| 2017 |  | Programme SIT Participant Cutover Plan Assurance | 44d | 2025-01-06 | 2025-03-06 | 2016FS+10d |  | 1d |  |
| 2018 | 1.8.12.1.4 | **M10/M11 Cutover Activities** | 620d | 2022-10-31 | 2025-03-14 |  |  | 11d |  |
| 2019 |  | Production DIP Portal (DIP Deployment) | 0d | 2025-02-21 | 2025-02-21 | 1073FS+10d |  | 7d |  |
| 2020 |  | Production Certificates (DIP Deployment) | 0d | 2025-02-21 | 2025-02-21 | 1073FS+10d |  | 7d |  |
| 2021 |  | Completion of the MHHS Data Cleanse | 0d | 2025-02-26 | 2025-02-26 | 1938FS+420d |  | 2d |  |
| 2022 |  | Market-wide Participant MHHS Supporting Functionality Ready - Confirmation from Code Bodies | 0d | 2025-03-03 | 2025-03-03 | 1905FS+501d |  | -3d |  |
| 2023 |  | Market-wide Participant MHHS Supporting Functionality Ready | 0d | 2025-03-07 | 2025-03-07 | 2022FS+4d |  | -3d |  |
| 2024 |  | Elexon Central Services Deployment | 0d | 2025-03-07 | 2025-03-07 | 2043 |  | -3d |  |
| 2025 |  | Service Management Go-Live | 0d | 2025-03-07 | 2025-03-07 | 2043 |  | -3d |  |
| 2026 |  | Data Transfer Service (DTS) New Functionality Deployment | 0d | 2025-03-07 | 2025-03-07 | 2043 |  | -3d |  |
| 2027 |  | Electricity Enquiry Service (EES) Deployment | 0d | 2025-03-07 | 2025-03-07 | 2043 |  | -3d |  |
| 2028 |  | MPRS, UMSO Role, LDSO Role Operational | 0d | 2025-03-07 | 2025-03-07 | 2043 |  | -3d |  |
| 2029 |  | Population of Domestic Premises Indicator | 0d | 2025-03-07 | 2025-03-07 | 2043 |  | -3d |  |
| 2030 |  | Population of Market Segment | 0d | 2025-03-07 | 2025-03-07 | 2043 |  | -3d |  |

| ID | WBS | Task | Duration | Start | Finish | Predecessors | Complete | Total float | Constraint |
| --- | --- | --- | --- | --- | --- | --- | --- | --- | --- |
| 2031 |  | Early Life Support Implemented | 0d | 2025-03-07 | 2025-03-07 | 2107FS+158d |  | 0d |  |
| 2032 |  | MCC Tested and Ready to Operate | 0d | 2022-10-31 | 2022-10-31 |  |  | 615d |  |
| 2033 |  | MCC Operational | 0d | 2022-10-31 | 2022-10-31 | 2032 |  | 615d |  |
| 2034 |  | Central Systems live and Codes designated at 00:00 | 0d | 2025-03-10 | 2025-03-10 | 2023FS+1d, 2024FS+1d, 2025FS+1d, 2026FS+1d, 2027FS+1d, 2028FS+1d, 2029FS+1d, 2030FS+1d, 2007FS+1d |  | -3d |  |
| 2035 |  | SIT Participant Qualification - The final date by which participant qualification status can be confirmed for participants to be ready for the start of Migration at M11. | 0d | 2025-03-14 | 2025-03-14 | 1073FS+25d |  | 11d |  |
| 2036 | 1.8.12.2 | **Cutover Governance** | 27d | 2025-02-26 | 2025-04-04 |  |  | 0d |  |
| 2037 |  | Confirmation that Pre-migration Data Cleanse Activities have successfully taken place | 0d | 2025-02-26 | 2025-02-26 | 2021 |  | 2d |  |
| 2038 |  | Confirmation of Qualification Status for SIT MVC | 0d | 2025-03-03 | 2025-03-03 | 1073FS+16d |  | -3d |  |
| 2039 |  | Confirmation of Qualification Status for Non-SIT LDSOs | 0d | 2025-03-03 | 2025-03-03 | 1331FS+6d |  | -3d |  |
| 2040 |  | Confirmation of Qualification Status of at least one Supplier and their contracted Agents | 0d | 2025-03-03 | 2025-03-03 | 2038 |  | -3d |  |
| 2041 |  | Declaration from all Central Services and LDSOs that they are in a position to move forwards | 0d | 2025-03-03 | 2025-03-03 | 1073, 1331FS+6d |  | -1d |  |
| 2042 |  | TORWG (Recommendation from TORWG that the Programme should enter M10) | 0d | 2025-03-05 | 2025-03-05 | 2037, 2038FS+2d, 2039FS+2d, 2040FS+2d, 2041 |  | -3d |  |
| 2043 |  | MCAG (Confirm that the Programme can Enter M10) | 0d | 2025-03-07 | 2025-03-07 | 2019, 2020, 2042FS+2d |  | -3d |  |
| 2044 |  | Self-Declaration from all Central Services and LDSOs that Cutover activities have been successfully carried out | 0d | 2025-03-10 | 2025-03-10 | 2043FS+1d |  | 0d |  |
| 2045 |  | Confirmation that DIP and ECS have been deployed, Service management is active, ISD has been populated | 0d | 2025-03-10 | 2025-03-10 | 2043FS+1d |  | 0d |  |
| 2046 |  | Self-Declarations against all M10 Data Cleanse Activities | 0d | 2025-03-10 | 2025-03-10 | 2043FS+1d |  | 0d |  |
| 2047 |  | IF-047 has been sent | 0d | 2025-03-10 | 2025-03-10 | 2043FS+1d |  | 0d |  |
| 2048 |  | Recommendation from TORWG that PSG should approve M10 | 0d | 2025-03-11 | 2025-03-11 | 2044FS+1d, 2045FS+1d, 2046FS+1d, 2047FS+1d |  | 0d |  |
| 2049 |  | PSG (OFGEM and PSG to Approve That Conditions of M10 and M13 Have Been Met) | 0d | 2025-03-12 | 2025-03-12 | 2048FS+1d |  | 0d |  |
| 2050 |  | Confirmation of Qualified Parties from Code Bodies | 11d | 2025-03-14 | 2025-03-28 | 2049FS+1d |  | 0d |  |
| 2051 |  | Self-Declaration that MHHS Functionality will be deployed to Production by Qualified parties | 0d | 2025-03-28 | 2025-03-28 | 2049FS+12d |  | 0d |  |
| 2052 |  | Production Service Activation Activities have taken place | 0d | 2025-03-28 | 2025-03-28 | 2049FS+12d |  | 0d |  |
| 2053 |  | TORWG (Confirmation of Qualified Parties from TORWG) | 0d | 2025-03-31 | 2025-03-31 | 2050FS+1d, 2051FS+1d, 2052FS+1d, 2035 |  | 0d |  |
| 2054 |  | MCAG (Provide recommendation to PSG on M11 decision) | 0d | 2025-04-02 | 2025-04-02 | 2053FS+2d |  | 0d |  |
| 2055 |  | PSG (OFGEM and PSG Decision to Confirm M11 and M12) | 0d | 2025-04-04 | 2025-04-04 | 2054FS+2d |  | 0d |  |
| 2056 | 1.8.13 | **UMS / Advanced Migration** | 391d | 2025-04-04 | 2026-10-02 |  |  | 1d |  |
| 2057 |  | SIT MVC UMS / Advanced Migration | 391d | 2025-04-04 | 2026-10-02 | 2114 |  | 1d |  |
| 2058 |  | SIT Non-MVC UMS / Advanced Migration | 326d | 2025-07-04 | 2026-10-02 | 2117 |  | 1d |  |
| 2059 |  | Wave 1 UMS / Advanced Migration | 261d | 2025-10-03 | 2026-10-02 | 2120 |  | 1d |  |
| 2060 |  | Wave 2 UMS / Advanced Migration | 216d | 2025-12-05 | 2026-10-02 | 2123 |  | 1d |  |
| 2061 |  | Wave 3 UMS / Advanced Migration | 181d | 2026-01-23 | 2026-10-02 | 2126 |  | 1d |  |
| 2062 |  | Wave 4 UMS / Advanced Migration | 131d | 2026-04-03 | 2026-10-02 | 2129 |  | 1d |  |
| 2063 | 1.8.14 | **Smart / Non-Smart Migration** | 391d | 2025-04-04 | 2026-10-02 |  |  | 1d |  |
| 2064 |  | SIT MVC Smart / Non-Smart Migration | 391d | 2025-04-04 | 2026-10-02 | 2114 |  | 1d |  |
| 2065 |  | SIT Non-MVC Smart / Non-Smart Migration | 326d | 2025-07-04 | 2026-10-02 | 2117 |  | 1d |  |
| 2066 |  | Wave 1 Smart / Non-Smart Migration | 261d | 2025-10-03 | 2026-10-02 | 2120 |  | 1d |  |
| 2067 |  | Wave 2 Smart / Non-Smart Migration | 216d | 2025-12-05 | 2026-10-02 | 2123 |  | 1d |  |
| 2068 |  | Wave 3 Smart / Non-Smart Migration | 181d | 2026-01-23 | 2026-10-02 | 2126 |  | 1d |  |
| 2069 |  | Wave 4 Smart / Non-Smart Migration | 131d | 2026-04-03 | 2026-10-02 | 2129 |  | 1d |  |
| 2070 | 1.8.15 | **External Programme Dependency Management** | 713d | 2022-10-31 A | 2025-07-23 |  | 66% | 482d |  |
| 2071 | 1.8.15.1 | **BSC Mod P432 & REC CP R0015** | 392d | 2022-10-31 A | 2024-04-30 A |  | 100% |  |  |
| 2072 |  | MHHSP engagement with BSCCo until Ofgem decision | 316d | 2022-10-31 A | 2024-01-15 A |  | 100% |  |  |
| 2073 |  | Monitor progress and await implementation date | 76d | 2024-01-16 A | 2024-04-30 A | 2072 | 100% |  |  |
| 2074 | 1.8.15.2 | **BSC Mod P434** | 713d | 2022-10-31 A | 2025-07-23 |  | 57% | 482d |  |
| 2075 |  | MHHSP engagement with BSCCo until Ofgem decision | 61d | 2022-10-31 A | 2023-01-23 A |  | 100% |  |  |
| 2076 |  | Monitor progress and await implementation date | 652d | 2023-01-24 A | 2025-07-23 | 2075 | 52% | 482d |  |
| 2077 | 1.8.15.3 | **Elexon System Capacity Upgrade** | 697d | 2022-10-31 A | 2025-07-01 |  | 58% | 498d |  |
| 2078 |  | Monitor progress to implementation | 697d | 2022-10-31 A | 2025-07-01 |  | 58% | 498d |  |
| 2079 |  | Implementation date | 0d | 2025-07-01 | 2025-07-01 | 2078 |  | 498d |  |
| 2080 | 1.8.15.4 | **DCC System Capacity Upgrade** | 25d | 2025-01-08 | 2025-02-11 |  |  | 598d |  |
| 2081 |  | Assurance of DCC capacity upgrade to ensure suitability to support migration | 20d | 2025-01-08 | 2025-02-04 | 2084FF-23d |  | 598d |  |
| 2082 |  | DCC Capacity Upgrade Operational | 0d | 2025-02-11 | 2025-02-11 | 2081FS+5d |  | 598d |  |
| 2083 | 1.8.16 | **Migration - Tier 1 Milestones** | 476d | 2025-03-07 | 2027-01-04 |  |  | 0d |  |
| 2084 |  | Central systems ready for migrating MPANs (M10) | 0d | 2025-03-07 | 2025-03-07 | 1073FS+20d, 2132, 2034FS+2d, 2031, 2043, 2033, 2013, 2017 |  | -3d | must finish on 2025-03-07 |
| 2085 |  | Central systems ready for migrating MPANs (M10*) - Late Exit | 0d | 2025-06-06 | 2025-06-06 | 2084FS+65d |  | 515d |  |
| 2086 |  | Load Shaping Service switched on (M13) | 0d | 2025-03-07 | 2025-03-07 | 2084 |  | 20d |  |
| 2087 |  | Load Shaping Service switched on (M13*) - Late Exit | 0d | 2025-06-06 | 2025-06-06 | 2086FS+65d |  | 515d |  |
| 2088 |  | Start of 18-month migration for UMS / Advanced (M11) | 0d | 2025-04-04 | 2025-04-04 | 2084FS+15d, 2086, 2114, 2054, 2055 |  | 0d |  |
| 2089 |  | Start of 18-month migration for UMS / Advanced (M11*) - Late Exit | 0d | 2025-07-04 | 2025-07-04 | 2088FS+65d |  | 495d |  |
| 2090 |  | Start of 18-month migration for Smart / Non-smart (M12) | 0d | 2025-04-04 | 2025-04-04 | 2084FS+20d, 2086 |  | 495d |  |
| 2091 |  | Start of 18-month migration for Smart / Non-smart (M12*) - Late Exit | 0d | 2025-07-04 | 2025-07-04 | 2090FS+65d |  | 495d |  |
| 2092 |  | All suppliers must be able to access MPANs under the new TOM (M14) | 0d | 2026-03-12 | 2026-03-12 |  |  | 0d | must start on 2026-03-12 |
| 2093 |  | All suppliers must be able to access MPANs under the new TOM (M14*) - Late Exit | 0d | 2026-06-12 | 2026-06-12 | 2092FS+66d |  | 250d |  |
| 2094 |  | Full transition complete (M15) | 0d | 2026-10-02 | 2026-10-02 | 2057, 2058, 2059, 2060, 2061, 2062, 2064, 2065, 2066, 2067, 2068, 2069, 1994 |  | 1d |  |
| 2095 |  | Full transition complete (M15*) - Late Exit | 0d | 2027-01-04 | 2027-01-04 | 2094FS+66d |  | 104d |  |
| 2096 | 1.9 | **BUSINESS & OPERATIONAL READINESS** | 1195d | 2022-10-31 A | 2027-05-28 |  | 8% | 0d |  |
| 2097 | 1.9.1 | **Service Management** | 839d | 2023-09-19 A | 2026-12-04 |  | 26% | 125d |  |
| 2098 | 1.9.1.1 | **Service Management Strategy** | 116d | 2023-09-19 A | 2024-02-27 A |  | 100% |  |  |
| 2099 |  | Develop document with relevant participants (incl. review of the design baseline to ensure service management arrangements are in place across the solution architecture) | 84d | 2023-09-19 A | 2024-01-12 A |  | 100% |  | start no earlier than 2023-09-19 |
| 2100 |  | Artefact review (via relevant Advisory Group) and updates | 31d | 2024-01-15 A | 2024-02-26 A | 2099 | 100% |  |  |

| ID | WBS | Task | Duration | Start | Finish | Predecessors | Complete | Total float | Constraint |
| --- | --- | --- | --- | --- | --- | --- | --- | --- | --- |
| 2101 |  | Service Management Strategy approved | 0d | 2024-02-27 A | 2024-02-27 A | 2100FS+1d | 100% |  |  |
| 2102 | 1.9.1.2 | **Early Life Support Model** | 110d | 2024-02-28 A | 2024-07-30 |  | 82% | 0d |  |
| 2103 |  | Draft Document | 74d | 2024-02-28 A | 2024-06-10 | 2101 | 96% | 0d |  |
| 2104 |  | Share document with SRO | 1d | 2024-06-11 | 2024-06-11 | 2103 |  | 0d |  |
| 2105 |  | Industry Consultation | 11d | 2024-06-18 | 2024-07-02 | 2104FS+4d |  | 0d |  |
| 2106 |  | Assurance Meeting | 1d | 2024-07-16 | 2024-07-16 | 2105FS+9d |  | 0d |  |
| 2107 |  | MCAG Approval of Early Life Support Model | 0d | 2024-07-30 | 2024-07-30 | 2106FS+10d |  | 0d |  |
| 2108 | 1.9.1.3 | **Service Management Arrangements Implementation** | 455d | 2025-03-10 | 2026-12-04 |  |  | 125d |  |
| 2109 |  | Hypercare post M10 | 80d | 2025-03-10 | 2025-06-27 | 2084 |  | 500d |  |
| 2110 |  | Monitor Elexon implementation of Service Management arrangements | 436d | 2025-04-04 | 2026-12-04 | 2057SS, 2064SS |  | 125d |  |
| 2111 | 1.9.2 | **Service Activation** | 894d | 2022-10-31 | 2026-04-02 |  |  | 301d |  |
| 2112 |  | Helix Preparatory Activities Complete | 0d | 2022-10-31 | 2022-10-31 |  |  | 1195d |  |
| 2113 |  | MHHSP Confirms SIT MVC PPs MHHS Enabled | 1d | 2022-10-31 | 2022-10-31 |  |  | 610d |  |
| 2114 |  | SIT MVC Service Activation | 24d | 2025-03-03 | 2025-04-03 | 1404SS, 2113 |  | 1d |  |
| 2115 |  | Helix Preparatory Activities Complete | 0d | 2022-10-31 | 2022-10-31 |  |  | 1195d |  |
| 2116 |  | MHHSP Confirms SIT Non-MVC PPs MHHS Enabled | 1d | 2022-10-31 | 2022-10-31 |  |  | 675d |  |
| 2117 |  | SIT Non-MVC Service Activation | 24d | 2025-06-02 | 2025-07-03 | 1410SS, 2116 |  | 1d |  |
| 2118 |  | Helix Preparatory Activities Complete | 0d | 2022-10-31 | 2022-10-31 |  |  | 1195d |  |
| 2119 |  | MHHSP Confirms Wave 1 PPs MHHS Enabled | 1d | 2022-10-31 | 2022-10-31 |  |  | 740d |  |
| 2120 |  | Wave 1 Service Activation | 24d | 2025-09-01 | 2025-10-02 | 1598, 2119 |  | 1d |  |
| 2121 |  | Helix Preparatory Activities Complete | 0d | 2022-10-31 | 2022-10-31 |  |  | 1195d |  |
| 2122 |  | MHHSP Confirms Wave 2 PPs MHHS Enabled | 1d | 2022-10-31 | 2022-10-31 |  |  | 785d |  |
| 2123 |  | Wave 2 Service Activation | 24d | 2025-11-03 | 2025-12-04 | 1628, 2122 |  | 1d |  |
| 2124 |  | Helix Preparatory Activities Complete | 0d | 2022-10-31 | 2022-10-31 |  |  | 1195d |  |
| 2125 |  | MHHSP Confirms Wave 3 PPs MHHS Enabled | 1d | 2022-10-31 | 2022-10-31 |  |  | 820d |  |
| 2126 |  | Wave 3 Service Activation | 24d | 2025-12-22 | 2026-01-22 | 1658, 2125 |  | 1d |  |
| 2127 |  | Helix Preparatory Activities Complete | 0d | 2022-10-31 | 2022-10-31 |  |  | 1195d |  |
| 2128 |  | MHHSP Confirms Wave 4 PPs MHHS Enabled | 1d | 2022-10-31 | 2022-10-31 |  |  | 870d |  |
| 2129 |  | Wave 4 Service Activation | 24d | 2026-03-02 | 2026-04-02 | 1688, 2128 |  | 1d |  |
| 2130 |  | Helix Preparatory Activities Complete | 0d | 2022-10-31 | 2022-10-31 |  |  | 1195d |  |
| 2131 |  | MHHSP Confirms Non-SIT LDSO PPs MHHS Enabled | 1d | 2022-10-31 | 2022-10-31 |  |  | 605d |  |
| 2132 |  | Non-SIT LDSO Service Activation | 9d | 2025-02-24 | 2025-03-06 | 1331, 2131 |  | 1d |  |
| 2133 | 1.9.3 | **Implement Early Life Support Plan** | 45d | 2025-01-06 | 2025-03-07 |  |  | 580d |  |
| 2134 |  | Implement Early Life Support Plan | 45d | 2025-01-06 | 2025-03-07 | 2107 |  | 580d | start no earlier than 2025-01-06 |
| 2135 | 1.9.4 | **Business Continuity and Disaster Recovery Plan** | 40d | 2025-01-13 | 2025-03-07 |  |  | 580d |  |
| 2136 |  | Central Parties BCDRs in Place | 20d | 2025-01-13 | 2025-02-07 | 1820FS-40d |  | 580d |  |
| 2137 |  | Risk Based Assurance of Cental Party BCDRs | 20d | 2025-02-10 | 2025-03-07 | 2136 |  | 580d |  |
| 2138 | 1.9.5 | **Training and Support Materials** | 39d | 2025-02-03 | 2025-03-27 |  |  | 566d |  |
| 2139 |  | Develop document | 20d | 2025-02-03 | 2025-02-28 | 2090FS-45d |  | 566d |  |
| 2140 |  | Document review and update | 19d | 2025-03-03 | 2025-03-27 | 2139 |  | 566d |  |
| 2141 |  | Training and Support Materials approved | 0d | 2025-03-27 | 2025-03-27 | 2140 |  | 566d |  |
| 2142 | 1.9.6 | **PP Business Change** | 129d | 2025-02-03 | 2025-07-31 |  |  | 476d |  |
| 2143 |  | Plan stakeholder management | 129d | 2025-02-03 | 2025-07-31 |  |  | 476d | start no earlier than 2025-02-03 |
| 2144 |  | Manage stakeholders | 129d | 2025-02-03 | 2025-07-31 |  |  | 476d | start no earlier than 2025-02-03 |
| 2145 |  | Develop & implement changes to KPIs, organisation & people management | 129d | 2025-02-03 | 2025-07-31 |  |  | 476d | start no earlier than 2025-02-03 |
| 2146 |  | Develop & test changes to business processes | 129d | 2025-02-03 | 2025-07-31 |  |  | 476d | start no earlier than 2025-02-03 |
| 2147 |  | Develop and deliver training | 129d | 2025-02-03 | 2025-07-31 |  |  | 476d | start no earlier than 2025-02-03 |
| 2148 |  | Programme support for PP Business Change activities | 129d | 2025-02-03 | 2025-07-31 |  |  | 476d | start no earlier than 2025-02-03 |
| 2149 | 1.9.7 | **Transition to New Settlement Timetable (M16)** | 560d | 2025-04-04 | 2027-05-28 |  |  | 0d |  |
| 2150 |  | Elexon to produce Settlement Calendar for Settlement Year 2025/2026 | 0d | 2025-04-04 | 2025-04-04 | 2088 |  | 0d |  |
| 2151 |  | Elexon monitor settlement data of migrated MPANs | 436d | 2025-04-07 | 2026-12-07 | 2150 |  | 0d |  |
| 2152 |  | M16 Checkpoint 1 | 0d | 2025-12-08 | 2025-12-08 | 2150FS+176d |  | 0d |  |
| 2153 |  | Confirm if M16 date retained as 07/12/2026 | 0d | 2026-01-05 | 2026-01-05 | 2152FS+20d |  | 0d |  |
| 2154 |  | Readiness assessment of participants' readiness to transition to new Settlement Timetable | 0d | 2026-02-02 | 2026-02-02 | 2153FS+20d |  | 0d |  |
| 2155 |  | Elexon to produce Settlement Calendar for Settlement Year 2026 up until day before M16 cutover | 0d | 2026-04-01 | 2026-04-01 | 2154FS+42d |  | 0d |  |
| 2156 |  | M16 Checkpoint 2 | 0d | 2026-09-15 | 2026-09-15 | 2155FS+119d |  | 0d |  |
| 2157 |  | Readiness assessment of participants' readiness to transition to new Settlement Timetable | 0d | 2026-09-30 | 2026-09-30 | 2156FS+11d |  | 0d |  |
| 2158 |  | Confirm M16 Date | 0d | 2026-10-13 | 2026-10-13 | 2157FS+9d |  | 0d |  |
| 2159 |  | Raise fast track change to ISD (November publish) | 0d | 2026-10-13 | 2026-10-13 | 2158 |  | 39d |  |
| 2160 | 1.9.7.11 | **M16 Approval Window** | 124d | 2026-12-07 | 2027-05-28 |  |  | 0d |  |
| 2161 |  | Panel approval that M16 criteria met | 0d | 2026-12-07 | 2026-12-07 | 2158FS+39d |  | 0d |  |
| 2162 |  | Cut over to new settlement timetable (M16) | 0d | 2026-12-07 | 2026-12-07 | 2161, 2094FS+45d, 2151, 2159, 2000 |  | 0d |  |
| 2163 |  | Maximum 6-month window for approval of M16 | 124d | 2026-12-08 | 2027-05-28 | 2162 |  | 0d |  |
| 2164 |  | Cut over to new settlement timetable (M16*) - Late Exit | 0d | 2027-05-28 | 2027-05-28 | 2163 |  | 0d |  |
| 2165 | 1.10 | **EARLY LIVE RUNNING** | 45d | 2026-10-05 | 2026-12-04 |  |  | 125d |  |
| 2166 | 1.10.1 | **Early Live Running Stabilisation Period** | 45d | 2026-10-05 | 2026-12-04 |  |  | 125d |  |
| 2167 |  | Manage Early Live Running stabilisation period | 45d | 2026-10-05 | 2026-12-04 | 2094 |  | 125d |  |
| 2168 |  | Monitor Early Live Running stabilisation period | 45d | 2026-10-05 | 2026-12-04 | 2167SS |  | 125d |  |
| 2169 | 1.11 | **PROGRAMME CLOSURE** | 86d | 2026-08-03 | 2026-11-30 |  |  | 129d |  |
| 2170 | 1.11.1 | **Handover Pack** | 86d | 2026-08-03 | 2026-11-30 |  |  | 129d |  |

| ID | WBS | Task | Duration | Start | Finish | Predecessors | Complete | Total float | Constraint |
| --- | --- | --- | --- | --- | --- | --- | --- | --- | --- |
| 2171 | 1.11.1.1 | **Draft Handover Pack (for M15)** | 40d | 2026-08-03 | 2026-09-25 |  |  | 175d |  |
| 2172 |  | Develop document | 20d | 2026-08-03 | 2026-08-28 | 2094FS-45d |  | 175d |  |
| 2173 |  | Document review and update | 20d | 2026-08-31 | 2026-09-25 | 2172 |  | 175d |  |
| 2174 |  | Draft Handover Pack approved | 0d | 2026-09-25 | 2026-09-25 | 2173 |  | 175d |  |
| 2175 | 1.11.1.2 | **Master Handover Pack (for M16)** | 40d | 2026-10-06 | 2026-11-30 |  |  | 129d |  |
| 2176 |  | Update document | 20d | 2026-10-06 | 2026-11-02 | 2162FS-45d |  | 129d |  |
| 2177 |  | Document review and update | 20d | 2026-11-03 | 2026-11-30 | 2176 |  | 129d |  |
| 2178 |  | Master Handover Pack approved | 0d | 2026-11-30 | 2026-11-30 | 2177 |  | 129d |  |
| 2179 | 1.11.2 | **Programme Lessons Learned** | 40d | 2026-08-03 | 2026-09-25 |  |  | 175d |  |
| 2180 |  | Develop document | 20d | 2026-08-03 | 2026-08-28 | 2094FS-45d |  | 175d |  |
| 2181 |  | Document review and update | 20d | 2026-08-31 | 2026-09-25 | 2180 |  | 175d |  |
| 2182 |  | Programme Lessons Learned document approved | 0d | 2026-09-25 | 2026-09-25 | 2181 |  | 175d |  |
| 2183 | 1.11.3 | **Programme Closure Report** | 40d | 2026-08-03 | 2026-09-25 |  |  | 175d |  |
| 2184 |  | Develop document | 20d | 2026-08-03 | 2026-08-28 | 2094FS-45d |  | 175d |  |
| 2185 |  | Document review and update | 20d | 2026-08-31 | 2026-09-25 | 2184 |  | 175d |  |
| 2186 |  | Programme Closure Report approved | 0d | 2026-09-25 | 2026-09-25 | 2185 |  | 175d |  |
| 2187 | 1.11.4 | **Benefit Realisation Report** | 45d | 2026-08-03 | 2026-10-02 |  |  | 170d |  |
| 2188 |  | Develop document | 20d | 2026-08-03 | 2026-08-28 | 2094FS-45d |  | 170d |  |
| 2189 |  | Document review and update | 20d | 2026-08-31 | 2026-09-25 | 2188 |  | 170d |  |
| 2190 |  | Benefit Realisation Report approved | 0d | 2026-10-02 | 2026-10-02 | 2189FS+5d |  | 170d |  |
| 2191 | 1.11.5 | **Operating Model Gap Review with recommendations** | 45d | 2026-08-03 | 2026-10-02 |  |  | 170d |  |
| 2192 |  | Develop document | 20d | 2026-08-03 | 2026-08-28 | 2094FS-45d |  | 170d |  |
| 2193 |  | Document review and update | 20d | 2026-08-31 | 2026-09-25 | 2192 |  | 170d |  |
| 2194 |  | Operating Model Gap Review with recommendations approved | 0d | 2026-10-02 | 2026-10-02 | 2193FS+5d |  | 170d |  |
| 2195 | 1.11.6 | **Post-Implementation Review** | 45d | 2026-08-03 | 2026-10-02 |  |  | 170d |  |
| 2196 |  | Develop document | 20d | 2026-08-03 | 2026-08-28 | 2094FS-45d |  | 170d |  |
| 2197 |  | Document review and update | 20d | 2026-08-31 | 2026-09-25 | 2196 |  | 170d |  |
| 2198 |  | Post-Implementation Review approved | 0d | 2026-10-02 | 2026-10-02 | 2197FS+5d |  | 170d |  |
| 2199 | 1.11.7 | **Reinforcement Guide** | 45d | 2026-08-03 | 2026-10-02 |  |  | 170d |  |
| 2200 |  | Develop document | 20d | 2026-08-03 | 2026-08-28 | 2094FS-45d |  | 170d |  |
| 2201 |  | Document review and update | 20d | 2026-08-31 | 2026-09-25 | 2200 |  | 170d |  |
| 2202 |  | Reinforcement Guide approved | 0d | 2026-10-02 | 2026-10-02 | 2201FS+5d |  | 170d |  |
| 2203 | 1.11.8 | **Material and Licenses Transfer** | 60d | 2026-09-08 | 2026-11-30 |  |  | 129d |  |
| 2204 |  | Transfer of Programme material to Elexon and perpetual licenses as appropriate | 60d | 2026-09-08 | 2026-11-30 | 2162FF-5d |  | 129d |  |
| 2205 | 1.12 | **READINESS ASSESSMENTS** | 849d | 2023-09-05 A | 2026-12-04 |  | 23% | 125d |  |
| 2206 | 1.12.1 | **Readiness Assessment 3 - Design and Build Progress Check and CP2 Check** | 60d | 2023-09-05 A | 2023-11-27 A |  | 100% |  |  |
| 2207 |  | Launch Readiness Assessment survey | 0d | 2023-09-05 A | 2023-09-05 A | 1001FS-40d | 100% |  |  |
| 2208 |  | PPs submit survey responses | 15d | 2023-09-05 A | 2023-09-25 A | 2207 | 100% |  |  |
| 2209 |  | Analyse survey responses | 15d | 2023-09-26 A | 2023-10-16 A | 2208 | 100% |  |  |
| 2210 |  | Conduct deep-dive interviews (sample of PPs) | 15d | 2023-09-26 A | 2023-10-16 A | 2208 | 100% |  |  |
| 2211 |  | Produce Readiness Assessment Reports (Overall Report & Individual Participant Reports) | 25d | 2023-10-17 A | 2023-11-20 A | 2209, 2210 | 100% |  |  |
| 2212 |  | Readiness Assessment 3 - Design & Build Checkpoint 1 - Completed (incl. Readiness Assessment Report approval) | 0d | 2023-11-27 A | 2023-11-27 A | 2211FS+5d | 100% |  |  |
| 2213 | 1.12.2 | **Readiness Assessment 5 / 6 - Start of Qualification and Participant Readiness for M10 and M11 and CP3/CP4 check** | 47d | 2024-11-12 | 2025-01-15 |  |  | 0d |  |
| 2214 |  | Launch Readiness Assessment survey | 0d | 2024-11-12 | 2024-11-12 |  |  | 0d | must start on 2024-11-12 |
| 2215 |  | PPs submit survey responses | 15d | 2024-11-12 | 2024-12-02 | 2214 |  | 617d |  |
| 2216 |  | Analyse survey responses | 15d | 2024-12-03 | 2024-12-23 | 2215 |  | 617d |  |
| 2217 |  | Conduct deep-dive interviews (sample of PPs) | 15d | 2024-12-03 | 2024-12-23 | 2215 |  | 617d |  |
| 2218 |  | Produce Readiness Assessment Reports (Overall Report & Individual Participant Reports) | 15d | 2024-12-24 | 2025-01-13 | 2216, 2217 |  | 617d |  |
| 2219 |  | Readiness Assessment 5 / 6 - Start of Qualification and Participant Readiness for M10 and M11 and CP3/CP4 check (incl. Readiness Assessment Report approval) Completed | 0d | 2025-01-15 | 2025-01-15 | 2218FS+2d |  | 617d |  |
| 2220 | 1.12.3 | **Readiness Assessment 7 - Migration Checkpoint** | 49d | 2025-08-04 | 2025-10-09 |  |  | 0d |  |
| 2221 |  | Launch Readiness Assessment survey | 0d | 2025-08-04 | 2025-08-04 |  |  | 0d | must start on 2025-08-04 |
| 2222 |  | PPs submit survey responses | 15d | 2025-08-04 | 2025-08-22 | 2221 |  | 426d |  |
| 2223 |  | Analyse survey responses | 15d | 2025-08-25 | 2025-09-12 | 2222 |  | 426d |  |
| 2224 |  | Conduct deep-dive interviews (sample of PPs) | 15d | 2025-08-25 | 2025-09-12 | 2222 |  | 426d |  |
| 2225 |  | Produce Readiness Assessment Reports (Overall Report & Individual Participant Reports) | 15d | 2025-09-15 | 2025-10-03 | 2223, 2224 |  | 426d |  |
| 2226 |  | Readiness Assessment 7 - Migration Checkpoint - Completed (incl. Readiness Assessment Report approval) | 0d | 2025-10-09 | 2025-10-09 | 2225FS+4d |  | 426d |  |
| 2227 | 1.12.4 | **Readiness Assessment 8 - Ready to Accept New MPANs** | 49d | 2026-01-02 | 2026-03-11 |  |  | 317d |  |
| 2228 |  | Launch Readiness Assessment survey | 0d | 2026-01-02 | 2026-01-02 | 2092FS-50d |  | 317d |  |
| 2229 |  | PPs submit survey responses | 15d | 2026-01-02 | 2026-01-22 | 2228 |  | 317d |  |
| 2230 |  | Analyse survey responses | 15d | 2026-01-23 | 2026-02-12 | 2229 |  | 317d |  |
| 2231 |  | Conduct deep-dive interviews (sample of PPs) | 15d | 2026-01-23 | 2026-02-12 | 2229 |  | 317d |  |
| 2232 |  | Produce Readiness Assessment Reports (Overall Report & Individual Participant Reports) | 15d | 2026-02-13 | 2026-03-05 | 2230, 2231 |  | 317d |  |
| 2233 |  | Readiness Assessment 8 - Ready to Accept New MPANs - Completed (incl. Readiness Assessment Report approval) | 0d | 2026-03-11 | 2026-03-11 | 2232FS+4d |  | 317d |  |
| 2234 | 1.12.5 | **Readiness Assessment 9 - Ready for New Settlement Timetable and CP5 Check** | 49d | 2026-09-29 | 2026-12-04 |  |  | 125d |  |
| 2235 |  | Launch Readiness Assessment survey | 0d | 2026-09-29 | 2026-09-29 | 2162FS-50d |  | 125d |  |
| 2236 |  | PPs submit survey responses | 15d | 2026-09-29 | 2026-10-19 | 2235 |  | 125d |  |
| 2237 |  | Analyse survey responses | 15d | 2026-10-20 | 2026-11-09 | 2236 |  | 125d |  |
| 2238 |  | Conduct deep-dive interviews (sample of PPs) | 15d | 2026-10-20 | 2026-11-09 | 2236 |  | 125d |  |
| 2239 |  | Produce Readiness Assessment Reports (Overall Report & Individual Participant Reports) | 15d | 2026-11-10 | 2026-11-30 | 2237, 2238 |  | 125d |  |
| 2240 |  | Readiness Assessment 9 - Readiness for New Settlement Timetable - Completed (incl. Readiness Assessment Report approval) | 0d | 2026-12-04 | 2026-12-04 | 2239FS+4d |  | 125d |  |

| ID | WBS | Task | Duration | Start | Finish | Predecessors | Complete | Total float | Constraint |
| --- | --- | --- | --- | --- | --- | --- | --- | --- | --- |
| 2241 | 1.12.6 | **Readiness Assessments - Tier 1 Milestones** | 435d | 2025-04-04 | 2026-12-04 |  |  | 125d |  |
| 2242 |  | Readiness Assessment 6 - Start of Migration - Completed (incl. Readiness Assessment Report approval) | 0d | 2025-04-04 | 2025-04-04 |  |  | 560d | finish no earlier than 2025-04-04 |
| 2243 |  | Readiness Assessment 7 - Migration Checkpoint - Completed (incl. Readiness Assessment Report approval) | 0d | 2025-10-09 | 2025-10-09 | 2225FS+4d |  | 426d |  |
| 2244 |  | Readiness Assessment 8 - Ready to Accept New MPANs - Completed (incl. Readiness Assessment Report approval) | 0d | 2026-03-11 | 2026-03-11 | 2232FS+4d |  | 317d |  |
| 2245 |  | Readiness Assessment 9 - Readiness for New Settlement Timetable - Completed (incl. Readiness Assessment Report approval) | 0d | 2026-12-04 | 2026-12-04 | 2239FS+4d |  | 125d |  |
| 2246 | 1.13 | **CONTROL POINTS** | 1063d | 2022-11-10 A | 2026-12-07 |  | 51% | 124d |  |
| 2247 | 1.13.1 | **Control Point 1 - Start of System Design, Build & Test** | 20d | 2022-11-10 A | 2022-12-07 A |  | 100% |  |  |
| 2248 |  | Control Point 1 Preparation (incl. Control Point Report development and review) | 15d | 2022-11-10 A | 2022-11-30 A | 2249SS-20d | 100% |  |  |
| 2249 |  | Control Point 1 - Start of System Design, Build & Test (incl. Control Point Report approval) | 0d | 2022-12-07 A | 2022-12-07 A |  | 100% |  | must finish on 2022-12-07 |
| 2250 | 1.13.2 | **Control Point 2 - Start of Integration & Test** | 20d | 2023-10-02 A | 2023-10-30 A |  | 100% |  |  |
| 2251 |  | Control Point 2 Preparation (incl. Control Point Report development and review) | 15d | 2023-10-02 A | 2023-10-20 A | 2252SS-20d | 100% |  |  |
| 2252 |  | Control Point 2 - Start of Integration & Test (incl. Control Point Report approval) | 0d | 2023-10-30 A | 2023-10-30 A | 1001 | 100% |  |  |
| 2253 | 1.13.3 | **Control Point 3/4 - Readiness for Migration** | 20d | 2025-02-28 | 2025-03-27 |  |  | 20d |  |
| 2254 |  | Control Point 3/4 Preparation (incl. Control Point Report development and review) | 14d | 2025-02-28 | 2025-03-19 | 2255SS-20d |  | 572d |  |
| 2255 |  | Control Point 3/4 - Readiness for Migration (incl. Control Point Report approval) | 0d | 2025-03-27 | 2025-03-27 |  |  | 0d | must start on 2025-03-27 |
| 2256 | 1.13.4 | **Control Point 5 - Cut Over to New Settlement Timetable** | 20d | 2026-11-10 | 2026-12-07 |  |  | 124d |  |
| 2257 |  | Control Point 5 Preparation (incl. Control Point Report development and review) | 15d | 2026-11-10 | 2026-11-30 | 2258SS-20d |  | 129d |  |
| 2258 |  | Control Point 5 - Cut Over to New Settlement Timetable (incl. Control Point Report approval) | 0d | 2026-12-07 | 2026-12-07 | 2162 |  | 124d |  |
| 2259 | 1.13.5 | **Control Points - Tier 1 Milestones** | 1043d | 2022-12-07 A | 2026-12-07 |  |  | 124d |  |
| 2260 |  | Control Point 1 - Start of System Design, Build & Test (incl. Control Point Report approval) | 0d | 2022-12-07 A | 2022-12-07 A | 2249SS | 100% |  |  |
| 2261 |  | Control Point 2 - Start of Integration & Test (incl. Control Point Report approval) | 0d | 2023-10-30 A | 2023-10-30 A | 2252SS | 100% |  |  |
| 2262 |  | Control Point 3/4 - Readiness for Migration (incl. Control Point Report approval) | 0d | 2025-03-27 | 2025-03-27 | 2255SS |  | 566d |  |
| 2263 |  | Control Point 5 - Cut Over to New Settlement Timetable (incl. Control Point Report approval) | 0d | 2026-12-07 | 2026-12-07 | 2258SS |  | 124d |  |
| 2264 | 1.14 | **MILESTONE RANGE CHECKPOINTS** | 436d | 2025-01-13 | 2026-09-15 |  |  | 184d |  |
| 2265 | 1.14.1 | **M10, M11, M12 and M13 milestone checkpoint** | 0d | 2025-01-13 | 2025-01-13 |  |  | 620d |  |
| 2266 |  | M10, M11, M12, and M13 milestone checkpoint - date approval | 0d | 2025-01-13 | 2025-01-13 | 2084FS-3mo, 2088FS-3mo, 2090FS-3mo, 2086FS-3mo |  | 620d |  |
| 2267 | 1.14.2 | **M14 milestone checkpoint** | 0d | 2025-12-19 | 2025-12-19 |  |  | 376d |  |
| 2268 |  | M14 milestone checkpoint - date approval | 0d | 2025-12-19 | 2025-12-19 | 2092FS-3mo |  | 376d |  |
| 2269 | 1.14.3 | **M15 milestone checkpoint** | 0d | 2026-07-13 | 2026-07-13 |  |  | 230d |  |
| 2270 |  | M15 milestone checkpoint - date approval | 0d | 2026-07-13 | 2026-07-13 | 2094FS-3mo |  | 230d |  |
| 2271 | 1.14.4 | **M16 milestone checkpoint** | 0d | 2026-09-15 | 2026-09-15 |  |  | 184d |  |
| 2272 |  | M16 milestone checkpoint - date approval | 0d | 2026-09-15 | 2026-09-15 | 2162FS-3mo |  | 184d |  |

## Version 2 (data date 2024-08-23, saved 2024-10-18, file MHHS-DEL1139 - MHHS Plan v6.1.mpp)

Last finish 2027-05-28 → 2027-12-23 (+209d). Complete tasks 988 → 1107.

Added:

| ID | Task | Duration | Start | Finish | Predecessors | Constraint |
| --- | --- | --- | --- | --- | --- | --- |
| 139 | **Interim Release 8.3 - Maintenance Window** | 11d | 2024-10-07 | 2024-10-21 |  |  |
| 141 | Interim Release 8.3 'effective from date' to SIT B | 0d | 2024-10-07 | 2024-10-07 | 140SS-11d |  |
| 142 | **Interim Release 8.4** | 36d | 2024-09-25 A | 2024-11-13 |  |  |
| 143 | Update baselined artefacts | 8d | 2024-09-25 A | 2024-10-04 A |  | start no earlier than 2024-09-25 |
| 144 | Interim release 8.4 Published | 0d | 2024-10-16 | 2024-10-16 | 143FS+8d | start no earlier than 2024-10-09 |
| 145 | Interim Release 8.4 Deployed to SIT by Participants | 0d | 2024-11-13 | 2024-11-13 | 144FS+20d |  |
| 175 | **Design Handover** | 741d? | 2024-09-02 A | 2027-07-05 |  |  |
| 176 | **Creation of the Configuration Management Database** | 14d | 2024-09-02 | 2024-09-19 |  |  |
| 177 | Identify all baselined design artefacts | 9d | 2024-09-02 | 2024-09-12 |  | start no earlier than 2024-09-02 |
| 178 | Create CMBD | 5d | 2024-09-13 | 2024-09-19 | 177 |  |
| 179 | **Knowledge Transfer** | 41d? | 2024-09-02 | 2024-10-28 |  |  |
| 180 | Elexon to document knowledge transfer requirements | 9d? | 2024-09-02 | 2024-09-12 |  | start no earlier than 2024-09-02 |
| 181 | Review Requirements | 5d | 2024-09-13 | 2024-09-19 | 180 |  |
| 182 | Agree Success Criteria | 10d | 2024-09-20 | 2024-10-03 | 181 |  |
| 183 | Identify Key personel with Elexon | 3d | 2024-10-04 | 2024-10-08 | 182 |  |
| 184 | Draft Agenda for initial meeting | 1d? | 2024-10-09 | 2024-10-09 | 183 |  |
| 185 | Define cadence for handover sessions | 2d | 2024-10-10 | 2024-10-11 | 184 |  |
| 186 | Share Design Information | 20d | 2024-09-02 | 2024-09-27 |  | start no earlier than 2024-09-02 |
| 187 | Conduct Initial Handover Session | 20d? | 2024-10-01 | 2024-10-28 |  | start no earlier than 2024-10-01 |
| 188 | **Triage Sessions** | 131d? | 2024-10-01 | 2025-04-01 |  |  |
| 189 | Design Triage Sessions | 131d? | 2024-10-01 | 2025-04-01 |  | start no earlier than 2024-10-01 |
| 190 | Test Triage Sessions | 131d? | 2024-10-01 | 2025-04-01 |  | finish no earlier than 2025-04-01 |
| 191 | **Knowledge Base** | 9d | 2024-09-02 A | 2024-09-12 A |  |  |
| 192 | Document Knowledge base update process | 4d | 2024-09-02 A | 2024-09-05 A |  | start no earlier than 2024-09-02 |
| 193 | Document Design updates to Collaboration Base | 5d | 2024-09-06 A | 2024-09-12 A |  | start no earlier than 2024-09-06 |
| 194 | **FreshDesk** | 30d? | 2025-02-03 | 2025-03-14 |  |  |
| 195 | Agree Indicative Handover of FreshDesk Calls to Service Now | 4d | 2025-02-03 | 2025-02-06 |  | start no earlier than 2025-02-03 |
| 196 | Prepare Comms to Industry | 10d | 2025-02-07 | 2025-02-20 |  | start no earlier than 2025-02-07 |
| 197 | Issue Comms to Industry | 1d? | 2025-02-21 | 2025-02-21 |  | start no earlier than 2025-02-21 |
| 198 | Redirect Design Mailbox to Service Now | 1d? | 2025-03-03 | 2025-03-03 |  | start no earlier than 2025-03-03 |
| 199 | Archive Freshdesk calls | 5d | 2025-03-03 | 2025-03-07 |  | start no earlier than 2025-03-03 |
| 200 | Decommission FreshDesk | 5d | 2025-03-10 | 2025-03-14 |  | start no earlier than 2025-03-10 |
| 201 | **Iserver** | 611d? | 2025-03-03 A | 2027-07-05 |  |  |
| 202 | Gather Licensing information | 1d? | 2025-03-03 A | 2025-03-03 A |  | start no earlier than 2025-03-03 |
| 203 | Clear down old information | 5d | 2025-03-03 | 2025-03-07 |  |  |
| 204 | Clear down accounts | 2d | 2025-03-10 | 2025-03-11 | 203 | start no earlier than 2025-03-10 |
| 205 | Identify Collaboration Base Design Dependencies on iServer | 2d | 2025-04-01 | 2025-04-02 | 204 | start no earlier than 2025-04-01 |
| 206 | Remove Design dependencies | 5d | 2025-04-03 | 2025-04-09 | 205 | start no earlier than 2025-04-03 |
| 207 | Close down iServer | 5d | 2025-04-10 | 2025-04-16 | 206 | start no earlier than 2025-04-10 |
| 547 | **Secure Volunteer SIT Participants** | 163d? | 2023-01-31 A | 2023-09-14 A |  |  |
| 548 | PPs decide whether to volunteer to participate in SIT and inform Programme of decision via Round 3 Replan consultation | 1d? | 2023-01-31 A | 2023-01-31 A |  | finish no earlier than 2023-01-31 |
| 549 | Assurance of SIT volunteers' plans (submitted via Round 3 Replan Consultation) | 1d? | 2023-02-14 A | 2023-02-14 A |  | finish no earlier than 2023-02-14 |
| 550 | SIT Participant Volunteers Identified | 1d? | 2023-02-14 A | 2023-02-14 A |  | start no earlier than 2023-02-14 |
| 551 | Engagement with SIT volunteers | 1d? | 2023-05-23 A | 2023-05-23 A |  | finish no earlier than 2023-05-23 |
| 552 | SIT Participants Agreed | 1d? | 2023-05-23 A | 2023-05-23 A |  | start no earlier than 2023-05-23 |
| 555 | Revise Overarching Test Data Approach& plan for DPIA (if required), including engagement with DWG | 1d? | 2023-07-13 A | 2023-07-13 A |  | finish no earlier than 2023-07-13 |
| 556 | Review (internal), update and approve revised Overarching Test Data Approach& Plan (if required) | 1d? | 2023-07-14 A | 2023-07-14 A |  | start no earlier than 2023-07-14 |
| 562 | **SI Data Cut Preparation& Infrastructure** | 45d? | 2023-06-19 A | 2023-08-18 A |  |  |
| 566 | SI Data Cut Preparation& Infrastructure Complete | 1d? | 2023-08-18 A | 2023-08-18 A |  | start no earlier than 2023-08-18 |
| 824 | Environment Approach and Plan - SIT Functional | 1d? | 2023-11-20 A | 2023-11-20 A |  | start no earlier than 2023-11-20 |
| 847 | **SIT Functional Programme RTTM** | 55d? | 2024-07-29 A | 2024-10-11 |  |  |
| 848 | **RTTM Development** | 40d? | 2024-07-29 A | 2024-09-20 |  |  |
| 849 | Development of Manual SIT Functional RTTM | 30d? | 2024-07-29 A | 2024-09-06 A |  | start no earlier than 2024-07-29 |
| 850 | Manual SIT Functional RTTM Complete | 0d? | 2024-09-06 A | 2024-09-06 A | 849 | start no earlier than 2024-07-29 |
| 851 | Development of Automated SIT Functional RTTM | 40d? | 2024-07-29 A | 2024-09-20 A |  | start no earlier than 2024-07-29 |
| 852 | Automated SIT Functional RTTM Complete | 0d? | 2024-09-20 A | 2024-09-20 | 851 | finish no earlier than 2024-09-20 |
| 853 | **Gap analysis** | 35d? | 2024-08-26 A | 2024-10-11 |  |  |
| 854 | Identify gaps in test case coverage following RTTM review. | 20d? | 2024-08-26 A | 2024-09-20 A | 851SS+20d |  |
| 855 | Address gaps in test case coverage following RTTM review. | 20d | 2024-09-09 A | 2024-10-04 | 854SS+10d |  |
| 856 | SRO Walkthrough | 1d? | 2024-10-09 | 2024-10-09 | 855FS+2d |  |
| 857 | SRO Approval | 1d? | 2024-10-09 | 2024-10-09 | 855FS+2d |  |
| 858 | Gap analysis complete | 0d | 2024-10-11 | 2024-10-11 | 857FS+2d |  |
| 859 | **Cycle 3 Test Evidence Capturing Approach** | 25d? | 2024-09-16 A | 2024-10-18 |  |  |
| 860 | Define guiding principles and proof of concept | 10d | 2024-09-16 A | 2024-09-27 A |  | start no earlier than 2024-09-16 |
| 861 | Draft proposed test evidence capturing approach | 3d | 2024-09-30 A | 2024-10-02 A | 860 |  |
| 862 | SRO review | 5d | 2024-10-03 A | 2024-10-09 A | 861 |  |
| 863 | Present proposed approach | 1d? | 2024-10-11 A | 2024-10-11 A | 862FS+1d |  |
| 864 | Incorporate feedback | 4d | 2024-10-14 A | 2024-10-17 | 863 |  |
| 865 | Publish proposed approach ahead of Cycle 3 start | 1d? | 2024-10-18 | 2024-10-18 | 864 |  |
| 866 | **DITL Cycle 3 Pack Development** | 8d? | 2024-10-08 A | 2024-10-17 |  |  |
| 867 | Programme Cycle 2 Retro | 1d? | 2024-10-08 A | 2024-10-08 A |  | start no earlier than 2024-10-08 |
| 868 | Post-retro DITL Changes | 3d | 2024-10-09 A | 2024-10-11 | 867 |  |
| 869 | SRO Review | 2d | 2024-10-14 | 2024-10-15 | 868 |  |
| 870 | Post-SRO Review Changes | 1d? | 2024-10-16 | 2024-10-16 | 869 |  |
| 871 | Publish Cycle 3 DITL / Cycle 3 DITL Online Sessions for SIT PPs | 1d? | 2024-10-17 | 2024-10-17 | 870 |  |
| 872 | **Test Script Exit Points** | 85d | 2024-10-14 A | 2025-02-07 |  |  |
| 873 | Identify exit points for Sprint 5 | 5d | 2024-10-14 A | 2024-10-18 | 865FS-5d |  |
| 874 | Identify exit points for Sprint 6 | 5d | 2024-10-21 | 2024-10-25 | 1255SS |  |
| 875 | Identify exit points for Sprint 7 | 5d | 2024-11-04 | 2024-11-08 | 1256SS |  |
| 876 | Identify exit points for Sprint 8 | 5d | 2024-11-18 | 2024-11-22 | 1257SS |  |
| 877 | Identify exit points for Sprint 9 | 5d | 2024-12-02 | 2024-12-06 | 1258SS |  |
| 878 | Identify exit points for Sprint 10 | 5d | 2024-12-23 | 2024-12-27 | 1259SS |  |
| 879 | Identify exit points for Sprint 11 | 5d | 2025-01-06 | 2025-01-10 | 1260SS |  |
| 880 | Identify exit points for Sprint 12 | 5d | 2025-01-20 | 2025-01-24 | 1261SS |  |
| 881 | Identify exit points for Sprint 13 | 5d | 2025-02-03 | 2025-02-07 | 1262SS |  |
| 882 | **Cycle 3 Test Case Rationalisation (Functional and Migration)** | 36d? | 2024-09-16 A | 2024-11-04 |  |  |
| 883 | Review Cycle 3 scope and identify candidates for rationalisation | 25d | 2024-09-16 A | 2024-10-18 |  | start no earlier than 2024-09-16 |
| 884 | Define proposal for rationalisation of test cases | 15d | 2024-09-30 A | 2024-10-18 A | 883 |  |
| 885 | SRO review | 5d | 2024-10-21 | 2024-10-25 | 884 |  |
| 886 | Present proposed approach | 1d? | 2024-10-28 | 2024-10-28 | 885 |  |
| 887 | Incorporate feedback | 4d | 2024-10-29 | 2024-11-01 | 886 |  |
| 888 | Publish proposed approach ahead of Cycle 3 start | 1d? | 2024-11-04 | 2024-11-04 | 887 |  |
| 918 | Cycle 3 data requirments analysis - check Cycle 2 data for gaps Check blocked test cases | 10d? | 2024-07-15 A | 2024-07-26 A |  | finish no earlier than 2024-07-26 |
| 919 | Provide DCC with MPANS for deletion secure file with password | 1d? | 2024-08-12 A | 2024-08-12 A |  |  |
| 920 | Receive MPANS from DCC to exclude | 1d? | 2024-08-09 A | 2024-08-09 A |  |  |
| 921 | Exclude MPANS from allocation | 1d | 2024-08-16 A | 2024-08-16 A |  |  |
| 922 | Allocate Cycle 3 MPANS | 16d? | 2024-08-06 A | 2024-08-27 A |  |  |
| 923 | Generate Cycle 3 Data | 2d? | 2024-08-27 A | 2024-08-28 A |  |  |
| 924 | Check data prior to sending to DCC | 5d? | 2024-08-22 A | 2024-08-28 A |  |  |
| 925 | Share Cycle 3 MPAN data with DCC | 1d? | 2024-08-29 A | 2024-08-29 A |  |  |
| 926 | DCC - load data and create registration Id's for Cycle 3 data | 13d? | 2024-08-27 A | 2024-09-12 A |  |  |
| 927 | Add registration ID's to Cycle 3 Data | 2d? | 2024-09-12 A | 2024-09-13 A |  |  |
| 928 | Share subset of data with St Cls for data load | 2d? | 2024-09-12 A | 2024-09-13 A |  |  |
| 929 | St Clements to run test with Subset of data - MPRS business process checks including Import/Export MPANS | 5d? | 2024-09-16 A | 2024-09-20 A |  |  |
| 930 | Send Cycle 3 data to partcipants for early sight of data | 3d? | 2024-09-25 A | 2024-09-27 A |  |  |
| 931 | St Clements MPRS data load bulk files for Cycle 3 | 15d? | 2024-09-23 A | 2024-10-11 A |  |  |
| 932 | New MPAN creation and load through DCC and St Clements | 1d? | 2024-10-11 A | 2024-10-11 |  | start no earlier than 2024-10-11 |
| 933 | Share files with PP's and central parties | 1d | 2024-10-11 | 2024-10-11 |  | start no earlier than 2024-10-11 |
| 934 | Avanade to load data | 6d | 2024-10-14 | 2024-10-21 |  | start no earlier than 2024-10-14 |
| 935 | Helix to load data | 6d | 2024-10-14 | 2024-10-21 |  | start no earlier than 2024-10-14 |
| 936 | PP's and central parties to load all Cycle 3 data | 6d | 2024-10-14 | 2024-10-21 |  | start no earlier than 2024-10-14 |
| 937 | All parties to finalise data load | 1d? | 2024-10-21 | 2024-10-21 |  | start no earlier than 2024-10-21 |
| 983 | **RTTM Development** | 27d? | 2024-08-29 A | 2024-10-04 |  |  |
| 984 | Develop Manual SIT Migration RTTM | 17d | 2024-08-29 A | 2024-09-20 A |  | start no earlier than 2024-08-29 |
| 985 | Manual SIT Migration RTTM Complete | 0d | 2024-09-20 A | 2024-09-20 A | 984 |  |
| 986 | Develop Automated SIT Migration RTTM | 20d | 2024-09-09 A | 2024-10-04 |  | start no earlier than 2024-09-09 |
| 987 | Automated SIT Migration RTTM Complete | 0d? | 2024-10-04 | 2024-10-04 | 986 |  |
| 988 | **Gap analysis** | 17d? | 2024-09-12 A | 2024-10-04 |  |  |
| 989 | Identify gaps in test case coverage following RTTM review. | 12d | 2024-09-12 A | 2024-09-27 A | 984SS+10d |  |
| 990 | Address gaps in test case coverage following RTTM review. | 12d | 2024-09-19 A | 2024-10-04 | 989SS+5d |  |
| 991 | Gap analysis complete | 0d? | 2024-10-04 | 2024-10-04 | 990 |  |
| 1044 | **SIT NFT Programme RTTM** | 21d? | 2024-09-18 | 2024-10-16 |  |  |
| 1045 | Develop Manual SIT NFT RTTM | 15d | 2024-09-18 | 2024-10-08 | 1043 |  |
| 1046 | Review with SRO | 1d? | 2024-10-09 | 2024-10-09 | 1045 |  |
| 1047 | Manual SIT NFT RTTM Complete | 0d | 2024-10-08 | 2024-10-08 | 1045 |  |
| 1048 | Develop Automated SIT NFT RTTM | 5d | 2024-10-09 | 2024-10-15 | 1047 |  |
| 1049 | Review with SRO | 1d? | 2024-10-16 | 2024-10-16 | 1048 |  |
| 1050 | Automated SIT NFT RTTM Complete | 0d | 2024-10-15 | 2024-10-15 | 1048 |  |
| 1051 | **NFT Performance Tool Theme 1 Setup** | 225d? | 2024-03-04 A | 2025-01-10 |  |  |
| 1052 | Theme 1 injection tool initial POC | 85d? | 2024-03-04 A | 2024-06-28 A |  |  |
| 1053 | Theme 1 injection tool configuration and validation against DIP SIM (IR7.1) | 38d | 2024-07-01 A | 2024-08-21 A | 1052 |  |
| 1054 | Theme 1 injection tool configuration and validation against DIP SIM (IR8.1) | 29d | 2024-08-22 A | 2024-10-01 A | 1053 |  |
| 1055 | Theme 1 injection tool configuration and validation againast UIT DIP (IR8.1) | 11d | 2024-10-02 | 2024-10-16 | 1054 |  |
| 1056 | Theme 1 injection tool configuration and validation against SIT-B DIP (IR8.3) | 62d? | 2024-10-17 | 2025-01-10 | 1055 |  |
| 1062 | **Helix and Avanade Environments Upscale** | 10d? | 2024-12-23 | 2025-01-03 |  |  |
| 1063 | Environment Uplift Window | 10d? | 2024-12-23 | 2025-01-03 | 1271 |  |
| 1064 | **Test Data - Non-Functional and Operational (SIT B)** | 50d? | 2025-01-06 | 2025-03-14 |  |  |
| 1065 | **Data Load** | 50d? | 2025-01-06 | 2025-03-14 |  |  |
| 1066 | Non-Functional Theme 1 (Helix & DIP Volume Testing) Data Load | 5d? | 2025-01-06 | 2025-01-10 | 1063 |  |
| 1067 | Non-Functional Theme 2 & 3 (Helix and DIP) Data Load | 5d | 2025-02-03 | 2025-02-07 | 1327 |  |
| 1068 | Non-Functional Themes 2 & 3 (Central Parties and PPs) Data Load | 20d? | 2025-01-06 | 2025-01-31 | 1063 |  |
| 1069 | Operational Themes 1, 2 & 3 (Batch 2) (Central Parties and PPs) Data Load | 20d? | 2025-01-06 | 2025-01-31 | 1063 | start no earlier than 2025-01-06 |
| 1070 | Operational Themes 1, 2 & 3 (Batch 2) (Helix & DIP) Data Load | 5d | 2025-02-03 | 2025-02-07 | 1327 |  |
| 1071 | Non-Functional and Operational Test Data Preparation Complete | 0d | 2025-02-07 | 2025-02-07 | 1070 |  |
| 1072 | Non-Functional Theme 2 & 3 PP Preparation | 25d? | 2025-02-10 | 2025-03-14 | 1067 |  |
| 1107 | **Elexon / Helix Service Management Test Prep** | 145d? | 2024-07-15 | 2025-01-31 |  |  |
| 1108 | Elexon Service Now Build and Implementation | 145d? | 2024-07-15 | 2025-01-31 |  | start no earlier than 2024-07-15 |
| 1109 | Helix Engagement and Comms | 105d? | 2024-09-09 | 2025-01-31 |  | start no earlier than 2024-09-09 |
| 1110 | Helix Service Management Documentation (Service Design Pack and Service User Op Model) | 105d? | 2024-09-09 | 2025-01-31 |  | start no earlier than 2024-09-09 |
| 1111 | Helix Knowledge Articles | 105d? | 2024-09-09 | 2025-01-31 |  | start no earlier than 2024-09-09 |
| 1113 | Conclude BCDR Scope with SRO, Code Bodies and DIP Manager | 22d | 2024-09-19 A | 2024-10-18 |  | start no earlier than 2024-09-19 |
| 1114 | Develop BDCR Test Scenarios & Test Cases (Batch 2) | 10d | 2024-10-14 A | 2024-10-25 A | 1113 |  |
| 1115 | Develop DIP Test Scenarios and Test Cases (Batch 2) | 27d | 2024-09-19 | 2024-10-25 |  | start no earlier than 2024-09-19 |
| 1116 | SRO Review | 5d | 2024-10-28 | 2024-11-01 | 1115 | start no earlier than 2024-10-28 |
| 1118 | Review Feedback and Update | 5d | 2024-11-18 | 2024-11-22 | 1117 |  |
| 1119 | Review with SIT WG (Batch 2) | 6d | 2024-11-28 | 2024-12-05 | 1118FS+3d |  |
| 1120 | SITAG Approval (Batch 2) | 1d? | 2024-12-11 | 2024-12-11 | 1119FS+3d |  |
| 1121 | **Theme 3 (Batch 1)** | 176d? | 2024-04-10 A | 2024-12-11 |  |  |
| 1123 | Conclude Industry Consultation (Batch 1) | 11d | 2024-09-05 A | 2024-09-19 A |  | start no earlier than 2024-09-05 |
| 1124 | Review Feedback and Update | 5d | 2024-09-20 A | 2024-09-26 | 1123 |  |
| 1125 | Draft Test Cases from Feedback and LLSD | 15d? | 2024-09-30 A | 2024-10-18 | 1124FS+1d, 1134 |  |
| 1126 | SRO Review | 5d? | 2024-10-21 | 2024-10-25 | 1125 |  |
| 1128 | Review Feedback and Update | 5d | 2024-11-11 | 2024-11-15 | 1127 |  |
| 1129 | Review with SITWG (Batch 1) | 5d? | 2024-11-28 | 2024-12-04 | 1128FS+8d |  |
| 1130 | SITAG for approval (Batch 1) | 1d | 2024-12-11 | 2024-12-11 | 1129FS+4d |  |
| 1132 | **Helix SDD and LLSD Development and Approval** | 1d | 2024-09-27 | 2024-09-30 |  |  |
| 1134 | Approval | 0d | 2024-09-30 | 2024-09-30 |  | start no earlier than 2024-09-30 |
| 1135 | **SIT Operational Programme RTTM** | 27d? | 2024-12-12 | 2025-01-17 |  |  |
| 1136 | Develop Manual SIT Operational RTTM | 22d? | 2024-12-12 | 2025-01-10 | 1131 |  |
| 1137 | Manual SIT Operational RTTM Complete | 0d | 2025-01-10 | 2025-01-10 | 1136 |  |
| 1138 | Develop Automated SIT Operational RTTM | 5d | 2025-01-13 | 2025-01-17 | 1136 |  |
| 1139 | Automated SIT Operational RTTM Complete | 0d | 2025-01-17 | 2025-01-17 | 1138 |  |
| 1153 | **Regression Test Preperation** | 175d? | 2024-09-16 A | 2025-05-16 |  |  |
| 1154 | **Regression Test Approach** | 48d | 2024-09-16 A | 2024-11-20 |  |  |
| 1155 | Develop approach doc | 22d | 2024-09-16 A | 2024-10-15 |  | start no earlier than 2024-09-16 |
| 1156 | SRO review of approach doc | 3d | 2024-10-16 | 2024-10-18 | 1155 |  |
| 1157 | SITWG feedback on approach doc | 2d | 2024-10-28 | 2024-10-29 | 1156FS+5d |  |
| 1158 | Incorporate SRO + SITWG feedback into approach doc | 2d | 2024-10-30 | 2024-10-31 | 1157 |  |
| 1159 | SITWG Recommendation | 1d | 2024-11-07 | 2024-11-07 | 1158FS+4d |  |
| 1160 | SITAG (inc SRO) Approval | 0d | 2024-11-20 | 2024-11-20 | 1159FS+9d |  |
| 1161 | SIT Regression Testing Approach and Plan Approval | 0d | 2024-11-20 | 2024-11-20 | 1160 |  |
| 1162 | **Regression Test Suite** | 38d? | 2024-11-21 | 2025-01-13 |  |  |
| 1163 | Build Regression Test Suite | 12d | 2024-11-21 | 2024-12-06 | 1161 |  |
| 1164 | SRO Review of regression suite doc | 10d | 2024-12-09 | 2024-12-20 | 1163 |  |
| 1165 | SITWG Feedback on regression suite doc | 5d | 2024-12-30 | 2025-01-03 | 1164FS+5d |  |
| 1166 | Incorporate SRO + SITWG feedback into regression suite doc | 1d? | 2025-01-06 | 2025-01-06 | 1165 |  |
| 1167 | SRO Approval | 0d | 2025-01-06 | 2025-01-06 | 1166 |  |
| 1168 | SIT Regression Suite Approval at SITAG | 0d | 2025-01-13 | 2025-01-13 | 1167FS+5d |  |
| 1169 | **Regression Test Data Load Window (SIT Functional and Migration) - SIT A** | 1d? | 2025-03-14 | 2025-03-17 |  |  |
| 1170 | Regression Test Data Load Start | 0d? | 2025-04-28 | 2025-04-28 | 1309, 1267FS+1d, 1313FS+1d |  |
| 1171 | Regression Test Data Load Window | 15d? | 2025-04-28 | 2025-05-16 | 1170FS-1d |  |
| 1172 | **Single Instance ADO** | 32d? | 2024-08-21 A | 2024-10-03 |  |  |
| 1173 | **Single ADO Project for all Cohorts - Implementation and Test Phase** | 30d? | 2024-08-21 A | 2024-10-01 |  |  |
| 1174 | Create test plans and suites in master project | 2d? | 2024-08-21 A | 2024-08-22 A |  | finish no earlier than 2024-08-22 |
| 1175 | Create area paths / iterations | 2d? | 2024-08-21 A | 2024-08-22 A |  | finish no earlier than 2024-08-22 |
| 1176 | Create IAM roles | 2d? | 2024-08-21 A | 2024-08-22 A |  | finish no earlier than 2024-08-22 |
| 1177 | Add users to roles | 1d? | 2024-08-23 A | 2024-08-23 A |  | start no earlier than 2024-08-23 |
| 1178 | **Testing permissions** | 2d? | 2024-08-27 A | 2024-08-28 A |  |  |
| 1179 | Adding tests | 2d? | 2024-08-27 A | 2024-08-28 A |  | finish no earlier than 2024-08-28 |
| 1180 | Deleting tests | 2d? | 2024-08-27 A | 2024-08-28 A |  | finish no earlier than 2024-08-28 |
| 1181 | Adding tests to incorrect Cohort | 2d? | 2024-08-27 A | 2024-08-28 A |  | finish no earlier than 2024-08-28 |
| 1182 | Add / delete defects | 2d? | 2024-08-27 A | 2024-08-28 A |  | finish no earlier than 2024-08-28 |
| 1183 | Migrate defects from cohort project to master - Option 2 | 3d | 2024-09-23 | 2024-09-25 |  | start no earlier than 2024-09-23 |
| 1184 | Testing Permissions - Evidence attachment security | 10d? | 2024-09-18 A | 2024-10-01 A |  | finish no earlier than 2024-10-01 |
| 1185 | **ADO Dashboard Updates** | 20d? | 2024-09-03 A | 2024-09-30 A |  |  |
| 1186 | Update reporting dashboards in ADO | 3d | 2024-09-03 A | 2024-09-05 A |  | start no earlier than 2024-09-03 |
| 1187 | Review dashboards with SI LDP leads | 16d | 2024-09-06 A | 2024-09-27 A |  | start no earlier than 2024-09-06 |
| 1188 | Review dashboards with SRO | 16d | 2024-09-09 A | 2024-09-30 A |  | start no earlier than 2024-09-09 |
| 1189 | Update dashboards following review | 2d | 2024-09-12 A | 2024-09-13 A |  | start no earlier than 2024-09-12 |
| 1190 | Document changes to dashboard creation process | 4d | 2024-09-16 A | 2024-09-19 A |  | start no earlier than 2024-09-16 |
| 1191 | Update SIT Dashboards for Sprints 4.1 & 4.2 across all Cohorts | 1d? | 2024-09-03 A | 2024-09-03 A |  | start no earlier than 2024-09-03 |
| 1192 | **Reporting Changes - PowerBI & QIP** | 23d? | 2024-08-23 A | 2024-09-24 |  |  |
| 1193 | Design, Create and ETL ADO Entities into PowerBI Data Model | 1d? | 2024-08-23 A | 2024-08-23 A |  | start no earlier than 2024-08-23 |
| 1194 | Determine Relationships between ADO Entities & Attributes | 1d? | 2024-08-27 A | 2024-08-27 A |  | start no earlier than 2024-08-27 |
| 1195 | Create Relevant Dax Measures | 1d? | 2024-08-28 A | 2024-08-28 A |  | start no earlier than 2024-08-28 |
| 1196 | Design & Build Visualisations (Graphs) | 1d? | 2024-08-29 A | 2024-08-29 A |  | start no earlier than 2024-08-29 |
| 1197 | Implement Filters | 1d? | 2024-09-23 A | 2024-09-23 A |  | start no earlier than 2024-09-23 |
| 1198 | Check Data Quality & Integrity | 1d? | 2024-09-24 A | 2024-09-24 A |  | start no earlier than 2024-09-24 |
| 1199 | Performance Optimisation | 1d? | 2024-09-24 A | 2024-09-24 A |  | start no earlier than 2024-09-24 |
| 1200 | Publish (QIP) | 1d? | 2024-09-04 | 2024-09-04 |  | start no earlier than 2024-09-04 |
| 1201 | Review & UAT | 1d? | 2024-09-05 | 2024-09-05 |  | start no earlier than 2024-09-05 |
| 1202 | QIP Training Material & User Guides | 1d? | 2024-09-10 | 2024-09-10 |  | start no earlier than 2024-09-10 |
| 1203 | **Reporting Changes - Daily Excel Extract & PDF** | 2d | 2024-09-05 | 2024-09-06 |  |  |
| 1204 | Excel Daily Report changes (Refer to above) | 2d | 2024-09-05 | 2024-09-06 |  | start no earlier than 2024-09-05 |
| 1205 | PDF Daily Report changes (Refer to Above) | 2d | 2024-09-05 | 2024-09-06 |  | start no earlier than 2024-09-05 |
| 1206 | **Documentation Updates** | 23d? | 2024-09-02 A | 2024-10-02 |  |  |
| 1207 | Changes to onboarding process (security) | 10d | 2024-09-02 | 2024-09-13 |  | start no earlier than 2024-09-02 |
| 1208 | Update the documents on loading tests into ADO? | 10d | 2024-09-02 A | 2024-09-13 A |  | start no earlier than 2024-09-02 |
| 1209 | Update ADO Training material | 10d | 2024-09-02 A | 2024-09-13 A |  | start no earlier than 2024-09-02 |
| 1210 | Update ADO User Guide | 10d | 2024-09-02 A | 2024-09-13 A |  | start no earlier than 2024-09-02 |
| 1211 | Update ADO Configuration document | 10d | 2024-09-02 A | 2024-09-13 A |  | start no earlier than 2024-09-02 |
| 1212 | Update ADO Training Material and User Guide following SRO review | 1d? | 2024-10-02 A | 2024-10-02 A |  | start no earlier than 2024-10-02 |
| 1213 | **ADO Changes - Review Stage** | 19d? | 2024-09-09 A | 2024-10-03 A |  |  |
| 1214 | Review implementation with SI LDP leads | 1d? | 2024-09-27 A | 2024-09-27 A |  | start no earlier than 2024-09-27 |
| 1215 | Review implementation with SRO | 1d? | 2024-09-30 A | 2024-09-30 A |  | start no earlier than 2024-09-30 |
| 1216 | LDP Review - ADO User Guide, Training Materials | 5d | 2024-09-09 A | 2024-09-13 A |  | start no earlier than 2024-09-09 |
| 1217 | SRO Review - ADO User Guide, Training Materials | 1d? | 2024-09-30 A | 2024-09-30 A |  | start no earlier than 2024-09-30 |
| 1218 | LDP Review - Config doc | 1d? | 2024-09-30 A | 2024-09-30 A |  | start no earlier than 2024-09-30 |
| 1219 | SRO Review - Config doc | 1d? | 2024-09-30 A | 2024-09-30 A |  | start no earlier than 2024-09-30 |
| 1220 | SRO Sign-off of all changes | 1d? | 2024-10-03 A | 2024-10-03 A |  | start no earlier than 2024-10-03 |
| 1221 | **Azure DevOps Changes - Final Implementation** | 1d? | 2024-10-03 A | 2024-10-03 A |  |  |
| 1222 | Final task rollout | 1d? | 2024-10-03 A | 2024-10-03 A |  | start no earlier than 2024-10-03 |
| 1223 | ADO Training Drop-in Session ahead of Cycle 3 | 1d? | 2024-10-03 A | 2024-10-03 A |  | start no earlier than 2024-10-03 |
| 1255 | Sprint 5 | 10d? | 2024-10-21 | 2024-11-01 | 140SS-1d |  |
| 1256 | Sprint 6 | 10d? | 2024-11-04 | 2024-11-15 | 1255 |  |
| 1257 | Sprint 7 | 10d? | 2024-11-18 | 2024-11-29 | 1256 |  |
| 1258 | Sprint 8 | 15d? | 2024-12-02 | 2024-12-20 | 1257 |  |
| 1259 | Christmas downtime | 10d? | 2024-12-23 | 2025-01-03 | 1258 |  |
| 1260 | Sprint 9 | 10d? | 2025-01-06 | 2025-01-17 | 1259 |  |
| 1261 | Sprint 10 | 10d? | 2025-01-20 | 2025-01-31 | 1260 |  |
| 1262 | Sprint 11 | 10d? | 2025-02-03 | 2025-02-14 | 1261 |  |
| 1263 | Sprint 12 | 10d? | 2025-02-17 | 2025-02-28 | 1262 |  |
| 1264 | Sprint 13 (RTTM Gap Analysis + CR056) | 10d? | 2025-03-03 | 2025-03-14 | 1263 |  |
| 1265 | Sprint 14 (RTTM Gap Analysis + CR056) | 10d? | 2025-03-17 | 2025-03-28 | 1264 |  |
| 1266 | Sprint 15 (Contingency 1) | 10d? | 2025-03-31 | 2025-04-11 | 1265 |  |
| 1267 | Sprint 16 (Contingency 2) | 10d? | 2025-04-14 | 2025-04-25 | 1266 |  |
| 1269 | **SIT Functional Settlement Testing** | 230d? | 2024-06-17 | 2025-05-02 |  |  |
| 1270 | Settlement Testing Cycle 1 | 70d | 2024-06-17 | 2024-09-20 |  | start no earlier than 2024-06-17 |
| 1271 | Settlement Testing Cycle 2 | 55d? | 2024-10-07 | 2024-12-20 | 1144 |  |
| 1272 | Settlement Testing Cycle 3 (CoS Settlement Testing) | 20d? | 2025-05-19 | 2025-06-13 | 942, 1171 |  |
| 1274 | Regression Sprint 1 | 10d? | 2025-06-16 | 2025-06-27 | 1272, 1167 |  |
| 1275 | Regression Sprint 2 | 10d | 2025-06-30 | 2025-07-11 | 1274 |  |
| 1276 | Regression Sprint 3 | 15d | 2025-07-14 | 2025-08-01 | 1275 |  |
| 1283 | **Helix E2E Settlement Testing** | 65d | 2025-01-06 | 2025-04-04 |  |  |
| 1284 | Helix E2E Settlement Testing Execution | 65d | 2025-01-06 | 2025-04-04 | 1271FS+10d |  |
| 1285 | Helix E2E Settlement Testing Execution Complete | 0d | 2025-04-04 | 2025-04-04 | 1284 |  |
| 1286 | MHHSP Helix E2E Testing Assurance | 65d | 2025-01-06 | 2025-04-04 | 1271FS+10d |  |
| 1287 | MHHSP Helix E2E Testing Assurance Complete | 0d | 2025-04-04 | 2025-04-04 | 1286 |  |
| 1290 | **SIT Migration Testing Execution (Minimum Viable Cohort)** | 380d? | 2024-03-11 | 2025-08-22 |  |  |
| 1293 | Defect resolution, assurance, review, data& environments maintenance | 15d? | 2024-05-27 | 2024-06-14 |  | finish no earlier than 2024-06-14 |
| 1297 | **SIT Functional Testing back-up progress risk-assessment** | 70d? | 2024-06-17 | 2024-09-20 |  |  |
| 1298 | Back-up risk-assessment of SIT Migration progress to assess whether Qualification Execution can start early | 15d? | 2024-10-07 | 2024-10-25 | 1296 | finish no earlier than 2024-10-04 |
| 1299 | Back-up SITAG decision on early Qualification Testing Execution start | 0d? | 2024-11-01 | 2024-11-01 | 1298FS+5d |  |
| 1301 | Sprint 5 | 10d | 2024-10-21 | 2024-11-01 | 140FS-1d | start no earlier than 2024-10-21 |
| 1302 | Sprint 6 | 10d | 2024-11-04 | 2024-11-15 | 1301 | start no earlier than 2024-11-04 |
| 1303 | Sprint 7 | 10d | 2024-11-18 | 2024-11-29 | 1302 |  |
| 1304 | Sprint 8 | 15d | 2024-12-02 | 2024-12-20 | 1303 | finish no earlier than 2024-11-15 |
| 1305 | Christmas downtime | 10d | 2024-12-23 | 2025-01-03 | 1304 | finish no earlier than 2024-11-29 |
| 1306 | Sprint 9 | 10d | 2025-01-06 | 2025-01-17 | 1305 | finish no earlier than 2024-12-20 |
| 1307 | Sprint 10 | 10d | 2025-01-20 | 2025-01-31 | 1306 | finish no earlier than 2025-01-03 |
| 1308 | Sprint 11 | 10d | 2025-02-03 | 2025-02-14 | 1307 | finish no earlier than 2025-01-17 |
| 1309 | Sprint 12 | 10d | 2025-02-17 | 2025-02-28 | 1308 | finish no earlier than 2025-01-31 |
| 1310 | Sprint 13 | 10d | 2025-03-03 | 2025-03-14 | 1309 |  |
| 1311 | Sprint 14 (RTTM Gap Analysis + CR056) | 10d? | 2025-03-17 | 2025-03-28 | 1310 |  |
| 1312 | Sprint 15 (Contingency 1) | 10d? | 2025-03-31 | 2025-04-11 | 1311 |  |
| 1313 | Sprint 16 (Contingency 2) | 10d? | 2025-04-14 | 2025-04-25 | 1312 |  |
| 1314 | **SIT Migration MVC Regression Testing (code freeze)** | 35d? | 2025-06-16 | 2025-08-01 |  |  |
| 1315 | Regression Sprint 1 | 10d? | 2025-06-16 | 2025-06-27 | 1272 |  |
| 1316 | Regression Sprint 2 | 10d? | 2025-06-30 | 2025-07-11 | 1315 |  |
| 1317 | Regression Sprint 3 | 15d? | 2025-07-14 | 2025-08-01 | 1316 |  |
| 1318 | SIT Migration Testing End (Minimum Viable Cohort) (incl. confirmation that PPs have submitted their Test Completion Reports to Programme for assurance) | 0d | 2025-08-01 | 2025-08-01 | 1317 | start no earlier than 2025-06-20 |
| 1319 | **SIT Migration Test Completion Report (Minimum Viable Cohort)** | 25d | 2025-07-14 | 2025-08-15 | 1013, 959, 963, 970, 976, 982 |  |
| 1326 | Theme 1 (Helix and DIP Volume Testing) Start | 0d? | 2025-01-13 | 2025-01-13 | 1066 | start no earlier than 2025-01-13 |
| 1327 | Theme 1 (Helix and DIP Volume Testing) Execution | 15d? | 2025-01-13 | 2025-01-31 | 1326 | start no earlier than 2025-01-13 |
| 1330 | Theme 3 SIT Non-Functional Testing Start | 1d? | 2025-03-17 | 2025-03-17 | 1068, 1072 |  |
| 1331 | Theme 3 SIT Non-Functional Testing Execution | 40d? | 2025-03-17 | 2025-05-09 | 1330SS |  |
| 1339 | **Non-SIT B Testing** | 25d? | 2025-02-03 | 2025-03-07 |  |  |
| 1340 | SIT Operational Testing Start (Theme 3 - Batch 1 (Service Management)) | 0d? | 2025-02-03 | 2025-02-03 | 1131, 1108, 1109, 1110, 1111, 1130 | start no earlier than 2025-02-03 |
| 1341 | SIT Operational Testing Execution Window (Theme 3 - Batch 1 (Service Management)) | 25d? | 2025-02-03 | 2025-03-07 | 1340 | start no earlier than 2025-01-06 |
| 1342 | **SIT B Testing** | 70d? | 2025-02-07 | 2025-05-16 |  |  |
| 1344 | SIT Operational Testing Execution Theme 3 Batch 2 | 25d? | 2025-02-10 | 2025-03-14 | 1343, 1120 |  |
| 1345 | SIT Operational Testing Execution Theme 1 | 25d? | 2025-03-17 | 2025-04-18 | 1344 |  |
| 1346 | SIT Operational Testing Execution Theme 2 | 20d? | 2025-04-21 | 2025-05-16 | 1345 |  |
| 1360 | Test Execution (Cycle 3 Completion and Regression Testing) | 95d? | 2025-06-16 | 2025-10-24 | 1272 |  |
| 1385 | Update E2E Sandbox guidance to reflect CR55 | 29d | 2025-01-13 | 2025-02-20 |  | start no earlier than 2025-01-13 |
| 1386 | Internal SI review | 5d | 2025-02-21 | 2025-02-27 | 1385 |  |
| 1387 | SRO / Code Bodies review | 5d | 2025-02-28 | 2025-03-06 | 1386 |  |
| 1388 | Submit version to QWG | 3d | 2025-03-07 | 2025-03-11 | 1387 |  |
| 1389 | Artefact Approval (via QWG) | 0d | 2025-03-11 | 2025-03-11 | 1388 |  |
| 1390 | Final Document updates post QWG review | 1d? | 2025-03-13 | 2025-03-13 | 1389FS+1d |  |
| 1391 | Submit final version to QAG | 1d? | 2025-03-17 | 2025-03-17 | 1390FS+1d |  |
| 1392 | E2E Sandbox guidance update approved | 1d? | 2025-03-24 | 2025-03-24 | 1391FS+4d |  |
| 1395 | Internal SI review and updates | 5d | 2025-02-19 | 2025-02-25 | 1394 |  |
| 1396 | SRO / Code Bodies review | 5d | 2025-02-26 | 2025-03-04 | 1395 |  |
| 1397 | Submit proposed version to QWG | 0d | 2025-03-04 | 2025-03-04 | 1396 |  |
| 1398 | Discuss document at QWG | 0d | 2025-03-11 | 2025-03-11 | 1397FS+5d |  |
| 1399 | Final updates prior to consultation | 4d | 2025-03-12 | 2025-03-17 | 1398 |  |
| 1400 | Industry Consultation for E2E Sandbox Test Data Approach and Plan document | 10d | 2025-03-18 | 2025-03-31 | 1399 |  |
| 1401 | Document updates post Industry Consultation | 3d | 2025-04-01 | 2025-04-03 | 1400 | finish no earlier than 2024-04-22 |
| 1402 | Submit Proposed Version to QWG | 3d | 2025-04-04 | 2025-04-08 | 1401 |  |
| 1403 | Artefact Approval (via QWG) | 0d | 2025-04-08 | 2025-04-08 | 1402 |  |
| 1404 | Final Document updates post QWG review | 0d | 2025-04-09 | 2025-04-09 | 1403FS+1d | start no earlier than 2024-05-01 |
| 1405 | Submit final version to QAG | 0d | 2025-04-10 | 2025-04-10 | 1404FS+1d | start no earlier than 2024-05-02 |
| 1406 | E2E Sandbox Test Data Approach and Plan | 0d | 2025-04-16 | 2025-04-16 | 1405FS+4d | start no earlier than 2024-05-09 |
| 1491 | **System Integration Testing - Tier 1 Milestones** | 214d? | 2025-02-28 | 2025-12-24 |  |  |
| 1492 | M10 Checkpoint | 1d? | 2025-02-28 | 2025-02-28 | 1493FS-149d |  |
| 1601 | Non-SIT LDSO QT - Migration Testing | 20d? | 2025-01-06 | 2025-01-31 | 1600FS-1d |  |
| 1602 | Non-SIT LDSO QT - Functional Testing | 40d? | 2025-02-03 | 2025-03-28 | 1601 |  |
| 1603 | Non-SIT LDSO QT - Operational Testing | 15d? | 2025-03-31 | 2025-04-18 | 1602 |  |
| 1604 | Non-SIT LDSO QT - Non-Functional Testing | 15d? | 2025-04-21 | 2025-05-09 | 1603 |  |
| 1605 | Non-SIT LDSO QT - Regression Testing | 30d? | 2025-03-31 | 2025-05-09 | 1602 |  |
| 1705 | BSC PAB & REC Manager approval of Qualification for Non-SIT LDSOs (Start of Migration for Qualification Participants) | 0d | 2025-09-11 | 2025-09-11 | 1606, 1704FS+14d |  |
| 1967 | **Qualification Tier 1 Milestone** | 66d | 2026-10-28 | 2027-01-28 |  |  |
| 2091 | Code Bodies Submit Final Modification/Change Reports | 1d | 2024-11-08 | 2024-11-08 | 2090 |  |
| 2092 | Ofgem Reviews Final Modification/Change Reports | 10d | 2024-11-11 | 2024-11-22 | 2091 |  |
| 2093 | Ofgem Drafts Decision/Direction Letters | 17d | 2024-11-18 | 2024-12-10 | 2092SS+5d |  |
| 2094 | Ofgem Internally Signs Off the Decision/Direction Letters and Sends Them to the Code Bodies | 1d | 2024-12-11 | 2024-12-11 | 2093 |  |
| 2096 | Ofgem Publishes the Decisions/Directions | 2d | 2024-12-12 | 2024-12-13 | 2095 |  |
| 2300 | Confirmation of Helix E2E Settlement Testing Complete | 0d | 2025-08-01 | 2025-08-01 | 1285FS+85d |  |
| 2301 | Confirmation of assurance of Helix E2E Settlement Testing | 0d | 2025-08-01 | 2025-08-01 | 1287FS+85d |  |
| 2306 | Market-wide Participant MHHS Migration Supporting Functionality is Live | 0d | 2025-09-15 | 2025-09-15 | 2284 |  |
| 2315 | **Cutover Governance M11** | 19d | 2025-09-26 | 2025-10-22 |  |  |
| 2374 | **SIT MVC** | 166d? | 2025-02-03 | 2025-09-22 |  |  |
| 2375 | **SIT MVC Service Activation Preparation Tasks** | 20d | 2025-02-03 | 2025-02-28 |  |  |
| 2376 | Identify operational resources | 5d | 2025-02-03 | 2025-02-07 |  | finish no earlier than 2025-02-07 |
| 2377 | Define and approve operational support model | 5d | 2025-02-10 | 2025-02-14 |  | finish no earlier than 2025-02-14 |
| 2378 | Confirm SA Training completed | 10d | 2025-02-10 | 2025-02-21 |  | finish no earlier than 2025-02-21 |
| 2379 | Participant Engagement / Communications | 15d | 2025-02-10 | 2025-02-28 |  | finish no earlier than 2025-02-28 |
| 2380 | Internal Communications | 15d | 2025-02-10 | 2025-02-28 |  | finish no earlier than 2025-02-28 |
| 2381 | Validate User Access | 5d | 2025-02-17 | 2025-02-21 |  | finish no earlier than 2025-02-21 |
| 2382 | Target Systems and Environments Ready | 3d | 2025-02-20 | 2025-02-24 |  | finish no earlier than 2025-02-24 |
| 2383 | Provide opeartional resources with LWIs | 5d | 2025-02-17 | 2025-02-21 |  | finish no earlier than 2025-02-21 |
| 2384 | Business Readiness Governance Approval | 3d | 2025-02-17 | 2025-02-19 |  | finish no earlier than 2025-02-19 |
| 2385 | SIT MVC Service Activation Preparation Tasks Complete | 0d | 2025-02-28 | 2025-02-28 |  | finish no earlier than 2025-02-28 |
| 2387 | **SIT MVC Service Activation Implementation** | 7d? | 2025-09-12 | 2025-09-22 |  |  |
| 2388 | Add EDF to DIP | 1d | 2025-09-12 | 2025-09-12 | 1687SS, 2386, 2385 |  |
| 2389 | DIP Promoted to Production | 1d? | 2025-09-15 | 2025-09-15 | 2388 |  |
| 2390 | SIT LDSOs Create Certificates and Test Connectivity | 1d? | 2025-09-16 | 2025-09-16 | 2389 |  |
| 2391 | SIT MVC S&As Create Certificates and Test Connectivity | 1d? | 2025-09-16 | 2025-09-16 | 2389 |  |
| 2392 | Create M16 in Customer Solution | 2d | 2025-09-16 | 2025-09-17 | 2389 | finish no earlier than 2025-03-07 |
| 2393 | Publish ISD | 2d | 2025-09-18 | 2025-09-19 | 2392 | finish no earlier than 2025-03-07 |
| 2394 | SIT LDSOs to update systems with ISD | 1d? | 2025-09-22 | 2025-09-22 | 2393 |  |
| 2395 | SIT MVC S&As to update systems with ISD | 1d? | 2025-09-22 | 2025-09-22 | 2393 |  |
| 2396 | SIT MVC Service Activation Implementation Complete | 0d | 2025-09-19 | 2025-09-19 | 2393 | finish no earlier than 2025-03-07 |
| 2397 | **SIT MVC Service Activation Implementation MDD** | 14d | 2025-03-06 | 2025-03-25 |  |  |
| 2398 | MDD Manual Load | 7d | 2025-03-06 | 2025-03-14 |  | finish no earlier than 2025-03-14 |
| 2399 | MDD Update | 8d | 2025-03-14 | 2025-03-25 |  | finish no earlier than 2025-03-25 |
| 2400 | SIT MVC Service Activation Implementation MDD Complete | 0d | 2025-03-25 | 2025-03-25 |  | finish no earlier than 2025-03-25 |
| 2401 | **SIT MVC Service Activation Hypercare** | 18d | 2025-03-03 | 2025-03-26 |  |  |
| 2402 | Service & Process Monitoring | 18d | 2025-03-03 | 2025-03-26 |  | finish no earlier than 2025-03-26 |
| 2403 | Daily Reporting | 18d | 2025-03-03 | 2025-03-26 |  | finish no earlier than 2025-03-26 |
| 2404 | Issue Management | 18d | 2025-03-03 | 2025-03-26 |  | finish no earlier than 2025-03-26 |
| 2405 | SA Hypercare Close Down Activities | 18d | 2025-03-03 | 2025-03-26 |  | finish no earlier than 2025-03-26 |
| 2406 | Handover to MHHSP | 3d | 2025-03-21 | 2025-03-25 |  | finish no earlier than 2025-03-25 |
| 2407 | SIT MVC Service Activation Hypercare Complete | 0d | 2025-03-25 | 2025-03-25 |  | finish no earlier than 2025-03-25 |
| 2408 | **SIT Non-MVC** | 829d | 2022-10-31 | 2026-01-01 |  |  |
| 2409 | **SIT Non-MVC Service Activation Preparation Tasks** | 1d | 2022-10-31 | 2022-10-31 |  |  |
| 2412 | **SIT Non-MVC Service Activation Implementation** | 8d | 2025-12-23 | 2026-01-01 |  |  |
| 2413 | Add EDF to DIP | 2d | 2025-12-23 | 2025-12-24 | 1693SS, 2411 | finish no earlier than 2025-06-04 |
| 2414 | DIP Promoted to Production | 2d | 2025-12-25 | 2025-12-26 | 2413 | finish no earlier than 2025-06-05 |
| 2415 | Create M16 in Customer Solution | 2d | 2025-12-29 | 2025-12-30 | 2414 | finish no earlier than 2025-06-06 |
| 2416 | Publish ISD | 2d | 2025-12-31 | 2026-01-01 | 2415 | finish no earlier than 2025-06-06 |
| 2417 | SIT Non-MVC Service Activation Implementation Complete | 0d | 2026-01-01 | 2026-01-01 | 2416 | finish no earlier than 2025-06-06 |
| 2418 | **SIT Non-MVC Service Activation Implementation MDD** | 14d | 2025-06-05 | 2025-06-24 |  |  |
| 2419 | MDD Manual Load | 7d | 2025-06-05 | 2025-06-13 |  | finish no earlier than 2025-06-13 |
| 2420 | MDD Update | 8d | 2025-06-13 | 2025-06-24 |  | finish no earlier than 2025-06-24 |
| 2421 | SIT Non-MVC Service Activation Implementation MDD Complete | 0d | 2025-06-24 | 2025-06-24 |  | finish no earlier than 2025-06-24 |
| 2422 | **Non-SIT MVC Service Activation Hypercare** | 19d | 2025-06-02 | 2025-06-26 |  |  |
| 2423 | Service& Process Monitoring | 18d | 2025-06-02 | 2025-06-25 |  | finish no earlier than 2025-06-25 |
| 2424 | Daily Reporting | 18d | 2025-06-02 | 2025-06-25 |  | finish no earlier than 2025-06-25 |
| 2425 | Issue Management | 18d | 2025-06-02 | 2025-06-25 |  | finish no earlier than 2025-06-25 |
| 2426 | SA Hypercare Close Down Activities | 18d | 2025-06-02 | 2025-06-25 |  | finish no earlier than 2025-06-25 |
| 2427 | Handover to MHHSP | 4d | 2025-06-23 | 2025-06-26 |  | finish no earlier than 2025-06-26 |
| 2428 | Non-SIT MVC Service Activation Hypercare Complete (M) | 0d | 2025-06-25 | 2025-06-25 |  | finish no earlier than 2025-06-25 |
| 2429 | **Wave 1** | 924d | 2022-10-31 | 2026-05-14 |  |  |
| 2430 | **SIT Non-MVC Service Activation Preparation Tasks** | 924d | 2022-10-31 | 2026-05-14 |  |  |
| 2434 | **Wave 1 - Service Activation Implementation** | 5d | 2025-09-01 | 2025-09-05 |  |  |
| 2435 | MHHSP Enabled Confirmation | 2d | 2025-09-01 | 2025-09-02 |  | finish no earlier than 2025-09-02 |
| 2436 | PAB Approval | 2d | 2025-09-01 | 2025-09-02 |  | finish no earlier than 2025-09-02 |
| 2437 | Add EDF to DIP | 2d | 2025-09-02 | 2025-09-03 |  | finish no earlier than 2025-09-03 |
| 2438 | DIP Promoted to Production | 2d | 2025-09-03 | 2025-09-04 |  | finish no earlier than 2025-09-04 |
| 2439 | Create M16 in Customer Solution | 2d | 2025-09-04 | 2025-09-05 |  | finish no earlier than 2025-09-05 |
| 2440 | Publish ISD | 2d | 2025-09-04 | 2025-09-05 |  | finish no earlier than 2025-09-05 |
| 2441 | Wave 1 - Service Activation Implementation Complete (M) | 0d | 2025-09-05 | 2025-09-05 |  | finish no earlier than 2025-09-05 |
| 2442 | **Wave 1 - Service Activation Implementation MDD** | 10d | 2025-09-04 | 2025-09-17 |  |  |
| 2443 | MDD Manual Load | 5d | 2025-09-04 | 2025-09-10 |  | finish no earlier than 2025-09-10 |
| 2444 | MDD Update | 6d | 2025-09-10 | 2025-09-17 |  | finish no earlier than 2025-09-17 |
| 2445 | Wave 1 - Service Activation Implementation MDD Complete (M) | 0d | 2025-09-17 | 2025-09-17 |  | finish no earlier than 2025-09-17 |
| 2446 | **Wave 1 - Service Activation Hypercare** | 754d | 2022-10-31 | 2025-09-18 |  |  |
| 2447 | Service& Process Monitoring | 14d | 2025-09-01 | 2025-09-18 |  | finish no earlier than 2025-09-18 |
| 2448 | Daily Reporting | 14d | 2025-09-01 | 2025-09-18 |  | finish no earlier than 2025-09-18 |
| 2449 | Issue Management | 14d | 2025-09-01 | 2025-09-18 |  | finish no earlier than 2025-09-18 |
| 2450 | SA Hypercare Close Down Activities | 14d | 2025-09-01 | 2025-09-18 |  | finish no earlier than 2025-09-18 |
| 2451 | Handover to MHHSP | 4d | 2025-09-15 | 2025-09-18 |  | finish no earlier than 2025-09-18 |
| 2452 | Non-SIT LDSO Service Activation Hypercare Complete (M) | 0d | 2022-10-31 | 2022-10-31 |  |  |
| 2453 | **Wave 2** | 957d | 2022-10-31 | 2026-06-30 |  |  |
| 2454 | **SIT Non-MVC Service Activation Preparation Tasks** | 957d | 2022-10-31 | 2026-06-30 |  |  |
| 2458 | **Wave 2 - Service Activation Implementation** | 5d | 2025-11-03 | 2025-11-07 |  |  |
| 2459 | MHHSP Enabled Confirmation | 2d | 2025-11-03 | 2025-11-04 |  | finish no earlier than 2025-11-04 |
| 2460 | PAB Approval | 2d | 2025-11-03 | 2025-11-04 |  | finish no earlier than 2025-11-04 |
| 2461 | Add EDF to DIP | 2d | 2025-11-04 | 2025-11-05 |  | finish no earlier than 2025-11-05 |
| 2462 | DIP Promoted to Production | 2d | 2025-11-05 | 2025-11-06 |  | finish no earlier than 2025-11-06 |
| 2463 | Create M16 in Customer Solution | 2d | 2025-11-06 | 2025-11-07 |  | finish no earlier than 2025-11-07 |
| 2464 | Publish ISD | 2d | 2025-11-06 | 2025-11-07 |  | finish no earlier than 2025-11-07 |
| 2465 | Wave 2 - Service Activation Implementation Complete (M) | 0d | 2025-11-07 | 2025-11-07 |  | finish no earlier than 2025-11-07 |
| 2466 | **Wave 2 - Service Activation Implementation MDD** | 10d | 2025-11-06 | 2025-11-19 |  |  |
| 2467 | MDD Manual Load | 5d | 2025-11-06 | 2025-11-12 |  | finish no earlier than 2025-11-12 |
| 2468 | MDD Update | 6d | 2025-11-12 | 2025-11-19 |  | finish no earlier than 2025-11-19 |
| 2469 | Wave 2 - Service Activation Implementation MDD Complete (M) | 0d | 2025-11-19 | 2025-11-19 |  | finish no earlier than 2025-11-19 |
| 2470 | **Wave 2 - Service Activation Hypercare** | 14d | 2025-11-03 | 2025-11-20 |  |  |
| 2471 | Service& Process Monitoring | 14d | 2025-11-03 | 2025-11-20 |  | finish no earlier than 2025-11-20 |
| 2472 | Daily Reporting | 14d | 2025-11-03 | 2025-11-20 |  | finish no earlier than 2025-11-20 |
| 2473 | Issue Management | 14d | 2025-11-03 | 2025-11-20 |  | finish no earlier than 2025-11-20 |
| 2474 | SA Hypercare Close Down Activities | 14d | 2025-11-03 | 2025-11-20 |  | finish no earlier than 2025-11-20 |
| 2475 | Handover to MHHSP | 4d | 2025-11-17 | 2025-11-20 |  | finish no earlier than 2025-11-20 |
| 2476 | Wave 2 - Service Activation Hypercare Complete (M) | 0d | 2025-11-19 | 2025-11-19 |  | finish no earlier than 2025-11-19 |
| 2477 | **Wave 3** | 998d | 2022-10-31 | 2026-08-26 |  |  |
| 2478 | **SIT Non-MVC Service Activation Preparation Tasks** | 998d | 2022-10-31 | 2026-08-26 |  |  |
| 2482 | **Wave 3 - Service Activation Implementation** | 7d | 2025-12-22 | 2025-12-30 |  |  |
| 2483 | MHHSP Enabled Confirmation | 2d | 2025-12-22 | 2025-12-23 |  | finish no earlier than 2025-12-23 |
| 2484 | PAB Approval | 2d | 2025-12-22 | 2025-12-23 |  | finish no earlier than 2025-12-23 |
| 2485 | Add EDF to DIP | 2d | 2025-12-23 | 2025-12-24 |  | finish no earlier than 2025-12-24 |
| 2486 | DIP Promoted to Production | 2d | 2025-12-29 | 2025-12-30 |  | finish no earlier than 2025-12-30 |
| 2487 | Create M16 in Customer Solution | 2d | 2025-12-29 | 2025-12-30 |  | finish no earlier than 2025-12-30 |
| 2488 | Publish ISD | 2d | 2025-12-29 | 2025-12-30 |  | finish no earlier than 2025-12-30 |
| 2489 | Wave 3 - Service Activation Implementation Complete (M) | 0d | 2025-12-30 | 2025-12-30 |  | finish no earlier than 2025-12-30 |
| 2490 | **Wave 3 - Service Activation Implementation MDD** | 839d | 2022-10-31 | 2026-01-15 |  |  |
| 2491 | MDD Manual Load | 7d | 2025-12-29 | 2026-01-06 |  | finish no earlier than 2026-01-06 |
| 2492 | MDD Update | 269d | 2025-01-06 | 2026-01-15 |  | finish no earlier than 2026-01-15 |
| 2493 | Wave 3 - Service Activation Implementation MDD Complete (M) | 0d | 2022-10-31 | 2022-10-31 |  |  |
| 2494 | **Wave 3 - Service Activation Hypercare** | 840d | 2022-10-31 | 2026-01-16 |  |  |
| 2495 | Service& Process Monitoring | 20d | 2025-12-22 | 2026-01-16 |  | finish no earlier than 2026-01-16 |
| 2496 | Daily Reporting | 20d | 2025-12-22 | 2026-01-16 |  | finish no earlier than 2026-01-16 |
| 2497 | Issue Management | 20d | 2025-12-22 | 2026-01-16 |  | finish no earlier than 2026-01-16 |
| 2498 | SA Hypercare Close Down Activities | 20d | 2025-12-22 | 2026-01-16 |  | finish no earlier than 2026-01-16 |
| 2499 | Handover to MHHSP | 4d | 2026-01-12 | 2026-01-15 |  | finish no earlier than 2026-01-15 |
| 2500 | Wave 3 Service Activation Hypercare Complete (M) | 0d | 2022-10-31 | 2022-10-31 |  |  |
| 2501 | **Wave 4** | 1039d | 2022-10-31 | 2026-10-22 |  |  |
| 2502 | **SIT Non-MVC Service Activation Preparation Tasks** | 1039d | 2022-10-31 | 2026-10-22 |  |  |
| 2506 | **Wave 4 - Service Activation Implementation** | 265d | 2025-03-03 | 2026-03-06 |  |  |
| 2507 | MHHSP Enabled Confirmation | 2d | 2026-03-02 | 2026-03-03 |  | finish no earlier than 2026-03-03 |
| 2508 | PAB Approval | 1d | 2025-03-03 | 2025-03-03 |  | finish no earlier than 2025-03-03 |
| 2509 | Add EDF to DIP | 2d | 2026-03-03 | 2026-03-04 |  | finish no earlier than 2026-03-04 |
| 2510 | DIP Promoted to Production | 2d | 2026-03-04 | 2026-03-05 |  | finish no earlier than 2026-03-05 |
| 2511 | Create M16 in Customer Solution | 2d | 2026-03-05 | 2026-03-06 |  | finish no earlier than 2026-03-06 |
| 2512 | Publish ISD | 2d | 2026-03-05 | 2026-03-06 |  | finish no earlier than 2026-03-06 |
| 2513 | Wave 4 - Service Activation Implementation Complete (M) | 0d | 2026-03-06 | 2026-03-06 |  | finish no earlier than 2026-03-06 |
| 2514 | **Wave 4 - Service Activation Implementation MDD** | 15d | 2026-03-06 | 2026-03-26 |  |  |
| 2515 | MDD Manual Load | 7d | 2026-03-06 | 2026-03-16 |  | finish no earlier than 2026-03-16 |
| 2516 | MDD Update | 9d | 2026-03-16 | 2026-03-26 |  | finish no earlier than 2026-03-26 |
| 2517 | Wave 4 - Service Activation Implementation MDD Complete | 0d | 2026-03-25 | 2026-03-25 |  | finish no earlier than 2026-03-25 |
| 2518 | **Wave 4 - Service Activation Hypercare** | 19d | 2026-03-02 | 2026-03-26 |  |  |
| 2519 | Service& Process Monitoring | 19d | 2026-03-02 | 2026-03-26 |  | finish no earlier than 2026-03-26 |
| 2520 | Daily Reporting | 19d | 2026-03-02 | 2026-03-26 |  | finish no earlier than 2026-03-26 |
| 2521 | Issue Management | 19d | 2026-03-02 | 2026-03-26 |  | finish no earlier than 2026-03-26 |
| 2522 | SA Hypercare Close Down Activities | 19d | 2026-03-02 | 2026-03-26 |  | finish no earlier than 2026-03-26 |
| 2523 | Handover to MHHSP | 4d | 2026-03-02 | 2026-03-05 |  | finish no earlier than 2026-03-05 |
| 2524 | Wave 4 - Service Activation Hypercare Complete (M) | 0d | 2026-03-25 | 2026-03-25 |  | finish no earlier than 2026-03-25 |
| 2525 | **Non-SIT LDSO** | 741d | 2022-10-31 | 2025-09-01 |  |  |
| 2526 | **Non-SIT LDSO Service Activation Data Loading** | 176d | 2024-06-07 | 2025-02-07 |  |  |
| 2527 | Define pre Non-SIT LDSO upfront activities | 7d | 2024-06-07 | 2024-06-17 |  | finish no earlier than 2024-06-17 |
| 2528 | **Execute Non-SIT LDSO Activities** | 5d | 2025-02-03 | 2025-02-07 |  |  |
| 2529 | Create Entity Forms in Customer Solution | 3d | 2025-02-03 | 2025-02-05 |  | finish no earlier than 2025-02-05 |
| 2530 | DIP - Promote to Production Environment | 3d | 2025-02-03 | 2025-02-05 |  | finish no earlier than 2025-02-05 |
| 2531 | DIP - Enable Technology capabilities for participants | 3d | 2025-02-03 | 2025-02-05 |  | finish no earlier than 2025-02-05 |
| 2532 | DIP - Add EFD to DIP | 3d | 2025-02-03 | 2025-02-05 |  | finish no earlier than 2025-02-05 |
| 2533 | ISD - Replicate Entity Forms from CS | 2d | 2025-02-06 | 2025-02-07 |  | finish no earlier than 2025-02-07 |
| 2534 | MDD - Load MHHS roles | 3d | 2025-02-03 | 2025-02-05 |  | finish no earlier than 2025-02-05 |
| 2535 | Non-SIT LDSO Service Activation Data Loading Completed (M) | 0d | 2025-02-07 | 2025-02-07 |  | finish no earlier than 2025-02-07 |
| 2536 | **SIT Non-MVC Service Activation Preparation Tasks** | 741d | 2022-10-31 | 2025-09-01 |  |  |
| 2540 | **Non-SIT LDSO Service Activation Implementation** | 4d | 2025-02-24 | 2025-02-27 |  |  |
| 2541 | MHHSP Enabled Confirmation | 2d | 2025-02-24 | 2025-02-25 |  | finish no earlier than 2025-02-25 |
| 2542 | PAB Approval | 2d | 2025-02-24 | 2025-02-25 |  | finish no earlier than 2025-02-25 |
| 2543 | Add EDF to DIP | 2d | 2025-02-25 | 2025-02-26 |  | finish no earlier than 2025-02-26 |
| 2544 | DIP Promoted to Production | 2d | 2025-02-26 | 2025-02-27 |  | finish no earlier than 2025-02-27 |
| 2545 | Create M16 in Customer Solution | 2d | 2025-02-26 | 2025-02-27 |  | finish no earlier than 2025-02-27 |
| 2546 | Publish ISD | 2d | 2025-02-26 | 2025-02-27 |  | finish no earlier than 2025-02-27 |
| 2547 | Non-SIT LDSO Service Activation Implementation Completed (M) | 0d | 2025-02-27 | 2025-02-27 |  | finish no earlier than 2025-02-27 |
| 2548 | **Non-SIT LDSO Service Activation Implementation MDD** | 14d | 2025-02-27 | 2025-03-18 |  |  |
| 2549 | MDD Manual Load | 7d | 2025-02-27 | 2025-03-07 |  | finish no earlier than 2025-03-07 |
| 2550 | MDD Update | 8d | 2025-03-07 | 2025-03-18 |  | finish no earlier than 2025-03-18 |
| 2551 | Non-SIT LDSO Service Activation Implementation MDD Complete (M) | 0d | 2025-03-18 | 2025-03-18 |  | finish no earlier than 2025-03-18 |
| 2552 | **Non-SIT LDSO Service Activation Hypercare** | 18d | 2025-02-24 | 2025-03-19 |  |  |
| 2553 | **Non-SIT LDSO Service Activation Hypercare Support** | 18d | 2025-02-24 | 2025-03-19 |  |  |
| 2554 | Service& Process Monitoring | 18d | 2025-02-24 | 2025-03-19 |  | finish no earlier than 2025-03-19 |
| 2555 | Daily Reporting | 18d | 2025-02-24 | 2025-03-19 |  | finish no earlier than 2025-03-19 |
| 2556 | Issue Management | 18d | 2025-02-24 | 2025-03-19 |  | finish no earlier than 2025-03-19 |
| 2557 | SA Hypercare Close Down Activities | 18d | 2025-02-24 | 2025-03-19 |  | finish no earlier than 2025-03-19 |
| 2558 | Handover to MHHSP | 3d | 2025-03-14 | 2025-03-18 |  | finish no earlier than 2025-03-18 |
| 2559 | Non-SIT LDSO Service Activation Hypercare Complete (M) | 0d | 2025-03-18 | 2025-03-18 |  | finish no earlier than 2025-03-18 |

Removed: 44 Plan Rebaselined (subject to Ofgem decision); 509 Test Query Tool; 510 Test Query Tool Implementation; 511 Requirements identification; 513 Testing; 514 Accept tool; 515 Implementation; 516 Test Query Tool User Guide; 518 Review, update and agree Test Query Tool User Guide internally; 527 Revise Overarching Test Data Approach & plan for DPIA (if required), including engagement with DWG; 528 Review (internal), update and approve revised Overarching Test Data Approach & Plan (if required); 534 SI Data Cut Preparation & Infrastructure; 538 SI Data Cut Preparation & Infrastructure Complete; 841 Prepare, Generate and Allocate Test Data; 842 Transmit Data Sets to PPs; 843 PP's Iterative load and data integrity check; 844 Cycle 3 - PP's confirmation that test data is ready for SIT Functional; 984 Industry Consultation Review; 985 Review with SIT Working Group; 1033 Core Systems Code Freeze; 1043 SIT Migration Testing Execution (Minimum Viable Cohort); 1045 Regression Testing (code freeze); 1048 SIT Migration Testing Test Completion Report (Minimum Viable Cohort); 1049 Develop document; 1063 SIT Operational Testing Execution (Minimum Viable Cohort); 1079 Defect resolution, assurance, review, data & environments maintenance; 1081 Test Execution; 1082 Defect resolution, assurance, review, data & environments maintenance; 1084 Test Execution; 1085 Defect resolution, assurance, review, data & environments maintenance; 1086 Regression Testing (code freeze); 1087 SIT Other PPs continued support; 1102 SIT Non-Functional Testing (Other Participants); 1103 SIT Non-Functional Testing Execution (Other Participants); 1104 SIT Non-Functional Testing End (Other Participants) (incl. confirmation that PPs have submitted their Test Completion Reports to Programme for assurance); 1105 Assurance of PPs Test Completion Reports; 1106 SIT Non-Functional Testing Test Completion Report (Other Participants); 1107 Develop document; 1108 Review & agree document; 1109 SIT Non-Functional Testing Test Completion Report (Other Participants) Approved; 1110 SIT Operational Testing (Other Participants); 1111 SIT Operational Testing Execution (Other Participants); 1112 SIT Operational Testing End (Other Participants) (incl. confirmation that PPs have submitted their Test Completion Reports to Programme for assurance); 1113 Assurance of PPs Test Completion Reports; 1114 SIT Operational Testing Test Completion Report (Other Participants); 1115 Develop document; 1116 Review & agree document; 1117 SIT Operational Testing Test Completion Report (Other Participants) Approved; 1130 Review, update & agree document internally; 1192 E2E Sandbox Test Data Approach and Plan Approved; 1304 Final Test Readiness Report Developed & Submitted; 1472 Draft QT Operational Test Cases - Batch 3; 1473 Issue Batch 3 for Consultation; 1474 Update Batch 3 Post Consultation; 1475 QWG Endorsement of Batch 3; 1476 QAG Approval of QT Operational Test Scenarios and Test Cases Batch 3; 1559 Qualification Testing Framework (Test Stubs and Supporting UI) Complete; 1800 Ofgem to draft open letter and direction to each code body specifying the timetable for each modification; 1801 Ofgem to publish open letter; 1812 Panel make recommendation to OFGEM; 1853 Consultation 4 - Test; 1854 Prepare Artefacts for Consultation; 1856 Triage and Action Comments; 1857 Industry Assurance Review; 1858 MWG Recommendation; 1859 Consultation 4 - Test - MCAG Approval of Interim Artefacts; 1877 Data Arrangements; 1878 Agree and Ratify Approach; 1879 Arrange for Data to be received; 1880 Test Data Being Received; 1989 M15/M16 cut-over plan; 1990 Draft Document; 1991 Share Document with SRO; 1992 Industry Consultation; 1993 Assurance Meeting; 1994 Approval of M15/M16 cut-over plan; 2001 Go-Live Dress Rehearsals; 2002 Define dress rehearsal scenarios (incl. engagement with MWG); 2003 Set up, coordinate and conduct dress rehearsals; 2004 Evaluate dress rehearsals and identify lessons learned; 2114 SIT MVC Service Activation; 2115 Helix Preparatory Activities Complete; 2117 SIT Non-MVC Service Activation

Changed:

| ID | Task | Start | Finish | Duration | Complete | Total float | Predecessors | Other |
| --- | --- | --- | --- | --- | --- | --- | --- | --- |
| 1 | **PROGRAMME PLAN.** |  | 2027-05-28 → 2027-12-23 (+209d) | 1195d → 1344d? | 53% → 51% |  |  | was named PROGRAMME PLAN; baseline finish 2027-05-28 → 2027-12-23 |
| 3 | **PROGRAMME MANAGEMENT** |  |  |  | 42% → 44% | 106d → 255d |  |  |
| 4 | **Programme Management** |  |  |  | 41% → 43% | 106d → 255d |  |  |
| 5 | Sprint-based prioritisation planning and execution |  |  |  | 41% → 43% | 106d → 255d |  |  |
| 6 | Programme governance secretariat |  |  |  | 41% → 43% | 106d → 255d |  |  |
| 7 | RAID management and reporting |  |  |  | 41% → 43% | 106d → 255d |  |  |
| 8 | Tracking against Programme outcomes and KPIs |  |  |  | 41% → 43% | 106d → 255d |  |  |
| 9 | Change control and reporting |  |  |  | 41% → 43% | 106d → 255d |  |  |
| 10 | Ongoing identification of lessons learned relating to the PMO and implementation of improvements |  |  |  | 41% → 43% | 106d → 255d |  |  |
| 11 | **Programme Internal Assurance Reviews** |  |  |  | 41% → 43% | 106d → 255d |  |  |
| 12 | Programme Internal Assurance Reviews |  |  |  | 41% → 43% | 106d → 255d |  |  |
| 13 | **Engagement with PPs** |  |  |  | 41% → 43% | 106d → 255d |  |  |
| 14 | Ongoing PP liaison activities |  |  |  | 41% → 43% | 106d → 255d |  |  |
| 15 | Milestone and Control Point objective setting |  |  |  | 41% → 43% | 106d → 255d |  |  |
| 16 | Reporting |  |  |  | 41% → 43% | 106d → 255d |  |  |
| 17 | **PP Engagement Events** |  |  |  | 41% → 43% | 106d → 255d |  |  |
| 18 | Bilateral meetings |  |  |  | 41% → 43% | 106d → 255d |  |  |
| 19 | Monthly webinars |  |  |  | 41% → 43% | 106d → 255d |  |  |
| 20 | Open days |  |  |  | 41% → 43% | 106d → 255d |  |  |
| 21 | **PP Communications** |  |  |  | 41% → 43% | 107d → 256d |  |  |
| 22 | The Clock updates (weekly) |  |  |  | 41% → 43% | 107d → 256d |  |  |
| 23 | Maintain and update content on public-facing Portal (and ongoing feedback reviews to identify and implement Portal improvements) |  |  |  | 41% → 43% | 107d → 256d |  |  |
| 24 | **Code Change Support / Other Programme Alignment** |  |  |  | 41% → 43% | 106d → 255d |  |  |
| 25 | Support DCC/BEIS on SEC change |  |  |  | 41% → 43% | 106d → 255d |  |  |
| 26 | Support on Smart Meters Act changes |  |  |  | 41% → 43% | 106d → 255d |  |  |
| 27 | Support DCC/RECCo on CSS change |  |  |  | 41% → 43% | 106d → 255d |  |  |
| 28 | Support Elexon on BSC change |  |  |  | 41% → 43% | 106d → 255d |  |  |
| 29 | Support code change inside & outside CCIAG |  |  |  | 41% → 43% | 106d → 255d |  |  |
| 30 | Support code change inside & outside CCAG |  |  |  | 41% → 43% | 106d → 255d |  |  |
| 44 | Programme Replan playbacks and drop-in sessions |  |  |  |  |  | Plan Rebaselined (subject to Ofgem decision) → none |  |
| 45 | **DESIGN, BUILD & TEST (PIT)** |  | 2027-01-18 → 2027-07-05 (+168d) | 1101d → 1221d? | 81% → 78% | 94d → 123d |  | baseline finish 2027-01-18 → 2027-07-05 |
| 73 | **PIT Stub Specification and Delivery** |  |  |  |  |  |  | baseline finish 2024-06-21 → 2024-06-28 |
| 80 | **DIP Simulator Uplifts** |  |  |  |  |  |  | baseline finish 2024-06-21 → 2024-06-28 |
| 88 | DIP Simulator uplifted to align with Interim Release 8 |  |  |  |  |  |  | baseline start 2024-06-21 → 2024-06-28; baseline finish 2024-06-21 → 2024-06-28 |
| 96 | **Design Artefact Releases** |  | 2024-08-30 → 2024-11-13 (+75d) | 398d → 451d | 97% → 99% | 5d → 811d |  | baseline finish 2024-08-30 → 2024-11-13 |
| 129 | Update baselined artefacts |  |  |  |  |  |  | baseline finish 2023-10-27 → 2023-11-01 |
| 130 | Interim release 6 Go live |  |  |  |  |  |  | baseline start 2023-10-27 → 2023-11-01; baseline finish 2023-10-27 → 2023-11-01 |
| 136 | **Interim release 8** |  | 2024-08-30 → 2024-11-13 (+75d) | 143d → 196d | 78% → 99% | 5d → 811d |  | baseline finish 2024-08-30 → 2024-11-13 |
| 140 | Interim Release 8.3 'effective from date' to SIT A | 2024-08-19 → 2024-10-21 (+63d) | 2024-08-30 → 2024-10-21 (+52d) | 10d → 0d |  |  | 138FS+97d → 138FS+143d | was named Interim Release 8 Deployed to SIT; baseline start 2024-08-19 → 2024-10-21; baseline finish 2024-08-30 → 2024-10-21 |
| 163 | **PP Design, Build & Test (DBT)** |  | 2024-09-20 → 2027-07-05 (+1018d) | 495d → 1221d? | 97% → 82% | 0d → 123d |  | baseline finish 2024-09-20 → 2027-07-05 |
| 208 | **Central Systems DBT** |  |  |  |  |  |  | baseline finish 2024-02-23 → 2024-01-26 |
| 209 | **Elexon Central Systems DBT CIT (Entering at Interval 1)** |  |  |  |  |  |  | baseline finish 2023-10-12 → 2023-10-11 |
| 210 | **Design and Build** |  |  |  |  |  |  | baseline finish 2023-09-29 → 2023-09-22 |
| 211 | Helix Design and Build |  |  |  |  |  |  | baseline finish 2023-09-29 → 2023-09-22 |
| 218 | **Test Readiness Report** |  |  |  |  |  |  | baseline start 2023-08-03 → 2023-07-28; baseline finish 2023-10-12 → 2023-08-18 |
| 219 | Test readiness reporting |  |  |  |  |  |  | baseline start 2023-08-03 → 2023-07-28; baseline finish 2023-10-12 → 2023-08-18 |
| 226 | **PIT Execution** |  |  |  |  |  |  | baseline start 2022-10-31 → 2023-08-21 |
| 227 | PIT Test Execution Progress Report |  |  |  |  |  |  | baseline start 2022-10-31 → 2023-09-04; baseline finish 2023-09-22 → 2023-09-27 |
| 228 | Elexon Central Systems PIT Execution |  |  |  |  |  |  | baseline start 2022-11-08 → 2023-08-21; baseline finish 2023-10-09 → 2023-09-27 |
| 231 | **DIP DBT CIT (Entering at Interval 1)** |  |  |  |  |  |  | baseline start 2022-10-31 → 2023-01-02 |
| 234 | **Test Approach & Plan** |  |  |  |  |  |  | baseline start 2022-10-31 → 2023-07-07; baseline finish 2023-07-21 → 2023-07-20 |
| 236 | DIP Test Approach & Plan (PIT) MHHS Review Completed |  |  |  |  |  |  | baseline start 2023-07-10 → 2023-07-20; baseline finish 2023-07-21 → 2023-07-20 |
| 237 | **PIT Test Readiness Report** |  |  |  |  |  |  | baseline finish 2023-09-29 → 2023-09-01 |
| 238 | Test readiness reporting |  |  |  |  |  |  | baseline finish 2023-09-29 → 2023-09-01 |
| 239 | **Requirements to test Traceability Matrix (RTTM)** |  |  |  |  |  |  | baseline start 2022-10-31 → 2023-08-04; baseline finish 2023-08-18 → 2023-08-30 |
| 241 | DIP RTTM MHHS Review Completed |  |  |  |  |  |  | baseline start 2023-08-07 → 2023-08-30; baseline finish 2023-08-18 → 2023-08-30 |
| 242 | **Test Scenarios** |  |  |  |  |  |  | baseline start 2022-10-31 → 2023-07-31; baseline finish 2023-08-14 → 2023-08-30 |
| 244 | DIP Test scenarios MHHS Review Completed |  |  |  |  |  |  | baseline start 2023-08-01 → 2023-08-30; baseline finish 2023-08-14 → 2023-08-30 |
| 245 | **PIT execution** |  |  |  |  |  |  | baseline start 2023-09-01 → 2023-08-29 |
| 247 | PIT Execution (Interim Release 1) |  |  |  |  |  |  | baseline start 2023-09-06 → 2023-08-29 |
| 253 | **DCC (DSP) DBT SIT Functional (Entering at SIT Functional)** |  |  |  |  |  |  | baseline finish 2024-02-23 → 2024-01-26 |
| 258 | **Test Readiness Report** |  |  |  |  |  |  | baseline start 2023-10-27 → 2023-12-04; baseline finish 2024-01-05 → 2024-01-02 |
| 259 | Test readiness reporting |  |  |  |  |  |  | baseline start 2023-10-27 → 2023-12-04; baseline finish 2024-01-05 → 2024-01-02 |
| 266 | **RECCo (EES) DBT CIT (Entering at Interval 6)** |  |  |  |  |  |  | baseline start 2022-10-31 → 2023-10-13 |
| 270 | **Test Readiness Report** |  |  |  |  |  |  | baseline finish 2024-01-05 → 2023-11-09 |
| 271 | Test readiness reporting |  |  |  |  |  |  | baseline finish 2024-01-05 → 2023-11-09 |
| 278 | **PIT execution** |  |  |  |  |  |  | baseline start 2022-10-31 → 2023-11-10 |
| 280 | PIT Execution |  |  |  |  |  |  | baseline start 2022-10-31 → 2023-11-10 |
| 287 | **Test Readiness Report** |  |  |  |  |  |  | baseline start 2023-08-11 → 2023-08-14; baseline finish 2023-10-20 → 2023-09-08 |
| 288 | Test readiness reporting |  |  |  |  |  |  | baseline start 2023-08-11 → 2023-08-14; baseline finish 2023-10-20 → 2023-09-08 |

| ID | Task | Start | Finish | Duration | Complete | Total float | Predecessors | Other |
| --- | --- | --- | --- | --- | --- | --- | --- | --- |
| 296 | PIT Test Execution Progress Report |  |  |  |  |  |  | baseline finish 2023-10-20 → 2023-10-25 |
| 298 | Registration Services PIT (CIT interval 2) Completion Report submitted to Programme for assurance |  |  |  |  |  |  | baseline start 2023-10-20 → 2023-10-25; baseline finish 2023-10-20 → 2023-10-25 |
| 300 | **SIT Participants DBT** |  | 2024-09-20 → 2024-12-20 (+91d) | 291d → 356d | 92% → 89% | 0d → 125d |  | baseline start 2022-10-31 → 2023-08-11; baseline finish 2024-09-20 → 2024-12-20 |
| 301 | **All Data Services DBT CIT (Entering at Interval 3)** |  |  |  |  |  |  | baseline start 2022-10-31 → 2023-08-11 |
| 307 | **Requirements to test Traceability Matrix (RTTM)** |  |  |  |  |  |  | baseline start 2023-09-22 → 2023-09-20 |
| 308 | All Data Services RTTMs submitted to Programme for assurance |  |  |  |  |  |  | baseline start 2023-09-22 → 2023-09-20; baseline finish 2023-09-22 → 2023-09-20 |
| 310 | **Test Scenarios** |  |  |  |  |  |  | baseline start 2023-09-22 → 2023-09-20 |
| 311 | All Data Services test scenarios' submitted to Programme for assurance |  |  |  |  |  |  | baseline start 2023-09-22 → 2023-09-20; baseline finish 2023-09-22 → 2023-09-20 |
| 313 | **PIT execution** |  |  |  |  |  |  | baseline start 2022-10-31 → 2023-09-11 |
| 314 | PIT Test Execution Progress Report |  |  |  |  |  |  | baseline start 2022-10-31 → 2023-09-11; baseline finish 2023-10-27 → 2023-11-03 |
| 315 | PIT Execution |  |  |  |  |  |  | baseline start 2022-10-31 → 2023-09-28 |
| 318 | **All Metering Services DBT CIT (Entering at Interval 4)** |  |  |  |  |  |  | baseline start 2022-10-31 → 2023-08-25 |
| 322 | **Test Readiness Report** |  |  |  |  |  |  | baseline start 2023-09-08 → 2023-09-11; baseline finish 2023-11-17 → 2023-09-25 |
| 323 | Test readiness reporting |  |  |  |  |  |  | baseline start 2023-09-08 → 2023-09-11; baseline finish 2023-11-17 → 2023-09-25 |
| 330 | **PIT execution** |  |  |  |  |  |  | baseline start 2022-10-31 → 2023-09-25 |
| 332 | PIT Execution |  |  |  |  |  |  | baseline start 2022-10-31 → 2023-09-25 |
| 335 | **All SIT Programme Participants PIT (SIT Functional)** |  | 2024-09-20 → 2024-12-20 (+91d) | 221d → 286d | 82% → 77% | 0d → 125d |  | baseline start 2022-12-30 → 2023-11-17; baseline finish 2024-09-20 → 2024-12-20 |
| 339 | **Test Readiness Reports** |  |  |  |  |  |  | baseline finish 2024-02-09 → 2023-12-15 |
| 347 | **PIT execution** |  |  |  |  |  |  | baseline start 2022-12-30 → 2023-12-15 |
| 349 | PIT Execution |  |  |  |  |  |  | baseline start 2022-12-30 → 2023-12-15 |
| 352 | **All SIT Programme Participants PIT (SIT Migration)** |  |  |  |  |  |  | baseline start 2023-03-31 → 2024-02-16 |
| 356 | **Test Readiness Reports** |  |  |  |  |  |  | baseline finish 2024-05-10 → 2024-03-15 |
| 357 | Test readiness reporting |  |  |  |  |  |  | baseline finish 2024-05-10 → 2024-03-15 |
| 364 | **PIT execution** |  |  |  |  |  |  | baseline start 2023-03-31 → 2024-03-15 |
| 366 | PIT Execution |  |  |  |  |  |  | baseline start 2023-03-31 → 2024-03-15 |
| 369 | **All SIT Programme Participants PIT (SIT Non Functional)** | 2024-05-10 A → 2024-07-12 A (+63d) | 2024-08-16 → 2024-12-20 (+126d) | 71d → 116d | 75% → 63% | 11d → 125d |  | baseline start 2023-06-23 → 2024-07-12; baseline finish 2024-08-16 → 2024-12-20 |
| 370 | **Test Approach & Plan** | 2024-05-10 A → 2024-09-27 A (+140d) | 2024-07-04 A → 2024-11-22 (+141d) | 40d → 41d | 100% → 0% | none → 145d |  | baseline start 2024-05-10 → 2024-09-27; baseline finish 2024-07-04 → 2024-11-22 |
| 371 | SIT Non-Functional PIT Test Approach & Plan (PIT) submitted to Programme for assurance | 2024-05-10 A → 2024-09-27 A (+140d) | 2024-05-10 A → 2024-09-27 (+140d) |  | 100% → 75% | none → 0d |  | baseline start 2024-05-10 → 2024-09-27; baseline finish 2024-05-10 → 2024-09-27 |
| 372 | SIT Non-Functional Test approach and plan MHHS Review Completed | 2024-07-04 A → 2024-11-21 A (+140d) | 2024-07-04 A → 2024-11-22 (+141d) | 0d → 1d | 100% → 0% | none → 145d |  | baseline start 2024-07-04 → 2024-11-21; baseline finish 2024-07-04 → 2024-11-22 |
| 373 | **Test Readiness Report** | 2024-05-24 A → 2024-10-04 A (+133d) | 2024-06-07 A → 2024-10-22 (+137d) | 11d → 13d | 100% → 85% | none → 0d |  | baseline start 2024-05-24 → 2024-10-04; baseline finish 2024-08-02 → 2024-10-22 |
| 374 | Test readiness reporting | 2024-05-24 A → 2024-10-04 A (+133d) | 2024-06-07 A → 2024-10-22 (+137d) | 11d → 13d | 100% → 85% | none → 0d |  | baseline start 2024-05-24 → 2024-10-04; baseline finish 2024-08-02 → 2024-10-22 |
| 375 | **Requirements to test Traceability Matrix (RTTM)** | 2024-05-30 → 2024-11-01 A (+155d) | 2024-07-11 → 2024-11-29 (+141d) | 30d → 20d |  | 37d → 140d |  | baseline start 2024-05-30 → 2024-11-01; baseline finish 2024-07-11 → 2024-11-29 |
| 376 | SIT Non-Functional PIT RTTM submitted to Programme for assurance | 2024-05-30 → 2024-11-01 A (+155d) | 2024-05-30 → 2024-11-01 (+155d) |  | 0% → 75% | 37d → 140d | 371FS+15d → 371FS+26d | baseline start 2024-05-30 → 2024-11-01; baseline finish 2024-05-30 → 2024-11-01 |
| 377 | SIT Non-Functional RTTM MHHS Review Completed | 2024-07-11 → 2024-11-29 (+141d) | 2024-07-11 → 2024-11-29 (+141d) |  |  | 37d → 140d | 376FS+30d → 376FS+20d | constraint none → start no earlier than 2024-11-29; baseline start 2024-07-11 → 2024-11-29; baseline finish 2024-07-11 → 2024-11-29 |
| 378 | **Test Scenarios** | 2024-05-30 → 2024-11-01 (+155d) | 2024-07-11 → 2024-11-29 (+141d) | 30d → 20d |  | 29d → 0d |  | baseline start 2024-05-30 → 2024-11-01; baseline finish 2024-07-11 → 2024-11-29 |
| 379 | SIT Non-Functional PIT test scenarios submitted to Programme for assurance | 2024-05-30 → 2024-11-01 (+155d) | 2024-05-30 → 2024-11-01 (+155d) |  |  | 29d → 0d | 371FS+15d → 371FS+26d | baseline start 2024-05-30 → 2024-11-01; baseline finish 2024-05-30 → 2024-11-01 |
| 380 | SIT Non-Functional Test scenarios MHHS Review Completed | 2024-07-11 → 2024-11-29 (+141d) | 2024-07-11 → 2024-11-29 (+141d) |  |  | 37d → 140d | 379FS+30d → 379FS+20d | baseline start 2024-07-11 → 2024-11-29; baseline finish 2024-07-11 → 2024-11-29 |
| 381 | **PIT execution** | 2024-06-07 A → 2024-07-12 A (+35d) | 2024-08-16 → 2024-12-20 (+126d) | 51d → 116d | 71% → 61% | 11d → 125d |  | baseline start 2023-06-23 → 2024-07-12; baseline finish 2024-08-16 → 2024-12-20 |
| 382 | PIT Test Execution Progress Report | 2024-06-10 A → 2024-07-15 A (+35d) | 2024-08-01 → 2024-11-21 (+112d) | 39d → 50d | 72% → 56% | 12d → 131d |  | constraint none → finish no earlier than 2024-11-21; baseline start 2024-06-10 → 2024-07-15; baseline finish 2024-08-01 → 2024-11-21 |
| 383 | PIT Execution | 2024-06-07 A → 2024-07-12 A (+35d) | 2024-08-02 → 2024-11-29 (+119d) | 41d → 44d | 71% → 66% | 11d → 125d |  | constraint none → finish no earlier than 2024-11-29; baseline start 2023-06-23 → 2024-07-12; baseline finish 2024-08-02 → 2024-11-29 |
| 384 | SIT Non-Functional PIT Completion Report submitted to Programme for assurance | 2024-08-02 → 2024-11-29 (+119d) | 2024-08-02 → 2024-11-29 (+119d) |  |  | 11d → 125d |  | baseline start 2024-08-02 → 2024-11-29; baseline finish 2024-08-02 → 2024-11-29 |
| 385 | SIT Non-Functional PIT Completion Report MHHS Review Completed | 2024-08-16 → 2024-12-20 (+126d) | 2024-08-16 → 2024-12-20 (+126d) |  |  | 11d → 125d | 372, 377, 380, 384FS+10d → 372, 377, 380, 384FS+15d | baseline start 2024-08-16 → 2024-12-20; baseline finish 2024-08-16 → 2024-12-20 |
| 386 | **All SIT Programme Participants PIT (SIT Operational)** | 2024-06-14 A → 2024-07-12 A (+28d) | 2024-09-20 → 2024-12-20 (+91d) | 71d → 116d | 52% → 46% | 0d → 87d |  | baseline start 2024-06-14 → 2024-07-12; baseline finish 2024-09-20 → 2024-12-20 |
| 387 | **Test Approach & Plan** | 2024-06-14 → 2024-09-27 (+105d) | 2024-08-08 → 2024-11-21 (+105d) |  |  | 19d → 0d |  | baseline start 2024-06-14 → 2024-09-27; baseline finish 2024-08-08 → 2024-11-21 |
| 388 | SIT Operational PIT Test Approach & Plan (PIT) submitted to Programme for assurance | 2024-06-14 → 2024-09-27 (+105d) | 2024-06-14 → 2024-09-27 (+105d) |  |  | 19d → 0d |  | constraint start no earlier than 2024-06-14 → start no earlier than 2024-09-27; baseline start 2024-06-14 → 2024-09-27; baseline finish 2024-06-14 → 2024-09-27 |
| 389 | SIT Operational Test approach and plan MHHS Review Completed | 2024-08-08 → 2024-11-21 (+105d) | 2024-08-08 → 2024-11-21 (+105d) |  |  | 31d → 108d |  | baseline start 2024-08-08 → 2024-11-21; baseline finish 2024-08-08 → 2024-11-21 |
| 390 | **Test Readiness Report** | 2024-06-28 A → 2024-10-04 A (+98d) | 2024-07-12 A → 2024-10-22 (+102d) | 11d → 13d | 100% → 42% | none → 0d |  | baseline start 2024-06-28 → 2024-10-04; baseline finish 2024-09-06 → 2024-10-22 |
| 391 | Test readiness reporting | 2024-06-28 A → 2024-10-04 A (+98d) | 2024-07-12 A → 2024-10-22 (+102d) | 11d → 13d | 100% → 42% | none → 0d |  | baseline start 2024-06-28 → 2024-10-04; baseline finish 2024-09-06 → 2024-10-22 |
| 392 | **Requirements to test Traceability Matrix (RTTM)** | 2024-07-04 → 2024-11-01 (+120d) | 2024-08-15 → 2024-11-29 (+106d) | 30d → 20d |  | 26d → 102d |  | baseline start 2024-07-04 → 2024-11-01; baseline finish 2024-08-15 → 2024-11-29 |
| 393 | SIT Operational PIT RTTM submitted to Programme for assurance | 2024-07-04 → 2024-11-01 (+120d) | 2024-07-04 → 2024-11-01 (+120d) |  |  | 26d → 102d | 388FS+15d → 388FS+26d | baseline start 2024-07-04 → 2024-11-01; baseline finish 2024-07-04 → 2024-11-01 |
| 394 | SIT Operational RTTM MHHS Review Completed | 2024-08-15 → 2024-11-29 (+106d) | 2024-08-15 → 2024-11-29 (+106d) |  |  | 26d → 102d | 393FS+30d → 393FS+20d | baseline start 2024-08-15 → 2024-11-29; baseline finish 2024-08-15 → 2024-11-29 |
| 395 | **Test Scenarios** | 2024-07-04 → 2024-11-01 (+120d) | 2024-08-15 → 2024-11-29 (+106d) | 30d → 20d |  | 19d → 0d |  | baseline start 2024-07-04 → 2024-11-01; baseline finish 2024-08-15 → 2024-11-29 |
| 396 | SIT Operational PIT test scenarios submitted to Programme for assurance | 2024-07-04 → 2024-11-01 (+120d) | 2024-07-04 → 2024-11-01 (+120d) |  |  | 19d → 0d | 388FS+15d → 388FS+26d | baseline start 2024-07-04 → 2024-11-01; baseline finish 2024-07-04 → 2024-11-01 |
| 397 | SIT Operational Test scenarios MHHS Review Completed | 2024-08-15 → 2024-11-29 (+106d) | 2024-08-15 → 2024-11-29 (+106d) |  |  | 26d → 102d | 396FS+30d → 396FS+20d | baseline start 2024-08-15 → 2024-11-29; baseline finish 2024-08-15 → 2024-11-29 |
| 398 | **PIT execution** |  | 2024-09-20 → 2024-12-20 (+91d) | 51d → 116d | 46% → 47% | 0d → 87d |  | baseline finish 2024-09-20 → 2024-12-20 |
| 399 | PIT Test Execution Progress Report |  | 2024-09-06 → 2024-11-21 (+76d) |  |  | 0d → 93d |  | baseline finish 2024-09-06 → 2024-11-21 |
| 400 | PIT Execution |  | 2024-09-06 → 2024-11-29 (+84d) | 41d → 39d | 46% → 49% | 0d → 87d | 396FS+5d → 396 | baseline finish 2024-09-06 → 2024-11-29 |
| 401 | SIT Operational PIT Completion Report submitted to Programme for assurance | 2024-09-06 → 2024-11-29 (+84d) | 2024-09-06 → 2024-11-29 (+84d) |  |  | 0d → 87d |  | baseline start 2024-09-06 → 2024-11-29; baseline finish 2024-09-06 → 2024-11-29 |
| 402 | SIT Operational PIT Completion Report MHHS Review Completed | 2024-09-20 → 2024-12-20 (+91d) | 2024-09-20 → 2024-12-20 (+91d) |  |  | 0d → 87d | 389, 394, 397, 401FS+10d → 389, 394, 397, 401FS+15d | baseline start 2024-09-20 → 2024-12-20; baseline finish 2024-09-20 → 2024-12-20 |
| 403 | **All Suppliers DBT CIT (Entering at Interval 5)** |  |  |  |  |  |  | baseline start 2022-10-31 → 2023-09-15 |
| 407 | **Test Readiness Report** |  |  |  |  |  |  | baseline finish 2023-12-08 → 2023-10-13 |
| 408 | Test readiness reporting |  |  |  |  |  |  | baseline finish 2023-12-08 → 2023-10-13 |
| 415 | **PIT execution** |  |  |  |  |  |  | baseline start 2022-10-31 → 2023-10-13 |
| 417 | PIT Execution |  |  |  |  |  |  | baseline start 2022-10-31 → 2023-10-13 |
| 420 | **All LDSO Network Operations DBT CIT (Entering at Interval 5)** |  |  |  |  |  |  | baseline start 2022-10-31 → 2023-09-15; baseline finish 2024-01-05 → 2023-12-22 |
| 421 | **Test Approach & Plan** |  |  |  |  |  |  | baseline start 2022-10-31 → 2023-09-15; baseline finish 2024-01-05 → 2023-12-22 |
| 424 | **Test Readiness Report** |  |  |  |  |  |  | baseline start 2023-08-11 → 2023-09-29; baseline finish 2023-10-20 → 2023-10-13 |
| 425 | Test readiness reporting |  |  |  |  |  |  | baseline start 2023-08-11 → 2023-09-29; baseline finish 2023-10-20 → 2023-10-13 |
| 432 | **PIT execution** |  |  |  |  |  |  | baseline start 2022-10-31 → 2023-10-13; baseline finish 2024-01-05 → 2023-12-22 |
| 433 | PIT Test Execution Progress Report |  |  |  |  |  |  | baseline start 2022-10-31 → 2023-10-16; baseline finish 2023-12-29 → 2023-12-08 |

| ID | Task | Start | Finish | Duration | Complete | Total float | Predecessors | Other |
| --- | --- | --- | --- | --- | --- | --- | --- | --- |
| 434 | PIT Execution |  |  |  |  |  |  | baseline start 2022-10-31 → 2023-10-13; baseline finish 2024-01-05 → 2023-12-08 |
| 437 | **All UMSO DBT CIT (Entering at Interval 6)** |  |  |  |  |  |  | baseline start 2022-10-31 → 2023-09-29 |
| 438 | **Test Approach & Plan** |  |  |  |  |  |  | baseline start 2023-09-15 → 2023-10-13 |
| 439 | All UMSO Test Approach & Plans (PIT) submitted to Programme for assurance |  |  |  |  |  |  | baseline start 2023-09-15 → 2023-10-13; baseline finish 2023-09-15 → 2023-10-13 |
| 441 | **Test Readiness Report** |  |  |  |  |  |  | baseline start 2023-10-27 → 2023-09-29; baseline finish 2023-11-10 → 2023-10-13 |
| 443 | **Requirements to test Traceability Matrix (RTTM)** |  |  |  |  |  |  | baseline start 2023-11-02 → 2023-10-05; baseline finish 2023-11-30 → 2023-11-01 |
| 446 | **Test Scenarios** |  |  |  |  |  |  | baseline start 2023-11-02 → 2023-10-05; baseline finish 2023-11-30 → 2023-11-01 |
| 449 | **PIT execution** |  |  |  |  |  |  | baseline start 2022-10-31 → 2023-11-10 |
| 451 | PIT Execution |  |  |  |  |  |  | baseline start 2022-10-31 → 2023-11-10; baseline finish 2024-01-05 → 2024-01-04 |
| 479 | Post-assurance review of recommendations take-up by assured participants |  |  |  |  |  |  | baseline start 2023-10-02 → 2023-08-29 |
| 488 | Post-assurance review of recommendations take-up by assured participants |  |  |  |  |  |  | baseline start 2023-10-02 → 2023-08-14 |
| 492 | **Test Assurance** |  |  |  |  | 499d → 648d |  | baseline start 2022-10-31 → 2023-02-01 |
| 500 | **SYSTEMS INTEGRATION TESTING (SIT)** |  |  | 910d → 910d? | 66% → 62% | 285d → none |  | baseline finish 2026-01-19 → 2026-04-24 |
| 501 | **SIT Preparation** |  | 2024-10-25 → 2025-05-16 (+203d) | 520d → 665d? | 98% → 81% | 675d → 679d |  | baseline finish 2025-03-03 → 2025-05-16 |
| 507 | Environment Approach and Plan - SIT Functional |  |  |  |  |  |  | baseline start 2023-11-15 → 2023-11-20; baseline finish 2023-11-15 → 2023-11-20 |
| 513 | **Overarching Test Scope (for all stages)** |  |  |  |  |  |  | baseline finish 2023-06-30 → 2023-01-27 |
| 531 | SIT CIT Full Traceability & Coverage complete |  |  |  |  |  |  | baseline finish 2023-12-08 → 2023-12-20 |
| 533 | **Test Tool Development** |  | 2023-10-23 A | 256d → 256d? | 99% → 100% | 939d → none |  | baseline finish 2023-06-30 → 2023-10-23 |
| 534 | **Test Management Tool** |  |  |  |  |  |  | baseline finish 2023-06-30 → 2023-10-23 |
| 535 | **Test Management Tool Implementation** |  |  |  |  |  |  | baseline finish 2023-06-30 → 2023-10-23 |
| 540 | Implementation |  |  |  |  |  |  | baseline start 2023-06-30 → 2023-10-23; baseline finish 2023-06-30 → 2023-10-23 |
| 553 | **Data Protection Impact Assessment (DPIA)** | 2023-06-01 A → 2023-06-30 A (+29d) |  | 32d → 11d? |  |  |  | baseline start 2023-06-01 → 2023-06-30 |
| 554 | Conduct DPIA on Overall Test Data Approach | 2023-06-01 A → 2023-06-30 A (+29d) |  | 22d → 1d? |  |  | 523 → none | constraint start no earlier than 2023-06-01 → finish no earlier than 2023-06-30; baseline start 2023-06-01 → 2023-06-30 |
| 557 | **Data Sharing Agreements** | 2023-07-17 A → 2023-08-04 A (+18d) |  | 44d → 30d? |  |  |  | baseline start 2023-07-17 → 2023-08-04 |
| 558 | Produce Data Sharing Agreement for Industry Review | 2023-07-17 A → 2023-08-04 A (+18d) |  | 15d → 1d? |  |  | Review (internal), update and approve revised Overarching Test Data Approach & Plan (if required) → none | constraint none → finish no earlier than 2023-08-04; baseline start 2023-07-17 → 2023-08-04 |
| 559 | Manage Participant Queries and Contract Agreement Execution | 2023-08-07 A → 2023-09-14 A (+38d) |  | 29d → 1d? |  |  | 558 → none | constraint none → finish no earlier than 2023-09-14; baseline start 2023-08-07 → 2023-09-14 |
| 560 | Data Sharing Agreements Complete |  |  | 0d → 1d? |  |  | 559 → none | constraint none → start no earlier than 2023-09-14 |
| 561 | **Production Data Cut & Data Obfuscation** | 2023-04-04 A → 2023-06-19 A (+76d) |  | 109d → 55d? |  |  |  | baseline start 2023-04-04 → 2023-06-19 |
| 563 | SI Data Cut Planning activities (incl. pre-cut and post-cut cleansing and population approach) | 2023-04-04 A → 2023-06-19 A (+76d) |  | 55d → 1d? |  |  |  | constraint must start on 2023-04-04 → finish no earlier than 2023-06-19; baseline start 2023-04-04 → 2023-06-19 |
| 564 | Set up SI database and transmission structure | 2023-06-19 A → 2023-08-17 A (+59d) |  | 44d → 1d? |  |  | 563 → none | constraint must start on 2023-06-19 → finish no earlier than 2023-08-17; baseline start 2023-06-19 → 2023-08-17 |
| 565 | Mechanism for transfer of data in place |  |  | 1d → 1d? |  |  | 564 → none | constraint none → start no earlier than 2023-08-18 |
| 567 | **Production Data Cut** |  |  | 55d → 55d? |  |  |  |  |
| 568 | Notification of Production Data Cut issued to relevant participants |  |  | 0d → 1d? |  |  | 523 → none | constraint none → start no earlier than 2023-06-19 |
| 569 | Coordinate relevant participants taking data cut from production systems | 2023-06-19 A → 2023-08-11 A (+53d) |  | 40d → 1d? |  |  | 568 → none | constraint none → finish no earlier than 2023-08-11; baseline start 2023-06-19 → 2023-08-11 |
| 570 | Production data cut GONG decision |  |  | 0d → 1d? |  |  | 569FS+3d → none | constraint none → start no earlier than 2023-08-16 |
| 571 | Relevant participants take data cut from production systems (Saturday 19 August) |  |  | 1d → 1d? |  |  | 570FS+2d → none | constraint none → start no earlier than 2023-08-21 |
| 572 | EES transmit request data to SI | 2023-08-21 A → 2023-08-25 A (+4d) |  | 5d → 1d? |  |  | 571SS → none | constraint none → finish no earlier than 2023-08-25; baseline start 2023-08-21 → 2023-08-25 |
| 573 | Check data alignment and integrity of data cut | 2023-08-28 A → 2023-09-01 A (+4d) |  | 5d → 1d? |  |  | 572 → none | constraint none → finish no earlier than 2023-09-01; baseline start 2023-08-28 → 2023-09-01 |
| 574 | Data cut from relevant participants' production systems completed (Saturday 19 August) |  |  | 0d → 1d? |  |  | 571, 554 → none | constraint none → start no earlier than 2023-08-21 |
| 575 | Production Data Cut Complete |  |  | 0d → 1d? |  |  | 574 → none | constraint none → start no earlier than 2023-08-21 |
| 582 | **SIT Stage-Specific Preparation** |  | 2024-10-25 → 2025-05-16 (+203d) | 520d → 665d? | 97% → 77% | 675d → 679d |  | baseline finish 2025-03-03 → 2025-05-16 |
| 583 | **SIT Component Integration Preparation** |  |  |  |  |  |  | baseline finish 2024-01-22 → 2024-01-19 |
| 611 | **CIT Interval 1 Preparation** |  |  |  |  |  |  | baseline finish 2023-12-08 → 2023-12-15 |
| 612 | **Environments (SIT A)** |  |  |  |  |  |  | baseline finish 2023-10-16 → 2023-10-25 |
| 614 | PPs register PKI Officers and request PKI certificates Complete - Interval 1 |  |  |  |  |  |  | baseline start 2023-10-13 → 2023-10-25; baseline finish 2023-10-13 → 2023-10-25 |
| 615 | PP SIT A environment preparation (incl. security certificates and security compliance) |  |  |  |  |  |  | baseline finish 2023-09-01 → 2023-10-13 |
| 616 | SI coordinate SIT Participants' SIT A environment preparation |  |  |  |  |  |  | baseline finish 2023-09-01 → 2023-10-13 |
| 617 | PP submit self-declaration of environment preparation complete (incl. security certificates and security compliance) to Programme for assurance |  |  |  |  |  |  | baseline start 2023-09-01 → 2023-10-13; baseline finish 2023-09-01 → 2023-10-13 |
| 618 | SI assure PPs' self-declaration of environment preparation complete (incl. security certificates and security compliance) |  |  |  |  |  |  | baseline start 2023-09-04 → 2023-10-16; baseline finish 2023-09-08 → 2023-10-20 |
| 620 | PP SIT A environment connectivity proving |  |  |  |  |  |  | baseline start 2023-09-12 → 2023-09-04; baseline finish 2023-10-09 → 2023-09-15 |
| 621 | SI coordinate SIT Participants' SIT A environment connectivity proving |  |  |  |  |  |  | baseline start 2023-09-12 → 2023-09-04; baseline finish 2023-10-09 → 2023-09-15 |
| 622 | PP deployment of MHHS solution code to SIT A environments |  |  |  |  |  |  | baseline start 2023-09-26 → 2023-09-25; baseline finish 2023-10-09 → 2023-10-06 |
| 623 | SI coordinate deployment of MHHS solution code to SIT Participants' SIT A environments |  |  |  |  |  |  | baseline start 2023-09-26 → 2023-09-25; baseline finish 2023-10-09 → 2023-10-06 |
| 624 | PP submit evidence of SIT A environment connectivity proving and code deployment completion to Programme for assurance |  |  |  |  |  |  | baseline start 2023-09-12 → 2023-09-04; baseline finish 2023-10-09 → 2023-10-13 |
| 625 | SI assurance of SIT Participants' SIT A environment connectivity proving and code deployment completion |  |  |  |  |  |  | baseline start 2023-09-12 → 2023-09-18; baseline finish 2023-10-16 → 2023-10-20 |
| 627 | Set-up Market Participants and DIP ID Data |  |  |  |  |  | 575 → none |  |
| 631 | Create Containers and Keys for Participants |  |  |  |  |  | SI Data Cut Preparation & Infrastructure Complete → none |  |
| 636 | Generate Sample Files off IF Messages |  |  |  |  |  | SI Data Cut Preparation & Infrastructure Complete → none |  |
| 639 | **Test Data - Detailed SIT Data Load Guidance** |  |  |  |  |  |  | baseline finish 2023-12-01 → 2023-12-06 |
| 640 | Document Guidance |  |  |  |  |  |  | baseline finish 2023-09-28 → 2023-10-05 |
| 641 | Provide Guidance to PPs |  |  |  |  |  |  | baseline start 2023-09-29 → 2023-10-06; baseline finish 2023-09-29 → 2023-10-06 |
| 642 | Test Data - Detailed SIT Functional Data Load Guidance Complete |  |  |  |  |  |  | baseline start 2023-12-01 → 2023-12-06; baseline finish 2023-12-01 → 2023-12-06 |
| 643 | **Test Data - Population of Data Items for Testing Guidance - Draft** |  |  |  |  |  |  | baseline finish 2023-12-01 → 2023-12-06 |
| 646 | Test Data - Population of Data Items for Testing Guidance - Draft Complete |  |  |  |  |  |  | baseline start 2023-12-01 → 2023-12-06; baseline finish 2023-12-01 → 2023-12-06 |
| 647 | **Test Data - Population of Data Items for Testing Guidance - Final** |  |  |  |  |  |  | baseline start 2023-10-09 → 2023-08-17; baseline finish 2023-12-08 → 2023-12-15 |
| 648 | Update Document Guidance With PPS Feedback |  |  |  |  |  |  | baseline start 2023-10-09 → 2023-08-17 |
| 650 | Test Data - Population of Data Items for Testing Guidance - Final Complete |  |  |  |  |  |  | baseline start 2023-12-08 → 2023-12-15; baseline finish 2023-12-08 → 2023-12-15 |
| 651 | **Test Data (SIT A) Interval 1** |  |  |  |  |  |  | baseline finish 2023-09-29 → 2023-10-27 |
| 652 | Run data allocation |  |  |  |  |  | 573, 592, 575, 629 → 592, 629 |  |
| 654 | Transmit data sets to PPs |  |  |  |  |  | 653, 560 → 653 | baseline finish 2023-09-15 → 2023-09-19 |

| ID | Task | Other |
| --- | --- | --- |
| 655 | PP - Load test data to test environments | baseline start 2023-09-18 → 2023-09-20; baseline finish 2023-09-22 → 2023-09-28 |
| 656 | PP Check data integrity on test environment | baseline start 2023-09-25 → 2023-09-29 |
| 658 | Test Data (SIT A) Interval 1 Complete | baseline start 2023-09-29 → 2023-10-27; baseline finish 2023-09-29 → 2023-10-27 |
| 662 | **SIT Component Integration Test Readiness Report** | baseline start 2023-10-09 → 2023-09-14; baseline finish 2023-10-20 → 2023-10-23 |
| 663 | PP submit Test Readiness Report to Programme for assurance | baseline start 2023-10-09 → 2023-10-20; baseline finish 2023-10-09 → 2023-10-20 |
| 664 | SI assure Test Participants' Test Readiness Reports | baseline start 2023-10-10 → 2023-10-23; baseline finish 2023-10-16 → 2023-10-23 |
| 665 | SI develop Overarching SIT Component Integration Test Readiness Report | baseline start 2023-10-10 → 2023-09-14; baseline finish 2023-10-13 → 2023-10-16 |
| 666 | Artefact review (via TMAG) and updates | baseline start 2023-10-16 → 2023-10-17 |
| 667 | SIT Component Integration Testing 1 Preparation Complete (incl. approval of SI SIT Component Integration Test Readiness Report) | baseline start 2023-10-23 → 2023-10-27; baseline finish 2023-10-23 → 2023-10-27 |
| 668 | **CIT Interval 2 Preparation** | baseline finish 2023-11-10 → 2023-11-22 |
| 669 | **Environments (SIT A)** | baseline finish 2023-11-10 → 2023-11-22 |
| 674 | DIP Onboarding Activity (1. PKI Officers and Certificates, 2. Set-up Validation, 3. End Point Creation, 4. Controlled Smoke Test ) | baseline finish 2023-11-10 → 2023-11-22 |
| 675 | DIP Onboarding Complete | baseline start 2023-11-10 → 2023-11-22; baseline finish 2023-11-10 → 2023-11-22 |
| 676 | PPs Register PKI Officers and request PKI certificates Complete - Interval 2 | baseline start 2023-10-20 → 2023-11-22; baseline finish 2023-10-20 → 2023-11-22 |
| 678 | **Test Data (SIT A) Interval 2** | baseline start 2023-09-18 → 2023-09-20; baseline finish 2023-10-20 → 2023-11-17 |
| 679 | Run data allocation | baseline start 2023-09-18 → 2023-09-20; baseline finish 2023-09-22 → 2023-09-28 |
| 680 | Cleanse and populate data post cut | baseline start 2023-09-25 → 2023-09-29; baseline finish 2023-09-29 → 2023-10-02 |
| 681 | Transmit data sets to PPs | baseline start 2023-10-02 → 2023-10-03 |
| 682 | PP - Load test data to test environments | baseline finish 2023-10-13 → 2023-11-17 |
| 683 | PP Check data integrity on test environment | baseline start 2023-10-16 → 2023-10-23; baseline finish 2023-10-20 → 2023-11-17 |
| 684 | PP submit self-declaration to Programme to confirm loading & verification of test data | baseline start 2023-10-20 → 2023-11-17; baseline finish 2023-10-20 → 2023-11-17 |
| 685 | Test Data (SIT A) Interval 2 Complete | baseline start 2023-10-20 → 2023-11-17; baseline finish 2023-10-20 → 2023-11-17 |
| 690 | PP submit Test Readiness Report to Programme for assurance | baseline start 2023-10-20 → 2023-10-25; baseline finish 2023-10-20 → 2023-10-25 |
| 691 | SI assure Test Participants' Test Readiness Reports | baseline start 2023-10-23 → 2023-10-26 |
| 695 | **CIT Interval 3 Preparation** | baseline start 2023-07-17 → 2023-10-03; baseline finish 2023-11-20 → 2023-12-15 |
| 696 | **PIT Test Completion Report (incl. evidence)** | baseline finish 2023-11-10 → 2023-11-17 |
| 697 | Submit draft PIT Test Completion Report (incl. evidence) and submit to Programme for assurance | baseline finish 2023-10-13 → 2023-10-27 |
| 698 | Finalise PIT Test Completion Report (incl. evidence) | baseline start 2023-10-16 → 2023-10-30 |
| 700 | PP Final PIT Completion Reports assured by SI | baseline finish 2023-11-10 → 2023-11-17 |
| 701 | **Environments (SIT A)** | baseline finish 2023-11-10 → 2023-12-15 |
| 706 | DIP Onboarding Activity (1. PKI Officers and Certificates, 2. Set-up Validation, 3. End Point Creation, 4. Controlled Smoke Test ) | baseline finish 2023-11-10 → 2023-12-15 |
| 707 | DIP Onboarding Complete | baseline start 2023-11-10 → 2023-12-15; baseline finish 2023-11-10 → 2023-12-15 |
| 708 | PPs Register PKI Officers and Request PKI certificates Complete - Interval 3 | baseline start 2023-11-10 → 2023-12-15; baseline finish 2023-11-10 → 2023-12-15 |
| 710 | **Test Data (SIT A) Interval 3** | baseline start 2023-10-02 → 2023-10-03; baseline finish 2023-11-03 → 2023-11-17 |
| 711 | Run data allocation | baseline start 2023-10-02 → 2023-10-03 |
| 715 | PP Check data integrity on test environment | baseline finish 2023-11-03 → 2023-11-17 |
| 716 | PP submit self-declaration to Programme to confirm loading & verification of test data | baseline start 2023-11-03 → 2023-11-17; baseline finish 2023-11-03 → 2023-11-17 |
| 717 | Test Data (SIT A) Interval 3 Complete | baseline start 2023-11-03 → 2023-11-17; baseline finish 2023-11-03 → 2023-11-17 |
| 718 | **Other Preparation** | baseline start 2023-07-17 → 2023-10-16; baseline finish 2023-10-06 → 2023-11-17 |
| 719 | Onboarding of Test Participants to Test Management Tool (Azure DevOps) | baseline start 2023-07-17 → 2023-10-16; baseline finish 2023-10-06 → 2023-11-17 |
| 720 | Test Management Tool onboarding | baseline start 2023-07-17 → 2023-10-16; baseline finish 2023-10-06 → 2023-11-17 |
| 733 | **Environments (SIT A)** | baseline start 2023-10-20 → 2023-10-23 |
| 735 | SIT Participants' SIT A environments ready to start connectivity proving CIT Interval 4 | baseline start 2023-10-20 → 2023-10-23; baseline finish 2023-10-20 → 2023-10-23 |
| 742 | **Test Data (SIT A) Interval 4** | baseline start 2023-10-16 → 2023-10-23; baseline finish 2023-11-17 → 2023-12-01 |
| 743 | Run data allocation | baseline start 2023-10-16 → 2023-10-23; baseline finish 2023-10-20 → 2023-10-27 |
| 744 | Cleanse and populate data post cut | baseline start 2023-10-23 → 2023-10-30; baseline finish 2023-10-27 → 2023-10-31 |
| 745 | Transmit data sets to PPs | baseline start 2023-10-30 → 2023-11-01; baseline finish 2023-10-31 → 2023-11-07 |
| 746 | PP - Load test data to test environments | baseline start 2023-11-01 → 2023-11-08; baseline finish 2023-11-10 → 2023-11-14 |
| 747 | PP Check data integrity on test environment | baseline start 2023-11-13 → 2023-11-15; baseline finish 2023-11-17 → 2023-12-01 |
| 748 | PP submit self-declaration to Programme to confirm loading & verification of test data | baseline start 2023-11-17 → 2023-12-01; baseline finish 2023-11-17 → 2023-12-01 |
| 749 | Test Data (SIT A) Interval 4 Complete | baseline start 2023-11-17 → 2023-12-01; baseline finish 2023-11-17 → 2023-12-01 |
| 753 | **SIT Component Integration Test Readiness Report** | baseline start 2023-10-30 → 2023-10-16; baseline finish 2023-12-01 → 2023-11-21 |
| 754 | PP submit Test Readiness Report to Programme for assurance | baseline start 2023-11-17 → 2023-11-03; baseline finish 2023-11-17 → 2023-11-03 |
| 755 | SI assure Test Participants' Test Readiness Reports | baseline start 2023-11-20 → 2023-11-06; baseline finish 2023-11-24 → 2023-11-10 |
| 756 | SI develop Overarching SIT Component Integration Test Readiness Report | baseline start 2023-10-30 → 2023-10-16; baseline finish 2023-11-24 → 2023-11-10 |
| 757 | Artefact review (via SITAG) and updates | baseline start 2023-11-27 → 2023-11-13; baseline finish 2023-12-01 → 2023-11-21 |
| 759 | **CIT Interval 5 Preparation** | baseline start 2023-10-30 → 2023-11-01 |
| 774 | **Test Data (SIT A) Interval 5** | baseline start 2023-10-30 → 2023-11-01; baseline finish 2023-12-08 → 2023-12-15 |
| 775 | Run data allocation | baseline start 2023-10-30 → 2023-11-01; baseline finish 2023-11-10 → 2023-11-07 |
| 776 | Cleanse and populate data post cut | baseline start 2023-11-13 → 2023-11-08 |
| 779 | PP Check data integrity on test environment | baseline finish 2023-12-08 → 2023-12-15 |
| 780 | PP submit self-declaration to Programme to confirm loading & verification of test data | baseline start 2023-12-08 → 2023-12-15; baseline finish 2023-12-08 → 2023-12-15 |
| 781 | Test Data (SIT A) Interval 5 Complete | baseline start 2023-12-08 → 2023-12-15; baseline finish 2023-12-08 → 2023-12-15 |
| 791 | **CIT Interval 6 Preparation** | baseline finish 2024-01-22 → 2024-01-19 |
| 807 | Run data allocation | baseline finish 2023-11-24 → 2023-12-01 |
| 808 | Cleanse and populate data post cut | baseline start 2023-11-27 → 2023-12-04; baseline finish 2023-12-01 → 2023-12-04 |
| 809 | Transmit data sets to PPs | baseline start 2023-12-04 → 2023-12-05 |
| 817 | **SIT Component Integration Test Readiness Report** | baseline start 2023-12-18 → 2023-11-20; baseline finish 2024-01-19 → 2023-12-22 |
| 818 | PP submit Test Readiness Report to Programme for assurance | baseline start 2024-01-05 → 2023-12-08; baseline finish 2024-01-05 → 2023-12-08 |
| 819 | SI assure Test Participants' Test Readiness Reports | baseline start 2024-01-08 → 2023-12-11; baseline finish 2024-01-12 → 2023-12-15 |

| ID | Task | Start | Finish | Duration | Complete | Total float | Predecessors | Other |
| --- | --- | --- | --- | --- | --- | --- | --- | --- |
| 820 | SI develop Overarching SIT Component Integration Test Readiness Report |  |  |  |  |  |  | baseline start 2023-12-18 → 2023-11-20; baseline finish 2024-01-12 → 2023-12-15 |
| 821 | Artefact review (via TMAG) and updates |  |  |  |  |  |  | baseline start 2024-01-15 → 2023-12-18; baseline finish 2024-01-19 → 2023-12-22 |
| 822 | SIT Component Integration Testing 6 Preparation Complete (incl. approval of SI SIT Component Integration Test Readiness Report) |  |  |  |  |  |  | baseline start 2024-01-22 → 2024-01-19; baseline finish 2024-01-22 → 2024-01-19 |
| 823 | **SIT Functional Preparation** |  | 2024-10-25 → 2025-04-07 (+164d) | 520d → 636d? | 93% → 85% | 17d → 708d |  | baseline finish 2024-10-25 → 2025-04-07 |
| 829 | SIT Functional Test Approach & Plan approved |  |  |  |  |  |  | was named SIT Functional Testing Test Approach & Plan approved |
| 840 | **Test cases** |  | 2024-02-21 A → 2025-02-07 (+352d) | 213d → 465d? | 100% → 84% | none → 749d |  | baseline finish 2024-02-21 → 2025-02-07 |
| 889 | **Environments (SIT-Staging)** |  |  |  |  |  |  | baseline start 2022-11-16 → 2023-12-04; baseline finish 2024-02-09 → 2023-12-15 |
| 898 | **Stand up SIT A Environment** |  |  |  |  |  |  | was named Environments (SIT A); baseline start 2024-01-08 → 2024-02-05; baseline finish 2024-02-09 → 2024-03-08 |
| 899 | **SIT Functional Connectivity Proving** |  |  |  |  |  |  | baseline start 2024-01-08 → 2024-02-12; baseline finish 2024-02-02 → 2024-03-01 |
| 902 | **PP Environments (SIT A)** |  |  |  |  |  |  | baseline finish 2024-02-09 → 2024-03-08 |
| 903 | Deployment of MHHS solution code to SIT A environments |  |  |  |  |  |  | baseline finish 2024-02-09 → 2024-03-08 |
| 904 | **SI Environments (SIT A)** |  |  |  |  |  |  | baseline finish 2024-02-09 → 2024-03-08 |
| 905 | Coordinate deployment of MHHS solution code to SIT Participants' SIT A environments |  |  |  |  |  |  | baseline finish 2024-02-09 → 2024-03-08 |
| 906 | **Test data (SIT A)** |  | 2024-10-25 → 2025-04-07 (+164d) | 225d → 341d? | 61% → 57% | 17d → 708d |  | baseline finish 2024-10-25 → 2025-04-07 |
| 909 | Transmit Data Sets to PPs |  |  |  |  |  |  | baseline start 2024-01-25 → 2024-01-26; baseline finish 2024-01-26 → 2024-01-31 |
| 910 | PP's Iterative load and data integrity check |  |  |  |  |  |  | baseline start 2024-01-29 → 2024-02-01; baseline finish 2024-02-09 → 2024-03-01 |
| 912 | **Cycle 2 Test data (inc. Settlement Data) (SIT A)** |  |  |  |  |  |  | was named Cycle 2 Test data (SIT A); baseline finish 2024-05-31 → 2024-06-14 |
| 916 | Cycle 2 - PP's confirmation that test data is ready for SIT Functional |  |  |  |  |  |  | baseline start 2024-05-31 → 2024-06-14; baseline finish 2024-05-31 → 2024-06-14 |
| 917 | **Cycle 3 Test data (SIT A) (2)** | 2024-06-24 A → 2024-07-15 A (+21d) | 2024-08-19 → 2024-10-21 (+63d) | 41d → 71d? | 32% → 80% | 17d → 828d |  | was named Cycle 3 Test data (SIT A); baseline start 2024-06-24 → 2024-07-15; baseline finish 2024-08-19 → 2024-10-21 |
| 938 | **Regression Test data (SIT A)** | 2024-08-26 → 2024-10-28 (+63d) | 2024-10-25 → 2025-04-07 (+164d) | 45d → 116d |  | 17d → 34d |  | baseline start 2024-08-26 → 2024-10-28; baseline finish 2024-10-25 → 2025-04-07 |
| 939 | Prepare, Generate and Allocate Test Data | 2024-08-26 → 2024-10-28 (+63d) | 2024-09-25 → 2025-03-06 (+162d) | 23d → 94d |  | 17d → 34d | Cycle 3 - PP's confirmation that test data is ready for SIT FunctionalFS+4d → 937FS+4d | baseline start 2024-08-26 → 2024-10-28; baseline finish 2024-09-25 → 2025-03-06 |
| 940 | Transmit Data Sets to PPs | 2024-09-26 → 2025-03-07 (+162d) | 2024-09-27 → 2025-03-10 (+164d) |  |  | 17d → 34d |  | baseline start 2024-09-23 → 2025-03-07; baseline finish 2024-10-04 → 2025-03-10 |
| 941 | PP's Iterative load and data integrity check | 2024-09-30 → 2025-03-11 (+162d) | 2024-10-25 → 2025-04-07 (+164d) |  |  | 17d → 34d |  | baseline start 2024-10-21 → 2025-03-11; baseline finish 2024-10-25 → 2025-04-07 |
| 942 | Regression - PP's confirmation that test data is ready for SIT Functional | 2024-10-25 → 2025-04-07 (+164d) | 2024-10-25 → 2025-04-07 (+164d) |  |  | 17d → 34d |  | baseline start 2024-10-25 → 2025-04-07; baseline finish 2024-10-25 → 2025-04-07 |
| 943 | **SIT Functional Test Readiness Report** |  | 2024-02-29 A → 2024-03-01 A (+1d) | 44d → 45d |  |  |  | baseline finish 2024-02-29 → 2024-03-01 |
| 947 | Finalise Test Readiness Report and submit to Programme for assurance |  |  |  |  |  |  | baseline start 2024-01-29 → 2024-01-30 |
| 953 | **SIT Migration Testing Preparation** |  | 2024-06-28 A → 2024-10-04 (+98d) | 435d → 505d? | 100% → 98% | none → 839d |  | baseline finish 2024-06-07 → 2024-10-04 |
| 955 | Develop document with SITWG |  |  |  |  |  |  | baseline finish 2023-10-11 → 2023-10-20 |
| 956 | Draft document review with Code Bodies |  |  |  |  |  |  | baseline start 2023-10-12 → 2023-10-23; baseline finish 2023-10-25 → 2023-11-01 |
| 958 | Artefact review (via TMAG) and updates |  |  |  |  |  |  | baseline start 2023-11-09 → 2023-11-16 |
| 962 | Artefact review (via TMAG) and updates |  |  |  |  |  |  | baseline start 2023-11-09 → 2023-11-16 |
| 964 | **Test scenarios & Test Cases** |  | 2024-04-17 A → 2024-10-04 (+170d) | 85d → 207d? | 100% → 93% | none → 839d |  | baseline finish 2024-03-20 → 2024-10-04 |
| 992 | **Environments (SIT B)** |  |  |  |  |  |  | baseline finish 2024-06-07 → 2024-06-28 |
| 993 | **PP Environments (SIT B)** |  |  |  |  |  |  | baseline finish 2024-06-07 → 2024-06-28 |
| 995 | PP Onboarding / Smoke test |  |  |  |  |  |  | baseline finish 2024-06-07 → 2024-06-28 |
| 996 | DTN Connectivity Proving Complete |  |  |  |  |  |  | baseline start 2024-05-31 → 2024-06-10; baseline finish 2024-05-31 → 2024-06-14 |
| 997 | PP Code Deployment |  |  |  |  |  |  | baseline start 2024-06-03 → 2024-06-14; baseline finish 2024-06-03 → 2024-06-14 |
| 998 | **SI Environments (SIT B)** |  |  |  |  |  |  | baseline finish 2024-06-07 → 2024-06-14 |
| 1001 | SIT Participants' SIT B environments ready to start connectivity proving (incl. certificates and security compliance) |  |  |  |  |  |  | baseline start 2024-05-03 → 2024-06-05; baseline finish 2024-05-03 → 2024-06-05 |
| 1002 | Coordinate SIT Participants' SIT B environment connectivity proving |  |  |  |  |  |  | baseline start 2024-05-14 → 2024-06-06 |
| 1003 | Coordinate deployment of MHHS solution code to SIT Participants' SIT B environments |  |  |  |  |  |  | baseline start 2024-06-04 → 2024-06-14; baseline finish 2024-06-07 → 2024-06-14 |
| 1006 | Develop draft Test Readiness Report and submit to Programme for assurance |  |  |  |  |  |  | baseline finish 2024-04-30 → 2024-04-29 |
| 1014 | **SIT Non-Functional Preparation** |  | 2024-08-27 → 2025-03-14 (+199d) | 193d → 337d? | 89% → 51% | 719d → 724d |  | baseline finish 2024-08-27 → 2025-03-14 |
| 1025 | **Test scenarios & Test Cases** |  | 2024-08-21 → 2024-07-17 (-35d) | 123d → 98d? | 97% → 78% | -9d → none |  | baseline finish 2024-08-21 → 2024-07-17 |
| 1038 | **Theme 3** |  | 2024-08-21 → 2024-07-17 (-35d) | 123d → 98d? | 94% → 100% | -9d → none |  | baseline finish 2024-08-21 → 2024-07-17 |
| 1042 | Review with NFT Working Group |  | 2024-08-08 → 2024-07-04 A (-35d) | 30d → 5d | 80% → 100% | -42d → none |  | baseline finish 2024-08-08 → 2024-07-04 |
| 1043 | SIT NFT Scenarios & Test Cases Approved - Theme 3 | 2024-08-21 → 2024-09-18 A (+28d) | 2024-08-21 → 2024-09-18 A (+28d) |  | 0% → 100% | -42d → none |  | constraint none → start no earlier than 2024-09-18; baseline start 2024-08-21 → 2024-09-18; baseline finish 2024-08-21 → 2024-09-18 |
| 1057 | **Environments (SIT B)** | 2024-08-27 A | 2024-08-27 → 2025-01-03 (+129d) | 0d → 94d? |  | 719d → 774d |  | baseline finish 2024-08-27 → 2025-01-03 |
| 1058 | **PP Environments (SIT B)** | 2024-08-27 A | 2024-08-27 A |  | 0% → 100% | 719d → none |  |  |
| 1059 | Deployment of MHHS solution code to SIT B environments | 2024-08-27 A | 2024-08-27 A |  | 0% → 100% | 719d → none |  |  |
| 1073 | **SIT Non-Functional Test Readiness Report** |  | 2024-08-23 → 2025-03-07 (+196d) | 44d → 184d | 65% → 19% | 6d → 70d |  | baseline finish 2024-08-23 → 2025-03-07 |
| 1074 | **PP SIT Non-Functional Test Readiness Report** |  | 2024-08-23 → 2025-03-07 (+196d) | 44d → 184d | 79% → 18% | 6d → 70d |  | baseline finish 2024-08-23 → 2025-03-07 |
| 1076 | Placing Reliance Stage 2 Review |  | 2024-08-23 → 2025-03-07 (+196d) | 40d → 180d | 70% → 16% | 6d → 70d | 1075SS+4d → none | baseline finish 2024-08-23 → 2025-03-07 |
| 1077 | Finalise Test Readiness Report and submit to Programme for assurance |  | 2024-08-05 → 2024-12-13 (+130d) | 10d → 104d | 70% → 7% | 5d → 7d |  | baseline finish 2024-08-05 → 2024-12-13 |
| 1078 | **SI SIT Non-Functional Test Readiness Report** |  | 2024-08-19 → 2025-01-10 (+144d) | 40d → 144d | 48% → 22% | 5d → 95d |  | baseline finish 2024-08-19 → 2025-01-10 |
| 1079 | Assure Test Participants' Test Readiness Reports |  | 2024-08-12 → 2024-12-13 (+123d) | 35d → 114d | 63% → 19% | 5d → 7d | 1075SS, 1077FF+5d → 1075SS, 1077FF | baseline finish 2024-08-12 → 2024-12-13 |
| 1080 | Develop Overarching SIT Non-Functional Test Readiness Report | 2024-07-16 A → 2024-12-02 A (+139d) | 2024-08-12 → 2024-12-20 (+130d) | 20d → 15d | 35% → 47% | 5d → 95d | 1079FF → 1079FS-10d | baseline start 2024-07-16 → 2024-12-02; baseline finish 2024-08-12 → 2024-12-20 |
| 1081 | Artefact review (via SITAG / SRO) and updates | 2024-08-13 → 2025-01-06 (+146d) | 2024-08-19 → 2025-01-10 (+144d) |  |  | 5d → 95d | 1080 → 1080FS+10d | was named Artefact review (via SITAG) and updates; baseline start 2024-08-13 → 2025-01-06; baseline finish 2024-08-19 → 2025-01-10 |
| 1082 | SIT Non-Functional Testing Preparation Complete | 2024-08-26 → 2025-03-07 (+193d) | 2024-08-26 → 2025-03-07 (+193d) |  |  | 5d → 70d | 1081FF+5d, 829, 385, 1076, 1031, 1037, 1043 → 1081FF+15d, 829, 385, 1031, 1037, 1043, 1076 | baseline start 2024-08-26 → 2025-03-07; baseline finish 2024-08-26 → 2025-03-07 |
| 1083 | **SIT Operational Preparation** |  | 2024-09-25 → 2025-01-31 (+128d) | 170d → 262d? | 92% → 38% | 697d → 754d |  | baseline finish 2025-03-03 → 2025-01-31 |
| 1086 | Draft document review with Code Bodies |  |  |  |  |  |  | baseline start 2024-03-07 → 2024-03-21; baseline finish 2024-03-20 → 2024-03-26 |
| 1088 | Artefact review (via SITAG) and updates |  |  |  |  |  |  | baseline start 2024-04-04 → 2024-04-10 |
| 1094 | **Test scenarios & Test Cases** |  | 2024-09-18 → 2025-01-31 (+135d) | 116d → 213d? | 96% → 31% | -20d → 754d |  | baseline finish 2024-09-18 → 2025-01-31 |
| 1095 | **Theme 1** |  | 2024-08-21 → 2024-09-06 A (+16d) | 96d → 108d | 99% → 100% | -35d → none |  | baseline finish 2024-08-21 → 2024-09-06 |
| 1096 | Develop Test Scenarios & Test Cases |  | 2024-05-01 A → 2024-06-21 A (+51d) | 16d → 53d |  |  |  | baseline finish 2024-05-01 → 2024-06-21 |
| 1097 | Industry Review Workshop | 2024-05-02 A → 2024-06-24 A (+53d) | 2024-05-02 A → 2024-06-24 A (+53d) |  |  |  |  | baseline start 2024-05-02 → 2024-06-24; baseline finish 2024-05-02 → 2024-06-24 |
| 1098 | Industry Consultation Review | 2024-05-28 A → 2024-07-02 A (+35d) | 2024-06-04 A → 2024-07-09 A (+35d) |  |  |  |  | baseline start 2024-05-28 → 2024-07-02; baseline finish 2024-06-04 → 2024-07-09 |
| 1099 | Review with SIT Working Group | 2024-06-27 A → 2024-08-19 A (+53d) | 2024-07-03 A → 2024-08-23 A (+51d) |  |  |  |  | baseline start 2024-06-27 → 2024-08-19; baseline finish 2024-07-03 → 2024-08-23 |
| 1100 | SIT Operational Scenarios & Test Cases Approved - Theme 1 | 2024-08-21 → 2024-09-06 A (+16d) | 2024-08-21 → 2024-09-06 A (+16d) |  | 0% → 100% | -62d → none | 1099FS+35d → 1099FS+10d | constraint none → start no earlier than 2024-09-06; baseline start 2024-08-21 → 2024-09-06; baseline finish 2024-08-21 → 2024-09-06 |
| 1101 | **Theme 2** |  | 2024-07-17 A → 2024-09-06 A (+51d) | 71d → 107d |  |  |  | baseline finish 2024-07-17 → 2024-09-06 |

| ID | Task | Start | Finish | Duration | Complete | Total float | Predecessors | Other |
| --- | --- | --- | --- | --- | --- | --- | --- | --- |
| 1102 | Develop Test Scenarios & Test Cases |  | 2024-05-22 A → 2024-06-21 A (+30d) | 31d → 53d |  |  |  | constraint none → finish no earlier than 2024-06-21; baseline finish 2024-05-22 → 2024-06-21 |
| 1103 | Industry Review Workshop | 2024-05-23 A → 2024-06-24 A (+32d) | 2024-05-23 A → 2024-06-24 A (+32d) |  |  |  |  | baseline start 2024-05-23 → 2024-06-24; baseline finish 2024-05-23 → 2024-06-24 |
| 1104 | Industry Consultation Review | 2024-06-04 A → 2024-07-02 A (+28d) | 2024-06-11 A → 2024-07-09 A (+28d) |  |  |  |  | baseline start 2024-06-04 → 2024-07-02; baseline finish 2024-06-11 → 2024-07-09 |
| 1105 | Review with SIT Working Group | 2024-06-27 A → 2024-08-19 A (+53d) | 2024-07-03 A → 2024-08-23 A (+51d) |  |  |  |  | baseline start 2024-06-27 → 2024-08-19; baseline finish 2024-07-03 → 2024-08-23 |
| 1106 | SIT Operational Scenarios & Test Cases Approved - Theme 2 | 2024-07-17 A → 2024-09-06 A (+51d) | 2024-07-17 A → 2024-09-06 A (+51d) |  |  |  |  | baseline start 2024-07-17 → 2024-09-06; baseline finish 2024-07-17 → 2024-09-06 |
| 1112 | **Theme 3 (Batch 2)** | 2024-04-10 A → 2024-09-19 A (+162d) | 2024-09-18 → 2024-12-11 (+84d) | 116d → 60d? | 91% → 26% | -20d → 791d |  | was named Theme 3; baseline start 2024-04-10 → 2024-09-19; baseline finish 2024-09-18 → 2024-12-11 |
| 1117 | Industry Review Workshop (Batch 2) | 2024-06-13 A → 2024-11-04 A (+144d) | 2024-06-13 A → 2024-11-15 (+155d) | 1d → 10d | 100% → 10% | none → 94d | 1122 → 1116 | was named Industry Review Workshop; baseline start 2024-06-13 → 2024-11-04; baseline finish 2024-06-13 → 2024-11-15 |
| 1122 | Develop Test Scenarios & Test Cases (Batch 1) |  | 2024-06-12 A → 2024-07-26 A (+44d) | 46d → 78d |  |  |  | was named Develop Test Scenarios & Test Cases; baseline finish 2024-06-12 → 2024-07-26 |
| 1127 | Industry Consultation | 2024-10-11 → 2024-10-28 (+17d) | 2024-10-24 → 2024-11-08 (+15d) | 10d → 10d? |  | 585d → 94d | Prepare Artefacts for Consultation → 1126 | baseline start 2024-10-11 → 2024-10-28; baseline finish 2024-10-24 → 2024-11-08 |
| 1131 | SIT Operational Scenarios & Test Cases Approved - Theme 3 (Batch 1 + 2) | 2024-09-18 → 2024-12-11 (+84d) | 2024-09-18 → 2024-12-11 (+84d) |  |  | -20d → 94d | Review with SIT Working GroupFS+35d → 1134, 1120, 1130 | was named SIT Operational Scenarios & Test Cases Approved - Theme 3; baseline start 2024-09-18 → 2024-12-11; baseline finish 2024-09-18 → 2024-12-11 |
| 1133 | Development | 2023-04-11 → 2024-09-27 (+535d) | 2023-04-24 → 2024-09-27 (+522d) | 10d → 0d |  | 0d → 845d | Requirements identification → none | constraint must start on 2023-04-11 → start no earlier than 2024-09-27; baseline start 2023-04-11 → 2024-09-27; baseline finish 2023-04-24 → 2024-09-27 |
| 1140 | **Environments (SIT B)** | 2024-08-27 → 2024-10-07 (+41d) | 2024-08-27 → 2024-10-07 (+41d) |  |  | 719d → 38d |  | baseline start 2024-08-27 → 2024-10-07; baseline finish 2024-08-27 → 2024-10-07 |
| 1141 | **PP Environments (SIT B)** | 2024-08-27 → 2024-10-07 (+41d) | 2024-08-27 → 2024-10-07 (+41d) |  |  | 719d → 38d |  | baseline start 2024-08-27 → 2024-10-07; baseline finish 2024-08-27 → 2024-10-07 |
| 1142 | Deployment of MHHS solution code to SIT B environments | 2024-08-27 → 2024-10-07 (+41d) | 2024-08-27 → 2024-10-07 (+41d) |  |  | 719d → 38d | none → 141 | baseline start 2024-08-27 → 2024-10-07; baseline finish 2024-08-27 → 2024-10-07 |
| 1143 | **SI Environments (SIT B)** | 2024-08-27 → 2024-10-07 (+41d) | 2024-08-27 → 2024-10-07 (+41d) |  |  | 719d → 38d |  | baseline start 2024-08-27 → 2024-10-07; baseline finish 2024-08-27 → 2024-10-07 |
| 1144 | Coordinate deployment of MHHS solution code to SIT Participants' SIT B environments | 2024-08-27 → 2024-10-07 (+41d) | 2024-08-27 → 2024-10-07 (+41d) |  |  | 719d → 38d |  | baseline start 2024-08-27 → 2024-10-07; baseline finish 2024-08-27 → 2024-10-07 |
| 1145 | **SIT Operational Test Readiness Report** | 2024-08-30 → 2024-08-05 (-25d) | 2024-09-25 → 2024-09-18 (-7d) | 19d → 33d |  | -3d → none |  | baseline finish 2025-03-03 → 2024-09-18 |
| 1146 | **PP SIT Operational Test Readiness Report** | 2024-08-30 → 2024-08-05 (-25d) | 2024-08-30 → 2024-08-05 (-25d) |  |  | -3d → none |  | baseline finish 2025-02-03 → 2024-08-05 |
| 1147 | Test Readiness Report submitted to Programme for assurance | 2024-08-30 → 2024-08-05 (-25d) | 2024-08-30 → 2024-08-05 (-25d) |  |  | -3d → 769d |  | constraint start no earlier than 2024-08-30 → start no earlier than 2024-08-05; baseline start 2025-01-07 → 2024-08-05; baseline finish 2025-02-03 → 2024-08-05 |
| 1148 | **SI SIT Operational Test Readiness Report** | 2024-08-30 → 2024-08-05 (-25d) | 2024-09-25 → 2025-01-17 (+114d) | 19d → 120d |  | -3d → 152d |  | baseline start 2025-01-07 → 2024-08-05; baseline finish 2025-03-03 → 2025-01-17 |
| 1149 | Assure Test Participants' Test Readiness Reports | 2024-08-30 → 2024-08-05 (-25d) | 2024-09-05 → 2025-01-10 (+127d) | 5d → 115d |  | -3d → 769d |  | baseline start 2025-01-07 → 2024-08-05; baseline finish 2025-02-24 → 2025-01-10 |
| 1150 | Develop Overarching SIT Operational Test Readiness Report | 2024-09-13 → 2024-12-02 (+80d) | 2024-09-18 → 2025-01-10 (+114d) | 4d → 30d |  | -3d → 67d | 1149SS+10d → none | constraint none → start no earlier than 2024-12-02; baseline start 2025-01-28 → 2024-12-02; baseline finish 2025-02-24 → 2025-01-10 |
| 1151 | Artefact review (via SITAG) and updates | 2024-09-19 → 2025-01-13 (+116d) | 2024-09-25 → 2025-01-17 (+114d) |  |  | -3d → 67d |  | baseline start 2025-02-25 → 2025-01-13; baseline finish 2025-03-03 → 2025-01-17 |
| 1152 | SIT Operational Testing Preparation Complete | 2024-09-25 → 2025-01-17 (+114d) | 2024-09-25 → 2025-01-17 (+114d) |  |  | -3d → 67d |  | constraint none → finish no earlier than 2024-10-04; baseline start 2024-09-25 → 2025-01-17; baseline finish 2024-09-25 → 2025-01-17 |
| 1224 | **SIT Execution** | 2023-10-30 A → 2022-10-31 A (-364d) | 2025-04-25 → 2025-11-27 (+216d) | 390d → 804d? | 22% → 15% | 545d → 540d |  | baseline start 2023-10-30 → 2022-10-31; baseline finish 2025-04-25 → 2025-11-27 |
| 1225 | System Integration Testing Start (M9) |  |  |  |  |  | 667FS+5d, 581, 575 → 667FS+5d, 581 |  |
| 1226 | **SIT Component Integration Testing** |  |  |  |  |  |  | baseline finish 2024-03-08 → 2024-03-11 |
| 1240 | SIT Component Integration Testing Test Completion Report Approved |  |  |  |  |  |  | baseline start 2024-03-08 → 2024-03-11; baseline finish 2024-03-08 → 2024-03-11 |
| 1241 | **SIT - Minimum Viable Cohort (MVC)** | 2024-03-11 A → 2022-10-31 A (-497d) | 2025-02-07 → 2025-08-22 (+196d) | 240d → 735d? | 18% → 8% | 600d → 609d |  | baseline start 2024-03-11 → 2022-10-31; baseline finish 2025-02-07 → 2025-08-22 |
| 1242 | **SIT Functional Testing (MVC)** | 2024-03-11 A → 2022-10-31 A (-497d) | 2025-01-17 → 2025-08-15 (+210d) | 225d → 730d? | 37% → 20% | 615d → 614d |  | baseline start 2024-03-11 → 2022-10-31; baseline finish 2025-01-17 → 2025-08-15 |
| 1244 | **SIT Functional Testing Execution (Minimum Viable Cohort)** | 2024-03-11 A → 2022-10-31 A (-497d) | 2025-01-17 → 2025-08-15 (+210d) | 225d → 730d? | 37% → 20% | 615d → 614d |  | baseline start 2024-03-11 → 2022-10-31; baseline finish 2025-01-17 → 2025-08-15 |
| 1245 | **Cycle 1 (Full Cycle)** |  |  |  |  |  |  | baseline finish 2024-07-12 → 2024-06-14 |
| 1246 | Test Execution |  |  |  |  |  |  | baseline finish 2024-06-28 → 2024-05-24 |
| 1247 | Defect resolution, assurance, review, data & environments maintenance |  |  |  |  |  |  | baseline start 2024-07-01 → 2024-05-27; baseline finish 2024-07-12 → 2024-06-14 |
| 1248 | **Cycle 2 (Defect retests and targeted regression testing)** |  | 2024-08-30 → 2024-10-04 (+35d) | 55d → 80d | 60% → 41% | 12d → 839d |  | baseline start 2024-07-15 → 2024-06-17; baseline finish 2024-09-20 → 2024-10-04 |
| 1249 | Test Execution |  | 2024-08-16 → 2024-09-20 (+35d) | 45d → 70d | 73% → 47% | 11d → 190d |  | baseline start 2024-07-15 → 2024-06-17; baseline finish 2024-09-06 → 2024-09-20 |
| 1250 | Defect resolution, assurance, review, data & environments maintenance | 2024-08-19 → 2024-09-23 (+35d) | 2024-08-30 → 2024-10-04 (+35d) |  |  | 12d → 839d |  | baseline start 2024-09-09 → 2024-09-23; baseline finish 2024-09-20 → 2024-10-04 |
| 1251 | **SIT Functional Testing back-up progress risk-assessment** | 2024-09-02 → 2022-10-31 (-672d) | 2024-09-27 → 2022-10-31 (-697d) | 20d → 0d |  | 695d → 1344d |  | baseline start 2024-09-23 → 2022-10-31; baseline finish 2024-10-18 → 2022-10-31 |
| 1252 | Back-up risk-assessment of SIT Functional progress to assess whether Qualification Execution can start early | 2024-09-02 → 2024-10-07 (+35d) | 2024-09-20 → 2024-10-25 (+35d) |  |  | 695d → 819d |  | baseline start 2024-09-23 → 2024-10-07; baseline finish 2024-10-11 → 2024-10-25 |
| 1253 | Back-up SITAG decision on early Qualification Testing Execution start | 2024-09-27 → 2024-11-01 (+35d) | 2024-09-27 → 2024-11-01 (+35d) |  |  | 695d → 819d |  | baseline start 2024-10-18 → 2024-11-01; baseline finish 2024-10-18 → 2024-11-01 |
| 1254 | **Cycle 3 (Defect retests and targeted regression testing)** | 2024-09-02 → 2024-10-21 (+49d) | 2024-11-01 → 2025-03-14 (+133d) | 45d → 105d? |  | 12d → none |  | baseline start 2024-09-23 → 2024-10-21; baseline finish 2024-11-01 → 2025-03-14 |
| 1268 | Defect resolution, assurance, review, data & environments maintenance |  |  |  |  | 12d → 819d | 1292 → none |  |
| 1273 | **SIT Functional MVC Regression Testing (code freeze)** | 2024-11-04 → 2025-06-16 (+224d) | 2025-01-03 → 2025-08-08 (+217d) | 45d → 40d? |  | 12d → 5d | 1268, 942 → none | was named Regression Testing (code freeze); baseline start 2024-11-04 → 2025-06-16; baseline finish 2025-01-03 → 2025-08-08 |
| 1277 | SIT Functional Testing End (Minimum Viable Cohort) (incl. confirmation that PPs have submitted their Test Completion Reports to Programme for assurance) | 2025-01-03 → 2025-08-01 (+210d) | 2025-01-03 → 2025-08-01 (+210d) |  |  | 12d → 5d | 1273FF → 1276 | constraint none → start no earlier than 2025-03-14; baseline start 2025-01-03 → 2025-08-01; baseline finish 2025-01-03 → 2025-08-01 |
| 1278 | Assurance of PPs Test Completion Reports | 2024-12-02 → 2025-06-30 (+210d) | 2025-01-10 → 2025-08-08 (+210d) |  |  | 12d → 5d |  | baseline start 2024-12-02 → 2025-06-30; baseline finish 2025-01-10 → 2025-08-08 |
| 1279 | **SIT Functional Test Completion Report (Minimum Viable Cohort)** | 2024-12-16 → 2025-07-14 (+210d) | 2025-01-10 → 2025-08-15 (+217d) | 20d → 25d |  | 12d → 5d |  | baseline start 2024-12-16 → 2025-07-14; baseline finish 2025-01-10 → 2025-08-15 |
| 1280 | Develop document | 2024-12-16 → 2025-07-14 (+210d) | 2025-01-03 → 2025-08-01 (+210d) |  |  | 12d → 5d |  | baseline start 2024-12-16 → 2025-07-14; baseline finish 2025-01-03 → 2025-08-01 |
| 1281 | Review & agree document | 2025-01-06 → 2025-08-04 (+210d) | 2025-01-10 → 2025-08-08 (+210d) |  |  | 12d → 5d |  | baseline start 2025-01-06 → 2025-08-04; baseline finish 2025-01-10 → 2025-08-08 |
| 1282 | SIT Functional Testing Test Completion Report (Minimum Viable Cohort) Approved | 2025-01-17 → 2025-08-15 (+210d) | 2025-01-17 → 2025-08-15 (+210d) |  |  | 12d → 5d |  | baseline start 2025-01-17 → 2025-08-15; baseline finish 2025-01-17 → 2025-08-15 |
| 1288 | **SIT Migration Testing (MVC)** | 2024-06-17 A → 2024-03-11 (-98d) | 2025-01-15 → 2025-08-22 (+219d) | 152d → 380d? | 16% → 0% | 14d → 0d |  | baseline start 2024-06-10 → 2024-03-11; baseline finish 2025-01-10 → 2025-08-22 |
| 1289 | SIT Migration Testing Start | 2024-06-17 A → 2024-03-11 (-98d) | 2024-06-17 A → 2024-03-11 (-98d) | 0d → 0d? | 100% → 0% | none → 989d | 1013FS+10d, 959, 963, 970, 976, 982 → none | constraint none → start no earlier than 2024-03-11; baseline start 2024-06-10 → 2024-03-11; baseline finish 2024-06-10 → 2024-03-11 |
| 1291 | **Cycle 1 (Full Cycle)** | 2024-03-11 A → 2024-03-11 | 2024-06-14 A → 2024-06-14 | 70d → 70d? | 100% → 0% |  |  | baseline finish 2024-07-12 → 2024-06-14 |
| 1292 | Test Execution | 2024-09-02 → 2024-03-11 (-175d) | 2024-10-18 → 2024-05-24 (-147d) | 35d → 55d? |  | 12d → 934d | 1250, Cycle 3 - PP's confirmation that test data is ready for SIT Functional → none | constraint none → start no earlier than 2024-03-11; baseline start 2024-09-23 → none; baseline finish 2024-10-18 → none |
| 1294 | **Cycle 2 (Defect retests and targeted regression testing)** | 2024-06-17 A → 2024-03-11 (-98d) | 2024-08-30 → 2024-06-28 (-63d) | 55d → 80d? | 60% → 0% | 5d → none |  | baseline start 2024-07-15 → 2024-03-11; baseline finish 2024-09-20 → 2024-06-28 |
| 1295 | Test Execution | 2024-03-11 A → 2024-06-17 (+98d) | 2024-05-24 A → 2024-09-20 (+119d) | 55d → 70d? | 100% → 0% | none → 819d | 1246SS, 127 → 1293 | constraint none → start no earlier than 2024-06-17; baseline start 2024-03-11 → none; baseline finish 2024-06-28 → none |
| 1296 | Defect resolution, assurance, review, data & environments maintenance | 2024-10-21 → 2024-09-23 (-28d) | 2024-11-01 → 2024-10-04 (-28d) | 10d → 10d? |  | 14d → 819d | SIT Migration Testing Execution (Minimum Viable Cohort) → 1295 | constraint none → finish no earlier than 2024-10-04; baseline start 2024-10-21 → none; baseline finish 2024-11-01 → none |
| 1300 | **Cycle 3 (Defect retests and targeted regression testing)** | 2024-09-02 → 2024-10-21 (+49d) | 2024-11-01 → 2025-04-25 (+175d) | 45d → 135d? |  |  |  | baseline start 2024-09-23 → 2024-10-21; baseline finish 2024-11-01 → 2025-04-25 |
| 1320 | Develop document | 2023-04-11 → 2025-07-14 (+825d) | 2023-04-24 → 2025-08-01 (+830d) | 10d → 15d |  | 1065d → 609d | 1133SS → 1318FF | constraint start no earlier than 2022-11-28 → none; baseline start 2023-04-11 → 2025-07-14; baseline finish 2023-04-24 → 2025-08-01 |
| 1321 | Review & agree document | 2025-01-06 → 2025-08-04 (+210d) | 2025-01-10 → 2025-08-08 (+210d) |  |  | 14d → 609d | Develop document, 1324FF → 1320 | baseline start 2024-10-07 → 2025-08-04; baseline finish 2024-10-11 → 2025-08-08 |
| 1322 | SIT Migration Testing Test Completion Report (Minimum Viable Cohort) Approved | 2025-01-15 → 2025-08-15 (+212d) | 2025-01-15 → 2025-08-15 (+212d) |  |  | 14d → 609d | 1321FF+3d → 1321FS+5d | baseline start 2024-10-18 → 2025-08-15; baseline finish 2024-10-18 → 2025-08-15 |
| 1323 | SIT Migration Testing End (Minimum Viable Cohort) (incl. confirmation that PPs have submitted their Test Completion Reports to Programme for assurance) | 2025-01-03 → 2025-08-15 (+224d) | 2025-01-03 → 2025-08-15 (+224d) |  |  | 14d → 609d | SIT Migration Testing Execution (Minimum Viable Cohort)FF, Regression Testing (code freeze) → 1320FF, 1322 | constraint none → start no earlier than 2025-03-14; baseline start 2025-01-03 → 2025-08-15; baseline finish 2025-01-03 → 2025-08-15 |
| 1324 | Assurance of PPs Test Completion Reports | 2024-12-02 → 2025-07-14 (+224d) | 2025-01-10 → 2025-08-22 (+224d) |  |  | 14d → 609d |  | baseline start 2024-12-02 → 2025-07-14; baseline finish 2025-01-10 → 2025-08-22 |
| 1325 | **SIT Non-Functional Testing (all SIT PPs)** | 2024-09-02 → 2025-01-13 (+133d) | 2025-01-17 → 2025-06-05 (+139d) | 99d → 104d? |  | 5d → 60d |  | was named SIT Non-Functional Testing (MVC); baseline start 2024-09-02 → 2025-01-13; baseline finish 2025-01-17 → 2025-06-05 |
| 1328 | Theme 2 SIT Non-Functional Testing Start | 2024-09-02 → 2025-03-14 (+193d) | 2024-09-02 → 2025-03-14 (+193d) |  |  | 5d → 70d | 1082FS+5d, 1249FS+5d, 1020, 1024, 1031, 1037, 1043 → 1082FS+5d, 1249FS+5d, 1020, 1024, 1031, 1037, 1043, 1068, 1072 | was named SIT Non-Functional Testing Start; baseline start 2024-09-02 → 2025-03-14; baseline finish 2024-09-02 → 2025-03-14 |
| 1329 | Theme 2 SIT Non-Functional Testing Execution | 2024-09-03 → 2025-03-17 (+195d) | 2025-01-03 → 2025-05-09 (+126d) | 89d → 40d |  | 12d → 70d |  | was named SIT Non-Functional Testing Execution (Minimum Viable Cohort); baseline start 2024-09-02 → 2025-03-17; baseline finish 2025-01-03 → 2025-05-09 |
| 1332 | SIT Non-Functional Testing End (all SIT PPs) (incl. confirmation that PPs have submitted their Test Completion Reports to Programme for assurance) | 2025-01-03 → 2025-05-23 (+140d) | 2025-01-03 → 2025-05-23 (+140d) |  |  | 12d → 61d | 1329FF → 1329FF, 1331FF | was named SIT Non-Functional Testing End (Minimum Viable Cohort) (incl. confirmation that PPs have submitted their Test Completion Reports to Programme for assurance); constraint none → start no earlier than 2025-05-23; baseline start 2025-01-03 → 2025-05-23; baseline finish 2025-01-03 → 2025-05-23 |
| 1333 | Assurance of PPs Test Completion Reports | 2024-12-02 → 2025-05-02 (+151d) | 2025-01-10 → 2025-05-29 (+139d) | 30d → 20d |  | 12d → 61d |  | baseline start 2024-12-02 → 2025-05-02; baseline finish 2025-01-10 → 2025-05-29 |
| 1334 | **SIT Non-Functional Testing Test Completion Report (all SIT PPs)** | 2024-12-16 → 2025-05-02 (+137d) | 2025-01-10 → 2025-05-29 (+139d) |  |  | 12d → 61d |  | was named SIT Non-Functional Testing Test Completion Report (Minimum Viable Cohort); baseline start 2024-12-16 → 2025-05-02; baseline finish 2025-01-10 → 2025-05-29 |
| 1335 | Develop document | 2024-12-16 → 2025-05-02 (+137d) | 2025-01-03 → 2025-05-23 (+140d) |  |  | 12d → 61d |  | baseline start 2024-12-16 → 2025-05-02; baseline finish 2025-01-03 → 2025-05-23 |
| 1336 | Review & agree document | 2025-01-06 → 2025-05-23 (+137d) | 2025-01-10 → 2025-05-29 (+139d) |  |  | 12d → 61d |  | baseline start 2025-01-06 → 2025-05-23; baseline finish 2025-01-10 → 2025-05-29 |

| ID | Task | Start | Finish | Duration | Complete | Total float | Predecessors | Other |
| --- | --- | --- | --- | --- | --- | --- | --- | --- |
| 1337 | SIT Non-Functional Testing Test Completion Report (all SIT PPs) Approved | 2025-01-17 → 2025-06-05 (+139d) | 2025-01-17 → 2025-06-05 (+139d) |  |  | 12d → 61d |  | was named SIT Non-Functional Testing Test Completion Report (Minimum Viable Cohort) Approved; baseline start 2025-01-17 → 2025-06-05; baseline finish 2025-01-17 → 2025-06-05 |
| 1338 | **SIT Operational Testing (all SIT PPs)** | 2024-10-07 → 2025-02-03 (+119d) | 2025-02-07 → 2025-06-06 (+119d) | 89d → 90d? |  | -3d → 60d |  | was named SIT Operational Testing (MVC); baseline start 2024-10-07 → 2025-02-03; baseline finish 2025-02-07 → 2025-06-06 |
| 1343 | SIT Operational Testing Start (SIT B) | 2024-10-07 → 2025-02-07 (+123d) | 2024-10-07 → 2025-02-07 (+123d) |  |  | -3d → 60d | 1152FS+8d, 1089, 1093, 1100, 1106, 1131 → 1152FS+8d, 1089, 1093, 1100, 1106, 1131, 1069, 1070 | was named SIT Operational Testing Start; baseline start 2024-10-07 → 2025-02-07; baseline finish 2024-10-07 → 2025-02-07 |
| 1347 | SIT Operational Testing End (all SIT PPs) (incl. confirmation that PPs have submitted their Test Completion Reports to Programme for assurance) | 2025-01-24 → 2025-05-23 (+119d) | 2025-01-24 → 2025-05-23 (+119d) |  |  | -3d → 60d | SIT Operational Testing Execution (Minimum Viable Cohort)FF → 1346FS+5d, 1341 | was named SIT Operational Testing End (Minimum Viable Cohort) (incl. confirmation that PPs have submitted their Test Completion Reports to Programme for assurance); baseline start 2025-01-24 → 2025-05-23; baseline finish 2025-01-24 → 2025-05-23 |
| 1348 | Assurance of PPs Test Completion Reports | 2024-12-23 → 2025-04-21 (+119d) | 2025-01-31 → 2025-05-30 (+119d) |  |  | -3d → 60d |  | baseline start 2024-12-23 → 2025-04-21; baseline finish 2025-01-31 → 2025-05-30 |
| 1349 | **SIT Operational Testing Test Completion Report (all SIT PPs)** | 2025-01-06 → 2025-05-05 (+119d) | 2025-01-31 → 2025-05-30 (+119d) |  |  | -3d → 60d |  | was named SIT Operational Testing Test Completion Report (Minimum Viable Cohort); baseline start 2025-01-06 → 2025-05-05; baseline finish 2025-01-31 → 2025-05-30 |
| 1350 | Develop document | 2025-01-06 → 2025-05-05 (+119d) | 2025-01-24 → 2025-05-23 (+119d) |  |  | -3d → 60d |  | baseline start 2025-01-06 → 2025-05-05; baseline finish 2025-01-24 → 2025-05-23 |
| 1351 | Review & agree document | 2025-01-27 → 2025-05-26 (+119d) | 2025-01-31 → 2025-05-30 (+119d) |  |  | -3d → 60d |  | baseline start 2025-01-27 → 2025-05-26; baseline finish 2025-01-31 → 2025-05-30 |
| 1352 | SIT Operational Testing Test Completion Report (all SIT PPs) Approved | 2025-02-07 → 2025-06-06 (+119d) | 2025-02-07 → 2025-06-06 (+119d) |  |  | -3d → 60d |  | was named SIT Operational Testing Test Completion Report (Minimum Viable Cohort) Approved; baseline start 2025-02-07 → 2025-06-06; baseline finish 2025-02-07 → 2025-06-06 |
| 1353 | **SIT MVC Test Exit Report** | 2025-01-06 → 2025-07-14 (+189d) | 2025-01-31 → 2025-08-08 (+189d) |  |  | -3d → 619d |  | baseline start 2025-01-06 → 2025-07-14; baseline finish 2025-01-31 → 2025-08-08 |
| 1354 | Develop document | 2025-01-06 → 2025-07-14 (+189d) | 2025-01-24 → 2025-08-01 (+189d) |  |  | -3d → 619d | 1350FF → 1280FF | baseline start 2025-01-06 → 2025-07-14; baseline finish 2025-01-24 → 2025-08-01 |
| 1355 | Review & agree document | 2025-01-27 → 2025-08-04 (+189d) | 2025-01-31 → 2025-08-08 (+189d) |  |  | -3d → 619d |  | baseline start 2025-01-27 → 2025-08-04; baseline finish 2025-01-31 → 2025-08-08 |
| 1356 | SIT Minimum Viable Cohort Complete (SIT Minimum Viable Cohort Test Exit Report Approved) | 2025-02-07 → 2025-08-22 (+196d) | 2025-02-07 → 2025-08-22 (+196d) |  |  | -3d → 5d | 1355FS+5d, 1240, 1282, 1322, 1337, 1352 → 1240, 1282FS+5d, 1337, 1352 | baseline start 2025-02-07 → 2025-08-22; baseline finish 2025-02-07 → 2025-08-22 |
| 1357 | **SIT (non-MVC)** | 2024-03-11 A → 2025-06-16 A (+462d) | 2025-04-25 → 2025-11-27 (+216d) | 295d → 119d? | 14% → 10% | 5d → 25d |  | was named SIT - Other Participants; baseline start 2024-03-11 → 2025-05-05; baseline finish 2025-04-25 → 2025-11-27 |
| 1358 | **SIT Functional Testing (non-MVC)** | 2024-03-11 A → 2025-06-16 (+462d) | 2025-04-25 → 2025-11-14 (+203d) | 295d → 110d? | 34% → 0% | 5d → 25d |  | was named SIT Functional Testing (Other Participants); baseline start 2024-03-11 → 2025-06-16; baseline finish 2025-04-25 → 2025-11-14 |
| 1359 | **SIT Functional Testing Execution (non-MVC)** | 2024-03-11 A → 2025-06-16 (+462d) | 2025-04-04 → 2025-10-24 (+203d) | 280d → 95d? | 37% → 0% | 5d → 25d |  | was named SIT Functional Testing Execution (Other Participants); baseline start 2024-03-11 → 2025-06-16; baseline finish 2025-04-04 → 2025-10-24 |
| 1361 | SIT Functional Testing End (non-MVC) (incl. confirmation that PPs have submitted their Test Completion Reports to Programme for assurance) | 2025-04-04 → 2025-10-24 (+203d) | 2025-04-04 → 2025-10-24 (+203d) |  |  | 5d → 25d | SIT Other PPs continued supportFF → 1360FF | was named SIT Functional Testing End (Other Participants) (incl. confirmation that PPs have submitted their Test Completion Reports to Programme for assurance); baseline start 2025-04-04 → 2025-10-24; baseline finish 2025-04-04 → 2025-10-24 |
| 1362 | Assurance of PPs Test Completion Reports | 2025-04-14 → 2025-11-03 (+203d) | 2025-04-18 → 2025-11-07 (+203d) |  |  | 5d → 25d |  | baseline start 2025-04-14 → 2025-11-03; baseline finish 2025-04-18 → 2025-11-07 |
| 1363 | **SIT Functional Testing Test Completion Report (non-MVC)** | 2025-03-17 → 2025-10-06 (+203d) | 2025-04-18 → 2025-11-07 (+203d) |  |  | 5d → 25d |  | was named SIT Functional Testing Test Completion Report (Other Participants); baseline start 2025-03-17 → 2025-10-06; baseline finish 2025-04-18 → 2025-11-07 |
| 1364 | Develop document | 2025-03-17 → 2025-10-06 (+203d) | 2025-04-04 → 2025-10-24 (+203d) |  |  | 10d → 30d |  | baseline start 2025-03-17 → 2025-10-06; baseline finish 2025-04-04 → 2025-10-24 |
| 1365 | Review & agree document | 2025-04-14 → 2025-11-03 (+203d) | 2025-04-18 → 2025-11-07 (+203d) |  |  | 5d → 25d |  | baseline start 2025-04-14 → 2025-11-03; baseline finish 2025-04-18 → 2025-11-07 |
| 1366 | SIT Functional Testing Test Completion Report (non-MVC) Approved | 2025-04-25 → 2025-11-14 (+203d) | 2025-04-25 → 2025-11-14 (+203d) |  |  | 5d → 25d |  | was named SIT Functional Testing Test Completion Report (Other Participants) Approved; baseline start 2025-04-25 → 2025-11-14; baseline finish 2025-04-25 → 2025-11-14 |
| 1367 | **SIT Migration Testing (non-MVC)** | 2024-06-18 A → 2025-06-16 A (+363d) | 2025-04-25 → 2025-11-14 (+203d) | 224d → 110d | 12% → 23% | 5d → 25d |  | was named SIT Migration Testing (Other Participants); baseline start 2024-06-10 → 2025-05-05; baseline finish 2025-04-25 → 2025-10-08 |
| 1368 | Test Execution (Cycle 3 Completion and Regression Testing) | 2024-06-18 A → 2025-06-16 A (+363d) | 2025-04-04 → 2025-10-24 (+203d) | 209d → 95d | 13% → 28% | 5d → 25d | 1289SS → 1272 | was named SIT Migration Testing Execution (Other Participants); baseline start 2024-06-10 → 2025-05-05; baseline finish 2025-04-04 → 2025-09-17 |
| 1369 | SIT Migration Testing End (non-MVC) (incl. confirmation that PPs have submitted their Test Completion Reports to Programme for assurance) | 2025-04-04 → 2025-10-24 (+203d) | 2025-04-04 → 2025-10-24 (+203d) |  |  | 5d → 25d |  | was named SIT Migration Testing End (Other Participants) (incl. confirmation that PPs have submitted their Test Completion Reports to Programme for assurance); baseline start 2025-04-04 → 2025-09-17; baseline finish 2025-04-04 → 2025-09-17 |
| 1370 | Assurance of PPs Test Completion Reports | 2025-04-14 → 2025-11-03 (+203d) | 2025-04-18 → 2025-11-07 (+203d) |  |  | 5d → 25d |  | baseline start 2025-04-14 → 2025-09-25; baseline finish 2025-04-18 → 2025-10-01 |
| 1371 | **SIT Migration Testing Test Completion Report (non-MVC)** | 2025-03-17 → 2025-10-06 (+203d) | 2025-04-18 → 2025-11-07 (+203d) |  |  | 5d → 25d |  | was named SIT Migration Testing Test Completion Report (Other Participants); baseline start 2025-03-17 → 2025-08-28; baseline finish 2025-04-18 → 2025-10-01 |
| 1372 | Develop document | 2025-03-17 → 2025-10-06 (+203d) | 2025-04-04 → 2025-10-24 (+203d) |  |  | 10d → 30d |  | baseline start 2025-03-17 → 2025-08-28; baseline finish 2025-04-04 → 2025-09-17 |
| 1373 | Review & agree document | 2025-04-14 → 2025-11-03 (+203d) | 2025-04-18 → 2025-11-07 (+203d) |  |  | 5d → 25d |  | baseline start 2025-04-14 → 2025-09-25; baseline finish 2025-04-18 → 2025-10-01 |
| 1374 | SIT Migration Testing Test Completion Report (non-MVC Approved) | 2025-04-25 → 2025-11-14 (+203d) | 2025-04-25 → 2025-11-14 (+203d) |  |  | 5d → 25d |  | was named SIT Migration Testing Test Completion Report (Other Participants) Approved; baseline start 2025-04-25 → 2025-10-08; baseline finish 2025-04-25 → 2025-10-08 |
| 1375 | **SIT non-MVC Test Exit Report** | 2025-03-17 → 2025-10-27 (+224d) | 2025-04-11 → 2025-11-21 (+224d) |  |  | 11d → 25d |  | was named SIT Other Participants Test Exit Report; baseline start 2025-03-17 → 2025-10-27; baseline finish 2025-04-11 → 2025-11-21 |
| 1376 | Develop document | 2025-03-17 → 2025-10-27 (+224d) | 2025-04-04 → 2025-11-14 (+224d) |  |  | 11d → 25d | Develop documentFF → 1366FF, 1374FF | baseline start 2025-03-17 → 2025-10-27; baseline finish 2025-04-04 → 2025-11-14 |
| 1377 | Review & agree document | 2025-04-07 → 2025-11-17 (+224d) | 2025-04-11 → 2025-11-21 (+224d) |  |  | 11d → 25d |  | baseline start 2025-04-07 → 2025-11-17; baseline finish 2025-04-11 → 2025-11-21 |
| 1378 | SIT non-MVC Complete | 2025-04-25 → 2025-11-27 (+216d) | 2025-04-25 → 2025-11-27 (+216d) |  |  | 5d → 25d | 1377FS+4d, 1366, 1374, SIT Non-Functional Testing Test Completion Report (Other Participants) Approved, SIT Operational Testing Test Completion Report (Other Participants) Approved → 1377FS+4d, 1366, 1374 | was named SIT - Other Participants Complete; baseline start 2025-04-25 → 2025-11-27; baseline finish 2025-04-25 → 2025-11-27 |
| 1379 | **UIT Environment Preparation** |  |  | 700d → 700d? | 44% → 46% | 495d → 644d |  | baseline finish 2025-06-06 → 2025-07-04 |
| 1380 | **Test Artefact Development** |  | 2024-07-18 → 2025-04-16 (+272d) | 361d → 556d? | 0% → 51% | 747d → 701d |  |  |
| 1381 | **E2E Sandbox Guidance** |  | 2024-07-18 → 2025-03-24 (+249d) | 361d → 539d? | 0% → 71% | 747d → 718d |  |  |
| 1382 | Develop document | 2023-03-01 A | 2023-06-23 A |  | 0% → 100% | 995d → none |  |  |
| 1383 | Artefact review (via SITAG) and updates | 2023-06-26 A | 2023-07-28 A |  | 0% → 100% | 1000d → none |  |  |
| 1393 | **E2E Sandbox Test Data Approach & Plan** | 2023-03-29 → 2025-01-13 (+656d) | 2023-08-04 → 2025-04-16 (+621d) | 93d → 68d |  | 995d → 701d |  | baseline start 2023-03-29 → 2023-12-05; baseline finish 2023-08-04 → 2024-05-09 |
| 1394 | Develop document | 2023-03-29 → 2025-01-13 (+656d) | 2023-06-30 → 2025-02-18 (+599d) | 68d → 27d |  | 995d → 701d | 1382SS+20d → 1382SS+199d | constraint none → start no earlier than 2025-01-13; baseline start 2023-03-29 → 2023-12-05; baseline finish 2023-06-30 → 2024-03-15 |
| 1407 | **UIT Stub Specification and Delivery** |  | 2024-08-23 → 2024-10-18 (+56d) | 190d → 230d | 88% → 89% | 694d → 829d |  | baseline finish 2024-08-23 → 2024-10-18 |
| 1408 | **Qualification Test Stubs** |  | 2024-08-23 → 2024-10-18 (+56d) | 190d → 230d | 88% → 89% | 694d → 829d |  | baseline finish 2024-08-23 → 2024-10-18 |
| 1410 | Build & Test |  |  |  | 88% → 90% | 694d → 33.75d |  |  |
| 1411 | Prepare for release | 2024-08-19 A | 2024-08-23 → 2024-10-18 (+56d) | 5d → 45d | 0% → 75% | 694d → 829d |  | baseline finish 2024-08-23 → 2024-10-18 |
| 1412 | Non-SIT LDSO Test Harness Released | 2024-08-23 → 2024-10-18 (+56d) | 2024-08-23 → 2024-10-18 (+56d) |  |  | 694d → 829d |  | baseline start 2024-08-23 → 2024-10-18; baseline finish 2024-08-23 → 2024-10-18 |
| 1413 | **Environments (UIT)** |  |  |  |  | 495d → 644d |  | baseline finish 2025-06-06 → 2025-07-04 |
| 1414 | **Central Party (Avenade) Environments (UIT)** |  |  |  |  | 695d → 844d |  | baseline finish 2024-10-04 → 2024-09-27 |
| 1415 | Central Party (Avendae) environment preparation (incl. security certificates and security compliance) |  |  |  |  |  |  | baseline finish 2024-08-23 → 2024-08-01 |
| 1416 | Submit self-declaration of environment preparation complete (incl. security certificates and security compliance) to Programme for assurance |  |  |  |  |  |  | baseline finish 2024-08-23 → 2024-08-01 |
| 1418 | Deployment of MHHS solution code to UIT environments |  |  |  |  | 737d → 886d |  | baseline start 2024-09-09 → 2024-07-29; baseline finish 2024-09-20 → 2024-07-30 |
| 1419 | Central Party (Avenade) UIT environment Regression Testing |  |  |  |  | 737d → 886d |  | baseline start 2024-09-23 → 2024-07-31; baseline finish 2024-10-04 → 2024-07-31 |
| 1426 | **SI Environments (UIT)** |  |  |  |  | 495d → 644d |  | baseline start 2022-10-31 → 2022-11-16; baseline finish 2025-06-06 → 2025-07-04 |
| 1427 | Coordinate Central Parties' UIT environment preparation |  |  |  |  |  |  | baseline finish 2024-08-23 → 2024-08-01 |
| 1429 | Central Parties' UIT environments ready to start connectivity proving (incl. certificates and security compliance) | 2024-08-23 A | 2024-08-23 A |  | 0% → 100% | 694d → none |  |  |
| 1430 | Coordinate Central Parties' UIT environment connectivity proving |  |  |  |  | 694d → 843d |  | baseline start 2025-05-12 → 2024-08-26; baseline finish 2025-06-05 → 2024-09-30 |
| 1431 | Coordinate deployment of MHHS solution code to Central Parties' UIT environments |  |  |  |  |  |  | baseline start 2025-05-26 → 2024-07-29; baseline finish 2025-06-06 → 2024-07-30 |
| 1432 | Coordinate Central Parties' UIT environment Regression Testing |  |  |  |  | 737d → 886d |  | baseline start 2024-09-23 → 2024-07-31; baseline finish 2024-10-04 → 2024-07-31 |
| 1433 | **Environments (Non-SIT LDSO)** |  |  |  |  | 694d → 843d |  | baseline start 2024-08-06 → 2024-08-01; baseline finish 2025-01-13 → 2024-09-30 |
| 1434 | Coordinate Qualification Participants' environment preparation |  |  |  |  | 720d → 869d |  | baseline start 2024-08-06 → 2024-08-01; baseline finish 2024-10-28 → 2024-08-23 |
| 1435 | Coordinate deployment of MHHS solution code to Qualification Participants' UIT environments |  |  |  |  | 694d → 843d |  | baseline start 2024-10-15 → 2024-08-01; baseline finish 2024-10-28 → 2024-08-23 |
| 1436 | Qualification Testing Tranche 1 Participants' UIT environments ready to start connectivity proving (incl. certificates and security compliance) |  |  |  |  | 694d → 843d |  | baseline start 2024-11-04 → 2024-08-26; baseline finish 2024-11-04 → 2024-08-26 |
| 1437 | **Coordinate Qualification Participants' connectivity proving (Non-SIT LDSO)** |  |  |  |  | 694d → 843d |  | baseline start 2024-11-05 → 2024-08-27; baseline finish 2025-01-13 → 2024-09-30 |
| 1438 | Assurance of Qualification Participants' connectivity proving |  |  |  |  | 694d → 843d |  | baseline start 2024-11-05 → 2024-08-27; baseline finish 2025-01-13 → 2024-09-30 |
| 1439 | **Environments (S&A) Wave 1** |  |  |  |  |  |  | baseline start 2024-08-06 → 2024-08-01; baseline finish 2025-01-13 → 2024-09-26 |
| 1440 | Coordinate Qualification Participants' environment preparation |  |  |  |  | 695d → 844d |  | baseline start 2024-08-06 → 2024-09-02; baseline finish 2024-10-28 → 2024-09-27 |
| 1441 | Coordinate deployment of MHHS solution code to Qualification Participants' UIT environments |  |  |  |  | 625d → 774d |  | baseline start 2024-10-15 → 2024-10-21; baseline finish 2024-10-28 → 2024-11-01 |
| 1442 | Qualification Testing Wave 1 Participants' UIT environments ready to start connectivity proving (incl. certificates and security compliance) |  |  |  |  | 625d → 774d |  | baseline start 2024-11-04 → 2024-11-05; baseline finish 2024-11-04 → 2024-11-29 |
| 1443 | **Coordinate Qualification Participants' connectivity proving (S&A)** |  |  |  |  | 625d → 774d |  | baseline start 2024-11-05 → 2024-12-02; baseline finish 2025-01-13 → 2025-01-03 |
| 1444 | Assurance of Qualification Participants' connectivity proving |  |  |  |  | 625d → 774d |  | baseline start 2024-11-05 → 2024-12-02; baseline finish 2025-01-13 → 2025-01-03 |

| ID | Task | Start | Finish | Duration | Complete | Total float | Predecessors | Other |
| --- | --- | --- | --- | --- | --- | --- | --- | --- |
| 1445 | **Environments (S&A) Wave 2** |  |  |  |  |  |  | baseline start 2024-08-06 → 2024-08-27; baseline finish 2025-01-13 → 2025-03-07 |
| 1446 | Coordinate Qualification Participants' environment preparation |  |  |  |  | 640d → 789d |  | baseline start 2024-08-06 → 2024-11-18; baseline finish 2024-10-28 → 2024-12-13 |
| 1447 | Coordinate deployment of MHHS solution code to Qualification Participants' UIT environments |  |  |  |  | 580d → 729d |  | baseline start 2024-10-15 → 2024-12-16; baseline finish 2024-10-28 → 2025-01-10 |
| 1448 | Qualification Testing Wave 2 Participants' UIT environments ready to start connectivity proving (incl. certificates and security compliance) |  |  |  |  | 580d → 729d |  | baseline start 2024-11-04 → 2025-01-13; baseline finish 2024-11-04 → 2025-01-31 |
| 1449 | **Coordinate Qualification Participants' connectivity proving (S&A)** |  |  |  |  |  |  | baseline start 2024-11-05 → 2024-08-27; baseline finish 2025-01-13 → 2024-09-30 |
| 1450 | Assurance of Qualification Participants' connectivity proving |  |  |  |  | 580d → 729d |  | baseline start 2024-11-05 → 2025-02-03; baseline finish 2025-01-13 → 2025-03-07 |
| 1451 | **Environments (S&A) Wave 3** |  |  |  |  | 495d → 644d |  | baseline start 2024-08-06 → 2025-03-17; baseline finish 2025-01-13 → 2025-07-04 |
| 1452 | Coordinate Qualification Participants' environment preparation |  |  |  |  | 545d → 694d |  | baseline start 2024-08-06 → 2025-03-17; baseline finish 2024-10-28 → 2025-04-25 |
| 1453 | Coordinate deployment of MHHS solution code to Qualification Participants' UIT environments |  |  |  |  | 495d → 644d |  | baseline start 2024-10-15 → 2025-04-28; baseline finish 2024-10-28 → 2025-05-09 |
| 1454 | Qualification Testing Wave 3 Participants' UIT environments ready to start connectivity proving (incl. certificates and security compliance) |  |  |  |  | 495d → 644d |  | baseline start 2024-11-04 → 2025-05-13; baseline finish 2024-11-04 → 2025-05-30 |
| 1455 | **Coordinate Qualification Participants' connectivity proving (S&A)** |  |  |  |  | 495d → 644d |  | baseline start 2024-11-05 → 2025-06-02; baseline finish 2025-01-13 → 2025-07-04 |
| 1456 | Assurance of Qualification Participants' connectivity proving |  |  |  |  | 495d → 644d |  | baseline start 2024-11-05 → 2025-06-02; baseline finish 2025-01-13 → 2025-07-04 |
| 1457 | **Environments (S&A) Wave 4** |  |  |  |  |  |  | baseline start 2024-08-06 → 2025-03-17; baseline finish 2025-01-13 → 2025-07-04 |
| 1458 | Coordinate Qualification Participants' environment preparation |  |  |  |  | 545d → 694d |  | baseline start 2024-08-06 → 2025-03-17; baseline finish 2024-10-28 → 2025-04-25 |
| 1459 | Coordinate deployment of MHHS solution code to Qualification Participants' UIT environments |  |  |  |  | 495d → 644d |  | baseline start 2024-10-15 → 2025-04-28; baseline finish 2024-10-28 → 2025-05-09 |
| 1460 | Qualification Testing Wave 4 Participants' UIT environments ready to start connectivity proving (incl. certificates and security compliance) |  |  |  |  | 495d → 644d |  | baseline start 2024-11-04 → 2025-05-13; baseline finish 2024-11-04 → 2025-05-30 |
| 1461 | **Coordinate Qualification Participants' connectivity proving (S&A)** |  |  |  |  |  |  | baseline start 2024-11-05 → 2025-06-02; baseline finish 2025-01-13 → 2025-07-04 |
| 1462 | Assurance of Qualification Participants' connectivity proving |  |  |  |  | 495d → 644d |  | baseline start 2024-11-05 → 2025-06-02; baseline finish 2025-01-13 → 2025-07-04 |
| 1473 | **Other Preparation** |  |  |  |  | 699d → 848d |  | baseline start 2022-11-16 → 2022-10-31 |
| 1474 | **SI Other Preparation** |  |  |  |  | 1129d → 1278d |  | baseline start 2024-05-02 → 2022-10-31; baseline finish 2024-08-01 → 2023-01-30 |
| 1475 | Onboarding of UIT E2E Sandbox Participants to Test Management Tool for E2E Sandbox Testing Start (onboarding of participants will be ongoing hereafter) |  |  |  |  | 1129d → 1278d |  | baseline start 2024-05-02 → 2022-10-31; baseline finish 2024-08-01 → 2023-01-30 |
| 1488 | **SIT PPs Early Sandbox Testing Execution** |  |  |  |  | 285d → 434d |  | was named SIT PPs E2E Sandbox Testing Execution; baseline start 2024-11-04 → 2025-02-07; baseline finish 2026-01-19 → 2026-04-24 |
| 1489 | SIT PPs E2E Sandbox Testing Start |  |  |  |  | 600d → 749d | Core Systems Code FreezeFS+1d, 1487FS+5d → 1487FS+5d |  |
| 1490 | SIT PPs E2E Sandbox Testing Execution |  |  |  |  | 285d → 434d |  | baseline start 2024-11-04 → 2025-02-07; baseline finish 2026-01-19 → 2026-04-24 |
| 1493 | Central systems ready for migrating MPANs (M10) | 2025-03-07 → 2025-09-24 (+201d) | 2025-03-07 → 2025-09-24 (+201d) |  |  | -3d → 5d |  | constraint must finish on 2025-03-07 → start no earlier than 2025-08-13; baseline start 2025-03-07 → 2025-09-24; baseline finish 2025-03-07 → 2025-09-24 |
| 1494 | Central systems ready for migrating MPANs (M10*) - Late Exit | 2025-06-06 → 2025-12-24 (+201d) | 2025-06-06 → 2025-12-24 (+201d) |  |  | 515d → 521d |  | baseline start 2025-06-06 → 2025-12-24; baseline finish 2025-06-06 → 2025-12-24 |
| 1505 | **NON SIT LDSO QUALIFICATION** |  | 2025-02-21 → 2025-08-22 (+182d) | 339d → 469d? | 74% → 67% | -3d → 609d |  | baseline finish 2025-02-28 → 2025-08-22 |
| 1506 | **Approach Planning** |  | 2024-08-22 A |  | 96% → 100% | 25d → none |  |  |
| 1516 | QWG Review Operational, Non-Functional & Migration Annexes of Approach & Plan | 2024-08-13 A | 2024-08-13 A |  | 0% → 100% | 25d → none |  |  |
| 1517 | Update Following QWG Review | 2024-08-14 A | 2024-08-21 A |  | 0% → 100% | 25d → none |  |  |
| 1518 | QAG Approval for Operational, Non-Functional & Migration Annexes of Approach & Plan | 2024-08-22 A | 2024-08-22 A |  | 0% → 100% | 25d → none |  |  |
| 1535 | **Test Execution Schedule** |  | 2024-08-22 → 2024-11-29 (+99d) | 90d → 161d |  | 25d → 799d |  | baseline finish 2024-08-22 → 2024-11-29 |
| 1541 | Qualification Testing for Non-SIT LDSOs (Functional, Migration, NFT, Operational) Test Execution Schedule Complete | 2024-08-22 → 2024-11-29 (+99d) | 2024-08-22 → 2024-11-29 (+99d) |  |  | 25d → 799d |  | constraint none → finish no earlier than 2024-11-29; baseline start 2024-08-22 → 2024-11-29; baseline finish 2024-08-22 → 2024-11-29 |
| 1542 | **Functional, Non-Functional, Operational & Migration Test Scenarios & Cases** |  | 2024-08-22 A |  | 90% → 100% | 25d → none |  |  |
| 1545 | Test Scenarios & Cases - Non-Functional - Drafted, Reviewed |  | 2024-08-22 A |  | 90% → 100% | 25d → none |  |  |
| 1546 | Test Scenarios & Cases - Non-Functional - Approved at QAG | 2024-08-22 A | 2024-08-22 A |  | 0% → 100% | 25d → none |  |  |
| 1549 | Test Scenarios & Cases - Operational - Drafted, Reviewed |  | 2024-08-22 A |  | 81% → 100% | 24d → none |  |  |
| 1550 | Test Scenarios & Cases - Operational - Approved at QAG | 2024-08-22 A | 2024-08-22 A |  | 0% → 100% | 24d → none |  |  |
| 1551 | **Test Data** |  | 2024-12-23 → 2025-05-16 (+144d) | 241d → 345d | 61% → 44% | 41d → 679d |  | baseline finish 2024-12-23 → 2025-05-16 |
| 1553 | Non-SIT LDSO QT Test Data Plan Approved by QAG |  |  |  |  |  |  | baseline start 2024-05-16 → 2024-05-23; baseline finish 2024-05-16 → 2024-05-23 |
| 1557 | Test Data Reviewed by the Programme |  | 2024-08-09 A |  | 95% → 100% | 41d → none |  |  |
| 1558 | Test Data Loaded |  | 2024-09-03 → 2024-12-06 (+94d) | 17d → 85d |  | 41d → 679d |  | baseline finish 2024-09-03 → 2024-12-06 |
| 1559 | Test Data Signed Off | 2024-09-03 → 2024-12-06 (+94d) | 2024-09-03 → 2024-12-06 (+94d) |  |  | 41d → 679d |  | baseline start 2024-09-03 → 2024-12-06; baseline finish 2024-09-03 → 2024-12-06 |
| 1560 | Test Execution Data Support | 2024-09-04 → 2024-12-09 (+96d) | 2024-12-23 → 2025-05-16 (+144d) | 79d → 115d |  | 41d → 679d |  | baseline start 2024-09-04 → 2024-12-09; baseline finish 2024-12-23 → 2025-05-16 |
| 1561 | **Tooling** |  | 2024-08-23 A |  | 96% → 100% | 24d → none |  |  |
| 1563 | Develop Training Requirements & Materials Inc. Day in the Life |  | 2024-08-13 A |  | 95% → 100% | 31d → none |  |  |
| 1564 | ADO Launch complete | 2024-08-23 A | 2024-08-23 A |  | 0% → 100% | 24d → none |  |  |
| 1565 | **Pre-Integration Testing** |  | 2024-09-30 → 2024-11-29 (+60d) | 174d → 218d | 84% → 90% | 0d → 799d |  | baseline finish 2024-09-30 → 2024-11-29 |
| 1568 | Develop and agree PIT Test Scenarios |  |  |  |  |  |  | baseline start 2024-06-17 → 2024-07-02 |
| 1569 | PIT Execution | 2024-07-30 A → 2024-09-30 A (+62d) | 2024-09-30 → 2024-11-29 (+60d) |  |  | -2d → none |  | constraint none → start no earlier than 2024-09-30; baseline start 2024-07-30 → 2024-09-30; baseline finish 2024-09-30 → 2024-11-29 |
| 1570 | Non-SIT LDSO Participants have submitted PIT Test Completion Report & evidence for QT Entry​ | 2024-09-30 → 2024-11-29 (+60d) | 2024-09-30 → 2024-11-29 (+60d) |  |  | -2d → 799d |  | baseline start 2024-09-30 → 2024-11-29; baseline finish 2024-09-30 → 2024-11-29 |
| 1571 | **Placing Reliance - Code Body & LDSO Functional and Migration** |  | 2024-08-22 A |  | 93% → 100% | 25d → none |  |  |
| 1575 | Review and Consultation |  | 2024-08-22 A |  | 87% → 100% | 25d → none |  |  |
| 1576 | **Placing Reliance - Code Body & LDSO Non Functional and Operational** |  | 2024-08-22 A |  | 78% → 100% | 25d → none |  |  |
| 1578 | Review and Consultation |  | 2024-08-22 A |  | 35% → 100% | 25d → none |  |  |
| 1579 | PP Test Scope Presented at QAG | 2024-08-22 A | 2024-08-22 A |  | 0% → 100% | 25d → none |  |  |
| 1580 | **LDSO Test Readiness Reporting** |  | 2024-10-01 → 2024-07-26 A (-67d) | 118d → 71d | 62% → 100% | -3d → none |  | baseline finish 2024-10-01 → 2024-07-26 |
| 1583 | **Test Environment** |  | 2024-09-18 → 2024-11-29 (+72d) | 111d → 163d | 65% → 37% | 5d → 67d |  | baseline finish 2024-09-18 → 2024-11-29 |
| 1585 | Central System (DIP Env & Helix Test Harness) Test Environment DBT |  | 2024-09-09 → 2024-11-29 (+81d) | 104d → 163d | 73% → 47% | 12d → 67d |  | constraint none → finish no earlier than 2024-11-29; baseline finish 2024-08-22 → 2024-11-29 |
| 1586 | Coordinate LDSO Environment Preparation |  | 2024-09-09 → 2024-11-29 (+81d) | 42d → 101d | 33% → 14% | 12d → 67d |  | was named Coordinate LDSO Env Preparation; baseline finish 2024-08-22 → 2024-11-29 |
| 1589 | LDSO Test Environments Connection Confirmed to UIT Environment | 2024-09-18 → 2024-11-29 (+72d) | 2024-09-18 → 2024-11-29 (+72d) |  |  | 5d → 67d |  | baseline start 2024-09-18 → 2024-11-29; baseline finish 2024-09-18 → 2024-11-29 |
| 1590 | **Test Readiness** |  | 2024-09-30 → 2024-12-20 (+81d) | 65d → 124d | 41% → 31% | -2d → 784d |  | baseline start 2024-06-17 → 2024-07-02; baseline finish 2024-09-30 → 2024-12-20 |
| 1591 | Preparation for Interim Test Readiness Report |  |  |  |  |  |  | baseline start 2024-06-17 → 2024-07-02 |
| 1592 | Interim Test Readiness Report Submission to MHHS Programme for Review | 2024-07-26 A | 2024-07-26 A |  | 0% → 100% | 8d → none |  |  |
| 1593 | LDSO Update Readiness Report & Final Assurance by Programme |  | 2024-08-30 → 2024-12-12 (+104d) | 25d → 99d | 32% → 20% | -3d → 42d |  | baseline finish 2024-08-30 → 2024-12-12 |
| 1594 | Final Test Readiness Report Submitted to MHHS Programme | 2024-09-02 → 2024-12-13 (+102d) | 2024-09-02 → 2024-12-13 (+102d) |  |  | 5d → 784d |  | baseline start 2024-09-02 → 2024-12-13; baseline finish 2024-09-02 → 2024-12-13 |
| 1595 | Final Programme Assurance of LDSO Test Readiness | 2024-09-02 → 2024-12-13 (+102d) | 2024-09-30 → 2024-12-20 (+81d) | 21d → 6d |  | -3d → 42d |  | baseline start 2024-09-02 → 2024-12-13; baseline finish 2024-09-30 → 2024-12-20 |
| 1596 | Qualification Testing for Non-SIT LDSOs (Functional, Migration, NFT, Operational) Programme Test Readiness confirmed | 2024-09-30 → 2024-12-20 (+81d) | 2024-09-30 → 2024-12-20 (+81d) |  |  | -2d → 784d | 1594FS+13d, 1570, 1544, 1546, 1548, 1584 → 1594FS+5d, 1570, 1544, 1546, 1548, 1584 | baseline start 2024-09-30 → 2024-12-20; baseline finish 2024-09-30 → 2024-12-20 |
| 1597 | Qualification Testing for Non-SIT LDSOs (Functional, Migration, NFT, Operational) Test Readiness Confirmed (Final Test Readiness Review for LDSO) | 2024-09-30 → 2024-12-20 (+81d) | 2024-09-30 → 2024-12-20 (+81d) |  |  | -3d → 42d |  | baseline start 2024-09-30 → 2024-12-20; baseline finish 2024-09-30 → 2024-12-20 |
| 1598 | **Test Window** | 2024-10-01 → 2025-01-06 (+97d) | 2024-12-20 → 2025-05-16 (+147d) | 59d → 94d? |  | -3d → 42d |  | baseline start 2024-10-01 → 2025-01-06; baseline finish 2024-12-20 → 2025-05-16 |

| ID | Task | Start | Finish | Duration | Complete | Total float | Predecessors | Other |
| --- | --- | --- | --- | --- | --- | --- | --- | --- |
| 1599 | **All Non-SIT LDSOs Qualification Testing** | 2024-10-01 → 2025-01-06 (+97d) | 2024-12-20 → 2025-05-16 (+147d) | 59d → 94d? |  | -3d → 42d |  | baseline start 2024-10-01 → 2025-01-06; baseline finish 2024-12-20 → 2025-05-16 |
| 1600 | Non-SIT LDSO QT Test Execution Starts | 2024-10-01 → 2025-01-06 (+97d) | 2024-10-01 → 2025-01-06 (+97d) |  |  | -3d → 42d | Final Test Readiness Report Developed & SubmittedFS+3d, 1564, 1589, 1596, 1597, 1541, 1579 → 1597FS+11d | constraint none → start no earlier than 2024-11-01; baseline start 2024-10-01 → 2025-01-06; baseline finish 2024-10-01 → 2025-01-06 |
| 1606 | Qualification Testing for Non-SIT LDSOs (Functional, Migration, NFT, Operational) 1 End | 2025-01-24 → 2025-05-16 (+112d) | 2025-01-24 → 2025-05-16 (+112d) |  |  | 17d → 38d | 1610FS+25d, 1560 → 1605 | constraint none → start no earlier than 2025-05-16; baseline start 2025-01-24 → 2025-05-16; baseline finish 2025-01-24 → 2025-05-16 |
| 1607 | **Test Result Assurance** | 2024-11-04 → 2025-04-21 (+168d) | 2025-01-24 → 2025-05-29 (+125d) | 60d → 29d |  | -3d → 38d |  | baseline start 2024-11-04 → 2025-04-21; baseline finish 2025-01-24 → 2025-05-29 |
| 1608 | LDSOs Develop & Submit Test Report (QT Test Completion Report) | 2024-11-04 → 2025-04-21 (+168d) | 2024-11-28 → 2025-05-16 (+169d) |  |  | -3d → 38d | 1600FS+23d → 1606FF | baseline start 2024-11-04 → 2025-04-21; baseline finish 2024-11-28 → 2025-05-16 |
| 1609 | Test Reports Reviewed By MHHS & Code Bodies & Finalised | 2024-11-29 → 2025-05-16 (+168d) | 2024-12-20 → 2025-05-29 (+160d) | 16d → 10d |  | -3d → 38d |  | baseline start 2024-11-29 → 2025-05-16; baseline finish 2024-12-20 → 2025-05-29 |
| 1610 | Non-SIT LDSOs submission deadline for their QT Test Completion Report to MHHS Programme | 2024-12-20 → 2025-05-29 (+160d) | 2024-12-20 → 2025-05-29 (+160d) |  |  | -3d → 38d |  | baseline start 2024-12-20 → 2025-05-29; baseline finish 2024-12-20 → 2025-05-29 |
| 1611 | **Non-SIT LDSO Qualification Closure** | 2024-12-23 → 2025-05-30 (+158d) | 2025-02-21 → 2025-08-22 (+182d) | 45d → 61d |  | -3d → 22d |  | baseline start 2024-12-23 → 2025-05-30; baseline finish 2025-02-28 → 2025-08-22 |
| 1612 | Non-SIT LDSO Qualification Learned Captured | 2024-12-23 → 2025-05-30 (+158d) | 2025-01-10 → 2025-06-19 (+160d) |  |  | -3d → 38d |  | baseline start 2024-12-23 → 2025-05-30; baseline finish 2025-01-10 → 2025-06-19 |
| 1613 | Non-SIT LDSO Qualification Closure Down | 2025-01-13 → 2025-06-20 (+158d) | 2025-01-17 → 2025-06-26 (+160d) |  |  | -3d → 38d |  | baseline start 2025-01-13 → 2025-06-20; baseline finish 2025-01-17 → 2025-06-26 |
| 1614 | BSC PAB & REC Manager approval of Qualification for Non-SIT LDSOs (Start of Migration for Qualification Participants) | 2025-02-21 → 2025-08-22 (+182d) | 2025-02-21 → 2025-08-22 (+182d) |  |  | -3d → 22d | 1613FS+25d, 1606, 1703, 1704 → 1703, 1704, 1613FS+25d | baseline start 2025-02-28 → 2025-08-22; baseline finish 2025-02-28 → 2025-08-22 |
| 1615 | **S & A QUALIFICATION** |  | 2026-02-27 → 2027-01-28 (+335d) | 604d → 843d | 33% → 32% | 325d → 235d |  | baseline finish 2026-02-27 → 2027-01-28 |
| 1616 | **MHHS Qualification - Qualification Deliverables** |  | 2025-03-07 → 2025-08-14 (+160d) | 349d → 463d | 85% → 60% | 2d → 615d |  | baseline finish 2025-03-07 → 2025-08-14 |
| 1617 | **BSC & REC Assessment Criteria** |  | 2024-08-29 → 2025-08-14 (+350d) | 213d → 463d | 99% → 23% | 56d → 615d |  | baseline finish 2024-08-29 → 2025-08-14 |
| 1622 | Update BSC Assessment Criteria (Functional, Non-Functional, Migration, Operational) |  |  |  |  |  | 1117FS+28d → none |  |
| 1623 | Assessment Criteria (Functional, Non-Functional, Migration, Operational) Approved by REC PAB and BSC PAB |  | 2024-08-29 → 2025-08-14 (+350d) | 0d → 250d |  | 56d → 615d |  | constraint none → start no earlier than 2023-09-15; baseline finish 2024-08-29 → 2025-08-14 |
| 1624 | **Qualification Approach and Plan** |  | 2024-08-29 A |  | 97% → 100% | 88d → none |  |  |
| 1635 | **Qualification Approach and Plan v3** |  | 2024-08-29 A |  | 94% → 100% | 88d → none |  |  |
| 1640 | QWG Endorsement of Qualification Approach and Plan v3 | 2024-08-13 A | 2024-08-13 A |  | 0% → 100% | 88d → none |  |  |
| 1641 | QAG Approval of Qualification Approach and Plan v3 | 2024-08-22 A | 2024-08-22 A |  | 0% → 100% | 88d → none |  |  |
| 1642 | BSC and REC PAB Approval of Qualification Approach and Plan v3 | 2024-08-27 A | 2024-08-29 A |  | 0% → 100% | 88d → none |  |  |
| 1643 | Non-Functional Testing elements of Qualification Approach and Plan v3 approved by REC PAB and BSC PAB | 2024-08-29 A | 2024-08-29 A |  | 0% → 100% | 88d → none |  |  |
| 1644 | **Qualification Assessment Document** |  |  |  | 76% → 81% | 2d → 633d |  |  |
| 1652 | **Qualification Assessment Document v3** |  | 2024-08-29 A |  | 94% → 100% | 62d → none |  | was named Qualification Assessment Document v2 |
| 1655 | Draft Qualification Assessment Document v3 |  |  |  |  |  | 1103, 1117, 1654 → 1103, 1654 | was named Draft Qualification Assessment Document v2 |
| 1656 | Internal Review (Code Bodies and MHHSP) of Qualification Assessment Document v3 |  |  |  |  |  |  | was named Internal Review (Code Bodies and MHHSP) of Qualification Assessment Document v2 |
| 1657 | Industry consultation for Qualification Assessment Document v3 |  |  |  |  |  |  | was named Industry consultation for Qualification Assessment Document v2 |
| 1658 | Update Post-Consultation for Qualification Assessment Document v3 |  |  |  |  |  |  | was named Update Post-Consultation for Qualification Assessment Document v2 |
| 1659 | QWG Endorsement of Qualification Assessment Document v3 | 2024-08-13 A | 2024-08-13 A |  | 0% → 100% | 62d → none |  | was named QWG Endorsement of Qualification Assessment Document v2 |
| 1660 | QAG Endorsement of Qualification Assessment Document v3 | 2024-08-22 A | 2024-08-22 A |  | 0% → 100% | 62d → none |  | was named QAG Endorsement of Qualification Assessment Document v2 |
| 1661 | BSC and REC PAB Approval of Qualification Assessment Document v3 | 2024-08-27 A | 2024-08-29 A |  | 0% → 100% | 62d → none |  | was named BSC and REC PAB Approval of Qualification Assessment Document v2 |
| 1662 | Qualification Assessment Document v3 approved by REC PAB and BSC PAB | 2024-08-29 A | 2024-08-29 A |  | 0% → 100% | 62d → none |  | was named Qualification Assessment Document v2 approved by REC PAB and BSC PAB |
| 1663 | **Qualification Assessment Document Portal** |  |  |  | 59% → 65% | 2d → 633d |  |  |
| 1668 | Qualification Assessment Document Portal Webinar (Date TBC) |  |  |  |  |  |  | baseline start 2024-06-11 → 2024-06-18; baseline finish 2024-06-11 → 2024-06-18 |
| 1675 | Update to Qualification Assessment Document Portal post QAD V3 | 2024-08-30 A | 2024-09-12 A |  | 0% → 100% | 62d → none |  | was named Update to Qualification Assessment Document Portal post QAD V2 |
| 1676 | Update to Qualification Assessment Document Portal post QAD V3 Complete | 2024-09-12 A | 2024-09-12 A |  | 0% → 100% | 62d → none |  | was named Update to Qualification Assessment Document Portal post QAD V2 Complete |
| 1677 | **MHHS Qualification - SIT Participants** | 2024-09-02 → 2025-01-06 (+126d) | 2025-05-30 → 2025-12-22 (+206d) | 194d → 251d |  | 1d → 60d |  | baseline start 2024-09-02 → 2025-01-06; baseline finish 2025-05-30 → 2025-12-22 |
| 1678 | Initial QAD Submission Window opens | 2024-09-02 → 2025-01-06 (+126d) | 2024-09-02 → 2025-01-06 (+126d) |  |  | 1d → 773d | 1669FS+6d → 1669FS+96d | constraint none → start no earlier than 2025-01-06; baseline start 2024-09-02 → 2025-01-06; baseline finish 2024-09-02 → 2025-01-06 |
| 1679 | SIT Participants submit Initial QAD | 2024-09-03 → 2025-01-06 (+125d) | 2024-10-10 → 2025-02-14 (+127d) | 28d → 30d |  | 1d → 60d | 1678 → none | constraint none → start no earlier than 2025-01-06; baseline start 2024-09-02 → 2025-01-06; baseline finish 2024-10-10 → 2025-02-14 |
| 1680 | Code Bodies review Initial QAD | 2024-10-11 → 2025-02-14 (+126d) | 2024-11-29 → 2025-04-04 (+126d) |  |  | 1d → 60d | 1679 → 1679FS-1d | baseline start 2024-10-11 → 2025-02-14; baseline finish 2024-11-29 → 2025-04-04 |
| 1681 | Completion of Code Bodies review of Initial QAD | 2024-11-29 → 2025-04-04 (+126d) | 2024-11-29 → 2025-04-04 (+126d) |  |  | 1d → 60d |  | baseline start 2024-11-29 → 2025-04-04; baseline finish 2024-11-29 → 2025-04-04 |
| 1682 | **MHHS Qualification - SIT MVC Participants** | 2024-11-29 → 2025-04-07 (+129d) | 2025-02-28 → 2025-09-11 (+195d) | 65d → 114d |  | 1d → 5d |  | baseline start 2024-11-29 → 2025-04-07; baseline finish 2025-02-28 → 2025-09-11 |
| 1683 | Final QAD Submission Window (MVC) opens | 2024-11-29 → 2025-04-07 (+129d) | 2024-11-29 → 2025-04-07 (+129d) |  |  | 6d → 60d | 1680, 1676, 1681 → 1680, 1676, 1681FS+1d | baseline start 2024-11-29 → 2025-04-07; baseline finish 2024-11-29 → 2025-04-07 |
| 1684 | SIT MVC Participants submit Final QAD | 2024-12-02 → 2025-04-07 (+126d) | 2025-01-06 → 2025-05-09 (+123d) | 26d → 25d |  | 6d → 60d | 1683 → 1683FS-1d | baseline start 2024-12-02 → 2025-04-07; baseline finish 2025-01-06 → 2025-05-09 |
| 1685 | Completion of Code Bodies review of Final QAD (MVC) | 2025-01-07 → 2025-05-12 (+125d) | 2025-01-31 → 2025-06-06 (+126d) | 19d → 20d |  | 6d → 60d |  | baseline start 2025-01-07 → 2025-05-12; baseline finish 2025-01-31 → 2025-06-06 |
| 1686 | QAD Sign Off Deadline (MVC) | 2025-02-07 → 2025-08-22 (+196d) | 2025-02-07 → 2025-08-22 (+196d) |  |  | 1d → 5d |  | constraint none → start no earlier than 2025-07-11; baseline start 2025-02-07 → 2025-08-22; baseline finish 2025-02-07 → 2025-08-22 |
| 1687 | REC Code Manager / BSC PAB Approval of Qualification (MVC) | 2025-02-28 → 2025-09-11 (+195d) | 2025-02-28 → 2025-09-11 (+195d) |  |  | 1d → 5d | 1686FS+15d → 1686FS+14d | baseline start 2025-02-28 → 2025-09-11; baseline finish 2025-02-28 → 2025-09-11 |
| 1688 | **MHHS Qualification - SIT Non-MVC Participants** | 2024-12-02 → 2025-05-19 (+168d) | 2025-05-30 → 2025-12-22 (+206d) | 129d → 156d |  | 1d → 25d |  | baseline start 2024-12-02 → 2025-05-19; baseline finish 2025-05-30 → 2025-12-22 |
| 1689 | Final QAD Submission Window (Non-MVC) opens | 2024-12-02 → 2025-05-19 (+168d) | 2024-12-02 → 2025-05-19 (+168d) |  |  | 1d → 134d | 1681FS+1d → 1681FS+31d | baseline start 2024-12-02 → 2025-05-19; baseline finish 2024-12-02 → 2025-05-19 |
| 1690 | SIT Non-MVC Participants submit Final QAD | 2024-12-03 → 2025-05-19 (+167d) | 2025-03-31 → 2025-09-19 (+172d) | 85d → 90d |  | 1d → 45d | 1689SS → 1689SS-1d | baseline start 2024-12-02 → 2025-05-19; baseline finish 2025-03-31 → 2025-09-19 |
| 1691 | Completion of Code Bodies review of Final QAD (Non-MVC) | 2025-04-01 → 2025-09-22 (+174d) | 2025-04-25 → 2025-10-24 (+182d) | 19d → 25d |  | 1d → 45d |  | baseline start 2025-04-01 → 2025-09-22; baseline finish 2025-04-25 → 2025-10-24 |
| 1692 | QAD Sign Off Deadline (Non-MVC) | 2025-05-02 → 2025-11-28 (+210d) | 2025-05-02 → 2025-11-28 (+210d) |  |  | 1d → 25d |  | baseline start 2025-05-02 → 2025-11-28; baseline finish 2025-05-02 → 2025-11-28 |
| 1693 | REC Code Manager / BSC PAB Approval of Qualification (Non-MVC) | 2025-05-30 → 2025-12-22 (+206d) | 2025-05-30 → 2025-12-22 (+206d) |  |  | 1d → 25d | 1692FS+20d → 1692FS+16d | baseline start 2025-05-30 → 2025-12-22; baseline finish 2025-05-30 → 2025-12-22 |
| 1694 | **MHHS Qualification - Non-SIT LDSO** | 2024-09-02 → 2025-01-06 (+126d) | 2025-02-07 → 2025-09-11 (+216d) | 114d → 179d |  | 7d → 71d |  | baseline start 2024-09-02 → 2025-01-06; baseline finish 2025-02-07 → 2025-09-11 |
| 1695 | Initial QAD Submission window opens | 2024-09-02 → 2025-01-06 (+126d) | 2024-09-02 → 2025-01-06 (+126d) |  |  | 7d → 773d | 1670FS+6d → 1670FS+96d | baseline start 2024-09-02 → 2025-01-06; baseline finish 2024-09-02 → 2025-01-06 |
| 1696 | Non-SIT LDSO Participants submit initial QAD | 2024-09-03 → 2025-01-06 (+125d) | 2024-10-10 → 2025-02-14 (+127d) | 28d → 30d |  | 7d → 71d | 1695 → none | constraint none → start no earlier than 2025-01-06; baseline start 2024-09-02 → 2025-01-06; baseline finish 2024-10-10 → 2025-02-14 |
| 1697 | Non-SIT LDSO QT Participants have submitted their initial QAD | 2024-10-10 → 2025-02-14 (+127d) | 2024-10-10 → 2025-02-14 (+127d) |  |  | 7d → 71d |  | baseline start 2024-10-10 → 2025-02-14; baseline finish 2024-10-10 → 2025-02-14 |
| 1698 | Code Bodies review of Non-SIT LDSO participants Initial QAD | 2024-10-11 → 2025-02-17 (+129d) | 2024-11-29 → 2025-04-04 (+126d) | 36d → 35d |  | 7d → 71d |  | baseline start 2024-10-11 → 2025-02-17; baseline finish 2024-11-29 → 2025-04-04 |
| 1699 | Completion of Code Bodies review of Initial QAD | 2024-11-29 → 2025-04-04 (+126d) | 2024-11-29 → 2025-04-04 (+126d) |  |  | 7d → 71d |  | baseline start 2024-11-29 → 2025-04-04; baseline finish 2024-11-29 → 2025-04-04 |
| 1700 | Final QAD Submission window opens | 2024-12-02 → 2025-04-07 (+126d) | 2024-12-02 → 2025-04-07 (+126d) |  |  | 7d → 71d |  | baseline start 2024-12-02 → 2025-04-07; baseline finish 2024-12-02 → 2025-04-07 |
| 1701 | Non-SIT LDSO Participants submit Final QAD | 2024-12-03 → 2025-04-21 (+139d) | 2025-01-06 → 2025-05-23 (+137d) |  |  | 7d → 62d |  | baseline start 2024-12-02 → 2025-04-21; baseline finish 2025-01-06 → 2025-05-23 |
| 1702 | Non-SIT LDSO QT Participants have submitted their final QAD | 2025-01-06 → 2025-05-23 (+137d) | 2025-01-06 → 2025-05-23 (+137d) |  |  | 7d → 62d |  | baseline start 2025-01-06 → 2025-05-23; baseline finish 2025-01-06 → 2025-05-23 |
| 1703 | Completion of Code Bodies review of the Final QAD | 2025-01-07 → 2025-05-26 (+139d) | 2025-01-31 → 2025-06-20 (+140d) | 19d → 20d |  | 7d → 62d |  | baseline start 2025-01-07 → 2025-05-26; baseline finish 2025-01-31 → 2025-06-20 |
| 1704 | QAD Sign Off Deadline (Non-SIT LDSOs) | 2025-02-07 → 2025-08-22 (+196d) | 2025-02-07 → 2025-08-22 (+196d) |  |  | 7d → 22d | 1703FS+5d → 1703FS+5d, 1356 | was named QAD Sign Off Deadline; baseline start 2025-02-07 → 2025-08-22; baseline finish 2025-02-07 → 2025-08-22 |
| 1706 | **MHHS Qualification - Qualification Waves** |  | 2026-02-27 → 2027-01-28 (+335d) | 575d → 814d | 28% → 29% | 325d → 235d |  | baseline finish 2026-02-27 → 2027-01-28 |
| 1707 | **Qualification Wave Prep** |  | 2025-07-31 → 2025-12-26 (+148d) | 424d → 530d | 53% → 55% | 476d → 519d |  | baseline finish 2025-07-31 → 2025-12-26 |
| 1719 | Internal Review (Code Bodies and MHHSP) of QT Test Data Approach and Plan |  |  |  |  |  |  | baseline finish 2024-05-31 → 2024-06-07 |
| 1720 | Issue QT Test Data Approach and Plan for Industry Consultation |  |  |  |  |  |  | baseline start 2024-06-03 → 2024-06-10; baseline finish 2024-06-14 → 2024-06-21 |
| 1721 | Update QT Test Approach and Plan Post Industry Consultation |  |  |  |  |  |  | baseline start 2024-06-17 → 2024-06-24 |
| 1739 | **QT Non-Functional Test Scenarios and Test Cases** | 2024-06-27 → 2024-09-20 (+85d) | 2024-09-19 → 2024-12-13 (+85d) |  |  | 0d → 775d |  | baseline start 2024-07-22 → 2024-09-20; baseline finish 2024-09-19 → 2024-12-13 |

| ID | Task | Start | Finish | Duration | Complete | Total float | Predecessors | Other |
| --- | --- | --- | --- | --- | --- | --- | --- | --- |
| 1740 | Draft Test Scenarios and Test Case list - Batch 2 | 2024-06-27 → 2024-09-20 (+85d) | 2024-08-02 → 2024-10-28 (+87d) |  |  | -42d → 775d |  | constraint must finish on 2024-08-02 → none; baseline start 2024-07-22 → 2024-09-20; baseline finish 2024-08-02 → 2024-10-28 |
| 1741 | Issue Batch 2 for Consultation | 2024-08-05 → 2024-10-29 (+85d) | 2024-08-16 → 2024-11-11 (+87d) |  |  | 80d → 775d |  | baseline start 2024-08-05 → 2024-10-29; baseline finish 2024-08-16 → 2024-11-11 |
| 1742 | Update Batch 2 Post Consultation | 2024-08-19 → 2024-11-12 (+85d) | 2024-08-30 → 2024-11-25 (+87d) |  |  | 80d → 775d |  | baseline start 2024-08-19 → 2024-11-12; baseline finish 2024-08-30 → 2024-11-25 |
| 1743 | QWG Endorsement of Batch 2 | 2024-09-10 → 2024-12-04 (+85d) | 2024-09-10 → 2024-12-04 (+85d) |  |  | 80d → 775d |  | baseline start 2024-09-10 → 2024-12-04; baseline finish 2024-09-10 → 2024-12-04 |
| 1744 | QAG Approval of QT Non-Functional Test Scenarios and Test Cases Batch 2 | 2024-09-19 → 2024-12-13 (+85d) | 2024-09-19 → 2024-12-13 (+85d) |  |  | 80d → 775d |  | baseline start 2024-09-19 → 2024-12-13; baseline finish 2024-09-19 → 2024-12-13 |
| 1745 | **QT Operational Test Scenarios and Test Cases** | 2024-05-30 → 2024-09-10 (+103d) | 2024-10-17 → 2025-01-01 (+76d) | 101d → 82d |  | 0d → 762d |  | baseline start 2024-07-22 → 2024-09-10; baseline finish 2024-10-17 → 2025-01-01 |
| 1746 | Draft QT Operational Test Cases - Batch 1 | 2024-05-30 → 2024-09-11 (+104d) | 2024-08-02 → 2024-11-14 (+104d) |  |  | -62d → 762d |  | constraint must finish on 2024-08-02 → none; baseline start 2024-07-22 → 2024-09-11; baseline finish 2024-08-02 → 2024-11-14 |
| 1747 | Issue Batch 1 for Consultation | 2024-08-05 → 2024-11-15 (+102d) | 2024-08-16 → 2024-11-28 (+104d) |  |  | 80d → 762d |  | baseline start 2024-08-05 → 2024-11-15; baseline finish 2024-08-16 → 2024-11-28 |
| 1748 | Update Batch 1 Post Consultation | 2024-08-19 → 2024-11-29 (+102d) | 2024-08-30 → 2024-12-12 (+104d) |  |  | 80d → 762d |  | baseline start 2024-08-19 → 2024-11-29; baseline finish 2024-08-30 → 2024-12-12 |
| 1749 | QWG Endorsement of Batch 1 | 2024-09-10 → 2024-12-23 (+104d) | 2024-09-10 → 2024-12-23 (+104d) |  |  | 80d → 762d |  | baseline start 2024-09-10 → 2024-12-23; baseline finish 2024-09-10 → 2024-12-23 |
| 1750 | QAG Approval of QT Operational Test Scenarios and Test Cases Batch 1 | 2024-09-19 → 2025-01-01 (+104d) | 2024-09-19 → 2025-01-01 (+104d) |  |  | 80d → 762d |  | baseline start 2024-09-19 → 2025-01-01; baseline finish 2024-09-19 → 2025-01-01 |
| 1751 | Draft QT Operational Test Cases - Batch 2 | 2024-07-22 → 2024-09-10 (+50d) | 2024-08-02 → 2024-09-23 (+52d) |  |  | 80d → 800d |  | baseline start 2024-07-22 → 2024-09-10; baseline finish 2024-08-02 → 2024-09-23 |
| 1752 | Issue Batch 2 for Consultation | 2024-08-05 → 2024-09-24 (+50d) | 2024-08-16 → 2024-10-07 (+52d) |  |  | 80d → 800d |  | baseline start 2024-08-05 → 2024-09-24; baseline finish 2024-08-16 → 2024-10-07 |
| 1753 | Update Batch 2 Post Consultation | 2024-08-19 → 2024-10-08 (+50d) | 2024-08-30 → 2024-10-21 (+52d) |  |  | 80d → 800d |  | baseline start 2024-08-19 → 2024-10-08; baseline finish 2024-08-30 → 2024-10-21 |
| 1754 | QWG Endorsement of Batch 2 | 2024-09-10 → 2024-10-30 (+50d) | 2024-09-10 → 2024-10-30 (+50d) |  |  | 80d → 800d |  | baseline start 2024-09-10 → 2024-10-30; baseline finish 2024-09-10 → 2024-10-30 |
| 1755 | QAG Approval of QT Operational Test Scenarios and Test Cases Batch 2 | 2024-09-19 → 2024-11-08 (+50d) | 2024-09-19 → 2024-11-08 (+50d) |  |  | 80d → 800d |  | baseline start 2024-09-19 → 2024-11-08; baseline finish 2024-09-19 → 2024-11-08 |
| 1756 | **Qualification Testing Framework (Test Stubs and Supporting UI)** |  | 2025-07-31 → 2025-12-26 (+148d) | 394d → 500d | 47% → 50% | 476d → 519d |  | baseline finish 2025-07-31 → 2025-12-26 |
| 1759 | **Agile DBT of Qualification Testing Framework** |  | 2024-08-16 A |  | 96% → 100% | 725d → none |  |  |
| 1765 | **Design, Build, Test** |  | 2024-08-16 A |  | 95% → 100% | 725d → none |  |  |
| 1767 | Tooling (Trigger Files / Template Generators) |  | 2024-08-16 A |  | 83% → 100% | 725d → none |  |  |
| 1772 | QTF Test Cases DBT Refinement, Execution and Results Validation, Defect Management, Error Handling | 2024-05-02 → 2024-07-03 (+62d) | 2024-10-31 → 2025-01-01 (+62d) |  |  | 50d → 762d | 1738FF, 1744FF, 1750FF, 1755FF, QAG Approval of QT Operational Test Scenarios and Test Cases Batch 3FF+10d → 1738FF, 1744FF, 1750FF, 1755FF | baseline start 2024-07-15 → 2024-07-03; baseline finish 2024-10-31 → 2025-01-01 |
| 1773 | **Environments** |  | 2024-11-20 → 2025-01-21 (+62d) | 158d → 202d | 49% → 54% | 657d → 762d |  | baseline finish 2024-11-20 → 2025-01-21 |
| 1778 | **MHHSP ADO Instance** |  |  |  |  | 67d → 216d |  | baseline start 2024-07-22 → 2024-07-23 |
| 1779 | MHHSP Instance Setup for QTF Production |  |  |  |  | 67d → 216d |  | baseline start 2024-07-22 → 2024-07-23 |
| 1790 | **QTF Deployment into Production** | 2024-11-01 → 2025-01-02 (+62d) | 2024-11-20 → 2025-01-21 (+62d) |  |  | 50d → 762d |  | baseline start 2024-11-01 → 2025-01-02; baseline finish 2024-11-20 → 2025-01-21 |
| 1791 | App Deployment | 2024-11-01 → 2025-01-02 (+62d) | 2024-11-01 → 2025-01-02 (+62d) |  |  | 50d → 762d |  | baseline start 2024-11-01 → 2025-01-02; baseline finish 2024-11-01 → 2025-01-02 |
| 1792 | Smoke Test | 2024-11-01 → 2025-01-02 (+62d) | 2024-11-04 → 2025-01-03 (+60d) |  |  | 50d → 762d |  | baseline start 2024-11-01 → 2025-01-02; baseline finish 2024-11-04 → 2025-01-03 |
| 1793 | PEN Test | 2024-11-05 → 2025-01-06 (+62d) | 2024-11-06 → 2025-01-07 (+62d) |  |  | 50d → 762d |  | baseline start 2024-11-05 → 2025-01-06; baseline finish 2024-11-06 → 2025-01-07 |
| 1794 | Regression Test | 2024-11-07 → 2025-01-08 (+62d) | 2024-11-20 → 2025-01-21 (+62d) |  |  | 50d → 762d |  | was named Regresssion Test; baseline start 2024-11-07 → 2025-01-08; baseline finish 2024-11-20 → 2025-01-21 |
| 1795 | **DIP Onboarding (UIT)** | 2024-08-05 A |  |  | 0% → 46% | 91d → 847d |  |  |
| 1796 | DIP available for Onboarding | 2024-08-05 A | 2024-08-05 A |  | 0% → 100% | 91d → none |  |  |
| 1797 | Qualification Testing for Non-SIT S&A Participants' environments) Ready to start DIP onboarding (incl. certificates and security compliance) | 2024-08-06 A | 2024-08-26 A |  | 0% → 100% | 91d → none |  |  |
| 1798 | Non-SIT S&A QTF Environments Connection Confirmed to UIT Environment | 2024-08-27 A | 2024-08-27 A |  | 0% → 100% | 91d → none |  |  |
| 1805 | **Test Data (MPANs, DIP Messages, Settlement, Consumption, Reference)** |  | 2025-07-31 → 2025-12-26 (+148d) | 299d → 405d | 14% → 15% | 476d → 519d |  | baseline finish 2025-07-31 → 2025-12-26 |
| 1807 | Test Data Templates and generator tools ready |  | 2024-08-02 A |  | 93% → 100% | 735d → none |  |  |
| 1814 | **Wave 1 Test Data** | 2024-11-29 → 2025-05-12 (+164d) | 2025-01-31 → 2025-07-14 (+164d) |  |  | 1d → 35d |  | baseline start 2024-11-29 → 2025-05-12; baseline finish 2025-01-31 → 2025-07-14 |
| 1815 | Test Data Request + Templates Completed | 2024-11-29 → 2025-05-12 (+164d) | 2024-12-20 → 2025-06-02 (+164d) |  |  | 1d → 35d |  | baseline start 2024-11-29 → 2025-05-12; baseline finish 2024-12-20 → 2025-06-02 |
| 1816 | Test Data Generated | 2024-12-23 → 2025-06-03 (+162d) | 2025-01-03 → 2025-06-16 (+164d) |  |  | 1d → 35d |  | baseline start 2024-12-23 → 2025-06-03; baseline finish 2025-01-03 → 2025-06-16 |
| 1817 | Test Data Loaded into QP Systems | 2025-01-06 → 2025-06-17 (+162d) | 2025-01-31 → 2025-07-14 (+164d) |  |  | 1d → 35d |  | baseline start 2025-01-06 → 2025-06-17; baseline finish 2025-01-31 → 2025-07-14 |
| 1818 | Test Data Loaded into QTF + ADO | 2025-01-06 → 2025-06-17 (+162d) | 2025-01-31 → 2025-07-11 (+161d) | 20d → 19d |  | 1d → 36d |  | baseline start 2025-01-06 → 2025-06-17; baseline finish 2025-01-31 → 2025-07-11 |
| 1819 | **Wave 2 Test Data** | 2025-01-31 → 2025-07-07 (+157d) | 2025-03-31 → 2025-09-02 (+155d) |  |  | 1d → 39d |  | baseline start 2025-01-31 → 2025-07-07; baseline finish 2025-03-31 → 2025-09-02 |
| 1820 | Test Data Request + Templates Completed | 2025-01-31 → 2025-07-07 (+157d) | 2025-02-21 → 2025-07-28 (+157d) |  |  | 1d → 39d |  | baseline start 2025-01-31 → 2025-07-07; baseline finish 2025-02-21 → 2025-07-28 |
| 1821 | Test Data Generated | 2025-02-24 → 2025-07-29 (+155d) | 2025-03-07 → 2025-08-11 (+157d) |  |  | 1d → 39d |  | baseline start 2025-02-24 → 2025-07-29; baseline finish 2025-03-07 → 2025-08-11 |
| 1822 | Test Data Loaded into QP Systems | 2025-03-10 → 2025-08-12 (+155d) | 2025-03-31 → 2025-09-02 (+155d) |  |  | 1d → 39d |  | baseline start 2025-03-10 → 2025-08-12; baseline finish 2025-03-31 → 2025-09-02 |
| 1823 | Test Data Loaded into QTF + ADO | 2025-03-10 → 2025-08-12 (+155d) | 2025-03-31 → 2025-09-02 (+155d) |  |  | 1d → 39d |  | baseline start 2025-03-10 → 2025-08-12; baseline finish 2025-03-31 → 2025-09-02 |
| 1824 | **Wave 3 Test Data** | 2025-03-31 → 2025-09-08 (+161d) | 2025-05-30 → 2025-11-07 (+161d) |  |  | 2d → 29d |  | baseline start 2025-03-31 → 2025-09-08; baseline finish 2025-05-30 → 2025-11-07 |
| 1825 | Test Data Request + Templates Completed | 2025-03-31 → 2025-09-08 (+161d) | 2025-04-18 → 2025-09-26 (+161d) |  |  | 2d → 29d |  | baseline start 2025-03-31 → 2025-09-08; baseline finish 2025-04-18 → 2025-09-26 |
| 1826 | Test Data Generated | 2025-04-21 → 2025-09-29 (+161d) | 2025-05-02 → 2025-10-10 (+161d) |  |  | 2d → 29d |  | baseline start 2025-04-21 → 2025-09-29; baseline finish 2025-05-02 → 2025-10-10 |
| 1827 | Test Data Loaded into QP Systems | 2025-05-05 → 2025-10-13 (+161d) | 2025-05-30 → 2025-11-07 (+161d) |  |  | 2d → 29d |  | baseline start 2025-05-05 → 2025-10-13; baseline finish 2025-05-30 → 2025-11-07 |
| 1828 | Test Data Loaded into QTF + ADO | 2025-05-05 → 2025-10-13 (+161d) | 2025-05-30 → 2025-11-07 (+161d) |  |  | 2d → 29d |  | baseline start 2025-05-05 → 2025-10-13; baseline finish 2025-05-30 → 2025-11-07 |
| 1829 | **Wave 4 Test Data** | 2025-05-30 → 2025-10-27 (+150d) | 2025-07-31 → 2025-12-26 (+148d) |  |  | 2d → 49d |  | baseline start 2025-05-30 → 2025-10-27; baseline finish 2025-07-31 → 2025-12-26 |
| 1830 | Test Data Request + Templates Completed | 2025-05-30 → 2025-10-27 (+150d) | 2025-06-19 → 2025-11-14 (+148d) |  |  | 2d → 49d |  | baseline start 2025-05-30 → 2025-10-27; baseline finish 2025-06-19 → 2025-11-14 |
| 1831 | Test Data Generated | 2025-06-20 → 2025-11-17 (+150d) | 2025-07-03 → 2025-11-28 (+148d) |  |  | 2d → 49d |  | baseline start 2025-06-20 → 2025-11-17; baseline finish 2025-07-03 → 2025-11-28 |
| 1832 | Test Data Loaded into QP Systems | 2025-07-04 → 2025-12-01 (+150d) | 2025-07-31 → 2025-12-26 (+148d) |  |  | 2d → 49d |  | baseline start 2025-07-04 → 2025-12-01; baseline finish 2025-07-31 → 2025-12-26 |
| 1833 | Test Data Loaded into QTF + ADO | 2025-07-04 → 2025-12-01 (+150d) | 2025-07-31 → 2025-12-26 (+148d) |  |  | 2d → 49d |  | baseline start 2025-07-04 → 2025-12-01; baseline finish 2025-07-31 → 2025-12-26 |
| 1838 | Qualification Testing Wave Readiness Confirmed | 2025-01-23 → 2024-12-27 (-27d) | 2025-01-23 → 2024-12-27 (-27d) |  |  | 8d → 176d | Qualification Testing Framework (Test Stubs and Supporting UI) CompleteFS+4d, 1837 → 1837 | baseline start 2025-01-23 → 2024-12-27; baseline finish 2025-01-23 → 2024-12-27 |
| 1847 | **Qualification Wave 1** | 2024-10-14 → 2025-03-24 (+161d) | 2025-08-29 → 2026-04-10 (+224d) | 229d → 275d |  | 1d → 5d |  | baseline start 2024-10-14 → 2025-03-24; baseline finish 2025-08-29 → 2026-04-10 |
| 1848 | **Qualification Wave 1 QAD Prep** | 2024-10-14 → 2025-03-24 (+161d) | 2025-01-31 → 2025-07-11 (+161d) | 79d → 80d |  | 1d → 36d |  | baseline start 2024-10-14 → 2025-03-24; baseline finish 2025-01-31 → 2025-07-11 |
| 1849 | Initial QAD Submission window opens | 2024-10-14 → 2025-03-24 (+161d) | 2024-10-14 → 2025-03-24 (+161d) |  |  | 1d → 36d | 1846, 1671FS+6d → 1846, 1671FS+121d | baseline start 2024-10-14 → 2025-03-24; baseline finish 2024-10-14 → 2025-03-24 |
| 1850 | Qualification Wave 1 Participants Submit Initial QAD | 2024-10-15 → 2025-03-24 (+160d) | 2024-12-20 → 2025-05-30 (+161d) | 49d → 50d |  | 1d → 36d | 1849 → 1849FS-1d | baseline start 2024-10-14 → 2025-03-24; baseline finish 2024-12-20 → 2025-05-30 |
| 1851 | Qualification Wave 1 Participants have submitted their initial QAD | 2024-12-20 → 2025-06-02 (+164d) | 2024-12-20 → 2025-06-02 (+164d) |  |  | 1d → 36d | 1850 → 1850FS+1d | baseline start 2024-12-20 → 2025-06-02; baseline finish 2024-12-20 → 2025-06-02 |
| 1852 | Code Bodies review of Wave 1 Participants Initial QAD | 2024-12-23 → 2025-06-02 (+161d) | 2025-01-31 → 2025-07-11 (+161d) |  |  | 1d → 36d | 1850, 1851 → 1850FS-1d, 1851FS-1d | baseline start 2024-12-23 → 2025-06-02; baseline finish 2025-01-31 → 2025-07-11 |
| 1853 | Completion of Code Bodies review of Initial QAD | 2025-01-31 → 2025-07-11 (+161d) | 2025-01-31 → 2025-07-11 (+161d) |  |  | 1d → 36d |  | baseline start 2025-01-31 → 2025-07-11; baseline finish 2025-01-31 → 2025-07-11 |
| 1854 | **Qualification Wave 1 Test Prep** | 2024-11-01 → 2025-04-14 (+164d) | 2025-01-24 → 2025-07-04 (+161d) |  |  | 7d → 41d |  | baseline start 2024-11-01 → 2025-04-14; baseline finish 2025-01-24 → 2025-07-04 |
| 1855 | Confirmation from Qualification Wave 1 Participants that DIP onboarding has commenced | 2024-11-01 → 2025-04-14 (+164d) | 2024-11-01 → 2025-04-14 (+164d) |  |  | 26d → 61d |  | constraint finish no earlier than 2024-11-01 → start no earlier than 2025-04-14; baseline start 2024-11-01 → 2025-04-14; baseline finish 2024-11-01 → 2025-04-14 |
| 1856 | Qualification Wave 1 Participants DIP Onboarding Window | 2024-11-04 → 2025-04-14 (+161d) | 2024-12-20 → 2025-05-30 (+161d) |  |  | 26d → 61d |  | baseline start 2024-11-04 → 2025-04-14; baseline finish 2024-12-20 → 2025-05-30 |
| 1857 | Confirmation from Qualification Wave 1 Participants that DIP onboarding has completed | 2024-12-20 → 2025-05-30 (+161d) | 2024-12-20 → 2025-05-30 (+161d) |  |  | 26d → 61d |  | baseline start 2024-12-20 → 2025-05-30; baseline finish 2024-12-20 → 2025-05-30 |
| 1858 | Qualification Wave 1 Participants' to provide status of PIT completion and submit QT Test Plan | 2024-11-29 → 2025-05-12 (+164d) | 2024-11-29 → 2025-05-12 (+164d) |  |  | 1d → 35d |  | constraint start no earlier than 2024-11-29 → start no earlier than 2025-05-12; baseline start 2024-11-29 → 2025-05-12; baseline finish 2024-11-29 → 2025-05-12 |
| 1859 | Review of Participants' PIT Status and QT Test Plan | 2024-12-02 → 2025-05-12 (+161d) | 2024-12-20 → 2025-05-30 (+161d) |  |  | 26d → 61d | 1858FS+1d → 1858 | baseline start 2024-12-02 → 2025-05-12; baseline finish 2024-12-20 → 2025-05-30 |
| 1860 | Qualification Test Plans for Wave 1 Participants approved | 2024-12-20 → 2025-05-30 (+161d) | 2024-12-20 → 2025-05-30 (+161d) |  |  | 26d → 61d |  | baseline start 2024-12-20 → 2025-05-30; baseline finish 2024-12-20 → 2025-05-30 |

| ID | Task | Start | Finish | Duration | Total float | Predecessors | Other |
| --- | --- | --- | --- | --- | --- | --- | --- |
| 1861 | Qualification Wave 1 Participants have submitted PIT Test Completion Report and evidence for QT Entry | 2024-12-20 → 2025-06-02 (+164d) | 2024-12-20 → 2025-06-02 (+164d) |  | 1d → 36d |  | constraint finish no earlier than 2024-12-20 → start no earlier than 2025-06-02; baseline start 2024-12-20 → 2025-06-02; baseline finish 2024-12-20 → 2025-06-02 |
| 1862 | Review of Participants PIT Test Completion Report | 2024-12-23 → 2025-06-02 (+161d) | 2025-01-24 → 2025-07-04 (+161d) |  | 1d → 36d |  | baseline start 2024-12-23 → 2025-06-02; baseline finish 2025-01-24 → 2025-07-04 |
| 1863 | Onboarding to QTF & ADO | 2024-12-23 → 2025-06-02 (+161d) | 2025-01-24 → 2025-07-04 (+161d) |  | 7d → 41d |  | baseline start 2024-12-23 → 2025-06-02; baseline finish 2025-01-24 → 2025-07-04 |
| 1864 | **Qualification Wave 1 QT Execution** | 2025-01-27 → 2025-07-07 (+161d) | 2025-06-13 → 2026-01-02 (+203d) | 100d → 130d | 1d → 10d |  | baseline start 2025-01-27 → 2025-07-07; baseline finish 2025-06-13 → 2026-01-02 |
| 1865 | Review Entry Criteria Evidence for each Wave 1 Participant | 2025-01-27 → 2025-07-07 (+161d) | 2025-01-31 → 2025-07-11 (+161d) |  | 1d → 36d |  | baseline start 2025-01-27 → 2025-07-07; baseline finish 2025-01-31 → 2025-07-11 |
| 1866 | Qualification Wave 1 Participant Test Readiness Confirmed | 2025-01-31 → 2025-07-14 (+164d) | 2025-01-31 → 2025-07-14 (+164d) |  | 1d → 35d | 1852, 1853, 1865, 1817, 1818 → 1852, 1853, 1865FF, 1817, 1818 | baseline start 2025-01-31 → 2025-07-14; baseline finish 2025-01-31 → 2025-07-14 |
| 1867 | Qualification Wave 1 QT Execution Start | 2025-02-03 → 2025-08-25 (+203d) | 2025-02-03 → 2025-08-25 (+203d) |  | 1d → 5d | 1866FS+1d, 1838, 1863, 1282 → 1866, 1838, 1863, 1282FS+6d | constraint none → start no earlier than 2025-07-14; baseline start 2025-02-03 → 2025-08-25; baseline finish 2025-02-03 → 2025-08-25 |
| 1868 | Qualification Wave 1 QT Execution Window | 2025-02-03 → 2025-08-25 (+203d) | 2025-06-13 → 2026-01-02 (+203d) |  | 6d → 10d |  | baseline start 2025-02-03 → 2025-08-25; baseline finish 2025-06-13 → 2026-01-02 |
| 1869 | Qualification Wave 1 QT Projected Execution End | 2025-06-13 → 2026-01-02 (+203d) | 2025-06-13 → 2026-01-02 (+203d) |  | 6d → 10d |  | baseline start 2025-06-13 → 2026-01-02; baseline finish 2025-06-13 → 2026-01-02 |
| 1870 | **Qualification Wave 1 Exit** | 2025-02-03 → 2025-08-25 (+203d) | 2025-08-29 → 2026-04-10 (+224d) | 149d → 165d | 1d → 5d |  | baseline start 2025-02-03 → 2025-08-25; baseline finish 2025-08-29 → 2026-04-10 |
| 1871 | Final QAD Submission window opens | 2025-02-03 → 2025-08-25 (+203d) | 2025-02-03 → 2025-08-25 (+203d) |  | 1d → 5d |  | baseline start 2025-02-03 → 2025-08-25; baseline finish 2025-02-03 → 2025-08-25 |
| 1872 | Qualification Wave 1 Participants submit their Final QAD | 2025-02-04 → 2025-08-25 (+202d) | 2025-06-20 → 2026-01-09 (+203d) | 99d → 100d | 1d → 5d | 1871 → 1871FS-1d | baseline start 2025-02-03 → 2025-08-25; baseline finish 2025-06-20 → 2026-01-09 |
| 1873 | Qualification Wave 1 Participants have submitted their final QAD | 2025-06-20 → 2026-01-09 (+203d) | 2025-06-20 → 2026-01-09 (+203d) |  | 1d → 5d |  | baseline start 2025-06-20 → 2026-01-09; baseline finish 2025-06-20 → 2026-01-09 |
| 1874 | Completion of Code Bodies review of Final QAD | 2025-06-23 → 2026-01-12 (+203d) | 2025-07-18 → 2026-02-27 (+224d) | 20d → 35d | 1d → 5d |  | baseline start 2025-06-23 → 2026-01-12; baseline finish 2025-07-18 → 2026-02-27 |
| 1875 | QAD Sign Off deadline | 2025-07-31 → 2026-03-13 (+225d) | 2025-07-31 → 2026-03-13 (+225d) |  | 1d → 5d | 1874FS+8d → 1874FS+9d | baseline start 2025-07-31 → 2026-03-13; baseline finish 2025-07-31 → 2026-03-13 |
| 1876 | Qualification Wave 1 Participants Qualification approved by BSC PAB and REC Manager | 2025-08-29 → 2026-04-10 (+224d) | 2025-08-29 → 2026-04-10 (+224d) |  | 1d → 5d | 1875FS+21d → 1875FS+20d | baseline start 2025-08-29 → 2026-04-10; baseline finish 2025-08-29 → 2026-04-10 |
| 1877 | **Qualification Wave 2** | 2024-11-18 → 2025-06-09 (+203d) | 2025-10-31 → 2026-05-27 (+208d) | 249d → 253d | 1d → 6d |  | baseline start 2024-11-18 → 2025-06-09; baseline finish 2025-10-31 → 2026-05-27 |
| 1878 | **Qualification Wave 2 QAD Prep** | 2024-11-18 → 2025-06-09 (+203d) | 2025-03-31 → 2025-10-17 (+200d) |  | 1d → 6d |  | baseline start 2024-11-18 → 2025-06-09; baseline finish 2025-03-31 → 2025-10-17 |
| 1879 | Initial QAD Submission window opens | 2024-11-18 → 2025-06-09 (+203d) | 2024-11-18 → 2025-06-09 (+203d) |  | 1d → 6d | 1672FS+6d → 1672FS+151d | baseline start 2024-11-18 → 2025-06-09; baseline finish 2024-11-18 → 2025-06-09 |
| 1880 | Qualification Wave 2 Participants Submit Initial QAD | 2024-11-19 → 2025-06-09 (+202d) | 2025-02-21 → 2025-09-12 (+203d) | 69d → 70d | 1d → 6d | 1879 → 1879FS-1d | baseline start 2024-11-18 → 2025-06-09; baseline finish 2025-02-21 → 2025-09-12 |
| 1881 | Qualification Wave 2 Participants have submitted their initial QAD | 2025-02-21 → 2025-09-12 (+203d) | 2025-02-21 → 2025-09-12 (+203d) |  | 1d → 6d |  | baseline start 2025-02-21 → 2025-09-12; baseline finish 2025-02-21 → 2025-09-12 |
| 1882 | Code Bodies review of Wave 2 Participants' Initial QAD | 2025-02-24 → 2025-09-15 (+203d) | 2025-03-31 → 2025-10-17 (+200d) | 26d → 25d | 1d → 6d |  | baseline start 2025-02-24 → 2025-09-15; baseline finish 2025-03-31 → 2025-10-17 |
| 1883 | Completion of Code Bodies review of Initial QAD | 2025-03-31 → 2025-10-17 (+200d) | 2025-03-31 → 2025-10-17 (+200d) |  | 1d → 6d |  | baseline start 2025-03-31 → 2025-10-17; baseline finish 2025-03-31 → 2025-10-17 |
| 1884 | **Qualification Wave 2 Test Prep** | 2025-01-06 → 2025-06-09 (+154d) | 2025-03-28 → 2025-08-29 (+154d) |  | 17d → 42d |  | baseline start 2025-01-06 → 2025-06-09; baseline finish 2025-03-28 → 2025-08-29 |
| 1885 | Confirmation from Qualification Wave 2 Participants that DIP Onboarding has commenced | 2025-01-06 → 2025-06-09 (+154d) | 2025-01-06 → 2025-06-09 (+154d) |  | 17d → 61d |  | constraint start no earlier than 2025-01-06 → start no earlier than 2025-06-09; baseline start 2025-01-06 → 2025-06-09; baseline finish 2025-01-06 → 2025-06-09 |
| 1886 | Qualification Wave 2 Participants DIP Onboarding Window | 2025-01-06 → 2025-06-09 (+154d) | 2025-02-28 → 2025-07-25 (+147d) | 40d → 35d | 17d → 61d |  | baseline start 2025-01-06 → 2025-06-09; baseline finish 2025-02-28 → 2025-07-25 |
| 1887 | Confirmation from Qualificiation Wave 2 Participants that DIP onboarding has completed | 2025-02-28 → 2025-07-25 (+147d) | 2025-02-28 → 2025-07-25 (+147d) |  | 17d → 61d |  | baseline start 2025-02-28 → 2025-07-25; baseline finish 2025-02-28 → 2025-07-25 |
| 1888 | Qualification Wave 2 Participants' to provide status of PIT completion and submit QT Test Plan | 2025-01-31 → 2025-07-07 (+157d) | 2025-01-31 → 2025-07-07 (+157d) |  | 1d → 39d |  | constraint start no earlier than 2025-01-31 → start no earlier than 2025-07-07; baseline start 2025-01-31 → 2025-07-07; baseline finish 2025-01-31 → 2025-07-07 |
| 1889 | Review of Participants' PIT Status and QT Test Plan | 2025-02-03 → 2025-07-07 (+154d) | 2025-02-21 → 2025-07-25 (+154d) |  | 590d → 61d | 1888FS+1d → 1888 | constraint none → start no earlier than 2025-07-07; baseline start 2025-02-03 → 2025-07-07; baseline finish 2025-02-21 → 2025-07-25 |
| 1890 | Qualification Test Plans for Wave 2 Participants approved | 2025-02-21 → 2025-07-25 (+154d) | 2025-02-21 → 2025-07-25 (+154d) |  | 590d → 61d |  | constraint none → start no earlier than 2025-07-25; baseline start 2025-02-21 → 2025-07-25; baseline finish 2025-02-21 → 2025-07-25 |
| 1891 | Qualification Wave 2 Participants have submitted PIT Test Completion Report and evidence for QT entry | 2025-02-21 → 2025-07-28 (+157d) | 2025-02-21 → 2025-07-28 (+157d) |  | 3d → 36d |  | constraint finish no earlier than 2025-02-21 → start no earlier than 2025-07-28; baseline start 2025-02-21 → 2025-07-28; baseline finish 2025-02-21 → 2025-07-28 |
| 1892 | Review of Participants' PIT Test Completion Report | 2025-02-24 → 2025-07-28 (+154d) | 2025-03-28 → 2025-08-29 (+154d) |  | 3d → 36d |  | baseline start 2025-02-24 → 2025-07-28; baseline finish 2025-03-28 → 2025-08-29 |
| 1893 | Onboarding to QTF & ADO | 2025-02-24 → 2025-07-28 (+154d) | 2025-03-28 → 2025-08-29 (+154d) |  | 3d → 42d |  | baseline start 2025-02-24 → 2025-07-28; baseline finish 2025-03-28 → 2025-08-29 |
| 1894 | **Qualification Wave 2 QT Execution** | 2025-03-25 → 2025-10-13 (+202d) | 2025-08-08 → 2026-02-27 (+203d) | 99d → 100d | 1d → 6d |  | baseline start 2025-03-25 → 2025-10-13; baseline finish 2025-08-08 → 2026-02-27 |
| 1895 | Review Entry Criteria Evidence for each Wave 2 Participant | 2025-03-25 → 2025-10-13 (+202d) | 2025-03-31 → 2025-10-17 (+200d) |  | 1d → 6d | 1883FF, 1887 → 1883FF, 1887, 1890, 1892 | baseline start 2025-03-25 → 2025-10-13; baseline finish 2025-03-31 → 2025-10-17 |
| 1896 | Qualification Wave 2 Participant Test Readiness Confirmed | 2025-03-31 → 2025-10-17 (+200d) | 2025-03-31 → 2025-10-17 (+200d) |  | 1d → 6d |  | baseline start 2025-03-31 → 2025-10-17; baseline finish 2025-03-31 → 2025-10-17 |
| 1897 | Qualification Wave 2 Execution Start | 2025-04-01 → 2025-10-20 (+202d) | 2025-04-01 → 2025-10-20 (+202d) |  | 1d → 6d |  | baseline start 2025-04-01 → 2025-10-20; baseline finish 2025-04-01 → 2025-10-20 |
| 1898 | Qualification Wave 2 QT Execution Window | 2025-04-02 → 2025-10-20 (+201d) | 2025-08-08 → 2026-02-27 (+203d) | 93d → 95d | 6d → 11d | 1897 → 1897SS-1d | baseline start 2025-04-01 → 2025-10-20; baseline finish 2025-08-08 → 2026-02-27 |
| 1899 | Qualfication Wave 2 QT Execution End | 2025-08-08 → 2026-02-27 (+203d) | 2025-08-08 → 2026-02-27 (+203d) |  | 6d → 11d |  | baseline start 2025-08-08 → 2026-02-27; baseline finish 2025-08-08 → 2026-02-27 |
| 1900 | **Qualification Wave 2 Exit** | 2025-04-01 → 2025-10-20 (+202d) | 2025-10-31 → 2026-05-27 (+208d) | 153d → 158d | 1d → 6d |  | baseline start 2025-04-01 → 2025-10-20; baseline finish 2025-10-31 → 2026-05-27 |
| 1901 | Final QAD Submission window opens | 2025-04-01 → 2025-10-20 (+202d) | 2025-04-01 → 2025-10-20 (+202d) |  | 1d → 6d |  | baseline start 2025-04-01 → 2025-10-20; baseline finish 2025-04-01 → 2025-10-20 |
| 1902 | Qualification Wave 2 Participants submit their Final QAD | 2025-04-02 → 2025-10-20 (+201d) | 2025-08-15 → 2026-03-06 (+203d) | 98d → 100d | 1d → 6d | 1901 → 1901FS-1d | baseline start 2025-04-01 → 2025-10-20; baseline finish 2025-08-15 → 2026-03-06 |
| 1903 | Qualification Wave 2 Participants have submitted their final QAD | 2025-08-15 → 2026-03-06 (+203d) | 2025-08-15 → 2026-03-06 (+203d) |  | 1d → 6d |  | baseline start 2025-08-15 → 2026-03-06; baseline finish 2025-08-15 → 2026-03-06 |
| 1904 | Completion of Code Bodies review of Final QAD | 2025-08-18 → 2026-03-09 (+203d) | 2025-09-23 → 2026-04-13 (+202d) | 27d → 26d | 1d → 6d |  | baseline start 2025-08-18 → 2026-03-09; baseline finish 2025-09-23 → 2026-04-13 |
| 1905 | QAD Sign Off deadline | 2025-09-30 → 2026-04-20 (+202d) | 2025-09-30 → 2026-04-20 (+202d) |  | 1d → 6d |  | baseline start 2025-09-30 → 2026-04-20; baseline finish 2025-09-30 → 2026-04-20 |
| 1906 | Qualification Wave 2 Participants Qualification approved by BSC PAB and REC Manager | 2025-10-31 → 2026-05-27 (+208d) | 2025-10-31 → 2026-05-27 (+208d) |  | 1d → 6d | 1905FS+23d → 1905FS+27d | baseline start 2025-10-31 → 2026-05-27; baseline finish 2025-10-31 → 2026-05-27 |
| 1907 | **Qualification Wave 3** | 2025-01-20 → 2025-08-04 (+196d) | 2025-12-19 → 2026-07-23 (+216d) | 239d → 254d | 2d → 5d |  | baseline start 2025-01-20 → 2025-08-04; baseline finish 2025-12-19 → 2026-07-23 |
| 1908 | **Qualification Wave 3 QAD Prep** | 2025-01-20 → 2025-08-11 (+203d) | 2025-05-30 → 2025-12-19 (+203d) | 94d → 95d | 2d → 0d |  | baseline start 2025-01-20 → 2025-08-11; baseline finish 2025-05-30 → 2025-12-19 |
| 1909 | Initial QAD Submission window opens | 2025-01-20 → 2025-08-11 (+203d) | 2025-01-20 → 2025-08-11 (+203d) |  | 2d → 0d | 1673FS+6d → 1673FS+151d | baseline start 2025-01-20 → 2025-08-11; baseline finish 2025-01-20 → 2025-08-11 |
| 1910 | Qualification Wave 3 Participants Submit Initial QAD | 2025-01-21 → 2025-08-11 (+202d) | 2025-04-18 → 2025-11-07 (+203d) | 64d → 65d | 2d → 0d | 1909 → 1909FS-1d | baseline start 2025-01-20 → 2025-08-11; baseline finish 2025-04-18 → 2025-11-07 |
| 1911 | Qualification Wave 3 Participants have submitted their initial QAD | 2025-04-18 → 2025-11-07 (+203d) | 2025-04-18 → 2025-11-07 (+203d) |  | 2d → 0d |  | baseline start 2025-04-18 → 2025-11-07; baseline finish 2025-04-18 → 2025-11-07 |
| 1912 | Code Bodies review of Wave 3 Participants' Initial QAD | 2025-04-21 → 2025-11-10 (+203d) | 2025-05-30 → 2025-12-19 (+203d) |  | 2d → 0d |  | baseline start 2025-04-21 → 2025-11-10; baseline finish 2025-05-30 → 2025-12-19 |
| 1913 | Completion of Code Bodies review of Initial QAD | 2025-05-30 → 2025-12-19 (+203d) | 2025-05-30 → 2025-12-19 (+203d) |  | 2d → 0d |  | baseline start 2025-05-30 → 2025-12-19; baseline finish 2025-05-30 → 2025-12-19 |
| 1914 | **Qualification Wave 3 Test Prep** | 2025-03-03 → 2025-08-04 (+154d) | 2025-05-30 → 2025-10-31 (+154d) |  | 22d → 54d |  | baseline start 2025-03-03 → 2025-08-04; baseline finish 2025-05-30 → 2025-10-31 |
| 1915 | Confirmation from Qualification Wave 3 Participants that DIP Onboarding has commenced | 2025-03-03 → 2025-08-04 (+154d) | 2025-03-03 → 2025-08-04 (+154d) |  | 24d → 60d |  | was named Qualification Wave 3 Participants' have started DIP Onboarding; constraint start no earlier than 2025-03-03 → start no earlier than 2025-08-04; baseline start 2025-03-03 → 2025-08-04; baseline finish 2025-03-03 → 2025-08-04 |
| 1916 | Qualification Wave 3 Participants DIP Onboarding window | 2025-03-03 → 2025-08-04 (+154d) | 2025-04-25 → 2025-09-19 (+147d) | 40d → 35d | 24d → 60d |  | constraint none → start no earlier than 2025-08-04; baseline start 2025-03-03 → 2025-08-04; baseline finish 2025-04-25 → 2025-09-19 |
| 1917 | Confirmation from Qualification Wave 3 Participants that DIP onboarding has completed | 2025-04-25 → 2025-09-22 (+150d) | 2025-04-25 → 2025-09-22 (+150d) |  | 24d → 60d |  | constraint none → start no earlier than 2025-09-22; baseline start 2025-04-25 → 2025-09-22; baseline finish 2025-04-25 → 2025-09-22 |
| 1918 | Qualification Wave 3 Participants' to provide status of PIT completion and submit QT Test Plan | 2025-03-31 → 2025-09-08 (+161d) | 2025-03-31 → 2025-09-08 (+161d) |  | 2d → 29d |  | constraint start no earlier than 2025-03-31 → start no earlier than 2025-09-08; baseline start 2025-03-31 → 2025-09-08; baseline finish 2025-03-31 → 2025-09-08 |
| 1919 | Review of Participants' PIT Status and QT Test Plan | 2025-03-31 → 2025-09-08 (+161d) | 2025-04-18 → 2025-09-26 (+161d) |  | 550d → 584d |  | constraint none → start no earlier than 2025-09-08; baseline start 2025-03-31 → 2025-09-08; baseline finish 2025-04-18 → 2025-09-26 |
| 1920 | Qualification Test Plans for Wave 3 Participants approved | 2025-04-18 → 2025-09-26 (+161d) | 2025-04-18 → 2025-09-26 (+161d) |  | 550d → 584d |  | constraint none → start no earlier than 2025-09-26; baseline start 2025-04-18 → 2025-09-26; baseline finish 2025-04-18 → 2025-09-26 |
| 1921 | Qualification Wave 3 Participants have submitted PIT Test Completion Report and evidence for QT Entry | 2025-04-18 → 2025-09-29 (+164d) | 2025-04-18 → 2025-09-29 (+164d) |  | 1d → 30d |  | constraint finish no earlier than 2025-04-18 → start no earlier than 2025-09-29; baseline start 2025-04-18 → 2025-09-29; baseline finish 2025-04-18 → 2025-09-29 |
| 1922 | Review of Participants' PIT Test Completion Report | 2025-04-21 → 2025-09-29 (+161d) | 2025-05-30 → 2025-10-31 (+154d) | 30d → 25d | 1d → 30d |  | constraint none → start no earlier than 2025-09-29; baseline start 2025-04-21 → 2025-09-29; baseline finish 2025-05-30 → 2025-10-31 |
| 1923 | Onboarding to QTF & ADO | 2025-04-21 → 2025-09-29 (+161d) | 2025-05-30 → 2025-10-31 (+154d) | 30d → 25d | 1d → 30d |  | constraint none → finish no earlier than 2025-10-31; baseline start 2025-04-21 → 2025-09-29; baseline finish 2025-05-30 → 2025-10-31 |
| 1924 | **Qualification Wave 3 QT Execution** | 2025-05-28 → 2025-11-03 (+159d) | 2025-10-10 → 2026-03-24 (+165d) | 98d → 102d | 2d → none |  | baseline start 2025-05-26 → 2025-11-03; baseline finish 2025-10-10 → 2026-03-24 |
| 1925 | Review Entry Criteria Evidence for each Wave 3 Participant | 2025-05-28 → 2025-12-15 (+201d) | 2025-05-30 → 2025-12-19 (+203d) | 3d → 5d | 2d → 0d | 1917, 1913FF → 1917, 1913FF, 1923 | constraint none → start no earlier than 2025-11-03; baseline start 2025-05-26 → 2025-12-15; baseline finish 2025-05-30 → 2025-12-19 |
| 1926 | Qualification Wave 3 Participant Test Readiness confirmed | 2025-05-30 → 2025-12-19 (+203d) | 2025-05-30 → 2025-12-19 (+203d) |  | 2d → 0d | 1917, 1925, 1827, 1828 → 1917, 1925FS-1d, 1827, 1828 | baseline start 2025-05-30 → 2025-12-19; baseline finish 2025-05-30 → 2025-12-19 |
| 1927 | Qualification Wave 3 Execution Start | 2025-06-02 → 2026-01-05 (+217d) | 2025-06-02 → 2026-01-05 (+217d) |  | 1d → 0d | 1926, 1923FS+1d → 1926FS+12d, 1923FS+1d | constraint none → start no earlier than 2025-11-03; baseline start 2025-06-02 → 2026-01-05; baseline finish 2025-06-02 → 2026-01-05 |
| 1928 | Qualification Wave 3 QT Execution Window | 2025-06-03 → 2026-01-05 (+216d) | 2025-10-10 → 2026-05-15 (+217d) | 94d → 95d | 6d → 5d | 1925, 1927 → 1925, 1927FS-1d | baseline start 2025-06-02 → 2026-01-05; baseline finish 2025-10-10 → 2026-05-15 |
| 1929 | Qualification Wave 3 Projected Execution End | 2025-10-10 → 2026-05-15 (+217d) | 2025-10-10 → 2026-05-15 (+217d) |  | 6d → 5d |  | baseline start 2025-10-10 → 2026-05-15; baseline finish 2025-10-10 → 2026-05-15 |
| 1930 | **Qualification Wave 3 Exit** | 2025-06-02 → 2026-01-05 (+217d) | 2025-12-19 → 2026-07-23 (+216d) |  | 1d → 0d |  | baseline start 2025-06-02 → 2026-01-05; baseline finish 2025-12-19 → 2026-07-23 |

| ID | Task | Start | Finish | Duration | Complete | Total float | Predecessors | Other |
| --- | --- | --- | --- | --- | --- | --- | --- | --- |
| 1931 | Final QAD Submission window opens | 2025-06-02 → 2026-01-05 (+217d) | 2025-06-02 → 2026-01-05 (+217d) |  |  | 1d → 0d |  | baseline start 2025-06-02 → 2026-01-05; baseline finish 2025-06-02 → 2026-01-05 |
| 1932 | Qualification Wave 3 Participants submit their Final QAD | 2025-06-03 → 2026-01-05 (+216d) | 2025-10-17 → 2026-05-22 (+217d) | 99d → 100d |  | 1d → 0d | 1931 → 1931FS-1d | baseline start 2025-06-02 → 2026-01-05; baseline finish 2025-10-17 → 2026-05-22 |
| 1933 | Qualification Wave 3 Participants have submitted their Final QAD | 2025-10-17 → 2026-05-22 (+217d) | 2025-10-17 → 2026-05-22 (+217d) |  |  | 1d → 0d |  | baseline start 2025-10-17 → 2026-05-22; baseline finish 2025-10-17 → 2026-05-22 |
| 1934 | Completion of Code Bodies review of Final QAD | 2025-10-20 → 2026-05-25 (+217d) | 2025-11-14 → 2026-06-19 (+217d) |  |  | 1d → 0d |  | baseline start 2025-10-20 → 2026-05-25; baseline finish 2025-11-14 → 2026-06-19 |
| 1935 | QAD Sign Off deadline | 2025-11-21 → 2026-06-26 (+217d) | 2025-11-21 → 2026-06-26 (+217d) |  |  | 1d → 0d |  | baseline start 2025-11-21 → 2026-06-26; baseline finish 2025-11-21 → 2026-06-26 |
| 1936 | Qualification Wave 3 Participants Qualification approved by BSC PAB and REC Manager | 2025-12-19 → 2026-07-23 (+216d) | 2025-12-19 → 2026-07-23 (+216d) |  |  | 1d → 0d | 1935FS+20d → 1935FS+19d | baseline start 2025-12-19 → 2026-07-23; baseline finish 2025-12-19 → 2026-07-23 |
| 1937 | **Qualification Wave 4** | 2025-03-17 → 2025-09-22 (+189d) | 2026-02-27 → 2027-01-28 (+335d) | 249d → 354d |  | 2d → 24d |  | baseline start 2025-03-17 → 2025-09-22; baseline finish 2026-02-27 → 2027-01-28 |
| 1938 | **Qualification Wave 4 QAD Prep** | 2025-03-17 → 2025-10-20 (+217d) | 2025-07-31 → 2026-02-27 (+211d) | 98d → 95d |  | 2d → 4d |  | baseline start 2025-03-17 → 2025-10-20; baseline finish 2025-07-31 → 2026-02-27 |
| 1939 | Initial QAD Submission window opens | 2025-03-17 → 2025-10-20 (+217d) | 2025-03-17 → 2025-10-20 (+217d) |  |  | 2d → 4d | 1674FS+6d → 1674FS+161d | baseline start 2025-03-17 → 2025-10-20; baseline finish 2025-03-17 → 2025-10-20 |
| 1940 | Qualification Wave 4 Participants Submit Initial QAD | 2025-03-18 → 2025-10-20 (+216d) | 2025-06-20 → 2026-01-16 (+210d) | 69d → 65d |  | 2d → 4d | 1939 → 1939FS-1d | baseline start 2025-03-17 → 2025-10-20; baseline finish 2025-06-20 → 2026-01-16 |
| 1941 | Qualification Wave 4 Participants have submitted their Initial QAD | 2025-06-20 → 2026-01-16 (+210d) | 2025-06-20 → 2026-01-16 (+210d) |  |  | 2d → 4d |  | baseline start 2025-06-20 → 2026-01-16; baseline finish 2025-06-20 → 2026-01-16 |
| 1942 | Code Bodies review of Wave 4 Participants' Initial QAD | 2025-06-23 → 2026-01-19 (+210d) | 2025-07-31 → 2026-02-27 (+211d) | 29d → 30d |  | 2d → 4d |  | baseline start 2025-06-23 → 2026-01-19; baseline finish 2025-07-31 → 2026-02-27 |
| 1943 | Completion of Code Bodies review of Initial QAD | 2025-07-31 → 2026-02-27 (+211d) | 2025-07-31 → 2026-02-27 (+211d) |  |  | 2d → 4d |  | baseline start 2025-07-31 → 2026-02-27; baseline finish 2025-07-31 → 2026-02-27 |
| 1944 | **Qualification Wave 4 Test Prep** | 2025-05-01 → 2025-09-22 (+144d) | 2025-08-01 → 2025-12-19 (+140d) | 67d → 65d |  | 21d → 60d |  | baseline start 2025-05-01 → 2025-09-22; baseline finish 2025-08-01 → 2025-12-19 |
| 1945 | Confirmation from Qualification 4 Participants that DIP Onboarding has commenced | 2025-05-01 → 2025-09-22 (+144d) | 2025-05-01 → 2025-09-22 (+144d) |  |  | 21d → 79d |  | constraint start no earlier than 2025-05-01 → start no earlier than 2025-09-22; baseline start 2025-05-01 → 2025-09-22; baseline finish 2025-05-01 → 2025-09-22 |
| 1946 | Qualification Wave 4 Participants DIP Onboarding Window | 2025-05-01 → 2025-09-22 (+144d) | 2025-06-27 → 2025-11-07 (+133d) | 42d → 35d |  | 21d → 79d |  | baseline start 2025-05-01 → 2025-09-22; baseline finish 2025-06-27 → 2025-11-07 |
| 1947 | Confirmation from Qualification Wave 4 Participants that DIP onboarding has completed | 2025-06-27 → 2025-11-07 (+133d) | 2025-06-27 → 2025-11-07 (+133d) |  |  | 21d → 79d |  | baseline start 2025-06-27 → 2025-11-07; baseline finish 2025-06-27 → 2025-11-07 |
| 1948 | Qualification Wave 4 Participants' to provide status of PIT completion and submit QT Test Plan | 2025-05-30 → 2025-10-27 (+150d) | 2025-05-30 → 2025-10-27 (+150d) |  |  | 2d → 49d |  | constraint start no earlier than 2025-05-30 → start no earlier than 2025-10-27; baseline start 2025-05-30 → 2025-10-27; baseline finish 2025-05-30 → 2025-10-27 |
| 1949 | Review of Participants' PIT Status and QT Test Plan | 2025-05-30 → 2025-10-27 (+150d) | 2025-06-20 → 2025-11-14 (+147d) | 16d → 15d |  | 505d → 60d |  | baseline start 2025-05-30 → 2025-10-27; baseline finish 2025-06-20 → 2025-11-14 |
| 1950 | Qualification Test Plans for Qualification Wave 4 Participants approved | 2025-06-20 → 2025-11-14 (+147d) | 2025-06-20 → 2025-11-14 (+147d) |  |  | 505d → 60d |  | baseline start 2025-06-20 → 2025-11-14; baseline finish 2025-06-20 → 2025-11-14 |
| 1951 | Qualification Wave 4 Participants have submitted PIT Test Completion Report and evidence for QT entry | 2025-06-20 → 2025-11-14 (+147d) | 2025-06-20 → 2025-11-14 (+147d) |  |  | 1d → 60d | none → 1950 | constraint finish no earlier than 2025-06-20 → none; baseline start 2025-06-20 → 2025-11-14; baseline finish 2025-06-20 → 2025-11-14 |
| 1952 | Review of Participants' PIT Test Completion Report | 2025-06-23 → 2025-11-17 (+147d) | 2025-07-31 → 2025-12-19 (+141d) | 29d → 25d |  | 1d → 60d |  | baseline start 2025-06-20 → 2025-11-17; baseline finish 2025-07-31 → 2025-12-19 |
| 1953 | Onboarding to QTF & ADO | 2025-06-23 → 2025-11-24 (+154d) | 2025-08-01 → 2025-12-19 (+140d) | 30d → 20d |  | 1d → 55d |  | constraint none → start no earlier than 2025-11-24; baseline start 2025-06-23 → 2025-11-24; baseline finish 2025-08-01 → 2025-12-19 |
| 1954 | **Qualification Wave 4 QT Execution** | 2025-07-25 → 2026-02-23 (+213d) | 2025-12-12 → 2026-07-10 (+210d) | 101d → 100d |  | 2d → 4d |  | baseline start 2025-07-25 → 2026-02-23; baseline finish 2025-12-12 → 2026-07-10 |
| 1955 | Review Entry Criteria Evidence for each Wave 4 Participant | 2025-07-25 → 2026-02-23 (+213d) | 2025-07-31 → 2026-02-27 (+211d) |  |  | 2d → 4d |  | constraint none → start no earlier than 2026-01-05; baseline start 2025-07-25 → 2026-02-23; baseline finish 2025-07-31 → 2026-02-27 |
| 1956 | Qualification Wave 4 Participant Test Readiness Confirmed | 2025-07-31 → 2026-02-27 (+211d) | 2025-07-31 → 2026-02-27 (+211d) |  |  | 2d → 4d |  | was named Qualification Test Plans for Qualification Wave 4 Participants approved; baseline start 2025-07-31 → 2026-02-27; baseline finish 2025-07-31 → 2026-02-27 |
| 1957 | Qualification Wave 4 QT Execution Start | 2025-08-01 → 2026-03-02 (+213d) | 2025-08-01 → 2026-03-02 (+213d) |  |  | 1d → 4d | 1956, 1953 → 1956FS+1d, 1953 | constraint none → start no earlier than 2026-01-07; baseline start 2025-08-01 → 2026-03-02; baseline finish 2025-08-01 → 2026-03-02 |
| 1958 | Qualification Wave 4 QT Execution Window | 2025-08-04 → 2026-03-02 (+210d) | 2025-12-12 → 2026-07-10 (+210d) |  |  | 6d → 9d | 1957, 1955 → 1957FS-1d, 1955 | baseline start 2025-08-01 → 2026-03-02; baseline finish 2025-12-12 → 2026-07-10 |
| 1959 | Qualification Wave 4 Projected Execution End | 2025-12-12 → 2026-07-10 (+210d) | 2025-12-12 → 2026-07-10 (+210d) |  |  | 6d → 9d |  | baseline start 2025-12-12 → 2026-07-10; baseline finish 2025-12-12 → 2026-07-10 |
| 1960 | **Qualification Wave 4 Exit** | 2025-08-01 → 2026-03-02 (+213d) | 2026-02-27 → 2026-09-18 (+203d) | 150d → 145d |  | 1d → 4d |  | baseline start 2025-08-01 → 2026-03-02; baseline finish 2026-02-27 → 2026-09-18 |
| 1961 | Final QAD Submission window opens | 2025-08-01 → 2026-03-02 (+213d) | 2025-08-01 → 2026-03-02 (+213d) |  |  | 1d → 4d |  | baseline start 2025-08-01 → 2026-03-02; baseline finish 2025-08-01 → 2026-03-02 |
| 1962 | Qualification Wave 4 Participants submit their Final QAD | 2025-08-04 → 2026-03-02 (+210d) | 2025-12-19 → 2026-07-17 (+210d) |  |  | 1d → 4d | 1961 → 1961FS-1d | baseline start 2025-08-01 → 2026-03-02; baseline finish 2025-12-19 → 2026-07-17 |
| 1963 | Qualification Wave 4 Participants have submitted their Final QAD | 2025-12-19 → 2026-07-17 (+210d) | 2025-12-19 → 2026-07-17 (+210d) |  |  | 1d → 4d |  | baseline start 2025-12-19 → 2026-07-17; baseline finish 2025-12-19 → 2026-07-17 |
| 1964 | Completion of Code Bodies review of Final QAD | 2025-12-22 → 2026-07-20 (+210d) | 2026-01-23 → 2026-08-14 (+203d) | 25d → 20d |  | 1d → 4d |  | baseline start 2025-12-22 → 2026-07-20; baseline finish 2026-01-23 → 2026-08-14 |
| 1965 | QAD Sign Off deadline | 2026-01-30 → 2026-08-21 (+203d) | 2026-01-30 → 2026-08-21 (+203d) |  |  | 1d → 4d |  | baseline start 2026-01-30 → 2026-08-21; baseline finish 2026-01-30 → 2026-08-21 |
| 1966 | Qualification Wave 4 Participants Qualification approved by BSC PAB and REC Manager | 2026-02-27 → 2026-09-18 (+203d) | 2026-02-27 → 2026-09-18 (+203d) |  |  | 1d → 4d |  | baseline start 2026-02-27 → 2026-09-18; baseline finish 2026-02-27 → 2026-09-18 |
| 1968 | All suppliers must be able to access MPANs under the new TOM (M14) | 2026-03-12 → 2026-10-28 (+230d) | 2026-03-12 → 2026-10-28 (+230d) |  |  | 0d → 235d | none → 1966FS+28d | constraint must start on 2026-03-12 → start no earlier than 2026-03-12; baseline start 2026-03-16 → 2026-10-28; baseline finish 2026-03-16 → 2026-10-28 |
| 1969 | All suppliers must be able to access MPANs under the new TOM (M14*) - Late Exit | 2026-06-12 → 2027-01-28 (+230d) | 2026-06-12 → 2027-01-28 (+230d) |  |  | 250d → 235d |  | baseline start 2026-06-16 → 2027-01-28; baseline finish 2026-06-16 → 2027-01-28 |
| 1970 | **REGULATORY** |  | 2025-06-06 → 2025-12-24 (+201d) | 680d → 823d | 94% → 93% | 515d → 521d |  | baseline finish 2025-06-06 → 2025-12-24 |
| 1971 | **Baseline MHHS Code Changes** |  | 2024-08-23 A |  | 99% → 100% | 720d → none |  |  |
| 1976 | **Code drafting** |  | 2024-08-21 A |  | 99% → 100% | 722d → none |  | baseline finish 2024-08-23 → 2024-08-21 |
| 2022 | **Interfaces / Data Specification (REC driven)** |  |  |  |  |  |  | baseline finish 2024-01-24 → 2024-01-23 |
| 2028 | CDWG review |  |  |  |  |  |  | baseline finish 2024-01-09 → 2024-01-16 |
| 2029 | CCAG review |  |  |  |  |  |  | baseline start 2024-01-10 → 2024-01-17; baseline finish 2024-01-24 → 2024-01-23 |
| 2030 | Code drafting for Interfaces / Data Specification topic areas approved |  |  |  |  |  |  | baseline start 2024-01-24 → 2024-01-23; baseline finish 2024-01-24 → 2024-01-23 |
| 2040 | **Consequential Code Change** |  |  |  |  |  |  | baseline finish 2024-03-08 → 2024-03-11 |
| 2042 | External industry review via consultation - drop 2 (Elexon) |  |  |  |  |  |  | baseline finish 2024-03-08 → 2024-03-11 |
| 2043 | **Transition Text (all codes)** |  |  |  |  |  |  | baseline finish 2024-01-24 → 2024-01-23 |
| 2050 | CCAG review |  |  |  |  |  |  | baseline finish 2024-01-24 → 2024-01-23 |
| 2051 | Code drafting for Transition Text topic area approved |  |  |  |  |  |  | baseline start 2024-01-24 → 2024-01-23; baseline finish 2024-01-24 → 2024-01-23 |
| 2060 | External industry review via consultation Final Consultation (2) |  |  |  |  |  |  | baseline finish 2024-03-08 → 2024-03-11 |
| 2061 | Triage and action comments |  |  |  |  |  |  | baseline start 2024-03-07 → 2024-03-11; baseline finish 2024-04-01 → 2024-04-03 |
| 2062 | CDWG review |  |  |  |  |  |  | baseline start 2024-04-02 → 2024-04-04 |
| 2065 | **Final code review, consistency check and approval** |  | 2024-08-21 A |  | 90% → 100% | 722d → none |  | baseline finish 2024-08-23 → 2024-08-21 |
| 2068 | Final documentation collated for final consultation |  |  |  |  |  |  | baseline finish 2024-06-24 → 2024-06-21 |
| 2069 | External industry review via consultation |  |  |  |  |  |  | baseline finish 2024-07-19 → 2024-07-12 |
| 2070 | Triage and action comments |  |  |  |  |  |  | baseline start 2024-07-18 → 2024-07-15; baseline finish 2024-08-05 → 2024-07-26 |
| 2071 | Final CDWG review |  | 2024-08-13 A |  | 50% → 100% | 586d → none |  | baseline start 2024-08-06 → 2024-08-02 |
| 2072 | Final CCAG review | 2024-08-14 A | 2024-08-21 A |  | 0% → 100% | 586d → none |  | baseline finish 2024-08-23 → 2024-08-21 |
| 2073 | CCAG recommend final code to PSG for baselining | 2024-08-21 A | 2024-08-21 A |  | 0% → 100% | 722d → none |  | baseline start 2024-08-23 → 2024-08-21; baseline finish 2024-08-23 → 2024-08-21 |
| 2074 | Code changes baselined (M6) | 2024-08-23 A | 2024-08-23 A |  | 0% → 100% | 586d → none |  |  |
| 2075 | **Ofgem preparation and enactment of SCR powers** |  | 2024-11-11 → 2024-12-13 (+32d) | 201d → 225d | 77% → 71% | 664d → 789d |  | baseline finish 2024-11-12 → 2024-12-13 |
| 2076 | **Preparation and enactment of SCR Powers** |  | 2024-11-11 → 2024-12-11 (+30d) | 201d → 223d | 77% → 72% | 664d → 726d |  | baseline finish 2024-11-11 → 2024-12-11 |
| 2077 | Ofgem to keep Ofgem legal informed of process followed and nature of Code drafting to ensure that prepared for SCR go/no go decision |  |  |  |  |  |  | baseline finish 2024-06-25 → 2024-06-24 |
| 2078 | OFGEM Legal to review Code Artefacts deliver policy intent and process followed and confirm that SCR powers are appropriate to use rather than SMAP - SCR go/no go |  |  |  |  |  |  | baseline finish 2024-07-12 → 2024-07-11 |
| 2079 | Code Bodies to draft MOD proposal forms |  |  |  |  |  |  | baseline start 2024-07-15 → 2024-07-12; baseline finish 2024-08-09 → 2024-08-08 |
| 2080 | Ofgem discuss and agree code mod timetable with code bodies (and MHHSP in relation to the dates for expected decisions) |  |  |  |  |  |  | baseline start 2024-07-15 → 2024-07-12; baseline finish 2024-08-09 → 2024-08-08 |
| 2081 | Ofgem to publish each Direction to each code body specifying the timetable for each modification | 2024-08-28 A | 2024-08-28 A |  | 0% → 100% | 717d → none | Ofgem to publish open letterFS+1d → 2080FS+13d |  |
| 2082 | Formally submit (by separate email) Modification Proposal Forms and legal texts to each code body | 2024-08-28 A | 2024-08-28 A |  | 0% → 100% | 586d → none | Ofgem to publish open letterFS+1d → 2080FS+13d |  |
| 2083 | Each Code Body publishes and issues Modification Proposal Forms | 2024-08-29 A | 2024-09-02 A |  | 0% → 100% | 586d → none | 2082 → 2082, 2081 |  |

| ID | Task | Start | Finish | Duration | Complete | Total float | Predecessors | Other |
| --- | --- | --- | --- | --- | --- | --- | --- | --- |
| 2084 | Each Code Body sends Modification Proposal Forms to Panel to approve Mod to go to consultation | 2024-09-03 A |  |  | 0% → 33% | 586d → 726d |  |  |
| 2095 | Ofgem decisions on M6 baselined code modification proposals (M7) | 2024-11-11 → 2024-12-11 (+30d) | 2024-11-11 → 2024-12-11 (+30d) |  |  | 586d → 726d | 2074, Panel make recommendation to OFGEM → 2074, 2094 | was named SCR powers enabled (M7); baseline start 2024-11-11 → 2024-12-11; baseline finish 2024-11-11 → 2024-12-11 |
| 2097 | **Deliver MHHS Code Changes** |  | 2025-06-06 → 2025-12-24 (+201d) | 149d → 292d |  | 515d → 521d |  | baseline finish 2025-06-06 → 2025-12-24 |
| 2098 | **Releases** |  | 2025-06-06 → 2025-12-24 (+201d) | 149d → 292d |  | 515d → 521d |  | baseline finish 2025-06-06 → 2025-12-24 |
| 2099 | Impacted codes make resourcing provisions and prepare to implement new Code via internal code body change processes |  |  |  |  | 586d → 735d | 2095 → none | constraint none → start no earlier than 2024-11-12 |
| 2100 | **Main Code Release** | 2025-02-28 → 2025-09-17 (+201d) | 2025-06-06 → 2025-12-24 (+201d) |  |  | 515d → 521d |  | baseline start 2025-02-28 → 2025-09-17; baseline finish 2025-06-06 → 2025-12-24 |
| 2101 | Release preparation (e.g. preparing release documentation) | 2025-02-28 → 2025-09-17 (+201d) | 2025-03-07 → 2025-09-24 (+201d) |  |  | 580d → 586d |  | baseline start 2025-02-28 → 2025-09-17; baseline finish 2025-03-07 → 2025-09-24 |
| 2102 | Implement new code on day of code release | 2025-03-07 → 2025-09-24 (+201d) | 2025-03-07 → 2025-09-24 (+201d) |  |  | 580d → 586d |  | baseline start 2025-03-07 → 2025-09-24; baseline finish 2025-03-07 → 2025-09-24 |
| 2103 | Code changes delivered (M8) | 2025-03-07 → 2025-09-24 (+201d) | 2025-03-07 → 2025-09-24 (+201d) |  |  | 515d → 521d |  | baseline start 2025-03-07 → 2025-09-24; baseline finish 2025-03-07 → 2025-09-24 |
| 2104 | Code changes delivered (M8*) late exit | 2025-06-06 → 2025-12-24 (+201d) | 2025-06-06 → 2025-12-24 (+201d) |  |  | 515d → 521d |  | baseline start 2025-06-06 → 2025-12-24; baseline finish 2025-06-06 → 2025-12-24 |
| 2109 | **MIGRATION** |  | 2027-01-04 → 2027-08-09 (+217d) | 1091d → 1246d | 36% → 35% | 104d → 98d |  | baseline finish 2027-01-05 → 2027-08-09 |
| 2111 | **Regulatory Governance** |  |  |  |  | 627d → 776d |  | baseline finish 2024-11-27 → 2025-01-01 |
| 2112 | Incentive Mods Created |  |  |  |  | 627d → 776d |  | baseline finish 2024-07-26 → 2024-08-30 |
| 2113 | Incentives Implemented |  |  |  |  | 627d → 776d |  | baseline start 2024-07-29 → 2024-09-02; baseline finish 2024-11-27 → 2025-01-01 |
| 2114 | **Migration Framework Agreed and Implemented** |  | 2024-11-26 → 2025-01-23 (+58d) | 214d → 256d | 61% → 62% | 653d → 121d |  | baseline finish 2024-11-26 → 2025-01-23 |
| 2129 | **Consultation 3 - Parameters** |  | 2024-10-22 → 2025-01-23 (+93d) | 76d → 143d | 35% → 18% | 678d → 121d |  | baseline finish 2024-10-22 → 2025-01-23 |
| 2130 | Prepare Artefacts (9) for Consultation |  | 2024-08-27 → 2024-11-18 (+83d) | 36d → 95d | 61% → 23% | 678d → 121d |  | baseline finish 2024-08-27 → 2024-11-18 |
| 2131 | Industry Consultation | 2024-08-28 → 2024-11-19 (+83d) | 2024-09-10 → 2024-12-02 (+83d) |  |  | 678d → 121d |  | baseline start 2024-08-28 → 2024-11-19; baseline finish 2024-09-10 → 2024-12-02 |
| 2132 | Triage and Action Comments | 2024-09-11 → 2024-12-03 (+83d) | 2024-09-24 → 2024-12-16 (+83d) |  |  | 678d → 121d |  | baseline start 2024-09-11 → 2024-12-03; baseline finish 2024-09-24 → 2024-12-16 |
| 2133 | Industry Assurance Review | 2024-09-25 → 2024-12-17 (+83d) | 2024-10-03 → 2024-12-25 (+83d) |  |  | 678d → 121d |  | baseline start 2024-09-25 → 2024-12-17; baseline finish 2024-10-03 → 2024-12-25 |
| 2134 | MWG Recommendation | 2024-10-03 → 2025-01-06 (+95d) | 2024-10-03 → 2025-01-06 (+95d) |  |  | 678d → 121d | 2133 → 2133FS+8d | baseline start 2024-10-03 → 2025-01-06; baseline finish 2024-10-03 → 2025-01-06 |
| 2135 | MCAG Approval of Migration Framework Artefacts (Baselined) | 2024-10-22 → 2025-01-23 (+93d) | 2024-10-22 → 2025-01-23 (+93d) |  |  | 678d → 121d |  | baseline start 2024-10-22 → 2025-01-23; baseline finish 2024-10-22 → 2025-01-23 |
| 2136 | **Migration Schedule Agreed and Maintained** |  | 2025-04-15 → 2026-01-30 (+290d) | 207d → 415d | 20% → 14% | 553d → 494d |  | baseline finish 2025-04-15 → 2026-01-30 |
| 2141 | V1.0 of Migration Schedule Baseline Approved at MCAG | 2024-10-22 → 2025-01-10 (+80d) | 2024-10-22 → 2025-01-10 (+80d) |  |  | 573d → 494d |  | baseline start 2024-10-22 → 2025-01-10; baseline finish 2024-10-22 → 2025-01-10 |
| 2142 | Sprint Planning (Cycle 1) | 2024-11-20 → 2025-06-16 (+208d) | 2024-12-17 → 2025-08-08 (+234d) | 20d → 40d |  | 553d → 494d | 2156, 2141 → 2141FS+110d | baseline start 2024-11-20 → 2025-06-16; baseline finish 2024-12-17 → 2025-08-08 |
| 2143 | Sprint Planning (Cycle 2) | 2025-01-22 → 2025-09-15 (+236d) | 2025-02-18 → 2025-11-07 (+262d) | 20d → 40d |  | 553d → 494d |  | baseline start 2025-01-22 → 2025-09-15; baseline finish 2025-02-18 → 2025-11-07 |
| 2144 | Sprint Planning (Cycle 3) | 2025-03-19 → 2025-12-08 (+264d) | 2025-04-15 → 2026-01-30 (+290d) | 20d → 40d |  | 553d → 494d |  | baseline start 2025-03-20 → 2025-12-08; baseline finish 2025-04-15 → 2026-01-30 |
| 2145 | **Migration Control Centre Tooling** |  | 2025-01-17 → 2025-04-11 (+84d) | 182d → 242d | 45% → 30% | 594d → 112d |  | baseline finish 2025-01-17 → 2025-04-11 |
| 2146 | Data Source Definition |  | 2024-07-31 → 2024-10-23 (+84d) | 60d → 120d | 92% → 46% | 575d → 112d |  | baseline finish 2024-07-31 → 2024-10-23 |
| 2147 | Scheduling and Data Requirements |  | 2024-07-31 → 2024-10-23 (+84d) | 60d → 120d | 92% → 46% | 575d → 112d |  | baseline finish 2024-07-31 → 2024-10-23 |
| 2148 | Tool Phase 1 | 2024-08-01 → 2024-10-24 (+84d) | 2024-08-15 → 2024-11-07 (+84d) |  |  | 575d → 112d |  | baseline start 2024-08-01 → 2024-10-24; baseline finish 2024-08-15 → 2024-11-07 |
| 2149 | Data Requirements | 2024-08-16 → 2024-11-08 (+84d) | 2024-09-13 → 2024-12-06 (+84d) |  |  | 575d → 112d |  | baseline start 2024-08-16 → 2024-11-08; baseline finish 2024-09-13 → 2024-12-06 |
| 2150 | Tool Phase 2 | 2024-09-16 → 2024-12-09 (+84d) | 2024-10-18 → 2025-01-10 (+84d) |  |  | 575d → 112d |  | baseline start 2024-09-16 → 2024-12-09; baseline finish 2024-10-18 → 2025-01-10 |
| 2151 | Data Source Provision | 2024-10-21 → 2025-01-13 (+84d) | 2024-10-29 → 2025-01-21 (+84d) |  |  | 594d → 112d | 2150, Test Data Being Received → 2150 | baseline start 2024-10-21 → 2025-01-13; baseline finish 2024-10-29 → 2025-01-21 |
| 2152 | Tool - Internal and External Testing | 2024-10-30 → 2025-01-22 (+84d) | 2025-01-17 → 2025-04-11 (+84d) |  |  | 594d → 112d |  | baseline start 2024-10-30 → 2025-01-22; baseline finish 2025-01-17 → 2025-04-11 |
| 2153 | **Migration Control Centre Mobilised and Ready** |  | 2025-02-03 → 2025-04-14 (+70d) | 135d → 185d | 2% → 1% | 584d → 112d |  | baseline start 2024-07-31 → 2024-07-30; baseline finish 2025-02-03 → 2025-04-14 |
| 2154 | Migration Control Centre TOM Definition |  | 2024-09-06 → 2024-10-28 (+52d) | 29d → 65d | 7% → 3% | 553d → 126d |  | baseline start 2024-07-31 → 2024-07-30; baseline finish 2024-09-09 → 2024-10-28 |
| 2155 | Access to Data | 2024-09-13 → 2024-11-04 (+52d) | 2024-10-17 → 2024-12-06 (+50d) |  |  | 553d → 126d |  | baseline start 2024-09-16 → 2024-11-04; baseline finish 2024-10-18 → 2024-12-06 |
| 2156 | Migration Control Centre Delegation of Authority | 2024-11-04 → 2024-12-24 (+50d) | 2024-11-19 → 2025-01-08 (+50d) |  |  | 553d → 126d |  | baseline start 2024-11-04 → 2024-12-24; baseline finish 2024-11-19 → 2025-01-08 |
| 2157 | Recruit and Train | 2024-11-04 → 2024-12-24 (+50d) | 2025-01-31 → 2025-03-24 (+52d) |  |  | 584d → 126d |  | baseline start 2024-11-04 → 2024-12-24; baseline finish 2025-01-31 → 2025-03-24 |
| 2158 | Dress Rehearsal | 2025-02-03 → 2025-04-14 (+70d) | 2025-02-03 → 2025-04-14 (+70d) |  |  | 584d → 112d |  | baseline start 2025-02-03 → 2025-04-14; baseline finish 2025-02-03 → 2025-04-14 |
| 2159 | **PP's Prepared for Migration** |  | 2025-01-30 → 2025-03-31 (+60d) | 154d → 196d |  | 585d → 121d |  | baseline finish 2025-01-30 → 2025-03-31 |
| 2162 | Guides Creation | 2024-11-29 → 2025-01-28 (+60d) | 2025-01-30 → 2025-03-31 (+60d) |  |  | 585d → 121d | Consultation 4 - Test - MCAG Approval of Interim ArtefactsFS+2d → 2135FS+2d | baseline start 2024-11-29 → 2025-01-28; baseline finish 2025-01-30 → 2025-03-31 |
| 2163 | Support Channels | 2024-11-29 → 2025-01-28 (+60d) | 2025-01-30 → 2025-03-31 (+60d) |  |  | 585d → 121d | Consultation 4 - Test - MCAG Approval of Interim ArtefactsFS+2d → 2135FS+2d | baseline start 2024-11-29 → 2025-01-28; baseline finish 2025-01-30 → 2025-03-31 |
| 2164 | **Migration Artefact Development and Publication** |  | 2025-04-04 → 2025-09-03 (+152d) | 635d → 743d | 78% → 80% | 560d → 601d |  | baseline finish 2025-04-04 → 2025-09-03 |
| 2207 | **Data Cleanse Plan** |  | 2025-04-04 → 2025-09-03 (+152d) | 547d → 655d | 63% → 65% | 560d → 601d |  | baseline finish 2025-04-04 → 2025-09-03 |
| 2212 | **MTDs** | 2024-08-16 A | 2025-01-24 → 2025-01-31 (+7d) | 115d → 120d | 0% → 45% | 610d → 754d |  | baseline finish 2024-12-23 → 2025-01-31 |
| 2213 | **ESME ID** | 2024-08-16 A |  |  |  | 635d → 784d |  |  |
| 2214 | DCC to extract ESME ID and share with LDSO | 2024-08-16 A | 2024-08-16 A |  | 0% → 100% | 635d → none |  |  |
| 2215 | LDSO ‘full refresh’ between their Registration Service and the EES (ESME ID) |  |  |  |  | 635d → 784d |  | baseline start 2024-09-27 → 2024-10-21; baseline finish 2024-09-27 → 2024-11-11 |
| 2218 | **Meter Location and Number of Displayed Register Digits** | 2024-09-13 A | 2025-01-24 → 2025-01-31 (+7d) | 96d → 101d | 0% → 78% | 610d → 754d |  | baseline start 2024-08-16 → 2024-09-13; baseline finish 2024-12-23 → 2025-01-31 |
| 2219 | MEM to extract data and share with LDSO | 2024-09-13 A | 2024-09-13 → 2024-09-20 A (+7d) | 1d → 6d | 0% → 100% | 610d → none |  | baseline start 2024-08-16 → 2024-09-13; baseline finish 2024-08-16 → 2024-09-20 |
| 2220 | LDSO ‘full refresh’ between their Registration Service and the EES (Meter Location and Number of Displayed Register Digits) | 2024-10-21 → 2024-10-28 A (+7d) | 2024-11-11 → 2024-11-18 (+7d) |  | 0% → 75% | 610d → 754d |  | baseline start 2024-09-27 → 2024-10-28; baseline finish 2024-09-27 → 2024-11-18 |
| 2221 | Suppliers complete investigation of exceptions and resolution of exceptions | 2025-01-24 → 2025-01-31 (+7d) | 2025-01-24 → 2025-01-31 (+7d) |  |  | 610d → 754d |  | baseline start 2024-12-20 → 2025-01-31; baseline finish 2024-12-20 → 2025-01-31 |
| 2222 | Meter Location and Number of Displayed Register Digits Complete | 2025-01-24 → 2025-01-31 (+7d) | 2025-01-24 → 2025-01-31 (+7d) |  |  | 610d → 754d |  | baseline start 2024-12-23 → 2025-01-31; baseline finish 2024-12-23 → 2025-01-31 |
| 2223 | **Registration Data** | 2024-09-06 A | 2025-03-31 → 2025-09-03 (+156d) | 147d → 259d | 0% → 5% | 564d → 601d |  | baseline finish 2025-03-31 → 2025-09-03 |
| 2224 | **Connection Type** | 2024-09-06 A |  |  | 0% → 6% | 664d → 813d |  | baseline finish 2024-09-27 → 2024-11-11 |
| 2225 | Automated Population of Connection Type for Measurement Classes ‘B’, ‘D’, ‘F’ & ‘G’ | 2024-10-04 A | 2024-10-04 A |  | 0% → 100% | 690d → none |  | constraint none → start no earlier than 2024-09-13; baseline start 2024-09-13 → 2024-10-04; baseline finish 2024-09-13 → 2024-10-04 |
| 2226 | BAU Population of Connection Type for Site Specific LLFCs within Measurement Classes ‘C’ & ‘E’ | 2024-10-04 A | 2024-10-04 A |  | 0% → 100% | 690d → none |  | baseline start 2024-09-13 → 2024-10-04; baseline finish 2024-09-13 → 2024-10-04 |
| 2227 | Automated Population of Connection Type for Smart Meters within Measurement Class ‘A’ | 2024-10-04 A | 2024-10-04 A |  | 0% → 100% | 690d → none |  | baseline start 2024-09-13 → 2024-10-04; baseline finish 2024-09-13 → 2024-10-04 |
| 2228 | Population of Connection Type for Traditional and Advanced Meters within Measurement Class ‘A’ | 2024-09-06 A | 2024-09-06 A |  | 0% → 100% | 710d → none |  |  |
| 2229 | Automated Population of Null Connection Type | 2024-10-04 A | 2024-10-04 A |  | 0% → 100% | 690d → none |  | baseline start 2024-09-13 → 2024-10-04; baseline finish 2024-09-13 → 2024-10-04 |
| 2230 | Full MPAN refresh to ESS |  |  |  |  | 664d → 813d |  | baseline start 2024-09-27 → 2024-10-21; baseline finish 2024-09-27 → 2024-11-11 |
| 2231 | Connection Type Complete |  |  |  |  | 664d → 813d |  | baseline start 2024-09-27 → 2024-11-11; baseline finish 2024-09-27 → 2024-11-11 |
| 2232 | **Domestic Premises Indicator** | 2025-03-07 → 2025-08-08 (+154d) | 2025-03-31 → 2025-09-03 (+156d) | 17d → 19d |  | 564d → 601d |  | baseline start 2025-03-07 → 2025-08-08; baseline finish 2025-03-31 → 2025-09-03 |
| 2233 | The DCC to extract Domestic Premises Indicator from the CSS and provide a file to each LDSO and EES. | 2025-03-07 → 2025-08-08 (+154d) | 2025-03-07 → 2025-08-11 (+157d) | 1d → 2d |  | 564d → 601d | 2210FS+426d → none | constraint none → start no earlier than 2025-08-08; baseline start 2025-03-07 → 2025-08-08; baseline finish 2025-03-07 → 2025-08-11 |
| 2234 | Each LDSO notifies the DCC of any exceptions | 2025-03-07 → 2025-08-12 (+158d) | 2025-03-07 → 2025-08-12 (+158d) |  |  | 564d → 601d | 2210FS+426d → 2233 | baseline start 2025-03-07 → 2025-08-12; baseline finish 2025-03-07 → 2025-08-12 |
| 2235 | Each LDSO and DCC completes investigation and resolution of exceptions | 2025-03-31 → 2025-09-03 (+156d) | 2025-03-31 → 2025-09-03 (+156d) |  |  | 564d → 601d |  | baseline start 2025-03-31 → 2025-09-03; baseline finish 2025-03-31 → 2025-09-03 |
| 2236 | Domestic Premises Indicator Complete | 2025-03-31 → 2025-09-03 (+156d) | 2025-03-31 → 2025-09-03 (+156d) |  |  | 564d → 601d |  | baseline start 2025-03-31 → 2025-09-03; baseline finish 2025-03-31 → 2025-09-03 |
| 2237 | **Export / Import MPANs** |  |  |  | 67% → 99% | 680d → 829d |  |  |

| ID | Task | Start | Finish | Duration | Complete | Total float | Predecessors | Other |
| --- | --- | --- | --- | --- | --- | --- | --- | --- |
| 2238 | **Linking of Export / Import MPANS** |  |  |  | 67% → 99% | 680d → 829d |  |  |
| 2241 | Each Supplier completes investigation and resolution of exceptions | 2024-08-23 A | 2024-08-23 A |  | 0% → 100% | 680d → none |  |  |
| 2244 | Pre-migration data cleanse complete | 2025-04-04 → 2025-08-13 (+131d) | 2025-04-04 → 2025-08-13 (+131d) |  |  | 560d → 617d | 2352FS-20d, 2354FS-20d, 2211FS+5d, 2217, 2222, 2231, 2236, 2243 → none | constraint none → start no earlier than 2025-08-13; baseline start 2025-04-04 → 2025-08-13; baseline finish 2025-04-04 → 2025-08-13 |
| 2245 | **Migration Period Planning** |  |  |  | 77% → 83% | 529d → 678d |  | baseline finish 2026-10-05 → 2024-11-26 |
| 2246 | **Migration Implementation Plan (incl. Migration Exit Criteria)** |  |  |  | 77% → 83% | 529d → 678d |  | baseline finish 2026-10-05 → 2024-11-26 |
| 2247 | **Migration Threshold Volumes** |  |  |  |  |  |  | baseline finish 2023-11-15 → 2023-11-20 |
| 2249 | Artefact review (via TMAG) and updates |  |  |  |  |  |  | baseline finish 2023-11-15 → 2023-11-20 |
| 2250 | Threshold volumes approved at TMAG |  |  |  |  |  |  | baseline start 2023-11-15 → 2023-11-20; baseline finish 2023-11-15 → 2023-11-20 |
| 2252 | Review acceptance criteria and reporting requirements with MWG |  |  |  |  |  |  | baseline finish 2023-10-27 → 2023-11-09 |
| 2259 | Assurance Meeting |  |  |  |  |  |  | baseline start 2024-05-14 → 2024-05-21; baseline finish 2024-05-14 → 2024-05-21 |
| 2262 | Draft Document |  |  |  |  | 529d → 678d | Draft DocumentSS+40d → none |  |
| 2267 | **Preparation for Cutover to Live** | 2022-10-31 A → 2024-06-28 A (+606d) | 2025-04-04 → 2025-10-22 (+201d) | 635d → 344d |  | 0d → 566d |  | baseline finish 2025-04-04 → 2025-10-22 |
| 2268 | **Central Systems Prepare for Cutover to Live** | 2022-10-31 A → 2024-06-28 A (+606d) | 2025-03-14 → 2025-09-26 (+196d) | 620d → 326d |  | 11d → 584d |  | baseline finish 2025-03-14 → 2025-09-26 |
| 2270 | **Development of Comms Approach and Declaration Guidance** | 2024-10-01 → 2025-03-03 (+153d) | 2025-01-17 → 2025-06-19 (+153d) |  |  | 35d → 74d |  | baseline start 2024-10-01 → 2025-03-03; baseline finish 2025-01-17 → 2025-06-19 |
| 2271 | Draft Cutover Comms Approach | 2024-10-01 → 2025-03-03 (+153d) | 2024-12-20 → 2025-05-22 (+153d) |  |  | 35d → 74d | 2260FS+84d → none | constraint none → start no earlier than 2025-03-03; baseline start 2024-10-01 → 2025-03-03; baseline finish 2024-12-20 → 2025-05-22 |
| 2272 | Draft Cutover Comms Approach shared | 2024-12-20 → 2025-05-22 (+153d) | 2024-12-20 → 2025-05-22 (+153d) |  |  | 35d → 74d |  | baseline start 2024-12-20 → 2025-05-22; baseline finish 2024-12-20 → 2025-05-22 |
| 2273 | Development of Implementation Group | 2024-10-01 → 2025-03-03 (+153d) | 2024-12-20 → 2025-05-22 (+153d) |  |  | 35d → 74d | 2260FS+84d → none | constraint none → start no earlier than 2025-03-03; baseline start 2024-10-01 → 2025-03-03; baseline finish 2024-12-20 → 2025-05-22 |
| 2274 | Implementation Group Established | 2024-12-20 → 2025-05-22 (+153d) | 2024-12-20 → 2025-05-22 (+153d) |  |  | 35d → 74d |  | baseline start 2024-12-20 → 2025-05-22; baseline finish 2024-12-20 → 2025-05-22 |
| 2275 | Finalised Cutover Comms Approach shared | 2025-01-17 → 2025-06-19 (+153d) | 2025-01-17 → 2025-06-19 (+153d) |  |  | 35d → 74d |  | baseline start 2025-01-17 → 2025-06-19; baseline finish 2025-01-17 → 2025-06-19 |
| 2276 | **Development of Cutover Plan requirements with Participants** | 2024-10-01 → 2025-03-03 (+153d) | 2025-03-06 → 2025-08-06 (+153d) |  |  | 1d → 40d |  | baseline start 2024-10-01 → 2025-03-03; baseline finish 2024-12-20 → 2025-08-06 |
| 2277 | Development of SIT Participant Cutover Plans | 2024-10-01 → 2025-03-03 (+153d) | 2024-12-20 → 2025-05-22 (+153d) |  |  | 1d → 40d | 2260FS+84d → none | constraint none → start no earlier than 2025-03-03; baseline start 2024-10-01 → 2025-03-03; baseline finish 2024-12-20 → 2025-05-22 |
| 2278 | SIT Participant Cutover Plans Ready | 2024-12-20 → 2025-05-22 (+153d) | 2024-12-20 → 2025-05-22 (+153d) |  |  | 1d → 40d |  | baseline start 2024-12-20 → 2025-05-22; baseline finish 2024-12-20 → 2025-05-22 |
| 2279 | Programme SIT Participant Cutover Plan Assurance | 2025-01-06 → 2025-06-06 (+151d) | 2025-03-06 → 2025-08-06 (+153d) |  |  | 1d → 40d |  | baseline start 2025-01-06 → 2025-06-06; baseline finish 2025-03-06 → 2025-08-06 |
| 2280 | **M10/M11 Cutover Activities** | 2022-10-31 → 2025-04-14 (+896d) | 2025-03-14 → 2025-09-26 (+196d) | 620d → 119d |  | 11d → 112d |  | baseline start 2025-02-21 → 2025-04-14; baseline finish 2025-03-14 → 2025-09-26 |
| 2281 | Production DIP Portal (DIP Deployment) | 2025-02-21 → 2025-09-05 (+196d) | 2025-02-21 → 2025-09-05 (+196d) |  |  | 7d → 13d |  | baseline start 2025-02-21 → 2025-09-05; baseline finish 2025-02-21 → 2025-09-05 |
| 2282 | Production Certificates (DIP Deployment) | 2025-02-21 → 2025-09-05 (+196d) | 2025-02-21 → 2025-09-05 (+196d) |  |  | 7d → 13d |  | baseline start 2025-02-21 → 2025-09-05; baseline finish 2025-02-21 → 2025-09-05 |
| 2283 | Completion of the pre-M10 MHHS Data Cleanse | 2025-02-26 → 2025-09-24 (+210d) | 2025-02-26 → 2025-09-24 (+210d) |  |  | 2d → 586d | 2210FS+420d → 1493 | was named Completion of the MHHS Data Cleanse; baseline start 2025-02-26 → 2025-09-24; baseline finish 2025-02-26 → 2025-09-24 |
| 2284 | Market-wide Participant MHHS Supporting Functionality Ready - Confirmation from Code Bodies | 2025-03-03 → 2025-09-15 (+196d) | 2025-03-03 → 2025-09-15 (+196d) |  |  | -3d → 594d | 2177FS+501d → 1493FS-8d | baseline start 2025-03-03 → 2025-09-15; baseline finish 2025-03-03 → 2025-09-15 |
| 2285 | Market-wide Participant MHHS Supporting Functionality Ready | 2025-03-07 → 2025-09-22 (+199d) | 2025-03-07 → 2025-09-22 (+199d) |  |  | -3d → 589d | 2284FS+4d → 1493FS-3d | baseline start 2025-03-07 → 2025-09-22; baseline finish 2025-03-07 → 2025-09-22 |
| 2286 | Elexon Central Services Deployment | 2025-03-07 → 2025-09-19 (+196d) | 2025-03-07 → 2025-09-19 (+196d) |  |  | -3d → 5d |  | baseline start 2025-03-07 → 2025-09-19; baseline finish 2025-03-07 → 2025-09-19 |
| 2287 | Service Management Go-Live | 2025-03-07 → 2025-09-19 (+196d) | 2025-03-07 → 2025-09-19 (+196d) |  |  | -3d → 5d |  | baseline start 2025-03-07 → 2025-09-19; baseline finish 2025-03-07 → 2025-09-19 |
| 2288 | Data Transfer Service (DTS) New Functionality Deployment | 2025-03-07 → 2025-09-19 (+196d) | 2025-03-07 → 2025-09-19 (+196d) |  |  | -3d → 5d |  | baseline start 2025-03-07 → 2025-09-19; baseline finish 2025-03-07 → 2025-09-19 |
| 2289 | Electricity Enquiry Service (EES) Deployment | 2025-03-07 → 2025-09-19 (+196d) | 2025-03-07 → 2025-09-19 (+196d) |  |  | -3d → 5d |  | baseline start 2025-03-07 → 2025-09-19; baseline finish 2025-03-07 → 2025-09-19 |
| 2290 | MPRS, UMSO Role, LDSO Role Operational | 2025-03-07 → 2025-09-19 (+196d) | 2025-03-07 → 2025-09-19 (+196d) |  |  | -3d → 5d |  | baseline start 2025-03-07 → 2025-09-19; baseline finish 2025-03-07 → 2025-09-19 |
| 2291 | Population of Domestic Premises Indicator | 2025-03-07 → 2025-09-19 (+196d) | 2025-03-07 → 2025-09-19 (+196d) |  |  | -3d → 5d |  | baseline start 2025-03-07 → 2025-09-19; baseline finish 2025-03-07 → 2025-09-19 |
| 2292 | Population of Market Segment | 2025-03-07 → 2025-09-19 (+196d) | 2025-03-07 → 2025-09-19 (+196d) |  |  | -3d → 5d |  | baseline start 2025-03-07 → 2025-09-19; baseline finish 2025-03-07 → 2025-09-19 |
| 2293 | Early Life Support Implemented | 2025-03-07 → 2025-09-19 (+196d) | 2025-03-07 → 2025-09-19 (+196d) |  |  | 0d → 8d | 2369FS+158d → 2308 | baseline start 2025-03-07 → 2025-09-19; baseline finish 2025-03-07 → 2025-09-19 |
| 2294 | MCC Tested and Ready to Operate | 2022-10-31 → 2025-04-14 (+896d) | 2022-10-31 → 2025-04-14 (+896d) |  |  | 615d → 112d | none → 2158 | baseline start 2025-03-07 → 2025-04-14; baseline finish 2025-03-07 → 2025-04-14 |
| 2295 | MCC Operational | 2022-10-31 → 2025-04-14 (+896d) | 2022-10-31 → 2025-04-14 (+896d) |  |  | 615d → 122d |  | baseline start 2025-03-07 → 2025-04-14; baseline finish 2025-03-07 → 2025-04-14 |
| 2296 | Central Systems live and Codes designated at 00:00 | 2025-03-10 → 2025-09-22 (+196d) | 2025-03-10 → 2025-09-22 (+196d) |  |  | -3d → 5d | 2285FS+1d, 2286FS+1d, 2287FS+1d, 2288FS+1d, 2289FS+1d, 2290FS+1d, 2291FS+1d, 2292FS+1d, 2269FS+1d → 2286FS+1d, 2287FS+1d, 2288FS+1d, 2289FS+1d, 2290FS+1d, 2291FS+1d, 2292FS+1d, 2269FS+1d | baseline start 2025-03-07 → 2025-09-22; baseline finish 2025-03-07 → 2025-09-22 |
| 2297 | SIT Participant Qualification - The final date by which participant qualification status can be confirmed for participants to be ready for the start of Migration at M11. | 2025-03-14 → 2025-09-26 (+196d) | 2025-03-14 → 2025-09-26 (+196d) |  |  | 11d → 16d |  | baseline start 2025-03-14 → 2025-09-26; baseline finish 2025-03-14 → 2025-09-26 |
| 2298 | **Cutover Governance M10** | 2025-02-26 → 2025-07-30 (+154d) | 2025-04-04 → 2025-09-24 (+173d) | 27d → 41d |  | 0d → 39d |  | was named Cutover Governance; baseline start 2025-02-26 → 2025-07-30; baseline finish 2025-04-04 → 2025-09-24 |
| 2299 | Confirmation that Pre-migration Data Cleanse Activities have successfully taken place | 2025-02-26 → 2025-07-30 (+154d) | 2025-02-26 → 2025-07-30 (+154d) |  |  | 2d → 41d | 2283 → none | constraint none → start no earlier than 2025-07-30; baseline start 2025-02-26 → 2025-07-30; baseline finish 2025-02-26 → 2025-07-30 |
| 2302 | Confirmation of Qualification Status for SIT MVC | 2025-03-03 → 2025-09-12 (+193d) | 2025-03-03 → 2025-09-12 (+193d) |  |  | -3d → 6d | 1356FS+16d → 1356FS+15d | baseline start 2025-03-03 → 2025-09-12; baseline finish 2025-03-03 → 2025-09-12 |
| 2303 | Confirmation of Qualification Status for Non-SIT LDSOs | 2025-03-03 → 2025-09-15 (+196d) | 2025-03-03 → 2025-09-15 (+196d) |  |  | -3d → 594d | 1614FS+6d → 2308FS-5d | baseline start 2025-03-03 → 2025-09-15; baseline finish 2025-03-03 → 2025-09-15 |
| 2304 | Confirmation of Qualification Status of at least one Supplier and their contracted Agents | 2025-03-03 → 2025-09-12 (+193d) | 2025-03-03 → 2025-09-12 (+193d) |  |  | -3d → 6d |  | baseline start 2025-03-03 → 2025-09-12; baseline finish 2025-03-03 → 2025-09-12 |
| 2305 | Declaration from all Central Services and LDSOs that they are in a position to move forwards | 2025-03-03 → 2025-09-15 (+196d) | 2025-03-03 → 2025-09-15 (+196d) |  |  | -1d → 594d | 1356, 1614FS+6d → 2308FS-5d, 1285, 1287 | baseline start 2025-03-03 → 2025-09-15; baseline finish 2025-03-03 → 2025-09-15 |
| 2307 | TORWG (Recommendation from TORWG that the Programme should enter M10) | 2025-03-05 → 2025-09-16 (+195d) | 2025-03-05 → 2025-09-16 (+195d) |  |  | -3d → 6d | 2299, 2302FS+2d, 2303FS+2d, 2304FS+2d, 2305 → 2299, 2302FS+2d, 2304FS+2d, 2281, 2282, 2390, 2300, 2301 | baseline start 2025-03-05 → 2025-09-16; baseline finish 2025-03-05 → 2025-09-16 |
| 2308 | MCAG (Confirm that the Programme can Enter M10) | 2025-03-07 → 2025-09-19 (+196d) | 2025-03-07 → 2025-09-19 (+196d) |  |  | -3d → 5d | 2281, 2282, 2307FS+2d → 2307FS+2d, 2396 | baseline start 2025-03-07 → 2025-09-19; baseline finish 2025-03-07 → 2025-09-19 |
| 2309 | Self-Declaration from all Central Services and LDSOs that Cutover activities have been successfully carried out | 2025-03-10 → 2025-09-22 (+196d) | 2025-03-10 → 2025-09-22 (+196d) |  |  | 0d → 5d |  | baseline start 2025-03-10 → 2025-09-22; baseline finish 2025-03-10 → 2025-09-22 |
| 2310 | Confirmation that DIP and ECS have been deployed, Service management is active, ISD has been populated | 2025-03-10 → 2025-09-22 (+196d) | 2025-03-10 → 2025-09-22 (+196d) |  |  | 0d → 5d |  | baseline start 2025-03-10 → 2025-09-22; baseline finish 2025-03-10 → 2025-09-22 |
| 2311 | Self-Declarations against all M10 Data Cleanse Activities | 2025-03-10 → 2025-09-22 (+196d) | 2025-03-10 → 2025-09-22 (+196d) |  |  | 0d → 5d |  | baseline start 2025-03-10 → 2025-09-22; baseline finish 2025-03-10 → 2025-09-22 |
| 2312 | IF-047 has been sent | 2025-03-10 → 2025-09-22 (+196d) | 2025-03-10 → 2025-09-22 (+196d) |  |  | 0d → 5d |  | baseline start 2025-03-10 → 2025-09-22; baseline finish 2025-03-10 → 2025-09-22 |
| 2313 | Recommendation from TORWG that PSG should approve M10 | 2025-03-11 → 2025-09-23 (+196d) | 2025-03-11 → 2025-09-23 (+196d) |  |  | 0d → 5d | 2309FS+1d, 2310FS+1d, 2311FS+1d, 2312FS+1d → 2309FS+1d, 2310FS+1d, 2311FS+1d, 2312FS+1d, 2394 | baseline start 2025-03-11 → 2025-09-23; baseline finish 2025-03-11 → 2025-09-23 |
| 2314 | PSG (OFGEM and PSG to Approve That Conditions of M10 and M13 Have Been Met) | 2025-03-12 → 2025-09-24 (+196d) | 2025-03-12 → 2025-09-24 (+196d) |  |  | 0d → 5d |  | baseline start 2025-03-12 → 2025-09-24; baseline finish 2025-03-12 → 2025-09-24 |
| 2316 | Confirmation of Qualified Parties from Code Bodies | 2025-03-14 → 2025-09-26 (+196d) | 2025-03-28 → 2025-10-10 (+196d) |  |  | 0d → 5d |  | baseline start 2025-03-14 → 2025-09-26; baseline finish 2025-03-28 → 2025-10-10 |
| 2317 | Self-Declaration that MHHS Functionality will be deployed to Production by Qualified parties | 2025-03-28 → 2025-10-10 (+196d) | 2025-03-28 → 2025-10-10 (+196d) |  |  | 0d → 5d |  | baseline start 2025-03-28 → 2025-10-10; baseline finish 2025-03-28 → 2025-10-10 |
| 2318 | Production Service Activation Activities have taken place | 2025-03-28 → 2025-10-10 (+196d) | 2025-03-28 → 2025-10-10 (+196d) |  |  | 0d → 5d |  | baseline start 2025-03-28 → 2025-10-10; baseline finish 2025-03-28 → 2025-10-10 |
| 2319 | TORWG (Confirmation of Qualified Parties from TORWG) | 2025-03-31 → 2025-10-13 (+196d) | 2025-03-31 → 2025-10-13 (+196d) |  |  | 0d → 5d | 2316FS+1d, 2317FS+1d, 2318FS+1d, 2297 → 2316FS+1d, 2317FS+1d, 2318FS+1d, 2297, 2391, 2395 | baseline start 2025-03-31 → 2025-10-13; baseline finish 2025-03-31 → 2025-10-13 |
| 2320 | MCAG (Provide recommendation to PSG on M11 decision) | 2025-04-02 → 2025-10-17 (+198d) | 2025-04-02 → 2025-10-17 (+198d) |  |  | 0d → 5d | 2319FS+2d → 2319FS+4d | baseline start 2025-04-02 → 2025-10-17; baseline finish 2025-04-02 → 2025-10-17 |
| 2321 | PSG (OFGEM and PSG Decision to Confirm M11 and M12) | 2025-04-04 → 2025-10-22 (+201d) | 2025-04-04 → 2025-10-22 (+201d) |  |  | 0d → 5d | 2320FS+2d → 2320FS+3d | baseline start 2025-04-04 → 2025-10-22; baseline finish 2025-04-04 → 2025-10-22 |
| 2322 | **UMS / Advanced Migration** | 2025-04-04 → 2025-10-23 (+202d) | 2026-10-02 → 2027-05-07 (+217d) | 391d → 402d |  | 1d → 0d |  | baseline start 2025-04-04 → 2025-10-23; baseline finish 2026-10-02 → 2027-05-07 |
| 2323 | SIT MVC UMS / Advanced Migration | 2025-04-04 → 2025-10-23 (+202d) | 2026-10-02 → 2027-04-22 (+202d) |  |  | 1d → 11d | SIT MVC Service Activation → 2396, 2352 | baseline start 2025-04-04 → 2025-10-23; baseline finish 2026-10-02 → 2027-04-22 |
| 2324 | SIT Non-MVC UMS / Advanced Migration | 2025-07-04 → 2026-01-02 (+182d) | 2026-10-02 → 2027-04-02 (+182d) |  |  | 1d → 25d | SIT Non-MVC Service Activation → 2417 | baseline start 2025-07-04 → 2026-01-02; baseline finish 2026-10-02 → 2027-04-02 |
| 2325 | Wave 1 UMS / Advanced Migration | 2025-10-03 → 2026-05-15 (+224d) | 2026-10-02 → 2027-04-30 (+210d) | 261d → 251d |  | 1d → 5d |  | baseline start 2025-10-03 → 2026-05-15; baseline finish 2026-10-02 → 2027-04-30 |
| 2326 | Wave 2 UMS / Advanced Migration | 2025-12-05 → 2026-07-01 (+208d) | 2026-10-02 → 2027-04-29 (+209d) | 216d → 217d |  | 1d → 6d |  | baseline start 2025-12-05 → 2026-07-01; baseline finish 2026-10-02 → 2027-04-29 |
| 2327 | Wave 3 UMS / Advanced Migration | 2026-01-23 → 2026-08-27 (+216d) | 2026-10-02 → 2027-05-07 (+217d) | 181d → 182d |  | 1d → 0d |  | baseline start 2026-01-23 → 2026-08-27; baseline finish 2026-10-02 → 2027-05-07 |
| 2328 | Wave 4 UMS / Advanced Migration | 2026-04-03 → 2026-10-23 (+203d) | 2026-10-02 → 2027-04-30 (+210d) | 131d → 136d |  | 1d → 5d |  | baseline start 2026-04-03 → 2026-10-23; baseline finish 2026-10-02 → 2027-04-30 |
| 2329 | **Smart / Non-Smart Migration** | 2025-04-04 → 2025-10-23 (+202d) | 2026-10-02 → 2027-05-07 (+217d) | 391d → 402d |  | 1d → 0d |  | baseline start 2025-04-04 → 2025-10-23; baseline finish 2026-10-02 → 2027-05-07 |
| 2330 | SIT MVC Smart / Non-Smart Migration | 2025-04-04 → 2025-10-23 (+202d) | 2026-10-02 → 2027-04-22 (+202d) |  |  | 1d → 11d | SIT MVC Service Activation → 2396, 2352 | baseline start 2025-04-04 → 2025-10-23; baseline finish 2026-10-02 → 2027-04-22 |

| ID | Task | Start | Finish | Duration | Complete | Total float | Predecessors | Other |
| --- | --- | --- | --- | --- | --- | --- | --- | --- |
| 2331 | SIT Non-MVC Smart / Non-Smart Migration | 2025-07-04 → 2026-01-02 (+182d) | 2026-10-02 → 2027-04-02 (+182d) |  |  | 1d → 25d | SIT Non-MVC Service Activation → 2417 | baseline start 2025-07-04 → 2026-01-02; baseline finish 2026-10-02 → 2027-04-02 |
| 2332 | Wave 1 Smart / Non-Smart Migration | 2025-10-03 → 2026-05-15 (+224d) | 2026-10-02 → 2027-04-30 (+210d) | 261d → 251d |  | 1d → 5d |  | constraint none → start no earlier than 2025-10-03; baseline start 2025-10-03 → 2026-05-15; baseline finish 2026-10-02 → 2027-04-30 |
| 2333 | Wave 2 Smart / Non-Smart Migration | 2025-12-05 → 2026-07-01 (+208d) | 2026-10-02 → 2027-04-29 (+209d) | 216d → 217d |  | 1d → 6d |  | baseline start 2025-12-05 → 2026-07-01; baseline finish 2026-10-02 → 2027-04-29 |
| 2334 | Wave 3 Smart / Non-Smart Migration | 2026-01-23 → 2026-08-27 (+216d) | 2026-10-02 → 2027-05-07 (+217d) | 181d → 182d |  | 1d → 0d |  | baseline start 2026-01-23 → 2026-08-27; baseline finish 2026-10-02 → 2027-05-07 |
| 2335 | Wave 4 Smart / Non-Smart Migration | 2026-04-03 → 2026-10-23 (+203d) | 2026-10-02 → 2027-04-30 (+210d) | 131d → 136d |  | 1d → 4d |  | baseline start 2026-04-03 → 2026-10-23; baseline finish 2026-10-02 → 2027-04-30 |
| 2336 | **External Programme Dependency Management** |  | 2025-07-23 → 2025-08-29 (+37d) | 713d → 740d |  | 482d → 604d |  | baseline finish 2025-12-30 → 2025-08-29 |
| 2337 | **BSC Mod P432 & REC CP R0015** |  |  |  |  |  |  | baseline finish 2025-12-30 → 2024-04-30 |
| 2338 | MHHSP engagement with BSCCo until Ofgem decision |  |  |  |  |  |  | baseline finish 2024-05-10 → 2024-01-15 |
| 2339 | Monitor progress and await implementation date |  |  |  |  |  |  | baseline start 2023-07-03 → 2024-01-16; baseline finish 2025-12-30 → 2024-04-30 |
| 2346 | **DCC System Capacity Upgrade** | 2025-01-08 → 2025-07-28 (+201d) | 2025-02-11 → 2025-08-29 (+199d) |  |  | 598d → 604d |  | baseline start 2025-01-13 → 2025-07-28; baseline finish 2025-02-14 → 2025-08-29 |
| 2347 | Assurance of DCC capacity upgrade to ensure suitability to support migration | 2025-01-08 → 2025-07-28 (+201d) | 2025-02-04 → 2025-08-22 (+199d) |  |  | 598d → 604d |  | baseline start 2025-01-13 → 2025-07-28; baseline finish 2025-02-07 → 2025-08-22 |
| 2348 | DCC Capacity Upgrade Operational | 2025-02-11 → 2025-08-29 (+199d) | 2025-02-11 → 2025-08-29 (+199d) |  |  | 598d → 604d |  | baseline start 2025-02-14 → 2025-08-29; baseline finish 2025-02-14 → 2025-08-29 |
| 2349 | **Migration - Tier 1 Milestones** | 2025-03-07 → 2025-09-24 (+201d) | 2027-01-04 → 2027-08-09 (+217d) | 476d → 488d |  | 0d → 25d |  | baseline start 2025-03-07 → 2025-09-24; baseline finish 2027-01-05 → 2027-08-09 |
| 2350 | Load Shaping Service switched on (M13) | 2025-03-07 → 2025-09-24 (+201d) | 2025-03-07 → 2025-09-24 (+201d) |  |  | 20d → 25d |  | baseline start 2025-03-07 → 2025-09-24; baseline finish 2025-03-07 → 2025-09-24 |
| 2351 | Load Shaping Service switched on (M13*) - Late Exit | 2025-06-06 → 2025-12-24 (+201d) | 2025-06-06 → 2025-12-24 (+201d) |  |  | 515d → 521d |  | baseline start 2025-06-06 → 2025-12-24; baseline finish 2025-06-06 → 2025-12-24 |
| 2352 | Start of 18-month migration for UMS / Advanced (M11) | 2025-04-04 → 2025-10-22 (+201d) | 2025-04-04 → 2025-10-22 (+201d) |  |  | 0d → 5d | 1493FS+15d, 2350, SIT MVC Service Activation, 2320, 2321 → 2350, 2320, 2321, 2396, 1493FS+20d | baseline start 2025-04-04 → 2025-10-22; baseline finish 2025-04-04 → 2025-10-22 |
| 2353 | Start of 18-month migration for UMS / Advanced (M11*) - Late Exit | 2025-07-04 → 2026-01-21 (+201d) | 2025-07-04 → 2026-01-21 (+201d) |  |  | 495d → 501d |  | baseline start 2025-07-04 → 2026-01-21; baseline finish 2025-07-04 → 2026-01-21 |
| 2354 | Start of 18-month migration for Smart / Non-smart (M12) | 2025-04-04 → 2025-10-22 (+201d) | 2025-04-04 → 2025-10-22 (+201d) |  |  | 495d → 501d |  | baseline start 2025-04-04 → 2025-10-22; baseline finish 2025-04-04 → 2025-10-22 |
| 2355 | Start of 18-month migration for Smart / Non-smart (M12*) - Late Exit | 2025-07-04 → 2026-01-21 (+201d) | 2025-07-04 → 2026-01-21 (+201d) |  |  | 495d → 501d |  | baseline start 2025-07-04 → 2026-01-21; baseline finish 2025-07-04 → 2026-01-21 |
| 2356 | Full transition complete (M15) | 2026-10-02 → 2027-05-07 (+217d) | 2026-10-02 → 2027-05-07 (+217d) |  |  | 1d → 0d | 2323, 2324, 2325, 2326, 2327, 2328, 2330, 2331, 2332, 2333, 2334, 2335, Approval of M15/M16 cut-over plan → 2323, 2324, 2325, 2326, 2327, 2328, 2330, 2331, 2332, 2333, 2334, 2335FS+1d | baseline start 2026-10-05 → 2027-05-07; baseline finish 2026-10-05 → 2027-05-07 |
| 2357 | Full transition complete (M15*) - Late Exit | 2027-01-04 → 2027-08-09 (+217d) | 2027-01-04 → 2027-08-09 (+217d) |  |  | 104d → 98d |  | baseline start 2027-01-05 → 2027-08-09; baseline finish 2027-01-05 → 2027-08-09 |
| 2358 | **BUSINESS & OPERATIONAL READINESS** |  | 2027-05-28 → 2027-12-23 (+209d) | 1195d → 1344d? | 8% → 6% |  |  | baseline start 2023-09-19 → 2022-10-31; baseline finish 2027-05-28 → 2027-12-23 |
| 2359 | **Service Management** |  | 2026-12-04 → 2027-06-24 (+202d) | 839d → 983d |  | 125d → 130d |  | baseline finish 2026-12-07 → 2027-06-24 |
| 2370 | **Service Management Arrangements Implementation** | 2025-03-10 → 2025-09-25 (+199d) | 2026-12-04 → 2027-06-24 (+202d) | 455d → 456d |  | 125d → 130d |  | baseline start 2025-03-13 → 2025-09-25; baseline finish 2026-12-07 → 2027-06-24 |
| 2371 | Hypercare post M10 | 2025-03-10 → 2025-09-25 (+199d) | 2025-06-27 → 2026-01-14 (+201d) |  |  | 500d → 506d |  | baseline start 2025-03-13 → 2025-09-25; baseline finish 2025-07-02 → 2026-01-14 |
| 2372 | Monitor Elexon implementation of Service Management arrangements | 2025-04-04 → 2025-10-23 (+202d) | 2026-12-04 → 2027-06-24 (+202d) |  |  | 125d → 130d |  | baseline start 2025-04-07 → 2025-10-23; baseline finish 2026-12-07 → 2027-06-24 |
| 2373 | **Service Activation** |  | 2026-04-02 → 2026-10-22 (+203d) | 894d → 1039d? |  | 301d → 305d |  | baseline start 2025-02-24 → 2022-10-31; baseline finish 2026-04-02 → 2026-10-22 |
| 2386 | MHHSP Confirms SIT MVC PPs MHHS Enabled | 2022-10-31 → 2025-04-15 (+897d) | 2022-10-31 → 2025-04-15 (+897d) |  |  | 610d → 112d | none → 2294 | baseline start none → 2025-04-15; baseline finish none → 2025-04-15 |
| 2410 | Helix Preparatory Activities Complete |  |  |  |  | 1195d → 1344d |  | baseline start none → 2022-10-31; baseline finish none → 2022-10-31 |
| 2411 | MHHSP Confirms SIT Non-MVC PPs MHHS Enabled |  |  |  |  | 675d → 845d |  | baseline start none → 2022-10-31; baseline finish none → 2022-10-31 |
| 2431 | Helix Preparatory Activities Complete |  |  |  |  | 1195d → 1344d |  | baseline start none → 2022-10-31; baseline finish none → 2022-10-31 |
| 2432 | MHHSP Confirms Wave 1 PPs MHHS Enabled |  |  |  |  | 740d → 904d |  | baseline start none → 2022-10-31; baseline finish none → 2022-10-31 |
| 2433 | Wave 1 Service Activation | 2025-09-01 → 2026-04-13 (+224d) | 2025-10-02 → 2026-05-14 (+224d) |  |  | 1d → 5d |  | baseline start 2025-08-29 → 2026-04-13; baseline finish 2025-10-02 → 2026-05-14 |
| 2455 | Helix Preparatory Activities Complete |  |  |  |  | 1195d → 1344d |  | baseline start none → 2022-10-31; baseline finish none → 2022-10-31 |
| 2456 | MHHSP Confirms Wave 2 PPs MHHS Enabled |  |  |  |  | 785d → 938d |  | baseline start none → 2022-10-31; baseline finish none → 2022-10-31 |
| 2457 | Wave 2 Service Activation | 2025-11-03 → 2026-05-28 (+206d) | 2025-12-04 → 2026-06-30 (+208d) |  |  | 1d → 6d |  | baseline start 2025-10-31 → 2026-05-28; baseline finish 2025-12-04 → 2026-06-30 |
| 2479 | Helix Preparatory Activities Complete |  |  |  |  | 1195d → 1344d |  | baseline start none → 2022-10-31; baseline finish none → 2022-10-31 |
| 2480 | MHHSP Confirms Wave 3 PPs MHHS Enabled |  |  |  |  | 820d → 973d |  | baseline start none → 2022-10-31; baseline finish none → 2022-10-31 |
| 2481 | Wave 3 Service Activation | 2025-12-22 → 2026-07-24 (+214d) | 2026-01-22 → 2026-08-26 (+216d) |  |  | 1d → 0d |  | baseline start 2025-12-19 → 2026-07-24; baseline finish 2026-01-22 → 2026-08-26 |
| 2503 | Helix Preparatory Activities Complete |  |  |  |  | 1195d → 1344d |  | baseline start none → 2022-10-31; baseline finish none → 2022-10-31 |
| 2504 | MHHSP Confirms Wave 4 PPs MHHS Enabled |  |  |  |  | 870d → 1018d |  | baseline start none → 2022-10-31; baseline finish none → 2022-10-31 |
| 2505 | Wave 4 Service Activation | 2026-03-02 → 2026-09-21 (+203d) | 2026-04-02 → 2026-10-22 (+203d) |  |  | 1d → 4d |  | baseline start 2026-02-27 → 2026-09-21; baseline finish 2026-04-02 → 2026-10-22 |
| 2537 | Helix Preparatory Activities Complete |  |  |  |  | 1195d → 1344d |  | baseline start none → 2022-10-31; baseline finish none → 2022-10-31 |
| 2538 | MHHSP Confirms Non-SIT LDSO PPs MHHS Enabled |  |  |  |  | 605d → 756d |  | baseline start none → 2022-10-31; baseline finish none → 2022-10-31 |
| 2539 | Non-SIT LDSO Service Activation | 2025-02-24 → 2025-08-25 (+182d) | 2025-03-06 → 2025-09-01 (+179d) | 9d → 6d |  | 1d → 22d |  | baseline start 2025-02-24 → 2025-08-25; baseline finish 2025-03-06 → 2025-09-01 |
| 2562 | **Business Continuity and Disaster Recovery Plan** | 2025-01-13 → 2025-07-31 (+199d) | 2025-03-07 → 2025-09-24 (+201d) |  |  | 580d → 586d |  | baseline start 2025-01-13 → 2025-07-31; baseline finish 2025-03-07 → 2025-09-24 |
| 2563 | Central Parties BCDRs in Place | 2025-01-13 → 2025-07-31 (+199d) | 2025-02-07 → 2025-08-27 (+201d) |  |  | 580d → 586d |  | baseline start 2025-01-13 → 2025-07-31; baseline finish 2025-02-07 → 2025-08-27 |
| 2564 | Risk Based Assurance of Cental Party BCDRs | 2025-02-10 → 2025-08-28 (+199d) | 2025-03-07 → 2025-09-24 (+201d) |  |  | 580d → 586d |  | baseline start 2025-02-10 → 2025-08-28; baseline finish 2025-03-07 → 2025-09-24 |
| 2565 | **Training and Support Materials** | 2025-02-03 → 2025-08-21 (+199d) | 2025-03-27 → 2025-10-14 (+201d) |  |  | 566d → 572d |  | baseline start 2025-02-03 → 2025-08-21; baseline finish 2025-03-28 → 2025-10-14 |
| 2566 | Develop document | 2025-02-03 → 2025-08-21 (+199d) | 2025-02-28 → 2025-09-17 (+201d) |  |  | 566d → 572d |  | baseline start 2025-02-03 → 2025-08-21; baseline finish 2025-02-28 → 2025-09-17 |
| 2567 | Document review and update | 2025-03-03 → 2025-09-18 (+199d) | 2025-03-27 → 2025-10-14 (+201d) |  |  | 566d → 572d |  | baseline start 2025-03-03 → 2025-09-18; baseline finish 2025-03-28 → 2025-10-14 |
| 2568 | Training and Support Materials approved | 2025-03-27 → 2025-10-14 (+201d) | 2025-03-27 → 2025-10-14 (+201d) |  |  | 566d → 572d |  | baseline start 2025-03-28 → 2025-10-14; baseline finish 2025-03-28 → 2025-10-14 |
| 2576 | **Transition to New Settlement Timetable (M16)** | 2025-04-04 → 2025-10-22 (+201d) | 2027-05-28 → 2027-12-23 (+209d) | 560d → 566d |  |  |  | baseline start 2025-04-04 → 2025-10-22; baseline finish 2027-05-28 → 2027-12-23 |
| 2577 | Elexon to produce Settlement Calendar for Settlement Year 2025/2026 | 2025-04-04 → 2025-10-22 (+201d) | 2025-04-04 → 2025-10-22 (+201d) |  |  | 0d → 5d |  | baseline start 2025-04-04 → 2025-10-22; baseline finish 2025-04-04 → 2025-10-22 |
| 2578 | Elexon monitor settlement data of migrated MPANs | 2025-04-07 → 2025-10-23 (+199d) | 2026-12-07 → 2027-06-24 (+199d) |  |  | 0d → 6d |  | baseline start 2025-04-07 → 2025-10-23; baseline finish 2026-12-07 → 2027-06-24 |
| 2579 | M16 Checkpoint 1 | 2025-12-08 → 2026-06-25 (+199d) | 2025-12-08 → 2026-06-25 (+199d) |  |  | 0d → 5d |  | baseline start 2025-12-08 → 2026-06-25; baseline finish 2025-12-08 → 2026-06-25 |
| 2580 | Confirm if M16 date retained as 07/12/2026 | 2026-01-05 → 2026-07-23 (+199d) | 2026-01-05 → 2026-07-23 (+199d) |  |  | 0d → 5d |  | baseline start 2026-01-05 → 2026-07-23; baseline finish 2026-01-05 → 2026-07-23 |
| 2581 | Readiness assessment of participants' readiness to transition to new Settlement Timetable | 2026-02-02 → 2026-08-20 (+199d) | 2026-02-02 → 2026-08-20 (+199d) |  |  | 0d → 5d |  | baseline start 2026-02-02 → 2026-08-20; baseline finish 2026-02-02 → 2026-08-20 |
| 2582 | Elexon to produce Settlement Calendar for Settlement Year 2026 up until day before M16 cutover | 2026-04-01 → 2026-10-19 (+201d) | 2026-04-01 → 2026-10-19 (+201d) |  |  | 0d → 5d |  | baseline start 2026-04-01 → 2026-10-19; baseline finish 2026-04-01 → 2026-10-19 |
| 2583 | M16 Checkpoint 2 | 2026-09-15 → 2027-04-02 (+199d) | 2026-09-15 → 2027-04-02 (+199d) |  |  | 0d → 5d |  | baseline start 2026-09-15 → 2027-04-02; baseline finish 2026-09-15 → 2027-04-02 |
| 2584 | Readiness assessment of participants' readiness to transition to new Settlement Timetable | 2026-09-30 → 2027-04-19 (+201d) | 2026-09-30 → 2027-04-19 (+201d) |  |  | 0d → 5d |  | baseline start 2026-09-30 → 2027-04-19; baseline finish 2026-09-30 → 2027-04-19 |
| 2585 | Confirm M16 Date | 2026-10-13 → 2027-04-30 (+199d) | 2026-10-13 → 2027-04-30 (+199d) |  |  | 0d → 5d |  | baseline start 2026-10-13 → 2027-04-30; baseline finish 2026-10-13 → 2027-04-30 |
| 2586 | Raise fast track change to ISD (November publish) | 2026-10-13 → 2027-04-30 (+199d) | 2026-10-13 → 2027-04-30 (+199d) |  |  | 39d → 45d |  | baseline start 2026-10-13 → 2027-04-30; baseline finish 2026-10-13 → 2027-04-30 |
| 2587 | **M16 Approval Window** | 2026-12-07 → 2027-06-25 (+200d) | 2027-05-28 → 2027-12-23 (+209d) | 124d → 129d |  |  |  | baseline start 2026-12-07 → 2027-06-25; baseline finish 2027-05-28 → 2027-12-23 |
| 2588 | Panel approval that M16 criteria met | 2026-12-07 → 2027-06-25 (+200d) | 2026-12-07 → 2027-06-25 (+200d) |  |  | 0d → 5d | 2585FS+39d → 2585FS+40d | baseline start 2026-12-07 → 2027-06-25; baseline finish 2026-12-07 → 2027-06-25 |
| 2589 | Cut over to new settlement timetable (M16) | 2026-12-07 → 2027-07-02 (+207d) | 2026-12-07 → 2027-07-02 (+207d) |  |  |  | 2588, 2356FS+45d, 2578, 2586, 2266 → 2588, 2356FS+40d, 2578, 2586, 2266 | baseline start 2026-12-07 → 2027-07-02; baseline finish 2026-12-07 → 2027-07-02 |
| 2590 | Maximum 6-month window for approval of M16 | 2026-12-08 → 2027-07-05 (+209d) | 2027-05-28 → 2027-12-23 (+209d) |  |  |  |  | baseline start 2026-12-08 → 2027-07-05; baseline finish 2027-05-28 → 2027-12-23 |
| 2591 | Cut over to new settlement timetable (M16*) - Late Exit | 2027-05-28 → 2027-12-23 (+209d) | 2027-05-28 → 2027-12-23 (+209d) |  |  |  |  | baseline start 2027-05-28 → 2027-12-23; baseline finish 2027-05-28 → 2027-12-23 |
| 2592 | **EARLY LIVE RUNNING** | 2026-10-05 → 2027-05-10 (+217d) | 2026-12-04 → 2027-07-09 (+217d) |  |  | 125d → 119d |  | baseline start 2024-01-02 → 2027-05-10; baseline finish 2027-05-28 → 2027-07-09 |
| 2593 | **Early Live Running Stabilisation Period** | 2026-10-05 → 2027-05-10 (+217d) | 2026-12-04 → 2027-07-09 (+217d) |  |  | 125d → 119d |  | baseline start 2026-10-06 → 2027-05-10; baseline finish 2026-12-07 → 2027-07-09 |

| ID | Task | Start | Finish | Duration | Total float | Predecessors | Other |
| --- | --- | --- | --- | --- | --- | --- | --- |
| 2594 | Manage Early Live Running stabilisation period | 2026-10-05 → 2027-05-10 (+217d) | 2026-12-04 → 2027-07-09 (+217d) |  | 125d → 119d |  | baseline start 2026-10-06 → 2027-05-10; baseline finish 2026-12-07 → 2027-07-09 |
| 2595 | Monitor Early Live Running stabilisation period | 2026-10-05 → 2027-05-10 (+217d) | 2026-12-04 → 2027-07-09 (+217d) |  | 125d → 119d |  | baseline start 2026-10-06 → 2027-05-10; baseline finish 2026-12-07 → 2027-07-09 |
| 2596 | **PROGRAMME CLOSURE** | 2026-08-03 → 2027-03-08 (+217d) | 2026-11-30 → 2027-06-25 (+207d) | 86d → 80d |  |  | baseline start 2026-08-04 → 2027-03-08; baseline finish 2026-11-30 → 2027-06-25 |
| 2597 | **Handover Pack** | 2026-08-03 → 2027-03-08 (+217d) | 2026-11-30 → 2027-06-25 (+207d) | 86d → 80d |  |  | baseline start 2026-08-04 → 2027-03-08; baseline finish 2026-11-30 → 2027-06-25 |
| 2598 | **Draft Handover Pack (for M15)** | 2026-08-03 → 2027-03-08 (+217d) | 2026-09-25 → 2027-04-30 (+217d) |  | 175d → 169d |  | baseline start 2026-08-04 → 2027-03-08; baseline finish 2026-09-28 → 2027-04-30 |
| 2599 | Develop document | 2026-08-03 → 2027-03-08 (+217d) | 2026-08-28 → 2027-04-02 (+217d) |  | 175d → 169d |  | baseline start 2026-08-04 → 2027-03-08; baseline finish 2026-08-31 → 2027-04-02 |
| 2600 | Document review and update | 2026-08-31 → 2027-04-05 (+217d) | 2026-09-25 → 2027-04-30 (+217d) |  | 175d → 169d |  | baseline start 2026-09-01 → 2027-04-05; baseline finish 2026-09-28 → 2027-04-30 |
| 2601 | Draft Handover Pack approved | 2026-09-25 → 2027-04-30 (+217d) | 2026-09-25 → 2027-04-30 (+217d) |  | 175d → 169d |  | baseline start 2026-09-28 → 2027-04-30; baseline finish 2026-09-28 → 2027-04-30 |
| 2602 | **Master Handover Pack (for M16)** | 2026-10-06 → 2027-05-03 (+209d) | 2026-11-30 → 2027-06-25 (+207d) |  |  |  | baseline start 2026-10-06 → 2027-05-03; baseline finish 2026-11-30 → 2027-06-25 |
| 2603 | Update document | 2026-10-06 → 2027-05-03 (+209d) | 2026-11-02 → 2027-05-28 (+207d) |  |  |  | baseline start 2026-10-06 → 2027-05-03; baseline finish 2026-11-02 → 2027-05-28 |
| 2604 | Document review and update | 2026-11-03 → 2027-05-31 (+209d) | 2026-11-30 → 2027-06-25 (+207d) |  |  |  | baseline start 2026-11-03 → 2027-05-31; baseline finish 2026-11-30 → 2027-06-25 |
| 2605 | Master Handover Pack approved | 2026-11-30 → 2027-06-25 (+207d) | 2026-11-30 → 2027-06-25 (+207d) |  |  |  | baseline start 2026-11-30 → 2027-06-25; baseline finish 2026-11-30 → 2027-06-25 |
| 2606 | **Programme Lessons Learned** | 2026-08-03 → 2027-03-08 (+217d) | 2026-09-25 → 2027-04-30 (+217d) |  | 175d → 169d |  | baseline start 2026-08-04 → 2027-03-08; baseline finish 2026-09-28 → 2027-04-30 |
| 2607 | Develop document | 2026-08-03 → 2027-03-08 (+217d) | 2026-08-28 → 2027-04-02 (+217d) |  | 175d → 169d |  | baseline start 2026-08-04 → 2027-03-08; baseline finish 2026-08-31 → 2027-04-02 |
| 2608 | Document review and update | 2026-08-31 → 2027-04-05 (+217d) | 2026-09-25 → 2027-04-30 (+217d) |  | 175d → 169d |  | baseline start 2026-09-01 → 2027-04-05; baseline finish 2026-09-28 → 2027-04-30 |
| 2609 | Programme Lessons Learned document approved | 2026-09-25 → 2027-04-30 (+217d) | 2026-09-25 → 2027-04-30 (+217d) |  | 175d → 169d |  | baseline start 2026-09-28 → 2027-04-30; baseline finish 2026-09-28 → 2027-04-30 |
| 2610 | **Programme Closure Report** | 2026-08-03 → 2027-03-08 (+217d) | 2026-09-25 → 2027-04-30 (+217d) |  | 175d → 169d |  | baseline start 2026-08-04 → 2027-03-08; baseline finish 2026-09-28 → 2027-04-30 |
| 2611 | Develop document | 2026-08-03 → 2027-03-08 (+217d) | 2026-08-28 → 2027-04-02 (+217d) |  | 175d → 169d |  | baseline start 2026-08-04 → 2027-03-08; baseline finish 2026-08-31 → 2027-04-02 |
| 2612 | Document review and update | 2026-08-31 → 2027-04-05 (+217d) | 2026-09-25 → 2027-04-30 (+217d) |  | 175d → 169d |  | baseline start 2026-09-01 → 2027-04-05; baseline finish 2026-09-28 → 2027-04-30 |
| 2613 | Programme Closure Report approved | 2026-09-25 → 2027-04-30 (+217d) | 2026-09-25 → 2027-04-30 (+217d) |  | 175d → 169d |  | baseline start 2026-09-28 → 2027-04-30; baseline finish 2026-09-28 → 2027-04-30 |
| 2614 | **Benefit Realisation Report** | 2026-08-03 → 2027-03-08 (+217d) | 2026-10-02 → 2027-05-07 (+217d) |  | 170d → 164d |  | baseline start 2026-08-04 → 2027-03-08; baseline finish 2026-10-05 → 2027-05-07 |
| 2615 | Develop document | 2026-08-03 → 2027-03-08 (+217d) | 2026-08-28 → 2027-04-02 (+217d) |  | 170d → 164d |  | baseline start 2026-08-04 → 2027-03-08; baseline finish 2026-08-31 → 2027-04-02 |
| 2616 | Document review and update | 2026-08-31 → 2027-04-05 (+217d) | 2026-09-25 → 2027-04-30 (+217d) |  | 170d → 164d |  | baseline start 2026-09-01 → 2027-04-05; baseline finish 2026-09-28 → 2027-04-30 |
| 2617 | Benefit Realisation Report approved | 2026-10-02 → 2027-05-07 (+217d) | 2026-10-02 → 2027-05-07 (+217d) |  | 170d → 164d |  | baseline start 2026-10-05 → 2027-05-07; baseline finish 2026-10-05 → 2027-05-07 |
| 2618 | **Operating Model Gap Review with recommendations** | 2026-08-03 → 2027-03-08 (+217d) | 2026-10-02 → 2027-05-07 (+217d) |  | 170d → 164d |  | baseline start 2026-08-04 → 2027-03-08; baseline finish 2026-10-05 → 2027-05-07 |
| 2619 | Develop document | 2026-08-03 → 2027-03-08 (+217d) | 2026-08-28 → 2027-04-02 (+217d) |  | 170d → 164d |  | baseline start 2026-08-04 → 2027-03-08; baseline finish 2026-08-31 → 2027-04-02 |
| 2620 | Document review and update | 2026-08-31 → 2027-04-05 (+217d) | 2026-09-25 → 2027-04-30 (+217d) |  | 170d → 164d |  | baseline start 2026-09-01 → 2027-04-05; baseline finish 2026-09-28 → 2027-04-30 |
| 2621 | Operating Model Gap Review with recommendations approved | 2026-10-02 → 2027-05-07 (+217d) | 2026-10-02 → 2027-05-07 (+217d) |  | 170d → 164d |  | baseline start 2026-10-05 → 2027-05-07; baseline finish 2026-10-05 → 2027-05-07 |
| 2622 | **Post-Implementation Review** | 2026-08-03 → 2027-03-08 (+217d) | 2026-10-02 → 2027-05-07 (+217d) |  | 170d → 164d |  | baseline start 2026-08-04 → 2027-03-08; baseline finish 2026-10-05 → 2027-05-07 |
| 2623 | Develop document | 2026-08-03 → 2027-03-08 (+217d) | 2026-08-28 → 2027-04-02 (+217d) |  | 170d → 164d |  | baseline start 2026-08-04 → 2027-03-08; baseline finish 2026-08-31 → 2027-04-02 |
| 2624 | Document review and update | 2026-08-31 → 2027-04-05 (+217d) | 2026-09-25 → 2027-04-30 (+217d) |  | 170d → 164d |  | baseline start 2026-09-01 → 2027-04-05; baseline finish 2026-09-28 → 2027-04-30 |
| 2625 | Post-Implementation Review approved | 2026-10-02 → 2027-05-07 (+217d) | 2026-10-02 → 2027-05-07 (+217d) |  | 170d → 164d |  | baseline start 2026-10-05 → 2027-05-07; baseline finish 2026-10-05 → 2027-05-07 |
| 2626 | **Reinforcement Guide** | 2026-08-03 → 2027-03-08 (+217d) | 2026-10-02 → 2027-05-07 (+217d) |  | 170d → 164d |  | baseline start 2026-08-04 → 2027-03-08; baseline finish 2026-10-05 → 2027-05-07 |
| 2627 | Develop document | 2026-08-03 → 2027-03-08 (+217d) | 2026-08-28 → 2027-04-02 (+217d) |  | 170d → 164d |  | baseline start 2026-08-04 → 2027-03-08; baseline finish 2026-08-31 → 2027-04-02 |
| 2628 | Document review and update | 2026-08-31 → 2027-04-05 (+217d) | 2026-09-25 → 2027-04-30 (+217d) |  | 170d → 164d |  | baseline start 2026-09-01 → 2027-04-05; baseline finish 2026-09-28 → 2027-04-30 |
| 2629 | Reinforcement Guide approved | 2026-10-02 → 2027-05-07 (+217d) | 2026-10-02 → 2027-05-07 (+217d) |  | 170d → 164d |  | baseline start 2026-10-05 → 2027-05-07; baseline finish 2026-10-05 → 2027-05-07 |
| 2630 | **Material and Licenses Transfer** | 2026-09-08 → 2027-04-05 (+209d) | 2026-11-30 → 2027-06-25 (+207d) |  |  |  | baseline start 2026-09-08 → 2027-04-05; baseline finish 2026-11-30 → 2027-06-25 |
| 2631 | Transfer of Programme material to Elexon and perpetual licenses as appropriate | 2026-09-08 → 2027-04-05 (+209d) | 2026-11-30 → 2027-06-25 (+207d) |  |  |  | baseline start 2026-09-08 → 2027-04-05; baseline finish 2026-11-30 → 2027-06-25 |
| 2632 | **READINESS ASSESSMENTS** |  | 2026-12-04 → 2027-06-17 (+195d) | 849d → 988d | 125d → 135d |  | baseline finish 2026-12-04 → 2027-06-17 |
| 2633 | **Readiness Assessment 3 - Design and Build Progress Check and CP2 Check** |  |  |  |  |  | baseline finish 2023-11-13 → 2023-11-27 |
| 2638 | Produce Readiness Assessment Reports (Overall Report & Individual Participant Reports) |  |  |  |  |  | baseline finish 2023-11-06 → 2023-11-20 |
| 2639 | Readiness Assessment 3 - Design & Build Checkpoint 1 - Completed (incl. Readiness Assessment Report approval) |  |  |  |  |  | baseline start 2023-11-13 → 2023-11-27; baseline finish 2023-11-13 → 2023-11-27 |
| 2640 | **Readiness Assessment 5 / 6 - Start of Qualification and Participant Readiness for M10 and M11 and CP3/CP4 check** | 2024-11-12 → 2025-04-21 (+160d) | 2025-01-15 → 2025-06-24 (+160d) |  | 0d → 652d |  | baseline start 2024-11-12 → 2025-04-21; baseline finish 2025-01-17 → 2025-06-24 |
| 2641 | Launch Readiness Assessment survey | 2024-11-12 → 2025-04-21 (+160d) | 2024-11-12 → 2025-04-21 (+160d) |  | 0d → 652d |  | constraint must start on 2024-11-12 → start no earlier than 2025-04-21; baseline start 2024-11-12 → 2025-04-21; baseline finish 2024-11-12 → 2025-04-21 |
| 2642 | PPs submit survey responses | 2024-11-12 → 2025-04-21 (+160d) | 2024-12-02 → 2025-05-09 (+158d) |  | 617d → 652d |  | baseline start 2024-11-12 → 2025-04-21; baseline finish 2024-12-02 → 2025-05-09 |
| 2643 | Analyse survey responses | 2024-12-03 → 2025-05-12 (+160d) | 2024-12-23 → 2025-05-30 (+158d) |  | 617d → 652d |  | baseline start 2024-12-03 → 2025-05-12; baseline finish 2024-12-23 → 2025-05-30 |
| 2644 | Conduct deep-dive interviews (sample of PPs) | 2024-12-03 → 2025-05-12 (+160d) | 2024-12-23 → 2025-05-30 (+158d) |  | 617d → 652d |  | baseline start 2024-12-03 → 2025-05-12; baseline finish 2024-12-23 → 2025-05-30 |
| 2645 | Produce Readiness Assessment Reports (Overall Report & Individual Participant Reports) | 2024-12-24 → 2025-06-02 (+160d) | 2025-01-13 → 2025-06-20 (+158d) |  | 617d → 652d |  | baseline start 2024-12-24 → 2025-06-02; baseline finish 2025-01-13 → 2025-06-20 |
| 2646 | Readiness Assessment 5 / 6 - Start of Qualification and Participant Readiness for M10 and M11 and CP3/CP4 check (incl. Readiness Assessment Report approval) Completed | 2025-01-15 → 2025-06-24 (+160d) | 2025-01-15 → 2025-06-24 (+160d) |  | 617d → 652d |  | baseline start 2025-01-17 → 2025-06-24; baseline finish 2025-01-17 → 2025-06-24 |
| 2647 | **Readiness Assessment 7 - Migration Checkpoint** | 2025-08-04 → 2026-01-12 (+161d) | 2025-10-09 → 2026-03-19 (+161d) |  | 0d → 460d |  | baseline start 2025-08-04 → 2026-01-12; baseline finish 2025-10-09 → 2026-03-19 |
| 2648 | Launch Readiness Assessment survey | 2025-08-04 → 2026-01-12 (+161d) | 2025-08-04 → 2026-01-12 (+161d) |  | 0d → 460d |  | constraint must start on 2025-08-04 → start no earlier than 2026-01-12; baseline start 2025-08-04 → 2026-01-12; baseline finish 2025-08-04 → 2026-01-12 |
| 2649 | PPs submit survey responses | 2025-08-04 → 2026-01-12 (+161d) | 2025-08-22 → 2026-01-30 (+161d) |  | 426d → 460d |  | baseline start 2025-08-04 → 2026-01-12; baseline finish 2025-08-22 → 2026-01-30 |
| 2650 | Analyse survey responses | 2025-08-25 → 2026-02-02 (+161d) | 2025-09-12 → 2026-02-20 (+161d) |  | 426d → 460d |  | baseline start 2025-08-25 → 2026-02-02; baseline finish 2025-09-12 → 2026-02-20 |
| 2651 | Conduct deep-dive interviews (sample of PPs) | 2025-08-25 → 2026-02-02 (+161d) | 2025-09-12 → 2026-02-20 (+161d) |  | 426d → 460d |  | baseline start 2025-08-25 → 2026-02-02; baseline finish 2025-09-12 → 2026-02-20 |
| 2652 | Produce Readiness Assessment Reports (Overall Report & Individual Participant Reports) | 2025-09-15 → 2026-02-23 (+161d) | 2025-10-03 → 2026-03-13 (+161d) |  | 426d → 460d |  | baseline start 2025-09-15 → 2026-02-23; baseline finish 2025-10-03 → 2026-03-13 |
| 2653 | Readiness Assessment 7 - Migration Checkpoint - Completed (incl. Readiness Assessment Report approval) | 2025-10-09 → 2026-03-19 (+161d) | 2025-10-09 → 2026-03-19 (+161d) |  | 426d → 460d |  | baseline start 2025-10-09 → 2026-03-19; baseline finish 2025-10-09 → 2026-03-19 |
| 2654 | **Readiness Assessment 8 - Ready to Accept New MPANs** | 2026-01-02 → 2026-08-06 (+216d) | 2026-03-11 → 2026-10-13 (+216d) |  | 317d → 312d |  | baseline start 2026-01-06 → 2026-08-06; baseline finish 2026-03-13 → 2026-10-13 |
| 2655 | Launch Readiness Assessment survey | 2026-01-02 → 2026-08-06 (+216d) | 2026-01-02 → 2026-08-06 (+216d) |  | 317d → 312d | 1968FS-50d → 1968FS-60d | baseline start 2026-01-06 → 2026-08-06; baseline finish 2026-01-06 → 2026-08-06 |
| 2656 | PPs submit survey responses | 2026-01-02 → 2026-08-06 (+216d) | 2026-01-22 → 2026-08-26 (+216d) |  | 317d → 312d |  | baseline start 2026-01-06 → 2026-08-06; baseline finish 2026-01-26 → 2026-08-26 |
| 2657 | Analyse survey responses | 2026-01-23 → 2026-08-27 (+216d) | 2026-02-12 → 2026-09-16 (+216d) |  | 317d → 312d |  | baseline start 2026-01-27 → 2026-08-27; baseline finish 2026-02-16 → 2026-09-16 |
| 2658 | Conduct deep-dive interviews (sample of PPs) | 2026-01-23 → 2026-08-27 (+216d) | 2026-02-12 → 2026-09-16 (+216d) |  | 317d → 312d |  | baseline start 2026-01-27 → 2026-08-27; baseline finish 2026-02-16 → 2026-09-16 |
| 2659 | Produce Readiness Assessment Reports (Overall Report & Individual Participant Reports) | 2026-02-13 → 2026-09-17 (+216d) | 2026-03-05 → 2026-10-07 (+216d) |  | 317d → 312d |  | baseline start 2026-02-17 → 2026-09-17; baseline finish 2026-03-09 → 2026-10-07 |
| 2660 | Readiness Assessment 8 - Ready to Accept New MPANs - Completed (incl. Readiness Assessment Report approval) | 2026-03-11 → 2026-10-13 (+216d) | 2026-03-11 → 2026-10-13 (+216d) |  | 317d → 312d |  | baseline start 2026-03-13 → 2026-10-13; baseline finish 2026-03-13 → 2026-10-13 |
| 2661 | **Readiness Assessment 9 - Ready for New Settlement Timetable and CP5 Check** | 2026-09-29 → 2027-04-12 (+195d) | 2026-12-04 → 2027-06-17 (+195d) |  | 125d → 135d |  | baseline start 2026-09-29 → 2027-04-12; baseline finish 2026-12-04 → 2027-06-17 |
| 2662 | Launch Readiness Assessment survey | 2026-09-29 → 2027-04-12 (+195d) | 2026-09-29 → 2027-04-12 (+195d) |  | 125d → 135d | 2589FS-50d → 2589FS-60d | baseline start 2026-09-29 → 2027-04-12; baseline finish 2026-09-29 → 2027-04-12 |
| 2663 | PPs submit survey responses | 2026-09-29 → 2027-04-12 (+195d) | 2026-10-19 → 2027-04-30 (+193d) |  | 125d → 135d |  | baseline start 2026-09-29 → 2027-04-12; baseline finish 2026-10-19 → 2027-04-30 |
| 2664 | Analyse survey responses | 2026-10-20 → 2027-05-03 (+195d) | 2026-11-09 → 2027-05-21 (+193d) |  | 125d → 135d |  | baseline start 2026-10-20 → 2027-05-03; baseline finish 2026-11-09 → 2027-05-21 |
| 2665 | Conduct deep-dive interviews (sample of PPs) | 2026-10-20 → 2027-05-03 (+195d) | 2026-11-09 → 2027-05-21 (+193d) |  | 125d → 135d |  | baseline start 2026-10-20 → 2027-05-03; baseline finish 2026-11-09 → 2027-05-21 |
| 2666 | Produce Readiness Assessment Reports (Overall Report & Individual Participant Reports) | 2026-11-10 → 2027-05-24 (+195d) | 2026-11-30 → 2027-06-11 (+193d) |  | 125d → 135d |  | baseline start 2026-11-10 → 2027-05-24; baseline finish 2026-11-30 → 2027-06-11 |
| 2667 | Readiness Assessment 9 - Readiness for New Settlement Timetable - Completed (incl. Readiness Assessment Report approval) | 2026-12-04 → 2027-06-17 (+195d) | 2026-12-04 → 2027-06-17 (+195d) |  | 125d → 135d |  | baseline start 2026-12-04 → 2027-06-17; baseline finish 2026-12-04 → 2027-06-17 |

| ID | Task | Start | Finish | Duration | Total float | Predecessors | Other |
| --- | --- | --- | --- | --- | --- | --- | --- |
| 2668 | **Readiness Assessments - Tier 1 Milestones** | 2025-04-04 → 2025-06-24 (+81d) | 2026-12-04 → 2027-06-17 (+195d) | 435d → 517d | 125d → 135d |  | baseline start 2023-11-13 → 2025-06-24; baseline finish 2026-12-04 → 2027-06-17 |
| 2669 | Readiness Assessment 6 - Start of Migration - Completed (incl. Readiness Assessment Report approval) | 2025-04-04 → 2025-06-24 (+81d) | 2025-04-04 → 2025-06-24 (+81d) |  | 560d → 652d | none → 2646 | baseline start 2025-04-04 → 2025-06-24; baseline finish 2025-04-04 → 2025-06-24 |
| 2670 | Readiness Assessment 7 - Migration Checkpoint - Completed (incl. Readiness Assessment Report approval) | 2025-10-09 → 2026-03-19 (+161d) | 2025-10-09 → 2026-03-19 (+161d) |  | 426d → 460d | 2652FS+4d → 2653 | baseline start 2025-10-09 → 2026-03-19; baseline finish 2025-10-09 → 2026-03-19 |
| 2671 | Readiness Assessment 8 - Ready to Accept New MPANs - Completed (incl. Readiness Assessment Report approval) | 2026-03-11 → 2026-10-13 (+216d) | 2026-03-11 → 2026-10-13 (+216d) |  | 317d → 312d | 2659FS+4d → 2660 | baseline start 2026-03-13 → 2026-10-13; baseline finish 2026-03-13 → 2026-10-13 |
| 2672 | Readiness Assessment 9 - Readiness for New Settlement Timetable - Completed (incl. Readiness Assessment Report approval) | 2026-12-04 → 2027-06-17 (+195d) | 2026-12-04 → 2027-06-17 (+195d) |  | 125d → 135d | 2666FS+4d → 2667 | baseline start 2026-12-04 → 2027-06-17; baseline finish 2026-12-04 → 2027-06-17 |
| 2673 | **CONTROL POINTS** |  | 2026-12-07 → 2027-06-23 (+198d) | 1063d → 1204d | 124d → 132d |  | baseline finish 2026-12-07 → 2027-06-23 |
| 2677 | **Control Point 2 - Start of Integration & Test** |  |  |  |  |  | baseline start 2023-10-03 → 2023-10-02 |
| 2678 | Control Point 2 Preparation (incl. Control Point Report development and review) |  |  |  |  |  | baseline start 2023-10-03 → 2023-10-02; baseline finish 2023-10-23 → 2023-10-20 |
| 2680 | **Control Point 3/4 - Readiness for Migration** | 2025-02-28 → 2025-08-21 (+174d) | 2025-03-27 → 2025-09-18 (+175d) |  | 20d → 591d |  | baseline start 2025-03-03 → 2025-08-21; baseline finish 2025-03-28 → 2025-09-18 |
| 2681 | Control Point 3/4 Preparation (incl. Control Point Report development and review) | 2025-02-28 → 2025-08-21 (+174d) | 2025-03-19 → 2025-09-09 (+174d) |  | 572d → 597d |  | baseline start 2025-03-03 → 2025-08-21; baseline finish 2025-03-20 → 2025-09-09 |
| 2682 | Control Point 3/4 - Readiness for Migration (incl. Control Point Report approval) | 2025-03-27 → 2025-09-18 (+175d) | 2025-03-27 → 2025-09-18 (+175d) |  | 0d → 591d | none → 1493FS-5d | constraint must start on 2025-03-27 → none; baseline start 2025-03-28 → 2025-09-18; baseline finish 2025-03-28 → 2025-09-18 |
| 2683 | **Control Point 5 - Cut Over to New Settlement Timetable** | 2026-11-10 → 2027-05-26 (+197d) | 2026-12-07 → 2027-06-23 (+198d) |  | 124d → 132d |  | baseline start 2026-11-10 → 2027-05-26; baseline finish 2026-12-07 → 2027-06-23 |
| 2684 | Control Point 5 Preparation (incl. Control Point Report development and review) | 2026-11-10 → 2027-05-26 (+197d) | 2026-11-30 → 2027-06-15 (+197d) |  | 129d → 137d |  | baseline start 2026-11-10 → 2027-05-26; baseline finish 2026-11-30 → 2027-06-15 |
| 2685 | Control Point 5 - Cut Over to New Settlement Timetable (incl. Control Point Report approval) | 2026-12-07 → 2027-06-23 (+198d) | 2026-12-07 → 2027-06-23 (+198d) |  | 124d → 132d | 2589 → 2589FS-8d | baseline start 2026-12-07 → 2027-06-23; baseline finish 2026-12-07 → 2027-06-23 |
| 2686 | **Control Points - Tier 1 Milestones** |  | 2026-12-07 → 2027-06-23 (+198d) | 1043d → 1184d | 124d → 132d |  | baseline finish 2026-12-07 → 2027-06-23 |
| 2689 | Control Point 3/4 - Readiness for Migration (incl. Control Point Report approval) | 2025-03-27 → 2025-09-18 (+175d) | 2025-03-27 → 2025-09-18 (+175d) |  | 566d → 591d |  | baseline start 2025-03-28 → 2025-09-18; baseline finish 2025-03-28 → 2025-09-18 |
| 2690 | Control Point 5 - Cut Over to New Settlement Timetable (incl. Control Point Report approval) | 2026-12-07 → 2027-06-23 (+198d) | 2026-12-07 → 2027-06-23 (+198d) |  | 124d → 132d |  | baseline start 2026-12-07 → 2027-06-23; baseline finish 2026-12-07 → 2027-06-23 |
| 2691 | **MILESTONE RANGE CHECKPOINTS** | 2025-01-13 → 2022-10-31 (-805d) | 2026-09-15 → 2027-04-12 (+209d) | 436d → 1160d? |  |  | baseline start 2025-01-13 → 2022-10-31; baseline finish 2026-09-15 → 2027-04-12 |
| 2692 | **M10, M11, M12 and M13 milestone checkpoint** | 2025-01-13 → 2025-07-31 (+199d) | 2025-01-13 → 2025-07-31 (+199d) |  | 620d → 626d |  | baseline start 2025-01-13 → 2025-07-31; baseline finish 2025-01-13 → 2025-07-31 |
| 2693 | M10, M11, M12, and M13 milestone checkpoint - date approval | 2025-01-13 → 2025-07-31 (+199d) | 2025-01-13 → 2025-07-31 (+199d) |  | 620d → 626d |  | baseline start 2025-01-13 → 2025-07-31; baseline finish 2025-01-13 → 2025-07-31 |
| 2694 | **M14 milestone checkpoint** | 2025-12-19 → 2026-08-06 (+230d) | 2025-12-19 → 2026-08-06 (+230d) |  | 376d → 361d |  | baseline start 2025-12-23 → 2026-08-06; baseline finish 2025-12-23 → 2026-08-06 |
| 2695 | M14 milestone checkpoint - date approval | 2025-12-19 → 2026-08-06 (+230d) | 2025-12-19 → 2026-08-06 (+230d) |  | 376d → 361d |  | baseline start 2025-12-23 → 2026-08-06; baseline finish 2025-12-23 → 2026-08-06 |
| 2696 | **M15 milestone checkpoint** | 2026-07-13 → 2027-02-15 (+217d) | 2026-07-13 → 2027-02-15 (+217d) |  | 230d → 224d |  | baseline start 2026-07-14 → 2027-02-15; baseline finish 2026-07-14 → 2027-02-15 |
| 2697 | M15 milestone checkpoint - date approval | 2026-07-13 → 2027-02-15 (+217d) | 2026-07-13 → 2027-02-15 (+217d) |  | 230d → 224d |  | baseline start 2026-07-14 → 2027-02-15; baseline finish 2026-07-14 → 2027-02-15 |
| 2698 | **M16 milestone checkpoint** | 2026-09-15 → 2022-10-31 (-1415d) | 2026-09-15 → 2027-04-12 (+209d) | 0d → 1160d? |  |  | baseline start 2026-09-15 → 2022-10-31; baseline finish 2026-09-15 → 2027-04-12 |
| 2699 | M16 milestone checkpoint - date approval | 2026-09-15 → 2027-04-12 (+209d) | 2026-09-15 → 2027-04-12 (+209d) |  |  |  | baseline start 2026-09-15 → 2027-04-12; baseline finish 2026-09-15 → 2027-04-12 |

## Version 3 (data date 2024-10-21, saved 2025-01-15, file MHHS-DEL1139 - MHHS Plan v6.16.mpp)

Last finish stays 2027-12-23. Complete tasks 1107 → 1419.

Added:

| ID | Task | Duration | Start | Finish | Predecessors | Constraint |
| --- | --- | --- | --- | --- | --- | --- |
| 146 | **Interim Release 8.5** | 71d | 2024-10-16 A | 2025-01-22 |  |  |
| 147 | Update baselined artefacts | 8d | 2024-10-16 A | 2024-10-25 A |  | start no earlier than 2024-10-16 |
| 148 | Interim Release 8.5 Published | 0d | 2024-11-06 A | 2024-11-06 A | 147FS+8d |  |
| 149 | Interim Release 8.5 Deployed to SIT by Participants | 3d | 2025-01-20 | 2025-01-22 | 148FS+52d |  |
| 150 | **Interim Release 8.6** | 45d? | 2024-11-21 A | 2025-01-22 |  |  |
| 151 | Update baselined artefacts | 2d? | 2024-11-21 A | 2024-11-22 A |  | start no earlier than 2024-11-21 |
| 152 | Interim Release 8.6 Published | 1d? | 2024-11-25 A | 2024-11-25 A | 151 |  |
| 153 | Interim Release 8.6 Deployed to SIT by Participants | 3d | 2025-01-20 | 2025-01-22 | 152FS+39d |  |
| 154 | **Interim Release 8.7** | 5d | 2025-01-20 | 2025-01-24 |  |  |
| 155 | Update baselined artefacts | 2d | 2025-01-20 | 2025-01-21 |  | start no earlier than 2025-01-20 |
| 156 | Interim Release 8.7 Published | 1d | 2025-01-22 | 2025-01-22 | 155 |  |
| 157 | Interim Release 8.7 Deployed to SIT by Participants | 3d | 2025-01-22 | 2025-01-24 | 156FS-1d |  |
| 398 | SIT Non-Functional PIT Completion Report Theme 2 & 3 MHHS Review Completed | 0d | 2025-02-21 | 2025-02-21 | 384, 389, 392, 396FS+60d |  |
| 868 | Test Script updates identified | 1d? | 2024-10-14 A | 2024-10-14 A | 867 |  |
| 869 | Test Scripts updates | 1d | 2024-10-15 A | 2024-10-15 A | 868 |  |
| 870 | RTTM Updated Additional Static RTTM WBS items | 10d | 2024-10-14 A | 2024-10-25 A | 868FS-1d |  |
| 871 | Removal of de-scoped TCs from the RTTMs | 5d | 2024-10-21 A | 2024-10-25 A | 870FS-5d |  |
| 872 | Update and stabilisation of all TC ADO IDs | 14d | 2024-10-21 A | 2024-11-07 A | 870FS-5d |  |
| 873 | Addition and integration of Role tags to reqs in the Role RTTMs | 5d | 2024-10-21 A | 2024-10-25 A | 870FS-5d |  |
| 874 | Update of the RTTM All sheet (porting of the individual RTTMs) | 7d | 2024-10-24 A | 2024-11-01 A | 870FS-2d |  |
| 875 | Define Additional ADO Tags | 1d | 2024-10-23 A | 2024-10-23 A | 870FS-3d |  |
| 876 | Functional RTTM ready for import into ADO | 0d | 2024-11-01 A | 2024-11-01 A | 874 |  |
| 877 | Further Interative Deepdive on the requirements to testcase mapping | 9d | 2024-10-21 A | 2024-10-31 A | 874FS-10d |  |
| 878 | Internal review | 5d | 2024-10-21 A | 2024-10-25 A | 877FS-9d |  |
| 879 | Issue Static RTTM to Code Bodies | 1d? | 2024-10-29 A | 2024-10-29 A | 878FS+1d |  |
| 880 | Code Body Acceptance of RTTM | 5d | 2024-10-30 A | 2024-11-05 A | 879 |  |
| 904 | Exit point identified and evidence capture flags updated | 0d | 2025-02-07 A | 2025-02-07 A | 903 |  |
| 1001 | Test Script updates identified | 1d? | 2024-10-14 A | 2024-10-14 A | 1000 |  |
| 1002 | Test Scripts updates | 16d? | 2024-10-14 A | 2024-11-04 A | 1001FS-1d |  |
| 1003 | RTTM Updated | 1d? | 2024-10-29 A | 2024-10-29 A | 1002FS-5d |  |
| 1004 | Removal of de-scoped TCs from the RTTMs | 2d | 2024-10-31 A | 2024-11-01 A | 1002FS-3d |  |
| 1005 | Update and stabilisation of all TC ADO IDs | 2d | 2024-10-31 A | 2024-11-01 A | 1002FS-3d |  |
| 1006 | Addition and integration of Role tags to reqs in the Role RTTMs | 3d | 2024-10-30 A | 2024-11-01 A | 1002FS-4d |  |
| 1007 | Update of the RTTM All sheet (porting of the individual RTTMs) | 2d | 2024-10-31 A | 2024-11-01 A | 1002FS-3d |  |
| 1008 | ADO IDs corrected | 1d? | 2024-11-04 A | 2024-11-04 A | 1007 | start no earlier than 2024-10-16 |
| 1009 | Migration RTTM ready for import into ADO | 0d | 2024-11-04 A | 2024-11-04 A | 1008 |  |
| 1010 | Issue Static RTTM to Code Bodies | 1d? | 2024-11-05 A | 2024-11-05 A | 1009 |  |
| 1011 | Implement Code Bodies feedback on RTTM | 6d | 2024-11-06 A | 2024-11-13 A | 1010 |  |
| 1012 | Code Body Acceptance of RTTM | 0d | 2024-11-13 A | 2024-11-13 A | 1010, 1011 |  |
| 1013 | **ADO Clean-up** | 17d? | 2024-10-24 | 2024-11-15 A |  |  |
| 1014 | Theme alignment | 1d? | 2024-10-28 A | 2024-10-28 A |  | start no earlier than 2024-10-28 |
| 1015 | Understand Additional suffix Fields in ADO as defined by Kevin | 1d? | 2024-10-25 A | 2024-10-25 A |  | finish no earlier than 2024-10-25 |
| 1016 | Correct Missing Test Case References | 1d? | 2024-10-28 A | 2024-10-28 A |  | start no earlier than 2024-10-28 |
| 1017 | Load Functional RTTMs into ADO | 1d? | 2024-10-28 A | 2024-10-28 A |  | start no earlier than 2024-10-28 |
| 1018 | Load Migration RTTMs into ADO | 1d? | 2024-11-06 A | 2024-11-06 A |  | start no earlier than 2024-11-06 |
| 1019 | Confirm Missing fields in ADO are resolved | 1d? | 2024-11-07 A | 2024-11-07 A |  | finish no earlier than 2024-11-07 |
| 1020 | Reload Functional RTTM into ADO | 1d? | 2024-11-07 A | 2024-11-07 A |  | start no earlier than 2024-11-07 |
| 1021 | **ADO Design Documentation** | 10d? | 2024-11-04 | 2024-11-15 A |  |  |
| 1022 | Produce ADO high Level Design and Data Model | 1d? | 2024-11-15 A | 2024-11-15 A |  | finish no earlier than 2024-11-15 |
| 1023 | Produce Report derivation document | 1d? | 2024-11-15 A | 2024-11-15 A |  | finish no earlier than 2024-11-15 |
| 1024 | **Test Case Rationalisation (Functional + Migration)** | 67d | 2024-11-07 A | 2025-02-07 |  |  |
| 1025 | Internal preliminary rationalisation workshop 1 | 1d | 2024-11-07 A | 2024-11-07 A | 1010FS+1d |  |
| 1026 | Baseline RTTMs | 0d | 2024-11-13 A | 2024-11-13 | 1012, 880 |  |
| 1027 | Baseline test cases | 0d | 2024-11-13 A | 2024-11-13 A | 1012 |  |
| 1028 | Produce requirements / test case analysis doc | 1d | 2024-11-14 A | 2024-11-14 A | 1027 |  |
| 1029 | Internal finalisation rationalisation workshop 2 | 13d | 2024-11-15 A | 2024-12-03 A | 1028 |  |
| 1030 | SRO walkthrough | 1d | 2024-12-04 A | 2024-12-04 A | 1029 |  |
| 1031 | Code Bodies walkthrough | 1d | 2024-12-04 A | 2024-12-04 A | 1029 |  |
| 1032 | Send invites to PPs for walkthrough | 1d | 2024-12-04 A | 2024-12-04 A | 1031FS-1d |  |
| 1033 | PP walkthrough | 1d | 2024-12-17 A | 2024-12-17 A | 1032FS+8d |  |
| 1034 | Update requirements / test case analysis doc | 29d | 2024-12-05 A | 2025-01-14 A | 1032 |  |
| 1035 | SITWG Paper Day | 0d | 2025-01-14 A | 2025-01-14 A | 1034 |  |
| 1036 | SITWG recommendation on requirements / test case analysis doc | 0d | 2025-01-21 | 2025-01-21 | 1035FS+5d |  |
| 1037 | Issue to SITAG / SITAG paper day | 0d | 2025-01-22 | 2025-01-22 | 1036FS+1d |  |
| 1038 | Prepare ADO update | 6d | 2025-01-22 | 2025-01-29 | 1036 |  |
| 1039 | Sign off by SITAG | 0d | 2025-01-29 | 2025-01-29 | 1037FS+5d |  |
| 1040 | Update ADO | 7d | 2025-01-30 | 2025-02-07 | 1039 |  |
| 1041 | Update all ADO reporting | 7d | 2025-01-30 | 2025-02-07 | 1039 |  |
| 1042 | Update test cases | 7d | 2025-01-30 | 2025-02-07 | 1039 |  |
| 1043 | Update RTTM | 7d | 2025-01-30 | 2025-02-07 | 1039 |  |
| 1044 | Update master test case spreadsheet | 7d | 2025-01-30 | 2025-02-07 | 1039 |  |
| 1045 | Test Case Rationalisation complete | 0d | 2025-02-07 | 2025-02-07 | 1040, 1041, 1039, 1042, 1043, 1044 |  |
| 1100 | LDP peer review | 10d | 2024-10-30 A | 2024-11-12 A | 1099 |  |
| 1102 | DIP Manager / Code Bodies / Full SRO to review | 5d | 2024-11-13 A | 2024-11-19 A | 1100 |  |
| 1103 | DIP Manager / Code Bodies / Full SRO acceptance of RTTM | 0d | 2024-11-19 A | 2024-11-19 A | 1102 |  |
| 1105 | **Production of NFT RTTM** | 19d? | 2025-01-23 A | 2025-02-18 |  |  |
| 1106 | Test Script updates identified | 1d? | 2025-01-23 | 2025-01-23 |  | start no earlier than 2025-01-23 |
| 1107 | Test Scripts updates | 1d | 2025-01-24 | 2025-01-24 | 1106 |  |
| 1108 | RTTM Updated Additional RTTM WBS items | 10d | 2025-01-23 | 2025-02-05 | 1106FS-1d |  |
| 1109 | Removal of de-scoped TCs from the RTTMs | 5d | 2025-01-30 | 2025-02-05 | 1108FS-5d |  |
| 1110 | Update and stabilisation of all TC ADO IDs | 14d | 2025-01-30 | 2025-02-18 | 1108FS-5d |  |
| 1111 | Addition and integration of Role tags to reqs in the Role RTTMs | 5d | 2025-01-30 | 2025-02-05 | 1108FS-5d |  |
| 1112 | Update of the RTTM All sheet (porting of the individual RTTMs) | 7d | 2025-02-04 | 2025-02-12 | 1108FS-2d |  |
| 1113 | Define Additional ADO Tags | 1d | 2025-02-03 | 2025-02-03 | 1108FS-3d |  |
| 1114 | Non-Functional RTTM ready for import into ADO | 0d | 2025-02-12 | 2025-02-12 | 1112 |  |
| 1115 | Further Interative Deepdive on the requirements to testcase mapping | 9d | 2025-01-30 | 2025-02-11 | 1112FS-10d |  |
| 1116 | Internal review | 5d | 2025-01-30 | 2025-02-05 | 1115FS-9d |  |
| 1117 | Issue Static RTTM to Code Bodies | 1d? | 2025-02-07 | 2025-02-07 | 1116FS+1d |  |
| 1118 | Code Body Acceptance of RTTM | 0d | 2025-02-07 A | 2025-02-07 A | 1117 |  |
| 1119 | **NFT (Theme 1, 2 and 3) DITL** | 18d | 2025-02-03 A | 2025-02-26 |  |  |
| 1120 | DITL Development | 10d | 2025-02-03 A | 2025-02-14 |  | start no earlier than 2025-02-03 |
| 1121 | SRO Review | 5d | 2025-02-17 | 2025-02-21 | 1120 |  |
| 1122 | Post-SRO Review Changes | 3d | 2025-02-24 | 2025-02-26 | 1121 |  |
| 1123 | Programme walkthrough with Theme 1 PPs on DITL | 0d | 2025-02-26 | 2025-02-26 | 1122 |  |
| 1149 | NFTWG paper day | 0d | 2025-02-11 | 2025-02-11 | 1148 | finish no earlier than 2025-02-11 |
| 1150 | NFTWG review the Non-Functional Theme 1 Overarching Test Readiness Report | 0d | 2025-02-18 | 2025-02-18 | 1149FS+5d |  |
| 1151 | Update Non-Functional Theme 1 Overarching Test Readiness Report following SRO / NFTWG feedback | 6d | 2025-02-19 | 2025-02-26 | 1148, 1150 | finish no earlier than 2025-02-26 |
| 1152 | eSITAG paper day | 0d | 2025-02-26 | 2025-02-26 | 1151 | finish no earlier than 2025-02-21 |
| 1153 | eSITAG approve Non-Functional Theme 1 Overarching Test Readiness Report | 0d | 2025-02-28 | 2025-02-28 | 1139 |  |
| 1154 | **SIT Non-Functional Overarching Test Readiness Report Theme 2 & 3** | 27d | 2025-02-18 | 2025-03-27 |  |  |
| 1155 | Develop Overarching SIT Non-Functional Overarching Test Readiness Report Theme 2 & 3 | 11d | 2025-02-18 | 2025-03-04 |  | finish no earlier than 2025-03-04 |
| 1156 | SRO review | 5d | 2025-03-05 | 2025-03-11 | 1155SS | start no earlier than 2025-03-05 |
| 1157 | NFTWG paper day | 0d | 2025-03-11 | 2025-03-11 | 1156 | finish no earlier than 2025-03-11 |
| 1158 | NFTWG review the Non-Functional Overarching Test Readiness Report Theme 2 & 3 | 0d | 2025-03-18 | 2025-03-18 | 1157FS+5d | finish no earlier than 2025-03-18 |
| 1159 | Update Non-Functional Overarching Test Readiness Report Theme 2 & 3 following SRO / NFTWG feedback | 5d | 2025-03-19 | 2025-03-25 | 1156, 1158 |  |
| 1160 | eSITAG paper day | 0d | 2025-03-25 | 2025-03-25 | 1159 | start no earlier than 2025-03-21 |
| 1161 | eSITAG approve Non-Functional Overarching Test Readiness Report Theme 2 & 3 | 0d | 2025-03-27 | 2025-03-27 | 1140FS-2d, 1141, 1160 |  |
| 1162 | **SIT Non-Functional Execution Model** | 20d | 2025-01-20 A | 2025-02-14 |  |  |
| 1163 | **Theme 1** | 18d | 2025-01-20 A | 2025-02-12 |  |  |
| 1164 | Develop execution model Theme 1 | 3d | 2025-01-20 A | 2025-01-22 A |  | start no earlier than 2025-01-20 |
| 1165 | SRO provide feedback | 5d | 2025-01-23 | 2025-01-29 | 1164 |  |
| 1166 | Address SRO feedback on execution model | 2d | 2025-01-30 | 2025-01-31 | 1165 |  |
| 1167 | Finalise execution model | 3d | 2025-02-03 | 2025-02-05 | 1166 |  |
| 1168 | SITWG paper day | 0d | 2025-02-05 | 2025-02-05 | 1167 |  |
| 1169 | SITWG update on execution model | 0d | 2025-02-12 | 2025-02-12 | 1168FS+5d |  |
| 1170 | **Theme 2 & 3** | 18d | 2025-01-20 A | 2025-02-12 |  |  |
| 1171 | Develop execution model Theme 2 & 3 | 3d | 2025-01-20 A | 2025-01-22 A |  | start no earlier than 2025-01-20 |
| 1172 | SRO provide feedback | 5d | 2025-01-23 | 2025-01-29 | 1171 |  |
| 1173 | Address SRO feedback on execution model | 2d | 2025-01-30 | 2025-01-31 | 1172 |  |
| 1174 | Finalise execution model | 3d | 2025-02-03 | 2025-02-05 | 1173 |  |
| 1175 | SITWG paper day | 0d | 2025-02-05 | 2025-02-05 | 1174 |  |
| 1176 | SITWG update on execution model | 0d | 2025-02-12 | 2025-02-12 | 1175FS+5d |  |
| 1177 | **SIT Non-Functional Progress reporting** | 17d | 2025-01-23 | 2025-02-14 |  |  |
| 1178 | Determine reporting methodology | 2d | 2025-01-23 | 2025-01-24 | 1171, 1164 |  |
| 1180 | SIT Non-Functional Testing Preparation Complete Theme 1 | 0d | 2025-02-28 | 2025-02-28 | 1139 | start no earlier than 2025-02-28 |
| 1181 | SIT Non-Functional Testing Preparation Complete Theme 2 & 3 | 0d | 2025-03-28 | 2025-03-28 | 1140, 1141, 398FS+5d |  |
| 1206 | **SIT Operations Manual** | 589d? | 2022-10-31 A | 2025-01-31 |  |  |
| 1207 | **Version 1 SIT Operations Manual** | 35d | 2024-10-07 A | 2024-11-22 A |  |  |
| 1208 | Creation of SIT Operations Manual Template | 8d | 2024-10-07 A | 2024-10-16 A |  | start no earlier than 2024-10-07 |
| 1209 | November TORWG Paper Day | 0d | 2024-11-07 A | 2024-11-07 A | 1208FS+16d |  |
| 1210 | November TORWG (Timeline and Next Steps for SIT Operations Manual) | 0d | 2024-11-14 A | 2024-11-14 A | 1209FS+5d |  |
| 1211 | SIT Operations Manual Version 1 Shared with MHHSP | 0d | 2024-11-11 A | 2024-11-11 A | 1208FS+18d |  |
| 1212 | MHHSP provide feedback on SIT Operations Manual Version 1 | 9d | 2024-11-12 A | 2024-11-22 A | 1211 |  |
| 1213 | SIT Operations Manual Version 1 Shared with Programme Participants | 0d | 2024-11-13 A | 2024-11-13 A | 1208FS+20d |  |
| 1214 | PPs provide feedback on SIT Operations Manual Version 1 | 7d | 2024-11-14 A | 2024-11-22 A | 1213 |  |
| 1215 | Programme Participants and MHHSP Feedback and Actions Received (SIT Ops Manual Version 1) | 0d | 2024-11-22 A | 2024-11-22 A | 1214, 1212 |  |
| 1216 | **Version 2 SIT Operations Manual** | 27d | 2024-11-12 A | 2024-12-18 A |  |  |
| 1217 | Version 2 SIT Operations Manual (Composition) | 12d | 2024-11-12 A | 2024-11-27 A | 1209FS+2d |  |
| 1218 | Version 2 SIT Operations Manual Completed | 0d | 2024-11-27 A | 2024-11-27 A | 1217 |  |
| 1219 | Version 2 SIT Operations Manual Shared with MHHSP & PPs for TORWG (Consultation Starts) | 0d | 2024-11-27 A | 2024-11-27 A | 1218 |  |
| 1220 | Version 2 SIT Ops Manual - PP Consultation (Iterative Feedback Process) | 10d | 2024-11-28 A | 2024-12-11 A | 1219 |  |
| 1221 | Version 2 SIT Ops Manual - PP Consultation Completed | 0d | 2024-12-11 A | 2024-12-11 A | 1220 |  |
| 1222 | December TORWG Paper Day | 0d | 2024-12-04 A | 2024-12-04 A | 1217FS+5d |  |
| 1223 | December TORWG (Initial Feedback, Common Themes and Comments) | 0d | 2024-12-11 A | 2024-12-11 A | 1222FS+5d |  |
| 1224 | December Extraordinary TORWG Paper Day | 0d | 2024-12-11 A | 2024-12-11 A | 1221 |  |
| 1225 | Publication of key themes from consultation to eTORWG | 2d | 2024-12-12 A | 2024-12-13 A | 1224 |  |
| 1226 | December Extraordinary TORWG (Summary of Version 2 Feedback and Response Approach Shared with PPs) | 0d | 2024-12-18 A | 2024-12-18 A | 1225FS+3d |  |
| 1227 | **Version 3 (Final) SIT Operations Manual** | 44d | 2024-11-28 A | 2025-01-28 |  |  |
| 1228 | Update SIT Operations Manual (Final) Version 3 (with Comments Received From Version 2) [Pre-Christmas Furlough] | 17d | 2024-11-28 A | 2024-12-20 A | 1218, 181FF |  |
| 1229 | Update SIT Operations Manual (Final) Version 3 (with Comments Received From Version 2) [Post-Christmas Furlough] | 5d | 2025-01-02 A | 2025-01-08 A | 1228FS+8d |  |
| 1230 | SIT Operations Manual (Final) Version 3 Completed | 0d | 2025-01-08 A | 2025-01-08 A | 1229 |  |
| 1231 | January TORWG Paper Day | 0d | 2025-01-08 A | 2025-01-08 A | 1230 |  |
| 1232 | January TORWG (SIT Operations Manual Agreement) [Assurance Meeting] | 0d | 2025-01-15 | 2025-01-15 | 1231FS+5d |  |
| 1233 | January MCAG Paper Day (Final SIT Operations Manual Submitted) | 0d | 2025-01-21 | 2025-01-21 | 1232FS+4d |  |
| 1234 | January MCAG (Final SIT Operations Manual Endorsement) [Advisory Group Sign-off] | 0d | 2025-01-28 | 2025-01-28 | 1233FS+5d |  |
| 1236 | **Incident Management Build** | 75d? | 2024-08-05 A | 2024-11-15 A |  |  |
| 1237 | Build | 40d | 2024-08-05 A | 2024-09-27 A |  | finish no earlier than 2024-09-27 |
| 1238 | Test | 15d | 2024-09-30 A | 2024-10-18 A | 1237 | finish no earlier than 2024-10-18 |
| 1239 | Deploy | 20d | 2024-10-21 A | 2024-11-15 A | 1238 | finish no earlier than 2024-11-15 |
| 1240 | Incident Management Build & Configuration Complete | 0d | 2024-11-15 A | 2024-11-15 A | 1239 |  |
| 1241 | **Major Incident Management Build & Configuration** | 0d? | 2024-11-15 | 2024-11-15 |  |  |
| 1242 | Build | 40d | 2024-10-02 A | 2024-11-26 A |  | finish no earlier than 2024-11-26 |
| 1243 | Test | 15d | 2024-11-27 A | 2024-12-17 A | 1242 | finish no earlier than 2024-12-17 |
| 1244 | Deploy | 20d | 2024-12-18 A | 2025-01-14 A | 1243 | finish no earlier than 2025-01-14 |
| 1245 | Major Incident Management Build & Configuration Complete | 0d | 2025-01-14 A | 2025-01-14 A | 1244 |  |
| 1246 | **Knowledge Management Build & Configuration** | 75d? | 2024-10-02 A | 2025-01-14 A |  |  |
| 1247 | Build | 40d | 2024-10-02 A | 2024-11-26 A |  | finish no earlier than 2024-11-26 |
| 1248 | Test | 15d | 2024-11-27 A | 2024-12-17 A | 1247 | finish no earlier than 2024-12-17 |
| 1249 | Deploy | 20d | 2024-12-18 A | 2025-01-14 A | 1248 | finish no earlier than 2025-01-14 |
| 1250 | Knowledge Management Build & Configuration Complete | 0d | 2025-01-14 A | 2025-01-14 A | 1249 |  |
| 1251 | **Problem Management Build & Configuration** | 1d? | 2024-08-01 | 2024-08-01 |  |  |
| 1252 | Build | 40d | 2024-10-02 A | 2024-11-26 A |  | finish no earlier than 2024-11-26 |
| 1253 | Test | 15d | 2024-11-27 A | 2024-12-17 A | 1252 | finish no earlier than 2024-12-17 |
| 1254 | Deploy | 20d | 2024-12-18 A | 2025-01-14 A | 1253 | finish no earlier than 2025-01-14 |
| 1255 | Problem Management Build & Configuration Complete | 0d | 2025-01-14 A | 2025-01-14 A | 1254 | start no earlier than 2025-01-14 |
| 1256 | **Change Management Build & Configuration** | 75d? | 2024-10-02 A | 2025-01-14 A |  |  |
| 1257 | Build | 40d | 2024-10-02 A | 2024-11-26 A |  | finish no earlier than 2024-11-26 |
| 1258 | Test | 15d | 2024-11-27 A | 2024-12-17 A | 1257 | finish no earlier than 2024-12-17 |
| 1259 | Deploy | 20d | 2024-12-18 A | 2025-01-14 A | 1258 | finish no earlier than 2025-01-14 |
| 1260 | Change Management Build & Configuration Complete | 0d | 2025-01-14 A | 2025-01-14 A | 1259 | start no earlier than 2025-01-14 |
| 1261 | **Service Catalogue Management Build & Configuration** | 75d? | 2024-10-02 A | 2025-01-14 A |  |  |
| 1262 | Build | 40d | 2024-10-02 A | 2024-11-26 A |  | finish no earlier than 2024-11-26 |
| 1263 | Test | 15d | 2024-11-27 A | 2024-12-17 A | 1262 | finish no earlier than 2024-12-17 |
| 1264 | Deploy | 20d | 2024-12-18 A | 2025-01-14 A | 1263 | finish no earlier than 2025-01-14 |
| 1265 | Service Catalogue Management Build & Configuration Complete | 0d | 2025-01-14 A | 2025-01-14 A | 1264 | start no earlier than 2025-01-14 |
| 1268 | Document Drafting | 95d | 2024-08-01 A | 2024-12-11 A |  | finish no earlier than 2024-12-11 |
| 1269 | Internal Elexon Review | 3d | 2025-01-06 A | 2025-01-08 A | 1268 | finish no earlier than 2024-12-16 |
| 1270 | Elexon Service Panel Sign off | 0d | 2025-01-08 A | 2025-01-08 A | 1269 | start no earlier than 2024-12-20 |
| 1271 | **Incident Management Support** | 1d? | 2022-10-31 | 2022-10-31 |  |  |
| 1272 | Identify Relevant Stakeholders to Support Incident Management Process | 10d | 2024-12-02 A | 2024-12-13 A |  | start no earlier than 2024-12-02 |
| 1273 | Schedule Time to Upskill Stakeholders | 5d | 2024-12-16 A | 2024-12-20 A | 1272 |  |
| 1274 | Helix Stakeholders Attendance at MHHS Defect Triage Meetings [Meeting Dates to be Confirmed] | 10d | 2025-01-06 A | 2025-01-17 | 1273FS+10d |  |
| 1275 | SIT Service Readiness (Elexon & Helix) Completed | 0d | 2025-01-17 | 2025-01-17 | 1274 |  |
| 1276 | **SIT Service Readiness (External Parties)** | 80d | 2024-10-07 A | 2025-01-24 |  |  |
| 1277 | **Helix Engagement & Comms** | 71d | 2024-10-07 A | 2025-01-13 A |  |  |
| 1278 | Engagement Execution | 71d | 2024-10-07 A | 2025-01-13 A |  | finish no earlier than 2025-01-13 |
| 1279 | Information Gathering | 32d | 2024-11-29 A | 2025-01-13 A |  | finish no earlier than 2025-01-13 |
| 1280 | SIT Participants Preparation | 9d | 2024-11-28 A | 2024-12-10 A |  | start no earlier than 2024-11-28 |
| 1281 | SIT Service Readiness (External Parties) Completed | 0d | 2025-01-24 | 2025-01-24 | 1278FS+9d, 1279, 1280 |  |
| 1282 | **ServiceNow Support Portal Onboarding (Helix Suppliers & SIT Participants)** | 78d? | 2024-10-02 A | 2025-01-17 |  |  |
| 1283 | **ServiceNow Portal Preparation and Planning** | 40d? | 2024-10-02 A | 2024-11-26 A |  |  |
| 1284 | Define Supplier Requirements | 30d? | 2024-10-02 A | 2024-11-12 A |  | start no earlier than 2024-10-02 |
| 1285 | Determine Supplier ServiceNow modules | 10d? | 2024-11-13 A | 2024-11-26 A | 1284 | finish no earlier than 2024-11-26 |
| 1286 | Review compliance requirements, including data privacy and access limitations. | 10d? | 2024-11-13 A | 2024-11-26 A | 1284 | finish no earlier than 2024-11-26 |
| 1287 | Conduct a security assessment to ensure the supplier complies with organisational policies. | 10d? | 2024-11-13 A | 2024-11-26 A | 1284 | finish no earlier than 2024-11-26 |
| 1288 | **ServiceNow Portal System Configuration** | 30d? | 2024-11-27 A | 2025-01-07 |  |  |
| 1289 | Create Supplier User Accounts | 33d | 2024-11-27 A | 2025-01-10 | 1287 | finish no earlier than 2025-01-10 |
| 1290 | Assign appropriate access based on the supplier’s needs and security requirements (e.g., read-only access, submit requests, etc.). | 10d? | 2024-12-30 A | 2025-01-10 | 1289FF | finish no earlier than 2024-12-24 |
| 1291 | Configure Access Controls | 10d? | 2024-12-30 A | 2025-01-10 | 1290FF | finish no earlier than 2025-01-07 |
| 1292 | **ServiceNow Portal Training and Documentation** | 5d? | 2025-01-06 A | 2025-01-10 |  |  |
| 1293 | Provide Training to the Supplier | 1d | 2025-01-24 | 2025-01-24 |  | start no earlier than 2025-01-24 |
| 1294 | Create Supplier Training Documentation | 5d | 2025-01-06 A | 2025-01-10 A |  | finish no earlier than 2025-01-10 |
| 1295 | **ServiceNow Portal Testing and Validation** | 8d? | 2025-01-08 | 2025-01-17 |  |  |
| 1296 | Conduct User Acceptance Testing (UAT) | 1d | 2025-01-24 | 2025-01-24 | 1293SS | finish no earlier than 2025-01-17 |
| 1297 | Validate Access and Security Controls | 4d | 2025-01-20 | 2025-01-23 | 1291FS+5d | finish no earlier than 2025-01-16 |
| 1298 | ServiceNow Support Portal Onboarding (Helix Suppliers& SIT Participants) Completed | 0d | 2025-01-24 | 2025-01-24 | 1287, 1291, 1294, 1297, 1293 | start no earlier than 2025-01-17 |
| 1299 | Stage 1 - Helix SIT Operational Readiness Completed | 0d | 2025-01-31 | 2025-01-31 |  | start no earlier than 2025-01-31 |
| 1307 | SITWG paper day | 0d | 2024-11-28 A | 2024-11-28 A | 1306 |  |
| 1309 | SITWG endorse Theme 3 (Batch 2) | 0d | 2024-12-05 A | 2024-12-05 A | 1308 |  |
| 1310 | SITAG paper day | 0d | 2024-12-11 A | 2024-12-11 A | 1309FS+4d |  |
| 1320 | SITWG paper day | 0d | 2024-11-28 A | 2024-11-28 A | 1319FS+4d |  |
| 1322 | SITWG endorse Theme 3 (Batch 1) | 0d | 2024-12-05 A | 2024-12-05 A | 1321 |  |
| 1323 | SITAG paper day | 0d | 2024-12-11 A | 2024-12-11 A | 1322FS+4d |  |
| 1331 | SRO review of Manual SIT Operational RTTM | 5d | 2025-01-13 | 2025-01-17 | 1330 |  |
| 1332 | DIP Manager / Code Bodies / Full SRO to review | 5d | 2025-01-20 | 2025-01-24 | 1331 |  |
| 1333 | DIP Manager / Code Bodies / Full SRO acceptance of Operational RTTM | 0d | 2025-01-24 | 2025-01-24 | 1332 |  |
| 1335 | **Theme 3 Work-off plan** | 86d? | 2025-01-06 A | 2025-05-05 |  |  |
| 1336 | Test Scripts updates | 52d | 2025-01-27 | 2025-04-08 | 1334 |  |
| 1337 | RTTM Updated Additional RTTM WBS items | 10d | 2025-04-09 | 2025-04-22 | 1336 |  |
| 1338 | Removal of de-scoped TCs from the RTTMs | 5d | 2025-04-16 | 2025-04-22 | 1337FS-5d |  |
| 1339 | Update and stabilisation of all TC ADO IDs | 14d | 2025-04-16 | 2025-05-05 | 1337FS-5d |  |
| 1340 | Addition and integration of Role tags to reqs in the Role RTTMs | 5d | 2025-04-16 | 2025-04-22 | 1337FS-5d |  |
| 1341 | Update of the RTTM All sheet (porting of the individual RTTMs) | 7d | 2025-04-21 | 2025-04-29 | 1337FS-2d |  |
| 1342 | Define Additional ADO Tags | 1d | 2025-04-18 | 2025-04-18 | 1337FS-3d |  |
| 1343 | Upload Operational RTTM to ADO | 0d | 2025-04-29 | 2025-04-29 | 1341 |  |
| 1344 | Further Interative Deepdive on the requirements to testcase mapping | 9d | 2025-04-16 | 2025-04-28 | 1341FS-10d |  |
| 1345 | Internal review | 5d | 2025-04-16 | 2025-04-22 | 1344FS-9d |  |
| 1346 | Issue Static RTTM to Code Bodies | 1d? | 2025-04-24 | 2025-04-24 | 1345FS+1d |  |
| 1347 | Code Body Acceptance of RTTM | 5d | 2025-04-25 | 2025-05-01 | 1346 |  |
| 1348 | **SIT Operational DITL** | 17d | 2025-01-06 A | 2025-01-28 |  |  |
| 1349 | DITL + Familiarisation session development | 8d | 2025-01-06 A | 2025-01-15 |  | start no earlier than 2025-01-06 |
| 1350 | SRO Review | 5d | 2025-01-16 | 2025-01-22 | 1349 |  |
| 1351 | Post-SRO Review Changes | 2d | 2025-01-23 | 2025-01-24 | 1350 |  |
| 1352 | Familiarisation session Service Management test case schedule + mapping | 0d | 2025-01-24 | 2025-01-24 | 1351 |  |
| 1353 | Publish Cycle 3 DITL / Cycle 3 DITL Online Sessions for SIT PPs | 0d | 2025-01-28 | 2025-01-28 | 1352FS+2d |  |
| 1360 | **SI SIT Operational Theme 3 (Batch 1) Overarching Test Readiness Report** | 31d | 2024-12-18 | 2025-01-29 |  |  |
| 1361 | Develop Overarching SIT Operational Theme 3 (Batch 1) Overarching Test Readiness Report | 20d | 2024-12-18 | 2025-01-14 | 414FF | finish no earlier than 2025-01-14 |
| 1362 | SRO review | 5d | 2025-01-08 | 2025-01-14 | 1361FF | finish no earlier than 2025-01-13 |
| 1363 | SITWG Paper day | 0d | 2025-01-14 | 2025-01-14 | 1362 | finish no earlier than 2025-01-14 |
| 1364 | SITWG review the Operational Theme 3 (Batch 1) Overarching Test Readiness Report | 0d | 2025-01-21 | 2025-01-21 | 1363FS+5d | finish no earlier than 2025-01-21 |
| 1365 | Update Operational Theme 3 (Batch 1) Overarching Test Readiness Report following SRO / SITWG feedback | 1d | 2025-01-22 | 2025-01-22 | 1364 | start no earlier than 2025-01-22 |
| 1366 | SITAG paper day | 0d | 2025-01-22 | 2025-01-22 | 1365 | finish no earlier than 2025-01-22 |
| 1367 | SITAG approve Theme 3 (Batch 1) Test Readiness Report | 0d | 2025-01-29 | 2025-01-29 | 1366FS+5d | finish no earlier than 2025-01-29 |
| 1368 | **SI SIT Operational Theme 1, 2 and 3 (Batch 2) Overarching Test Readiness Report** | 45d | 2025-01-27 | 2025-03-28 |  |  |
| 1369 | Develop Overarching SIT Operational Theme 1, 2 and 3 (Batch 2) Overarching Test Readiness Report | 20d | 2025-01-27 | 2025-02-21 | 397FS+25d | start no earlier than 2025-01-20 |
| 1370 | SRO review | 5d | 2025-02-24 | 2025-02-28 | 1369 |  |
| 1371 | SITWG Paper day | 0d | 2025-02-27 | 2025-02-27 |  | finish no earlier than 2025-02-27 |
| 1372 | SITWG review the Operational Theme 1, 2 and 3 (Batch 2) Overarching Test Readiness Report | 0d | 2025-03-06 | 2025-03-06 | 1371SS+5d |  |
| 1373 | Update Operational Theme 1, 2 and 3 (Batch 2) Overarching Test Readiness Report following SRO feedback | 13d | 2025-03-07 | 2025-03-25 | 1372 | start no earlier than 2025-03-07 |
| 1374 | eSITAG paper day | 0d | 2025-03-26 | 2025-03-26 | 1373 | finish no earlier than 2025-03-26 |
| 1375 | eSITAG approve Operational Theme 1, 2 and 3 (Batch 2) Overarching Test Readiness Report | 0d | 2025-03-28 | 2025-03-28 | 1142, 1143 |  |
| 1376 | **SIT Operational Execution Model** | 43d | 2024-08-05 A | 2024-10-02 |  |  |
| 1377 | **Theme 3 (Batch 1)** | 27d | 2024-08-05 | 2024-09-10 |  |  |
| 1378 | Develop execution model Theme 3 (Batch 1) | 3d | 2024-12-16 A | 2024-12-18 A | 1325FF |  |
| 1379 | SRO provide feedback | 14d | 2024-12-19 A | 2025-01-07 A | 1378 |  |
| 1380 | Address SRO feedback on execution model | 2d | 2025-01-08 A | 2025-01-09 A | 1379 |  |
| 1381 | Finalise execution model | 3d | 2025-01-10 A | 2025-01-14 A | 1380 |  |
| 1382 | SITWG paper day | 0d | 2025-01-14 | 2025-01-14 | 1381 |  |
| 1383 | SITWG update on execution model | 0d | 2025-01-21 | 2025-01-21 | 1382FS+5d |  |
| 1384 | **Theme 1, 2 and 3 (Batch 2)** | 23d | 2024-08-05 | 2024-09-04 |  |  |
| 1385 | Develop execution model Theme 1, 2 and 3 (Batch 2) | 3d | 2025-01-13 | 2025-01-15 | 1325 | start no earlier than 2025-01-13 |
| 1386 | SRO provide feedback | 5d | 2025-01-16 | 2025-01-22 | 1385 |  |
| 1387 | Address SRO feedback on execution model | 2d | 2025-01-23 | 2025-01-24 | 1386 |  |
| 1388 | Finalise execution model | 3d | 2025-01-27 | 2025-01-29 | 1387 |  |
| 1389 | SITWG paper day | 0d | 2025-02-05 | 2025-02-05 | 1388FS+5d |  |
| 1390 | SITWG update on execution model | 0d | 2025-02-12 | 2025-02-12 | 1389FS+5d |  |
| 1391 | **SIT Operational Theme 3 (Batch 1) progress reporting** | 29d? | 2024-12-19 A | 2025-01-28 |  |  |
| 1392 | Determine reporting methodology | 2d? | 2024-12-19 A | 2024-12-20 A |  |  |
| 1393 | Implement reporting | 10d | 2024-12-23 | 2025-01-03 | 1392 |  |
| 1394 | SIT Operational Theme 3 (Batch 1) Testing Preparation Complete | 0d | 2025-01-30 | 2025-01-30 | 1367FS+1d, 1298 |  |
| 1401 | Industry review of approach | 10d | 2025-01-23 | 2025-02-05 | 1400 |  |
| 1402 | Updates to approach doc on back of industry feedback | 4d | 2025-02-06 | 2025-02-11 | 1401 |  |
| 1403 | eSITWG paper day | 0d | 2025-02-11 | 2025-02-11 | 1402 |  |
| 1404 | eSITWG Recommendation | 0d | 2025-02-18 | 2025-02-18 | 1403FS+5d | start no earlier than 2025-01-20 |
| 1411 | SITWG paper day | 1d | 2025-02-27 | 2025-02-27 | 1410SS | start no earlier than 2025-02-27 |
| 1412 | SITWG provides feedback on regression suite approach | 0d | 2025-03-06 | 2025-03-06 | 1411FS+5d |  |
| 1413 | LDP walkthrough of Regression Test Suite | 1d | 2025-02-28 | 2025-02-28 | 1410FF |  |
| 1415 | Incorporate SRO feedback into regression suite doc | 5d | 2025-03-03 | 2025-03-07 | 1414SS, 1412FF |  |
| 1416 | Industry review of Regression Test Suite | 10d | 2025-03-10 | 2025-03-21 | 1415 |  |
| 1417 | Incorporate Industry feedback into regression suite doc | 4d | 2025-03-24 | 2025-03-27 | 1416 |  |
| 1418 | SITWG paper day | 0d | 2025-03-27 | 2025-03-27 | 1417 |  |
| 1422 | eSITAG (inc SRO) Approval of regression suite doc | 0d | 2025-04-16 | 2025-04-16 | 1421FS+5d | finish no earlier than 2025-04-16 |
| 1425 | Data Load preparation activities | 20d | 2025-03-31 | 2025-04-25 | 1140 | start no earlier than 2025-03-17 |
| 1524 | SIT Functional Cycle 3 Complete | 1d? | 2025-04-28 | 2025-04-28 | 1523 |  |
| 1528 | Sprint 5 | 20d? | 2024-10-07 A | 2024-11-01 A |  |  |
| 1529 | Sprint 5 Review (Flexibility Window Checkpoint) | 0d | 2024-11-04 A | 2024-11-04 A | 1528SS+21d |  |
| 1530 | Sprint 6 | 10d? | 2024-11-04 A | 2024-11-15 A | 1528 |  |
| 1531 | Sprint 6 Review (Pre Christmas Contingency Decision Point) | 0d | 2024-11-18 A | 2024-11-18 A | 1530SS+11d |  |
| 1532 | Sprint 7 | 10d? | 2024-11-18 A | 2024-11-29 A | 1530 |  |
| 1533 | Sprint 7 Review (Post Christmas Contingency Decision Point) | 0d | 2024-12-02 A | 2024-12-02 A | 1532SS+11d |  |
| 1534 | Sprint 8 | 15d | 2024-12-02 A | 2024-12-20 A | 1532 |  |
| 1535 | Post-Christmas Stabilisation | 5d | 2025-01-06 A | 2025-01-10 A | 1534FS+10d |  |
| 1536 | Sprint 9 | 10d | 2025-01-06 A | 2025-01-17 | 1534FS+10d |  |
| 1537 | Sprint 9 Review | 0d | 2025-01-20 | 2025-01-20 | 1536FS+1d |  |
| 1538 | Sprint 10 | 10d | 2025-01-20 | 2025-01-31 | 1536 |  |
| 1539 | Sprint 10 Review | 0d | 2025-02-03 | 2025-02-03 | 1538FS+1d |  |
| 1540 | Sprint 11 | 10d | 2025-02-03 | 2025-02-14 | 1538 |  |
| 1541 | Sprint 11 Review | 0d | 2025-02-14 | 2025-02-14 | 1540 |  |
| 1542 | Sprint 12 | 5d | 2025-02-17 | 2025-02-21 | 1541 |  |
| 1543 | End of Settlement Testing Cycle 3 | 0d | 2025-02-21 | 2025-02-21 | 1542 |  |
| 1546 | Regression Test Execution Start | 1d | 2025-06-16 | 2025-06-16 | 1427, 1544 |  |
| 1557 | Programme agreement into Settlement Testing | 1d? | 2025-02-07 | 2025-02-07 |  | start no earlier than 2025-02-07 |
| 1588 | SIT Migration Cycle 3 Complete | 0d | 2025-04-25 | 2025-04-25 | 1587 |  |
| 1733 | **Sandbox Testing Execution (UIT)** | 260d | 2025-09-01 | 2026-08-28 |  |  |
| 1734 | Sandbox Testing Start (UIT) | 0d | 2025-09-01 | 2025-09-01 | 1631, 2162FS+5d, 1732 | start no earlier than 2025-02-10 |
| 1735 | Sandbox Testing Execution (UIT) | 260d | 2025-09-01 | 2026-08-28 | 1734SS-1d | start no earlier than 2024-11-04 |
| 1736 | Sandbox Testing End (UIT) | 0d | 2026-08-28 | 2026-08-28 | 1735 |  |
| 1819 | PIT Execution (Non-Functional and Operational) | 90d | 2024-09-23 A | 2025-01-24 | 1817 |  |
| 1821 | Non-SIT LDSO Participants have submitted non-functional PIT Test Completion Report | 0d | 2025-01-24 | 2025-01-24 | 1819 |  |
| 1852 | LDSO Alpha | 86d | 2025-01-06 A | 2025-05-05 | 1851FS-1d |  |
| 1853 | LDSO Bravo | 59d | 2025-01-06 | 2025-03-27 | 1851FS-1d |  |
| 1854 | LDSO Charlie | 88d | 2025-01-06 | 2025-05-07 | 1851FS-1d |  |
| 1855 | LDSO Delta | 83d | 2025-01-06 A | 2025-04-30 | 1851FS-1d |  |
| 1856 | LDSO Echo | 69d | 2025-01-06 | 2025-04-10 | 1851FS-1d |  |
| 1857 | LDSO Foxtrot | 44d | 2025-01-20 | 2025-03-20 | 1851FS+9d |  |
| 1858 | LDSO Golf | 66d | 2025-01-06 | 2025-04-07 | 1851FS-1d |  |
| 1859 | LDSO Hotel | 45d | 2025-01-06 A | 2025-03-07 | 1851FS-1d |  |
| 1860 | LDSO India | 86d | 2025-01-06 A | 2025-05-05 | 1851FS-1d |  |
| 1862 | Potential for non-SIT LDSO QT Regression for Qualification | 70d? | 2025-05-19 | 2025-08-22 | 1861FS+1d |  |
| 1994 | **QT Functional (inc NF and Operational) Test Scenarios and Test Cases** | 63d | 2024-11-05 A | 2025-01-30 |  |  |
| 1995 | Draft Test Scenarios and Test Case list - Batch 3 | 20d | 2024-11-05 A | 2024-12-02 A | 880FS-1d |  |
| 1996 | Issue Batch 3 for Consultation | 10d | 2024-12-03 A | 2024-12-16 | 1995 |  |
| 1997 | Update Batch 3 Post Consultation | 20d | 2024-12-17 | 2025-01-13 | 1996 |  |
| 1998 | QWG Endorsement of Batch 3 | 0d | 2025-01-22 | 2025-01-22 | 1997FS+7d |  |
| 1999 | QAG Approval of QT Functional Test Scenarios and Test Cases Batches 3 | 0d | 2025-01-30 | 2025-01-30 | 1998FS+6d |  |
| 2028 | Hub Development Dev/Test | 20d | 2024-06-10 A | 2024-07-05 A | 2027SS+10d |  |
| 2039 | DIP Simulator | 15d | 2024-07-26 A | 2024-08-15 A |  | finish no earlier than 2024-08-15 |
| 2040 | DIP (UIT) Instance available for Onboarding | 1d | 2024-08-05 A | 2024-08-05 A |  | start no earlier than 2024-08-05 |
| 2041 | DIP (UIT) Portal | 1d | 2024-09-03 A | 2024-09-03 A | 2040 | start no earlier than 2024-09-03 |
| 2042 | DIP (UIT) Onboarding for Development (incl. certificates and security compliance) | 39d | 2024-08-06 A | 2024-09-27 A | 2040 | finish no earlier than 2024-09-27 |
| 2043 | DIP (UIT) Onboarding for Development Connection Confirmed | 1d | 2024-09-30 A | 2024-09-30 A | 2042 | start no earlier than 2024-09-30 |
| 2044 | DIP (UIT) Onboarding for Test (incl. certificates and security compliance) | 5d | 2024-10-01 A | 2024-10-07 A | 2043 | finish no earlier than 2024-10-07 |
| 2045 | DIP (UIT) Onboarding for Test Connection Confirmed | 1d | 2024-10-08 A | 2024-10-08 A | 2044 | start no earlier than 2024-10-08 |
| 2046 | DIP (UIT) Onboarding for Prod (incl. certificates and security compliance) | 5d | 2024-10-09 A | 2024-10-15 A | 2045 | finish no earlier than 2024-10-15 |
| 2047 | DIP (UIT) Onboarding for Prod Connection Confirmed | 1d | 2024-10-16 A | 2024-10-16 A | 2046 | start no earlier than 2024-10-16 |
| 2052 | New VPN Connection (Test) | 30d | 2024-08-05 A | 2024-09-13 A | 2051 | start no earlier than 2024-08-05 |
| 2053 | New VPN Connection (Prod) | 30d | 2024-09-16 A | 2024-10-25 A | 2052 | finish no earlier than 2024-10-25 |
| 2055 | **Generate Tooling** | 334d | 2024-04-22 A | 2025-07-31 |  |  |
| 2056 | MPAN Core Generator | 25d | 2024-04-22 A | 2024-05-24 A |  | finish no earlier than 2024-05-24 |
| 2057 | MPAN File Generator | 55d | 2024-05-27 A | 2024-08-09 A | 2056 | finish no earlier than 2024-08-09 |
| 2058 | MPAN Template Loader | 32d | 2024-08-12 A | 2024-09-24 A | 2057 | finish no earlier than 2024-09-24 |
| 2059 | ADO Extract (QTC) From SIT | 30d | 2024-05-06 A | 2024-06-14 A |  | finish no earlier than 2024-06-14 |
| 2060 | Populate QT ADO | 40d | 2024-06-17 A | 2024-08-09 A | 2059 | finish no earlier than 2024-08-09 |
| 2061 | Create QTC Spreadsheets | 20d | 2024-06-03 A | 2024-06-28 A | 2059 | finish no earlier than 2024-06-28 |
| 2062 | Upload QTC Spreadsheets to QTF | 20d | 2024-07-01 A | 2024-07-26 A | 2061 | finish no earlier than 2024-07-26 |
| 2063 | Create QTC Set / Master QTC Loader | 40d | 2024-07-22 A | 2024-09-13 A | 2062 | finish no earlier than 2024-09-13 |
| 2064 | **Test Data** | 15d | 2024-06-10 A | 2024-06-28 A |  |  |
| 2066 | **MPANs, DIP Messages, Settlement, Consumption, Reference** | 423d? | 2024-05-27 A | 2026-01-07 |  |  |
| 2067 | Create MPAN Data | 55d | 2024-05-27 A | 2024-08-09 A | 2056 | finish no earlier than 2024-08-09 |
| 2068 | Create message templates (DIP, CSS, DTN) | 40d | 2024-06-03 A | 2024-07-26 A |  | finish no earlier than 2024-07-26 |
| 2069 | Create Consumption Data Templates | 20d | 2024-09-16 A | 2024-10-11 A |  | finish no earlier than 2024-10-11 |
| 2070 | Load Consumption Data | 25d | 2024-11-11 A | 2024-12-13 A | 2069FS+20d |  |
| 2071 | Create Load Shape and Load Shape Total Templates | 20d | 2024-09-16 A | 2024-10-11 A |  | finish no earlier than 2024-10-11 |
| 2072 | Load Shape and Load Shape Total Data | 25d | 2024-11-11 A | 2024-12-13 A | 2071FS+20d |  |
| 2073 | Create Settlement Report Templates | 20d | 2024-09-16 A | 2024-10-11 A |  | finish no earlier than 2024-10-11 |
| 2074 | Load Settlement Report Data | 25d | 2024-11-11 A | 2024-12-13 A | 2073FS+20d |  |
| 2075 | Market Domain Data (MDD) For Legacy Systems | 25d | 2024-07-29 A | 2024-08-30 A |  | finish no earlier than 2024-08-30 |
| 2078 | Helix Dev Environment migration | 6d | 2024-07-29 A | 2024-08-05 A | 2077 | finish no earlier than 2024-08-05 |
| 2079 | STGi (UK) migration | 5d | 2024-09-09 A | 2024-09-13 A | 2077 | finish no earlier than 2024-09-13 |
| 2080 | Maintenance window between cycle 2 and 3 | 1d | 2024-09-20 A | 2024-09-20 A | 2077 | finish no earlier than 2024-09-20 |
| 2082 | Second View of Migrated ISD Data (HXT1 (SIT B) migration) | 5d | 2024-09-23 A | 2024-09-27 A | 2080 | finish no earlier than 2024-09-27 |
| 2086 | **BETA Testing 1 - Test Data** | 27d | 2024-11-01 A | 2024-12-09 |  |  |
| 2087 | Provide Example MPAN File | 3d | 2024-11-01 A | 2024-11-05 A | 2130SS | finish no earlier than 2024-11-05 |
| 2088 | Load Example MPAN File | 6d | 2024-11-06 A | 2024-11-13 A | 2087 | finish no earlier than 2024-11-13 |
| 2089 | Industry Standing Data (ISD) | 6d | 2024-11-06 A | 2024-11-13 A | 2130SS+3d | finish no earlier than 2024-11-13 |
| 2090 | Market Domain Data (MDD) | 6d | 2024-11-06 A | 2024-11-13 A | 2130SS+3d | finish no earlier than 2024-11-13 |
| 2091 | Load ISD / MDD Data | 1d | 2024-12-06 A | 2024-12-06 A | 2089FS+16d, 2090FS+11d | start no earlier than 2024-11-14 |
| 2092 | Create QTC sets and Test MPANs via QTF | 1d | 2024-12-06 A | 2024-12-06 A | 2088FS+16d | start no earlier than 2024-11-14 |
| 2093 | Create QTC sets in ADO via QTF | 1d | 2024-12-06 A | 2024-12-06 A | 2092SS | start no earlier than 2024-11-14 |
| 2094 | Provide Test MPANs (Suppliers only) allocated to specfic QTC's | 1d | 2024-12-06 A | 2024-12-06 A | 2091SS | start no earlier than 2024-11-14 |
| 2095 | Load Test MPANs | 1d | 2024-12-09 A | 2024-12-09 A | 2094 | start no earlier than 2024-11-15 |
| 2096 | **BETA Testing 2 - Test Data** | 11d | 2025-01-08 A | 2025-01-22 |  |  |
| 2097 | Provide Example MPAN File | 3d | 2025-01-08 A | 2025-01-10 A | 2131SS | start no earlier than 2025-01-08 |
| 2098 | Load Example MPAN File | 6d | 2025-01-13 A | 2025-01-20 | 2097 | start no earlier than 2025-01-13 |
| 2099 | Industry Standing Data (ISD) | 6d | 2025-01-08 | 2025-01-15 | 2085, 2131SS | start no earlier than 2025-01-08 |
| 2100 | Market Domain Data (MDD) | 6d | 2025-01-08 | 2025-01-15 | 2069, 2131SS | start no earlier than 2025-01-08 |
| 2101 | Load ISD / MDD Data | 1d | 2025-01-16 | 2025-01-16 | 2099, 2100, 2131SS | start no earlier than 2025-01-16 |
| 2102 | Create QTC sets and Test MPANs via QTF | 1d | 2025-01-21 | 2025-01-21 | 2098 | start no earlier than 2025-01-21 |
| 2103 | Create QTC sets in ADO via QTF | 1d | 2025-01-21 | 2025-01-21 | 2102SS | start no earlier than 2025-01-21 |
| 2104 | Provide Test MPANs (Suppliers only) allocated to specfic QTC's | 1d | 2025-01-21 | 2025-01-21 | 2102SS | start no earlier than 2025-01-21 |
| 2105 | Load Test MPANs | 1d | 2025-01-22 | 2025-01-22 | 2104 | start no earlier than 2025-01-22 |
| 2130 | BETA Testing | 33d | 2024-11-01 A | 2024-12-17 A |  | finish no earlier than 2024-12-17 |
| 2131 | BETA Testing 2 | 58d | 2025-01-08 | 2025-03-28 | 2130 | start no earlier than 2025-01-08 |
| 2132 | Qualification Testing Framework Readiness Confirmed | 0d | 2025-03-28 | 2025-03-28 | 2131 | start no earlier than 2025-03-28 |
| 2430 | MCAG Paper Day | 0d | 2025-02-25 | 2025-02-25 | 2429FS+2d |  |
| 2432 | **Consultation 4** | 87d? | 2025-01-07 A | 2025-05-07 |  |  |
| 2433 | **Prepare Artefacts** | 87d? | 2025-01-07 A | 2025-05-07 |  |  |
| 2434 | Test Approach | 20d? | 2025-01-07 A | 2025-02-03 |  | start no earlier than 2025-01-07 |
| 2435 | Test Plan | 20d? | 2025-02-04 | 2025-03-03 | 2434 |  |
| 2436 | Other Framework items | 47d? | 2025-03-04 | 2025-05-07 | 2435 |  |
| 2437 | Industry Consultation | 10d? | 2025-03-12 | 2025-03-25 |  | start no earlier than 2025-03-12 |
| 2438 | Triage Response | 10d? | 2025-03-26 | 2025-04-08 | 2437 |  |
| 2439 | Assurance and MCAG Approval | 10d? | 2025-04-09 | 2025-04-22 | 2438 |  |
| 2440 | Consultation 4 Approved | 0d | 2025-04-22 | 2025-04-22 | 2439 |  |
| 2441 | Framework Baselined at MCAG | 0d | 2025-04-22 | 2025-04-22 | 2440 |  |
| 2447 | Schedule Production v1 | 25d? | 2024-11-18 A | 2024-12-20 A |  | start no earlier than 2024-11-18 |
| 2448 | Schedule Production v2 | 80d? | 2025-03-31 | 2025-07-18 |  | start no earlier than 2025-03-31 |
| 2450 | **MCC Stood up** | 265d? | 2024-11-18 | 2025-11-21 |  |  |
| 2451 | **MPMT Delivered** | 265d? | 2024-11-18 | 2025-11-21 |  |  |
| 2452 | **Migration Planning Tool - Delivery** | 265d? | 2024-11-18 | 2025-11-21 |  |  |
| 2453 | MPMT Build Sprints - MVP | 120d? | 2025-01-06 | 2025-06-20 |  | start no earlier than 2025-01-06 |
| 2454 | Delivery Activity | 265d? | 2024-11-18 | 2025-11-21 |  |  |
| 2455 | MCC - Pilot | 0d | 2024-11-20 | 2024-11-20 |  | start no earlier than 2024-11-20 |
| 2456 | MCC Stood up complete | 1d? | 2024-11-18 | 2024-11-18 |  |  |
| 2730 | SIT non-MVC S&As Create Certificates and Test Connectivity | 1d? | 2025-12-23 | 2025-12-23 | 2729 |  |
| 2733 | SIT non-MVC S&As to update systems with ISD | 1d? | 2025-12-29 | 2025-12-29 | 2732 |  |

Removed: 851 Development of Automated SIT Functional RTTM; 852 Automated SIT Functional RTTM Complete; 856 SRO Walkthrough; 857 SRO Approval; 882 Cycle 3 Test Case Rationalisation (Functional and Migration); 883 Review Cycle 3 scope and identify candidates for rationalisation; 884 Define proposal for rationalisation of test cases; 886 Present proposed approach; 887 Incorporate feedback; 888 Publish proposed approach ahead of Cycle 3 start; 938 Regression Test data (SIT A); 939 Prepare, Generate and Allocate Test Data; 940 Transmit Data Sets to PPs; 941 PP's Iterative load and data integrity check; 942 Regression - PP's confirmation that test data is ready for SIT Functional; 986 Develop Automated SIT Migration RTTM; 987 Automated SIT Migration RTTM Complete; 1048 Develop Automated SIT NFT RTTM; 1049 Review with SRO; 1050 Automated SIT NFT RTTM Complete; 1072 Non-Functional Theme 2 & 3 PP Preparation; 1074 PP SIT Non-Functional Test Readiness Report; 1075 Develop draft Test Readiness Report and submit to Programme for assurance; 1076 Placing Reliance Stage 2 Review; 1077 Finalise Test Readiness Report and submit to Programme for assurance; 1079 Assure Test Participants' Test Readiness Reports; 1081 Artefact review (via SITAG / SRO) and updates; 1108 Elexon Service Now Build and Implementation; 1111 Helix Knowledge Articles; 1138 Develop Automated SIT Operational RTTM; 1139 Automated SIT Operational RTTM Complete; 1146 PP SIT Operational Test Readiness Report; 1147 Test Readiness Report submitted to Programme for assurance; 1148 SI SIT Operational Test Readiness Report; 1149 Assure Test Participants' Test Readiness Reports; 1150 Develop Overarching SIT Operational Test Readiness Report; 1151 Artefact review (via SITAG) and updates; 1268 Defect resolution, assurance, review, data & environments maintenance; 1433 Environments (Non-SIT LDSO); 1434 Coordinate Qualification Participants' environment preparation; 1435 Coordinate deployment of MHHS solution code to Qualification Participants' UIT environments; 1436 Qualification Testing Tranche 1 Participants' UIT environments ready to start connectivity proving (incl. certificates and security compliance); 1437 Coordinate Qualification Participants' connectivity proving (Non-SIT LDSO); 1438 Assurance of Qualification Participants' connectivity proving; 1439 Environments (S&A) Wave 1; 1440 Coordinate Qualification Participants' environment preparation; 1441 Coordinate deployment of MHHS solution code to Qualification Participants' UIT environments; 1442 Qualification Testing Wave 1 Participants' UIT environments ready to start connectivity proving (incl. certificates and security compliance); 1443 Coordinate Qualification Participants' connectivity proving (S&A); 1444 Assurance of Qualification Participants' connectivity proving; 1445 Environments (S&A) Wave 2; 1446 Coordinate Qualification Participants' environment preparation; 1447 Coordinate deployment of MHHS solution code to Qualification Participants' UIT environments; 1448 Qualification Testing Wave 2 Participants' UIT environments ready to start connectivity proving (incl. certificates and security compliance); 1449 Coordinate Qualification Participants' connectivity proving (S&A); 1450 Assurance of Qualification Participants' connectivity proving; 1451 Environments (S&A) Wave 3; 1452 Coordinate Qualification Participants' environment preparation; 1453 Coordinate deployment of MHHS solution code to Qualification Participants' UIT environments; 1454 Qualification Testing Wave 3 Participants' UIT environments ready to start connectivity proving (incl. certificates and security compliance); 1455 Coordinate Qualification Participants' connectivity proving (S&A); 1456 Assurance of Qualification Participants' connectivity proving; 1457 Environments (S&A) Wave 4; 1458 Coordinate Qualification Participants' environment preparation; 1459 Coordinate deployment of MHHS solution code to Qualification Participants' UIT environments; 1460 Qualification Testing Wave 4 Participants' UIT environments ready to start connectivity proving (incl. certificates and security compliance); 1461 Coordinate Qualification Participants' connectivity proving (S&A); 1462 Assurance of Qualification Participants' connectivity proving; 1601 Non-SIT LDSO QT - Migration Testing; 1602 Non-SIT LDSO QT - Functional Testing; 1603 Non-SIT LDSO QT - Operational Testing; 1604 Non-SIT LDSO QT - Non-Functional Testing; 1605 Non-SIT LDSO QT - Regression Testing; 1614 BSC PAB & REC Manager approval of Qualification for Non-SIT LDSOs (Start of Migration for Qualification Participants); 1739 QT Non-Functional Test Scenarios and Test Cases; 1740 Draft Test Scenarios and Test Case list - Batch 2; 1741 Issue Batch 2 for Consultation; 1742 Update Batch 2 Post Consultation; 1743 QWG Endorsement of Batch 2; 1744 QAG Approval of QT Non-Functional Test Scenarios and Test Cases Batch 2; 1745 QT Operational Test Scenarios and Test Cases; 1746 Draft QT Operational Test Cases - Batch 1; 1747 Issue Batch 1 for Consultation; 1748 Update Batch 1 Post Consultation; 1749 QWG Endorsement of Batch 1; 1750 QAG Approval of QT Operational Test Scenarios and Test Cases Batch 1; 1751 Draft QT Operational Test Cases - Batch 2; 1752 Issue Batch 2 for Consultation; 1753 Update Batch 2 Post Consultation; 1754 QWG Endorsement of Batch 2; 1755 QAG Approval of QT Operational Test Scenarios and Test Cases Batch 2; 1770 DIP (SIT-A) Onboarding for Development inc. Test Stubs; 1771 DTN Onboarding for Development inc. Test Stubs; 1796 DIP available for Onboarding; 1797 Qualification Testing for Non-SIT S&A Participants' environments) Ready to start DIP onboarding (incl. certificates and security compliance); 1798 Non-SIT S&A QTF Environments Connection Confirmed to UIT Environment; 1803 New VPN Connection; 1805 Test Data (MPANs, DIP Messages, Settlement, Consumption, Reference); 1807 Test Data Templates and generator tools ready

Changed:

| ID | Task | Start | Finish | Duration | Complete | Total float | Predecessors | Other |
| --- | --- | --- | --- | --- | --- | --- | --- | --- |
| 1 | **PROGRAMME PLAN.** |  |  |  | 51% → 56% | 0d → none |  |  |
| 45 | **DESIGN, BUILD & TEST (PIT)** |  |  |  | 78% → 79% |  |  |  |
| 96 | **Design Artefact Releases** |  | 2024-11-13 → 2025-01-24 (+72d) | 451d → 503d? | 99% → 97% | 811d → 759d |  |  |
| 136 | **Interim release 8** |  | 2024-11-13 → 2025-01-24 (+72d) | 196d → 248d? | 99% → 84% | 811d → 759d |  |  |
| 139 | **Interim Release 8.3 - Maintenance Window** | 2024-10-07 A | 2024-10-21 A |  | 0% → 100% | 16d → none |  |  |
| 140 | Interim Release 8.3 'effective from date' to SIT A | 2024-10-21 A | 2024-10-21 A |  | 0% → 100% | 5d → none |  |  |
| 141 | Interim Release 8.3 'effective from date' to SIT B | 2024-10-07 A | 2024-10-07 A |  | 0% → 100% | 38d → none |  |  |
| 142 | **Interim Release 8.4** |  | 2024-11-13 → 2024-12-02 A (+19d) | 36d → 49d | 99% → 100% | 811d → none |  |  |
| 144 | Interim Release 8.4 Published | 2024-10-16 A | 2024-10-16 A |  | 0% → 100% | 811d → none |  | was named Interim release 8.4 Published |
| 145 | Interim Release 8.4 Deployed to SIT by Participants | 2024-11-13 → 2024-11-25 A (+12d) | 2024-11-13 → 2024-12-02 A (+19d) | 0d → 6d | 0% → 100% | 811d → none | 144FS+20d → 144FS+25d |  |
| 175 | **PP Design, Build & Test (DBT)** |  |  |  | 82% → 83% |  |  |  |
| 187 | **Design Handover** |  |  |  | 2% → 6% |  |  |  |
| 188 | **Creation of the Configuration Management Database** | 2024-09-02 A | 2024-09-19 A |  | 0% → 100% | 850d → none |  |  |
| 189 | Identify all baselined design artefacts | 2024-09-02 A | 2024-09-12 A |  | 0% → 100% | 850d → none |  |  |
| 190 | Create CMBD | 2024-09-13 A | 2024-09-19 A |  | 0% → 100% | 850d → none |  |  |
| 213 | **iServer** |  |  |  |  |  |  | was named Iserver |
| 312 | **SIT Participants DBT** |  | 2024-12-20 → 2025-02-21 (+63d) | 356d → 401d |  | 125d → 734d |  |  |
| 347 | **All SIT Programme Participants PIT (SIT Functional)** |  | 2024-12-20 → 2025-02-21 (+63d) | 286d → 331d |  | 125d → 734d |  |  |
| 381 | **All SIT Programme Participants PIT (SIT Non Functional)** |  | 2024-12-20 → 2025-02-21 (+63d) | 116d → 161d |  | 125d → 734d |  |  |
| 383 | SIT Non-Functional PIT Test Approach & Plan (PIT) submitted to Programme for assurance |  | 2024-09-27 A |  | 75% → 100% | 0d → none |  |  |
| 388 | SIT Non-Functional PIT RTTM submitted to Programme for assurance |  | 2024-11-01 A |  | 75% → 100% | 140d → none |  |  |
| 390 | **Test Scenarios** | 2024-11-01 A |  |  |  | 0d → 170d |  |  |
| 391 | SIT Non-Functional PIT test scenarios submitted to Programme for assurance | 2024-11-01 A | 2024-11-01 A |  | 0% → 100% | 0d → none |  |  |
| 393 | **PIT execution** |  | 2024-12-20 → 2025-02-21 (+63d) | 116d → 161d |  | 125d → 734d |  |  |
| 397 | SIT Non-Functional PIT Completion Report Theme 1 MHHS Review Completed | 2024-12-20 A |  |  | 0% → 50% | 125d → 155d |  | was named SIT Non-Functional PIT Completion Report MHHS Review Completed |
| 399 | **All SIT Programme Participants PIT (SIT Operational)** |  | 2024-12-20 → 2025-01-31 (+42d) | 116d → 146d |  | 87d → 66d |  |  |
| 400 | **Test Approach & Plan** | 2024-09-27 A |  |  |  | 0d → 117d |  |  |
| 401 | SIT Operational PIT Test Approach & Plan (PIT) submitted to Programme for assurance | 2024-09-27 A | 2024-09-27 A |  | 0% → 100% | 0d → none |  |  |
| 405 | **Requirements to test Traceability Matrix (RTTM)** | 2024-11-01 A |  |  |  | 102d → 111d |  |  |
| 406 | SIT Operational PIT RTTM submitted to Programme for assurance | 2024-11-01 A | 2024-11-01 A |  | 0% → 100% | 102d → none |  |  |
| 408 | **Test Scenarios** | 2024-11-01 A |  |  |  | 0d → 111d |  |  |
| 409 | SIT Operational PIT test scenarios submitted to Programme for assurance | 2024-11-01 A | 2024-11-01 A |  | 0% → 100% | 0d → none |  |  |
| 411 | **PIT execution** |  | 2024-12-20 → 2025-01-31 (+42d) | 116d → 146d |  | 87d → 66d |  |  |
| 414 | SIT Operational PIT Completion Report submitted to Programme for assurance | 2024-11-29 → 2025-01-10 (+42d) | 2024-11-29 → 2025-01-10 (+42d) |  |  | 87d → 66d | 412, 413 → 412, 413FS+30d |  |
| 415 | SIT Operational PIT Completion Report MHHS Review Completed | 2024-12-20 → 2025-01-31 (+42d) | 2024-12-20 → 2025-01-31 (+42d) |  |  | 87d → 66d |  |  |
| 467 | **DBT Monitoring and Assurance** |  |  |  | 64% → 69% |  |  |  |
| 472 | **Design Assurance** |  |  |  | 71% → 80% |  |  |  |
| 503 | **Non-SIT PPs design assurance** |  |  |  | 33% → 53% |  |  |  |
| 504 | Non-SIT PPs design assurance (risk-based sample) |  |  |  | 33% → 53% |  |  |  |
| 505 | **Test Assurance** |  |  |  | 63% → 71% |  |  |  |
| 506 | Non-SIT PPs test assurance |  |  |  | 63% → 71% |  |  |  |
| 513 | **SYSTEMS INTEGRATION TESTING (SIT)** |  |  |  | 62% → 72% |  |  |  |
| 514 | **SIT Preparation** |  |  |  | 81% → 93% |  |  |  |
| 595 | **SIT Stage-Specific Preparation** |  |  |  | 77% → 91% |  |  |  |
| 836 | **SIT Functional Preparation** |  | 2025-04-07 → 2025-02-07 A (-59d) | 636d? → 595d? | 85% → 100% | 708d → none |  |  |
| 853 | **Test cases** |  | 2025-02-07 A |  | 84% → 100% | 749d → none |  |  |
| 860 | **SIT Functional Programme RTTM** |  | 2024-10-11 → 2024-11-07 A (+27d) | 55d? → 74d? | 95% → 100% | 834d → none |  |  |
| 861 | **RTTM Development** |  | 2024-09-20 → 2024-09-06 A (-14d) | 40d? → 30d? | 99% → 100% | 849d → none |  |  |
| 864 | **Gap analysis** |  | 2024-10-11 → 2024-11-07 A (+27d) | 35d? → 54d? | 86% → 100% | 834d → none |  |  |
| 865 | Identify gaps in test case coverage following RTTM review |  |  |  |  |  | Development of Automated SIT Functional RTTMSS+20d → none | was named Identify gaps in test case coverage following RTTM review. |
| 866 | Address gaps in test case coverage following RTTM review |  | 2024-10-04 → 2024-10-11 A (+7d) | 20d → 25d | 80% → 100% | 834d → none |  | was named Address gaps in test case coverage following RTTM review. |
| 867 | Gap analysis complete | 2024-10-11 A | 2024-10-11 A |  | 0% → 100% | 834d → none | SRO ApprovalFS+2d → 866 |  |
| 881 | **Cycle 3 Test Evidence Capturing Approach** |  | 2024-10-18 A |  | 93% → 100% | 3d → none |  |  |
| 886 | Incorporate feedback |  | 2024-10-17 A |  | 80% → 100% | 3d → none |  |  |
| 887 | Publish proposed approach ahead of Cycle 3 start | 2024-10-18 A | 2024-10-18 A |  | 0% → 100% | 3d → none |  |  |
| 888 | **DITL Cycle 3 Pack Development** |  | 2024-10-17 A |  | 31% → 100% | 830d → none |  |  |
| 890 | Post-retro DITL Changes |  | 2024-10-11 A |  | 50% → 100% | 830d → none |  |  |
| 891 | SRO Review | 2024-10-14 A | 2024-10-15 A |  | 0% → 100% | 830d → none |  |  |
| 892 | Post-SRO Review Changes | 2024-10-16 A | 2024-10-16 A |  | 0% → 100% | 830d → none |  |  |
| 893 | Publish Cycle 3 DITL / Cycle 3 DITL Online Sessions for SIT PPs | 2024-10-17 A | 2024-10-17 A |  | 0% → 100% | 830d → none |  |  |
| 894 | **Test Script Exit Points** |  | 2025-02-07 A |  | 7% → 100% | 749d → none |  |  |
| 895 | Implement exit points for Sprint 5 |  | 2024-10-18 A |  | 60% → 100% | 829d → none |  | was named Identify exit points for Sprint 5 |
| 896 | Identify exit points for Sprint 6 | 2024-10-21 → 2024-11-07 A (+17d) | 2024-10-25 → 2024-11-13 A (+19d) |  | 0% → 100% | 824d → none |  |  |
| 897 | Identify exit points for Sprint 7 | 2024-11-04 → 2024-11-08 A (+4d) | 2024-11-08 → 2024-11-14 A (+6d) |  | 0% → 100% | 814d → none |  | constraint none → start no earlier than 2024-11-08 |
| 898 | Identify exit points for Sprint 8 | 2024-11-18 A | 2024-11-22 A |  | 0% → 100% | 804d → none |  |  |
| 899 | Identify exit points for Sprint 9 | 2024-12-02 A | 2024-12-06 A |  | 0% → 100% | 794d → none |  |  |
| 900 | Identify exit points for Sprint 10 | 2024-12-23 A | 2024-12-27 A |  | 0% → 100% | 779d → none |  |  |
| 901 | Identify exit points for Sprint 11 | 2025-01-06 A | 2025-01-10 A |  | 0% → 100% | 769d → none |  |  |
| 902 | Identify exit points for Sprint 12 | 2025-01-20 A | 2025-01-24 A |  | 0% → 100% | 759d → none |  |  |
| 903 | Identify exit points for Sprint 13 | 2025-02-03 A | 2025-02-07 A |  | 0% → 100% | 749d → none |  |  |

| ID | Task | Start | Finish | Duration | Complete | Total float | Predecessors | Other |
| --- | --- | --- | --- | --- | --- | --- | --- | --- |
| 922 | **Test data (SIT A)** |  | 2025-04-07 → 2024-10-21 A (-168d) | 341d? → 221d? | 57% → 100% | 708d → none |  |  |
| 933 | **Cycle 3 Test data (SIT A) (2)** |  | 2024-10-21 A |  | 80% → 100% | 828d → none |  |  |
| 948 | New MPAN creation and load through DCC and St Clements |  | 2024-10-11 A |  | 95% → 100% | 834d → none |  |  |
| 949 | Share files with PP's and central parties | 2024-10-11 A | 2024-10-11 A |  | 0% → 100% | 834d → none |  |  |
| 950 | Avanade to load data | 2024-10-14 A | 2024-10-21 A |  | 0% → 100% | 828d → none |  |  |
| 951 | Helix to load data | 2024-10-14 A | 2024-10-21 A |  | 0% → 100% | 828d → none |  |  |
| 952 | PP's and central parties to load all Cycle 3 data | 2024-10-14 A | 2024-10-21 A |  | 0% → 100% | 828d → none |  |  |
| 953 | All parties to finalise data load | 2024-10-21 A | 2024-10-21 A |  | 0% → 100% | 34d → none |  |  |
| 964 | **SIT Migration Testing Preparation** |  | 2024-10-04 → 2025-02-07 (+126d) | 505d? → 595d? | 98% → 96% | 839d → 749d |  |  |
| 975 | **Test scenarios & Test Cases** |  | 2024-10-04 → 2025-02-07 (+126d) | 207d? → 297d? | 93% → 88% | 839d → 749d |  |  |
| 994 | **RTTM Development** |  | 2024-10-04 → 2024-09-20 A (-14d) | 27d? → 17d | 84% → 100% | 839d → none |  |  |
| 997 | **Gap analysis** |  | 2024-10-04 → 2025-02-07 (+126d) | 17d? → 107d? | 60% → 75% | 839d → 749d |  |  |
| 999 | Address gaps in test case coverage following RTTM review. |  | 2024-10-04 → 2024-10-11 A (+7d) | 12d → 17d | 20% → 100% | 839d → none |  |  |
| 1000 | Gap analysis complete | 2024-10-04 → 2024-10-11 A (+7d) | 2024-10-04 → 2024-10-11 A (+7d) |  | 0% → 100% | 839d → none |  |  |
| 1068 | **SIT Non-Functional Preparation** |  | 2025-03-14 → 2025-03-28 (+14d) | 337d? → 347d? | 51% → 73% | 724d → 714d |  |  |
| 1079 | **Test scenarios & Test Cases** |  |  |  | 78% → 85% |  |  |  |
| 1098 | **SIT NFT Programme RTTM** | 2024-09-18 A | 2024-10-16 → 2024-11-19 A (+34d) | 21d? → 45d | 0% → 100% | 831d → none |  |  |
| 1099 | Develop Manual SIT NFT RTTM | 2024-09-18 A | 2024-10-08 → 2024-10-29 A (+21d) | 15d → 30d | 0% → 100% | 831d → none |  | baseline finish 2024-10-08 → 2024-10-29 |
| 1101 | Review with SRO | 2024-10-09 → 2024-11-13 A (+35d) | 2024-10-09 → 2024-11-19 A (+41d) | 1d? → 5d | 0% → 100% | 836d → none | 1099 → 1100 | baseline start 2024-10-09 → 2024-11-13; baseline finish 2024-10-09 → 2024-11-19 |
| 1104 | Manual SIT NFT RTTM Complete | 2024-10-08 → 2024-11-19 A (+42d) | 2024-10-08 → 2024-11-19 A (+42d) |  | 0% → 100% | 831d → none | 1099 → 1101, 1102 | baseline start 2024-10-08 → 2024-11-19; baseline finish 2024-10-08 → 2024-11-19 |
| 1124 | **NFT Performance Tool Theme 1 Setup** |  | 2025-01-10 → 2025-03-12 (+61d) | 225d? → 268d? | 68% → 98% | 769d → 726d |  |  |
| 1128 | Theme 1 injection tool configuration and validation againast UIT DIP (IR8.1) | 2024-10-02 A | 2024-10-16 A |  | 0% → 100% | 769d → none |  |  |
| 1129 | Theme 1 injection tool configuration and validation against SIT-B DIP (IR8.X) | 2024-10-17 → 2025-03-10 (+144d) | 2025-01-10 → 2025-03-12 (+61d) | 62d? → 3d? |  | 769d → 726d | 1128 → 1543FS+10d | was named Theme 1 injection tool configuration and validation against SIT-B DIP (IR8.3); baseline start 2024-10-17 → 2025-01-06; baseline finish 2025-01-10 → 2025-01-08 |
| 1130 | **Environments (SIT B)** |  | 2025-01-03 → 2025-02-28 (+56d) | 94d? → 134d |  | 774d → 25d |  |  |
| 1133 | **SI Environments (SIT B)** | 2024-08-27 A | 2024-08-27 A |  | 0% → 100% | 868d → none |  |  |
| 1134 | Coordinate deployment of MHHS solution code to SIT Participants' SIT B environments | 2024-08-27 A | 2024-08-27 A |  | 0% → 100% | 868d → none |  |  |
| 1135 | **Helix and Avanade Environments Upscale** | 2024-12-23 → 2025-02-24 (+63d) | 2025-01-03 → 2025-02-28 (+56d) | 10d? → 5d |  | 60d → 25d |  |  |
| 1136 | Environment Uplift Window | 2024-12-23 → 2025-02-24 (+63d) | 2025-01-03 → 2025-02-28 (+56d) | 10d? → 5d |  | 60d → 25d | 1527 → 1543 |  |
| 1137 | **Test Data - Non-Functional and Operational (SIT B)** | 2025-01-06 → 2025-02-24 (+49d) | 2025-03-14 → 2025-03-28 (+14d) | 50d? → 25d? |  | 60d → 6d |  |  |
| 1138 | **Data Load** | 2025-01-06 → 2025-02-24 (+49d) | 2025-03-14 → 2025-03-28 (+14d) | 50d? → 25d? |  | 60d → 6d |  |  |
| 1139 | Non-Functional Theme 1 (Avenade) Data Load | 2025-01-06 → 2025-02-24 (+49d) | 2025-01-10 → 2025-02-28 (+49d) |  |  | 60d → 6d | 1136 → 1543 | was named Non-Functional Theme 1 (Helix & DIP Volume Testing) Data Load; baseline start 2025-01-06 → 2025-02-24; baseline finish 2025-01-10 → 2025-02-28 |
| 1140 | Non-Functional Theme 2 & 3 (Helix, Avenade & PPs) Data Load | 2025-02-03 → 2025-03-24 (+49d) | 2025-02-07 → 2025-03-28 (+49d) |  |  | 70d → 6d |  | was named Non-Functional Theme 2 & 3 (Helix and DIP) Data Load; baseline start 2025-02-03 → 2025-03-24; baseline finish 2025-02-07 → 2025-03-28 |
| 1141 | Non-Functional Themes 2 & 3 (LDSO's and DCC) Data Load | 2025-01-06 → 2025-03-03 (+56d) | 2025-01-31 → 2025-03-21 (+49d) | 20d? → 15d |  | 100d → 65d |  | was named Non-Functional Themes 2 & 3 (Central Parties and PPs) Data Load; baseline start 2025-01-06 → 2025-03-03; baseline finish 2025-01-31 → 2025-03-21 |
| 1142 | Operational Themes 1, 2 & 3 (Batch 2) (LDSO's and DCC) Data Load | 2025-01-06 → 2025-03-03 (+56d) | 2025-01-31 → 2025-03-28 (+56d) |  |  | 65d → 25d |  | was named Operational Themes 1, 2 & 3 (Batch 2) (Central Parties and PPs) Data Load; baseline start 2025-01-06 → 2025-03-03; baseline finish 2025-01-31 → 2025-03-28 |
| 1143 | Operational Themes 1, 2 & 3 (Batch 2) (Helix, Avenade & PPs) Data Load | 2025-02-03 → 2025-03-24 (+49d) | 2025-02-07 → 2025-03-28 (+49d) |  |  | 60d → 25d |  | was named Operational Themes 1, 2 & 3 (Batch 2) (Helix & DIP) Data Load; baseline start 2025-02-03 → 2025-03-24; baseline finish 2025-02-07 → 2025-03-28 |
| 1144 | Non-Functional and Operational Test Data Preparation Complete | 2025-02-07 → 2025-03-28 (+49d) | 2025-02-07 → 2025-03-28 (+49d) |  |  | 749d → 714d |  | baseline start 2025-02-07 → 2025-03-28; baseline finish 2025-02-07 → 2025-03-28 |
| 1145 | **SIT Non-Functional Test Readiness Report** | 2024-06-25 A → 2025-01-20 A (+209d) | 2025-03-07 → 2025-03-27 (+20d) | 184d → 48d | 19% → 7% | 70d → 716d |  |  |
| 1146 | **SIT Non-Functional Theme 1 Overarching Test Readiness Report** | 2024-06-25 A → 2025-01-21 (+210d) | 2025-01-10 → 2025-02-28 (+49d) | 144d → 29d | 22% → 0% | 95d → 35d |  | was named SI SIT Non-Functional Test Readiness Report |
| 1147 | Develop Overarching SIT Non-Functional Theme 1 Overarching Test Readiness Report | 2024-12-02 A → 2025-01-21 (+50d) | 2024-12-20 → 2025-02-04 (+46d) | 15d → 11d | 47% → 0% | 95d → 736d | Assure Test Participants' Test Readiness ReportsFS-10d → 397 | was named Develop Overarching SIT Non-Functional Test Readiness Report; constraint none → finish no earlier than 2025-02-04 |
| 1148 | SRO review | 2024-10-21 → 2025-02-05 (+107d) | 2024-10-25 → 2025-02-11 (+109d) |  |  | 818d → 736d | Define proposal for rationalisation of test cases → 1147 | constraint none → finish no earlier than 2025-02-10; baseline start 2024-10-21 → 2025-01-10; baseline finish 2024-10-25 → 2025-01-16 |
| 1179 | Implement reporting | 2025-03-07 → 2025-01-27 (-39d) | 2025-03-07 → 2025-02-14 (-21d) | 0d → 15d |  | 70d → 130d | Artefact review (via SITAG / SRO) and updatesFF+15d, 842, 397, 1085, 1091, 1097, Placing Reliance Stage 2 Review → 842, 397, 1085, 1091, 1097, 1178 | was named SIT Non-Functional Testing Preparation Complete; baseline start 2025-03-07 → 2025-01-27; baseline finish 2025-03-07 → 2025-02-14 |
| 1182 | **SIT Operational Preparation** | 2024-02-01 A → 2022-10-31 A (-458d) | 2025-01-31 → 2025-05-05 (+94d) | 262d? → 656d? | 38% → 89% | 754d → 688d |  |  |
| 1193 | **Test scenarios & Test Cases** |  | 2025-01-31 → 2024-09-06 A (-147d) | 213d? → 108d | 31% → 100% | 754d → none |  |  |
| 1235 | **Elexon / Helix Service Now Test Prep** | 2024-07-15 → 2024-08-01 A (+17d) | 2025-01-31 → 2025-01-14 A (-17d) | 145d? → 119d? | 0% → 100% | 115d → none |  | was named Elexon / Helix Service Management Test Prep |
| 1266 | ServiceNow SIT Ops Available | 2024-09-09 → 2025-01-14 A (+127d) | 2025-01-31 → 2025-01-14 A (-17d) | 105d? → 0d? | 0% → 100% | 115d → none | none → 1240, 1245, 1250, 1255, 1260, 1265 | was named Helix Engagement and Comms; baseline start 2024-09-09 → 2025-01-14; baseline finish 2025-01-31 → 2025-01-14 |
| 1267 | **Helix Service Management Documentation (Service Design Pack)** | 2024-09-09 → 2024-08-01 A (-39d) | 2025-01-31 → 2025-01-08 A (-23d) | 105d? → 115d | 0% → 100% | 115d → none |  | was named Helix Service Management Documentation (Service Design Pack and Service User Op Model); constraint start no earlier than 2024-09-09 → none |
| 1300 | **Theme 3 (Batch 2)** |  | 2024-12-11 → 2024-12-18 A (+7d) | 60d? → 65d | 26% → 100% | 791d → none |  |  |
| 1301 | Conclude BCDR Scope with SRO, Code Bodies and DIP Manager |  | 2024-10-18 A |  | 50% → 100% | 829d → none |  |  |
| 1303 | Develop DIP Test Scenarios and Test Cases (Batch 2) | 2024-09-19 A | 2024-10-25 A |  | 0% → 100% | 1d → none |  |  |
| 1304 | SRO Review | 2024-10-28 A | 2024-11-01 A |  | 0% → 100% | 1d → none |  |  |
| 1305 | Industry Consultation (Batch 2) | 2024-11-04 A → 2024-11-11 A (+7d) | 2024-11-15 → 2024-11-22 A (+7d) |  | 10% → 100% | 94d → none |  | was named Industry Review Workshop (Batch 2); baseline start 2024-11-04 → 2024-11-11; baseline finish 2024-11-15 → 2024-11-22 |
| 1306 | Review Feedback and Update | 2024-11-18 → 2024-11-25 A (+7d) | 2024-11-22 → 2024-11-28 A (+6d) | 5d → 4d | 0% → 100% | 94d → none |  | baseline start 2024-11-18 → 2024-11-25; baseline finish 2024-11-22 → 2024-11-29 |
| 1308 | Review with SIT WG (Batch 2) | 2024-11-28 → 2024-11-29 A (+1d) | 2024-12-05 A | 6d → 5d | 0% → 100% | 94d → none | 1306FS+3d → 1307 | baseline start 2024-11-28 → 2024-11-29 |
| 1311 | SITAG approve Theme 3 (Batch 2) | 2024-12-11 → 2024-12-18 A (+7d) | 2024-12-11 → 2024-12-18 A (+7d) | 1d? → 1d | 0% → 100% | 94d → none | 1308FS+3d → 1310FS+4d | was named SITAG Approval (Batch 2); baseline start 2024-12-11 → 2024-12-18; baseline finish 2024-12-11 → 2024-12-18 |
| 1312 | **Theme 3 (Batch 1)** |  | 2024-12-11 → 2024-12-18 A (+7d) | 176d? → 181d? | 75% → 100% | 94d → none |  |  |
| 1315 | Review Feedback and Update |  | 2024-09-26 A |  | 90% → 100% | 7.5d → none |  |  |
| 1316 | Draft Test Cases from Feedback and LLSD |  | 2024-10-18 A |  | 50% → 100% | 94d → none |  |  |
| 1317 | SRO Review | 2024-10-21 A | 2024-10-25 A |  | 0% → 100% | 94d → none |  |  |
| 1318 | Industry Consultation | 2024-10-28 A | 2024-11-08 A |  | 0% → 100% | 94d → none |  |  |
| 1319 | Review Feedback and Update | 2024-11-11 A | 2024-11-15 → 2024-11-22 A (+7d) | 5d → 10d | 0% → 100% | 94d → none |  |  |
| 1321 | Review with SITWG (Batch 1) | 2024-11-28 → 2024-11-29 A (+1d) | 2024-12-04 → 2024-12-05 A (+1d) | 5d? → 5d | 0% → 100% | 94d → none | 1319FS+8d → 1320 | baseline start 2024-11-28 → 2024-11-29; baseline finish 2024-12-04 → 2024-12-05 |
| 1324 | SITAG approve Theme 3 (Batch 1) | 2024-12-11 → 2024-12-18 A (+7d) | 2024-12-11 → 2024-12-18 A (+7d) | 1d → 0d | 0% → 100% | 94d → none | 1321FS+4d → 1323FS+5d | was named SITAG for approval (Batch 1); baseline start 2024-12-11 → 2024-12-18; baseline finish 2024-12-11 → 2024-12-18 |
| 1325 | SIT Operational Scenarios & Test Cases Approved - Theme 3 (Batch 1 + 2) | 2024-12-11 → 2024-12-18 A (+7d) | 2024-12-11 → 2024-12-18 A (+7d) |  | 0% → 100% | 94d → none |  | baseline start 2024-12-11 → 2024-12-18; baseline finish 2024-12-11 → 2024-12-18 |
| 1326 | **Helix SDD and LLSD Development and Approval** | 2024-09-27 A | 2024-09-30 A |  | 0% → 100% | 8.5d → none |  |  |
| 1327 | Development | 2024-09-27 A | 2024-09-27 A |  | 0% → 100% | 845d → none |  |  |
| 1328 | Approval | 2024-09-30 A | 2024-09-30 A |  | 0% → 100% | 7.5d → none |  |  |
| 1329 | **SIT Operational Programme RTTM** | 2024-12-12 → 2024-12-09 A (-3d) | 2025-01-17 → 2025-01-24 (+7d) | 27d? → 35d | 0% → 71% | 764d → 688d |  |  |
| 1330 | Develop Manual SIT Operational RTTM | 2024-12-12 → 2024-12-09 A (-3d) | 2025-01-10 A | 22d? → 25d | 0% → 100% | 764d → none | 1325 → 1325FF |  |
| 1334 | Manual SIT Operational RTTM Complete | 2025-01-10 → 2025-01-24 (+14d) | 2025-01-10 → 2025-01-24 (+14d) |  |  | 769d → 688d | 1330 → 1330, 1333 |  |
| 1354 | **Environments (SIT B)** | 2024-10-07 A | 2024-10-07 A |  | 0% → 100% | 38d → none |  |  |

| ID | Task | Start | Finish | Duration | Complete | Total float | Predecessors | Other |
| --- | --- | --- | --- | --- | --- | --- | --- | --- |
| 1355 | **PP Environments (SIT B)** | 2024-10-07 A | 2024-10-07 A |  | 0% → 100% | 38d → none |  |  |
| 1356 | Deployment of MHHS solution code to SIT B environments | 2024-10-07 A | 2024-10-07 A |  | 0% → 100% | 38d → none |  |  |
| 1357 | **SI Environments (SIT B)** | 2024-10-07 A | 2024-10-07 A |  | 0% → 100% | 38d → none |  |  |
| 1358 | Coordinate deployment of MHHS solution code to SIT Participants' SIT B environments | 2024-10-07 A | 2024-10-07 A |  | 0% → 100% | 38d → none |  |  |
| 1359 | **SIT Operational Overarching Test Readiness Reports** | 2024-08-05 A |  | 33d → 33d? | 0% → 22% |  |  | was named SIT Operational Test Readiness Report |
| 1395 | SIT Operational Theme 1, 2, 3 (Batch 2) Testing Preparation Complete | 2025-01-17 → 2025-03-28 (+70d) | 2025-01-17 → 2025-03-28 (+70d) |  |  | 67d → 26d | 415, 1199, 1205, 1325, Artefact review (via SITAG) and updates → 415, 1199, 1205, 1325, 1375 | was named SIT Operational Testing Preparation Complete; baseline start 2025-01-17 → 2025-03-31; baseline finish 2025-01-17 → 2025-04-25 |
| 1396 | **Regression Test Preparation** | 2024-09-16 A → 2024-11-18 A (+63d) | 2025-05-16 → 2024-11-19 (-178d) | 175d? → 2d? | 3% → 10% | 679d → none |  | was named Regression Test Preperation |
| 1397 | **Regression Test Approach** | 2024-09-16 A → 2024-11-18 A (+63d) | 2024-11-20 → 2024-11-29 (+9d) | 48d → 10d | 7% → 22% | 119d → none |  |  |
| 1398 | Develop approach doc | 2024-09-16 A → 2024-11-18 A (+63d) | 2024-10-15 → 2025-01-15 (+92d) | 22d → 43d | 10% → 35% | 119d → 16d |  | baseline start 2024-09-16 → 2024-11-18; baseline finish 2024-10-15 → 2024-12-13 |
| 1399 | SRO / LDP review of approach doc | 2024-10-16 → 2025-01-16 (+92d) | 2024-10-18 → 2025-01-22 (+96d) | 3d → 5d |  | 119d → 16d |  | was named SRO review of approach doc; baseline start 2024-10-16 → 2024-12-16; baseline finish 2024-10-18 → 2024-12-18 |
| 1400 | Incorporate SRO feedback into approach doc | 2024-10-28 → 2025-01-16 (+80d) | 2024-10-29 → 2025-01-22 (+85d) | 2d → 5d |  | 119d → 16d | 1399FS+5d → 1399FF | was named SITWG feedback on approach doc; baseline start 2024-10-28 → 2024-12-19; baseline finish 2024-10-29 → 2024-12-20 |
| 1405 | Incorporate eSITWG feedback into approach doc | 2024-10-30 → 2025-02-19 (+112d) | 2024-10-31 → 2025-02-20 (+112d) |  |  | 119d → 735d | 1400 → 1404 | was named Incorporate SRO + SITWG feedback into approach doc; baseline start 2024-10-30 → 2025-01-09; baseline finish 2024-10-31 → 2025-01-09 |
| 1406 | eSITAG paper day | 2024-11-07 → 2025-02-20 (+105d) | 2024-11-07 → 2025-02-20 (+105d) | 1d → 0d |  | 119d → 735d | 1405FS+4d → 1405 | was named SITWG Recommendation; baseline start 2024-11-07 → 2025-01-09; baseline finish 2024-11-07 → 2025-01-09 |
| 1407 | eSITAG (inc SRO) Approval | 2024-11-20 → 2025-02-28 (+100d) | 2024-11-20 → 2025-02-28 (+100d) |  |  | 119d → 734d | 1406FS+9d → 1406FS+5d | was named SITAG (inc SRO) Approval; constraint none → finish no earlier than 2025-02-28; baseline start 2024-11-20 → 2025-01-16; baseline finish 2024-11-20 → 2025-01-16 |
| 1408 | SIT Regression Testing Approach and Plan Approval | 2024-11-20 → 2025-02-28 (+100d) | 2024-11-20 → 2025-02-28 (+100d) |  |  | 119d → 734d |  | baseline start 2024-11-20 → 2025-01-16; baseline finish 2024-11-20 → 2025-01-16 |
| 1409 | **Regression Test Suite** | 2024-11-21 → 2025-02-12 (+83d) | 2025-01-13 → 2025-04-16 (+93d) | 38d? → 46d |  | 119d → 16d |  | baseline start 2024-11-21 → 2025-01-17; baseline finish 2025-01-13 → 2025-03-18 |
| 1410 | Build Regression Test Suite | 2024-11-21 → 2025-02-12 (+83d) | 2024-12-06 → 2025-02-28 (+84d) | 12d → 13d |  | 119d → 16d | 1408 → 1403 | baseline start 2024-11-21 → 2025-01-17; baseline finish 2024-12-06 → 2025-02-06 |
| 1414 | SRO Review of regression suite doc | 2024-12-09 → 2025-03-03 (+84d) | 2024-12-20 → 2025-03-07 (+77d) | 10d → 5d |  | 119d → 16d |  | baseline start 2024-12-09 → 2025-02-07; baseline finish 2024-12-20 → 2025-02-20 |
| 1419 | SITWG endorses regression suite doc | 2024-12-30 → 2025-04-03 (+94d) | 2025-01-03 → 2025-04-03 (+90d) | 5d → 0d |  | 119d → 16d | 1414FS+5d → 1418FS+5d | was named SITWG Feedback on regression suite doc; constraint none → finish no earlier than 2025-04-03; baseline start 2024-12-30 → 2025-03-06; baseline finish 2025-01-03 → 2025-03-06 |
| 1420 | Incorporate SITWG feedback into regression suite doc | 2025-01-06 → 2025-04-04 (+88d) | 2025-01-06 → 2025-04-04 (+88d) | 1d? → 1d |  | 119d → 16d |  | was named Incorporate SRO + SITWG feedback into regression suite doc; baseline start 2025-01-06 → 2025-03-07; baseline finish 2025-01-06 → 2025-03-11 |
| 1421 | eSITAG paper day | 2025-01-06 → 2025-04-09 (+93d) | 2025-01-06 → 2025-04-09 (+93d) |  |  | 119d → 13d |  | was named SRO Approval; constraint none → finish no earlier than 2025-04-09; baseline start 2025-01-06 → 2025-03-11; baseline finish 2025-01-06 → 2025-03-11 |
| 1423 | SIT Regression Approval | 2025-01-13 → 2025-04-16 (+93d) | 2025-01-13 → 2025-04-16 (+93d) |  |  | 768d → 13d | 1421FS+5d → 1422 | was named SIT Regression Suite Approval at SITAG; baseline start 2025-01-13 → 2025-03-18; baseline finish 2025-01-13 → 2025-03-18 |
| 1424 | **Regression Test Data Load Window (SIT Functional and Migration) - SIT A** | 2025-03-14 → 2025-04-28 (+45d) | 2025-03-17 → 2025-04-29 (+43d) |  |  |  |  |  |
| 1426 | Regression Test Data Load Start |  |  |  |  |  | 1583, 1523FS+1d, 1587FS+1d → 1583, 1523FS+1d, 1587FS+1d, 1425, 1423 |  |
| 1427 | Regression Test Data Load Window | 2025-04-28 → 2025-04-29 (+1d) |  | 15d? → 14d |  |  | 1426FS-1d → 1426 | constraint none → start no earlier than 2025-04-28 |
| 1428 | **Single Instance ADO** |  |  |  | 86% → 98% |  |  |  |
| 1429 | **Single ADO Project for all Cohorts - Implementation and Test Phase** |  | 2024-10-01 A |  | 89% → 100% | 842d → none |  |  |
| 1439 | Migrate defects from cohort project to master - Option 2 | 2024-09-23 A | 2024-09-25 A |  | 0% → 100% | 846d → none |  |  |
| 1459 | **Reporting Changes - Daily Excel Extract & PDF** | 2024-09-05 A | 2024-09-06 A |  | 0% → 100% | 859d → none |  |  |
| 1460 | Excel Daily Report changes (Refer to above) | 2024-09-05 A | 2024-09-06 A |  | 0% → 100% | 859d → none |  |  |
| 1461 | PDF Daily Report changes (Refer to Above) | 2024-09-05 A | 2024-09-06 A |  | 0% → 100% | 859d → none |  |  |
| 1462 | **Documentation Updates** |  | 2024-10-02 A |  | 80% → 100% | 841d → none |  |  |
| 1463 | Changes to onboarding process (security) | 2024-09-02 A | 2024-09-13 A |  | 0% → 100% | 854d → none |  |  |
| 1480 | **SIT Execution** |  |  |  | 15% → 36% |  |  |  |
| 1491 | SIT Component Integration Testing End (incl. confirmation that PPs have submitted their Test Completion Reports to Programme for assurance) |  |  |  |  |  |  | constraint none → finish no earlier than 2024-02-23 |
| 1497 | **SIT - Minimum Viable Cohort (MVC)** |  |  |  | 8% → 35% |  |  |  |
| 1498 | **SIT Functional Testing (MVC)** |  |  |  | 20% → 49% |  |  |  |
| 1500 | **SIT Functional Testing Execution (Minimum Viable Cohort)** |  |  |  | 20% → 49% |  |  |  |
| 1504 | **Cycle 2 (Defect retests and targeted regression testing)** |  | 2024-10-04 A |  | 41% → 100% | 839d → none |  |  |
| 1505 | Test Execution |  | 2024-09-20 A |  | 47% → 100% | 190d → none |  |  |
| 1506 | Defect resolution, assurance, review, data & environments maintenance | 2024-09-23 A | 2024-10-04 A |  | 0% → 100% | 839d → none |  |  |
| 1510 | **Cycle 3 (Defect retests and targeted regression testing)** | 2024-10-21 A |  |  | 0% → 41% |  |  |  |
| 1511 | Sprint 5 | 2024-10-21 A | 2024-11-01 A |  | 0% → 100% | 5d → none |  |  |
| 1512 | Sprint 6 | 2024-11-04 A | 2024-11-15 A |  | 0% → 100% | 5d → none |  |  |
| 1513 | Sprint 7 | 2024-11-18 A | 2024-11-29 A |  | 0% → 100% | 5d → none |  |  |
| 1514 | Sprint 8 | 2024-12-02 A | 2024-12-20 A |  | 0% → 100% | 5d → none |  |  |
| 1515 | Christmas downtime | 2024-12-23 A | 2025-01-03 A |  | 0% → 100% | 5d → none |  |  |
| 1516 | Sprint 9 | 2025-01-06 A |  |  | 0% → 10% |  |  |  |
| 1525 | **SIT Functional Settlement Testing** |  |  |  | 0% → 35% |  |  |  |
| 1526 | SIT-B Settlement Testing Cycle 2 | 2024-06-17 → 2025-03-10 (+266d) | 2024-09-20 → 2025-06-13 (+266d) |  |  | 849d → 659d | none → 1543FS+10d | was named Settlement Testing Cycle 1 |
| 1527 | **SIT-B Settlement Testing Cycle 3** | 2024-10-07 A | 2024-12-20 → 2025-02-21 (+63d) | 55d? → 100d? | 0% → 68% | 38d → 664d |  | was named Settlement Testing Cycle 2 |
| 1544 | SIT-A CoS Settlement Testing |  |  |  |  |  | Regression - PP's confirmation that test data is ready for SIT Functional, 1427 → 1427 | was named Settlement Testing Cycle 3 (CoS Settlement Testing) |
| 1548 | Regression Sprint 2 |  | 2025-07-11 → 2025-07-18 (+7d) | 10d → 15d |  |  |  | baseline finish 2025-07-11 → 2025-07-18 |
| 1549 | Regression Sprint 3 | 2025-07-14 → 2025-07-21 (+7d) | 2025-08-01 → 2025-08-08 (+7d) |  |  |  |  | baseline start 2025-07-14 → 2025-07-21; baseline finish 2025-08-01 → 2025-08-08 |
| 1550 | SIT Functional Testing End (Minimum Viable Cohort) (incl. confirmation that PPs have submitted their Test Completion Reports to Programme for assurance) | 2025-08-01 → 2025-08-08 (+7d) | 2025-08-01 → 2025-08-08 (+7d) |  |  |  |  | baseline start 2025-08-01 → 2025-08-08; baseline finish 2025-08-01 → 2025-08-08 |
| 1551 | Assurance of PPs Test Completion Reports | 2025-06-30 → 2025-07-14 (+14d) | 2025-08-08 → 2025-08-15 (+7d) | 30d → 25d |  |  |  | baseline start 2025-06-30 → 2025-07-14; baseline finish 2025-08-08 → 2025-08-15 |
| 1552 | **SIT Functional Test Completion Report (Minimum Viable Cohort)** | 2025-07-14 → 2025-07-21 (+7d) |  | 25d → 20d |  |  |  | baseline start 2025-07-14 → 2025-07-21 |
| 1553 | Develop document | 2025-07-14 → 2025-07-21 (+7d) | 2025-08-01 → 2025-08-08 (+7d) |  |  |  |  | baseline start 2025-07-14 → 2025-07-21; baseline finish 2025-08-01 → 2025-08-08 |
| 1554 | Review & agree document | 2025-08-04 → 2025-08-11 (+7d) | 2025-08-08 → 2025-08-15 (+7d) |  |  |  |  | baseline start 2025-08-04 → 2025-08-11; baseline finish 2025-08-08 → 2025-08-15 |
| 1555 | SIT Functional Testing Test Completion Report (Minimum Viable Cohort) Approved |  |  |  |  |  | 1554FF+5d → 1554FF |  |
| 1556 | **Helix E2E Settlement Testing** | 2025-01-06 → 2025-02-07 (+32d) | 2025-04-04 → 2025-06-06 (+63d) | 65d → 86d? |  | 38d → 664d |  |  |
| 1558 | Helix E2E Settlement Testing Execution | 2025-01-06 → 2025-03-10 (+63d) | 2025-04-04 → 2025-06-06 (+63d) |  |  | 38d → 664d |  |  |
| 1559 | Helix E2E Settlement Testing Execution Complete | 2025-04-04 → 2025-06-06 (+63d) | 2025-04-04 → 2025-06-06 (+63d) |  |  | 38d → 664d |  |  |
| 1560 | MHHSP Helix E2E Testing Assurance | 2025-01-06 → 2025-03-10 (+63d) | 2025-04-04 → 2025-06-06 (+63d) |  |  | 38d → 664d |  |  |
| 1561 | MHHSP Helix E2E Testing Assurance Complete | 2025-04-04 → 2025-06-06 (+63d) | 2025-04-04 → 2025-06-06 (+63d) |  |  | 38d → 664d |  |  |
| 1562 | **SIT Migration Testing (MVC)** | 2024-03-11 A |  |  | 0% → 54% | 0d → 609d |  |  |
| 1564 | **SIT Migration Testing Execution (Minimum Viable Cohort)** | 2024-03-11 A |  |  | 0% → 54% | 0d → 609d |  |  |
| 1565 | **Cycle 1 (Full Cycle)** | 2024-03-11 A | 2024-06-14 A |  | 0% → 100% |  |  |  |
| 1566 | Test Execution | 2024-03-11 A | 2024-05-24 A |  | 0% → 100% | 934d → none |  | baseline start none → 2024-03-11; baseline finish none → 2024-05-24 |
| 1567 | Defect resolution, assurance, review, data& environments maintenance | 2024-05-27 A | 2024-06-14 A |  | 0% → 100% | 819d → none |  | baseline start none → 2024-05-27; baseline finish none → 2024-06-14 |

| ID | Task | Start | Finish | Duration | Complete | Total float | Predecessors | Other |
| --- | --- | --- | --- | --- | --- | --- | --- | --- |
| 1568 | **Cycle 2 (Defect retests and targeted regression testing)** |  |  |  | 0% → 100% |  |  |  |
| 1569 | Test Execution | 2024-06-17 A | 2024-09-20 A |  | 0% → 100% | 819d → none |  | baseline start none → 2024-06-17; baseline finish none → 2024-09-20 |
| 1570 | Defect resolution, assurance, review, data & environments maintenance | 2024-09-23 A | 2024-10-04 A |  | 0% → 100% | 819d → none |  | baseline start none → 2024-09-23; baseline finish none → 2024-10-04 |
| 1574 | **Cycle 3 (Defect retests and targeted regression testing)** | 2024-10-21 A |  |  | 0% → 41% | 5d → 694d |  |  |
| 1575 | Sprint 5 | 2024-10-21 A | 2024-11-01 A |  | 0% → 100% | 5d → none |  |  |
| 1576 | Sprint 6 | 2024-11-04 A | 2024-11-15 A |  | 0% → 100% | 5d → none |  |  |
| 1577 | Sprint 7 | 2024-11-18 A | 2024-11-29 A |  | 0% → 100% | 5d → none |  |  |
| 1578 | Sprint 8 | 2024-12-02 A | 2024-12-20 A |  | 0% → 100% | 5d → none |  |  |
| 1579 | Christmas downtime | 2024-12-23 A | 2025-01-03 A |  | 0% → 100% | 5d → none |  |  |
| 1580 | Sprint 9 | 2025-01-06 A |  |  | 0% → 10% |  |  |  |
| 1600 | **SIT Non-Functional Testing (all SIT PPs)** | 2025-01-13 → 2025-03-03 (+49d) |  | 104d? → 69d? |  | 60d → 6d |  | baseline start 2025-01-13 → 2025-02-28; baseline finish 2025-06-05 → 2025-07-10 |
| 1601 | Theme 1 (Helix and DIP Volume Testing) Start | 2025-01-13 → 2025-03-03 (+49d) | 2025-01-13 → 2025-03-03 (+49d) |  |  | 60d → 6d | 1139 → 1139, 1153FS+1d | constraint start no earlier than 2025-01-13 → finish no earlier than 2025-01-13; baseline start 2025-01-13 → 2025-03-03; baseline finish 2025-01-13 → 2025-03-03 |
| 1602 | Theme 1 (Helix and DIP Volume Testing) Execution | 2025-01-13 → 2025-03-03 (+49d) | 2025-01-31 → 2025-03-21 (+49d) |  |  | 60d → 6d | 1601 → 1601FS-1d | baseline start 2025-01-13 → 2025-03-03; baseline finish 2025-01-31 → 2025-03-21 |
| 1603 | Theme 2 SIT Non-Functional Testing Start | 2025-03-14 → 2025-03-27 (+13d) | 2025-03-14 → 2025-03-27 (+13d) |  |  | 70d → 101d | 1179FS+5d, 1505FS+5d, 1074, 1078, 1085, 1091, 1097, 1141, Non-Functional Theme 2 & 3 PP Preparation → 1179, 1505, 1074, 1078, 1085, 1091, 1097, 1141, 1543, 1161FS+1d | baseline start 2025-03-14 → 2025-03-31; baseline finish 2025-03-14 → 2025-03-31 |
| 1604 | Theme 2 SIT Non-Functional Testing Execution | 2025-03-17 → 2025-03-27 (+10d) | 2025-05-09 → 2025-05-21 (+12d) |  |  | 70d → 62d | 1603SS → 1603SS-1d | baseline start 2025-03-17 → 2025-05-01; baseline finish 2025-05-09 → 2025-06-25 |
| 1605 | Theme 3 SIT Non-Functional Testing Start | 2025-03-17 → 2025-03-27 (+10d) | 2025-03-17 → 2025-03-27 (+10d) |  |  | 70d → 62d | 1141, Non-Functional Theme 2 & 3 PP Preparation → 1141, 1161 | baseline start 2025-03-17 → 2025-05-02; baseline finish 2025-03-17 → 2025-05-02 |
| 1606 | Theme 3 SIT Non-Functional Testing Execution | 2025-03-17 → 2025-03-27 (+10d) | 2025-05-09 → 2025-05-21 (+12d) |  |  | 70d → 62d |  | baseline start 2025-03-17 → 2025-05-02; baseline finish 2025-05-09 → 2025-06-26 |
| 1608 | Assurance of PPs Test Completion Reports |  |  |  |  |  |  | baseline start 2025-05-02 → 2025-05-05; baseline finish 2025-05-29 → 2025-05-30 |
| 1610 | Develop document |  |  |  |  |  |  | baseline start 2025-05-02 → 2025-05-05 |
| 1611 | Review & agree document |  |  |  |  |  |  | baseline start 2025-05-23 → 2025-05-26; baseline finish 2025-05-29 → 2025-05-30 |
| 1612 | SIT Non-Functional Testing Test Completion Report (all SIT PPs) Approved |  |  |  |  |  |  | baseline start 2025-06-05 → 2025-06-06; baseline finish 2025-06-05 → 2025-06-06 |
| 1613 | **SIT Operational Testing (all SIT PPs)** |  | 2025-06-06 → 2025-07-25 (+49d) | 90d? → 125d? |  | 60d → 25d |  |  |
| 1615 | SIT Operational Testing Start (Theme 3 - Batch 1 (Service Management)) |  |  |  |  |  | 1325, Elexon Service Now Build and Implementation, 1266, 1267, Helix Knowledge Articles, 1324 → 1325, 1266, 1267 |  |
| 1617 | **SIT B Testing** | 2025-02-07 → 2025-03-31 (+52d) | 2025-05-16 → 2025-07-04 (+49d) |  |  | 60d → 25d |  |  |
| 1618 | SIT Operational Testing Start (SIT B) | 2025-02-07 → 2025-03-31 (+52d) | 2025-02-07 → 2025-03-31 (+52d) |  |  | 60d → 25d | 1395FS+8d, 1188, 1192, 1199, 1205, 1325, 1142, 1143 → 1395, 1188, 1192, 1199, 1205, 1325, 1142, 1143, 1375FS+1d | baseline start 2025-02-07 → 2025-03-31; baseline finish 2025-02-07 → 2025-03-31 |
| 1619 | SIT Operational Testing Execution Theme 3 Batch 2 | 2025-02-10 → 2025-03-31 (+49d) | 2025-03-14 → 2025-05-02 (+49d) |  |  | 60d → 25d | 1618, 1311 → 1618FS-1d, 1311 | baseline start 2025-02-10 → 2025-03-31; baseline finish 2025-03-14 → 2025-05-02 |
| 1620 | SIT Operational Testing Execution Theme 1 | 2025-03-17 → 2025-05-05 (+49d) | 2025-04-18 → 2025-06-06 (+49d) |  |  | 60d → 25d |  | baseline start 2025-03-17 → 2025-05-05; baseline finish 2025-04-18 → 2025-06-06 |
| 1621 | SIT Operational Testing Execution Theme 2 | 2025-04-21 → 2025-06-09 (+49d) | 2025-05-16 → 2025-07-04 (+49d) |  |  | 60d → 25d |  | baseline start 2025-04-21 → 2025-06-09; baseline finish 2025-05-16 → 2025-07-04 |
| 1622 | SIT Operational Testing End (all SIT PPs) (incl. confirmation that PPs have submitted their Test Completion Reports to Programme for assurance) | 2025-05-23 → 2025-07-11 (+49d) | 2025-05-23 → 2025-07-11 (+49d) |  |  | 60d → 25d |  | baseline start 2025-05-23 → 2025-07-11; baseline finish 2025-05-23 → 2025-07-11 |
| 1623 | Assurance of PPs Test Completion Reports | 2025-04-21 → 2025-06-09 (+49d) | 2025-05-30 → 2025-07-18 (+49d) |  |  | 60d → 25d |  | baseline start 2025-04-21 → 2025-06-09; baseline finish 2025-05-30 → 2025-07-18 |
| 1624 | **SIT Operational Testing Test Completion Report (all SIT PPs)** | 2025-05-05 → 2025-06-23 (+49d) | 2025-05-30 → 2025-07-18 (+49d) |  |  | 60d → 25d |  | baseline start 2025-05-05 → 2025-06-23; baseline finish 2025-05-30 → 2025-07-18 |
| 1625 | Develop document | 2025-05-05 → 2025-06-23 (+49d) | 2025-05-23 → 2025-07-11 (+49d) |  |  | 60d → 25d |  | baseline start 2025-05-05 → 2025-06-23; baseline finish 2025-05-23 → 2025-07-11 |
| 1626 | Review & agree document | 2025-05-26 → 2025-07-14 (+49d) | 2025-05-30 → 2025-07-18 (+49d) |  |  | 60d → 25d |  | baseline start 2025-05-26 → 2025-07-14; baseline finish 2025-05-30 → 2025-07-18 |
| 1627 | SIT Operational Testing Test Completion Report (all SIT PPs) Approved | 2025-06-06 → 2025-07-25 (+49d) | 2025-06-06 → 2025-07-25 (+49d) |  |  | 60d → 25d |  | baseline start 2025-06-06 → 2025-07-25; baseline finish 2025-06-06 → 2025-07-25 |
| 1628 | **SIT MVC Test Exit Report** | 2025-07-14 → 2025-07-21 (+7d) | 2025-08-08 → 2025-08-15 (+7d) |  |  | 619d → 614d |  |  |
| 1629 | Develop document | 2025-07-14 → 2025-07-21 (+7d) | 2025-08-01 → 2025-08-08 (+7d) |  |  | 619d → 614d |  |  |
| 1630 | Review & agree document | 2025-08-04 → 2025-08-11 (+7d) | 2025-08-08 → 2025-08-15 (+7d) |  |  | 619d → 614d |  |  |
| 1643 | Test Execution (Cycle 3 Completion and Regression Testing) |  |  |  |  | 25d → 29d |  | baseline start 2025-05-05 → 2025-06-16; baseline finish 2025-09-17 → 2025-10-24 |
| 1644 | SIT Migration Testing End (non-MVC) (incl. confirmation that PPs have submitted their Test Completion Reports to Programme for assurance) |  |  |  |  | 25d → 29d |  | baseline start 2025-09-17 → 2025-10-24; baseline finish 2025-09-17 → 2025-10-24 |
| 1645 | Assurance of PPs Test Completion Reports |  |  |  |  | 25d → 29d |  | baseline start 2025-09-25 → 2025-11-03; baseline finish 2025-10-01 → 2025-11-07 |
| 1646 | **SIT Migration Testing Test Completion Report (non-MVC)** |  |  |  |  | 25d → 29d |  | baseline start 2025-08-28 → 2025-10-06; baseline finish 2025-10-01 → 2025-11-07 |
| 1647 | Develop document |  |  |  |  | 30d → 34d |  | baseline start 2025-08-28 → 2025-10-06; baseline finish 2025-09-17 → 2025-10-24 |
| 1648 | Review & agree document |  |  |  |  | 25d → 29d |  | baseline start 2025-09-25 → 2025-11-03; baseline finish 2025-10-01 → 2025-11-07 |
| 1649 | SIT Migration Testing Test Completion Report (non-MVC Approved) |  |  |  |  | 25d → 29d |  | baseline start 2025-10-08 → 2025-11-14; baseline finish 2025-10-08 → 2025-11-14 |
| 1654 | **UIT Environment Preparation** |  | 2025-07-04 → 2025-06-06 (-28d) | 700d? → 680d? | 46% → 51% | 644d → 664d |  |  |
| 1660 | Update E2E Sandbox guidance to reflect CR55 |  |  |  |  |  |  | baseline start none → 2025-01-13; baseline finish none → 2025-02-20 |
| 1661 | Internal SI review |  |  |  |  |  |  | baseline start none → 2025-02-21; baseline finish none → 2025-02-27 |
| 1662 | SRO / Code Bodies review |  |  |  |  |  |  | baseline start none → 2025-02-28; baseline finish none → 2025-03-06 |
| 1663 | Submit version to QWG |  |  |  |  |  |  | baseline start none → 2025-03-07; baseline finish none → 2025-03-11 |
| 1664 | Artefact Approval (via QWG) |  |  |  |  |  |  | baseline start none → 2025-03-11; baseline finish none → 2025-03-11 |
| 1665 | Final Document updates post QWG review |  |  | 1d? → 1d |  |  |  | baseline start none → 2025-03-13; baseline finish none → 2025-03-13 |
| 1666 | Submit final version to QAG |  |  |  |  |  |  | baseline start none → 2025-03-17; baseline finish none → 2025-03-17 |
| 1667 | E2E Sandbox guidance update approved |  |  |  |  |  |  | baseline start none → 2025-03-24; baseline finish none → 2025-03-24 |
| 1669 | Develop document |  |  |  |  |  |  | baseline start 2023-12-05 → 2025-01-13; baseline finish 2024-03-15 → 2025-02-18 |
| 1670 | Internal SI review and updates |  |  |  |  |  |  | baseline start 2024-03-11 → 2025-02-19; baseline finish 2024-03-15 → 2025-02-25 |
| 1671 | SRO / Code Bodies review |  |  |  |  |  |  | baseline start 2024-03-18 → 2025-02-26; baseline finish 2024-03-22 → 2025-03-04 |
| 1674 | Final updates prior to consultation |  |  |  |  |  |  | baseline start 2024-03-25 → 2025-03-12; baseline finish 2024-03-29 → 2025-03-17 |
| 1675 | Industry Consultation for E2E Sandbox Test Data Approach and Plan document |  |  |  |  |  |  | baseline start 2024-04-01 → 2025-03-18; baseline finish 2024-04-12 → 2025-03-31 |
| 1676 | Document updates post Industry Consultation |  |  |  |  |  |  | baseline start 2024-04-15 → 2025-04-01; baseline finish 2024-04-22 → 2025-04-03 |
| 1677 | Submit Proposed Version to QWG |  |  |  |  |  |  | baseline start 2024-04-23 → 2025-04-04; baseline finish 2024-04-23 → 2025-04-08 |
| 1678 | Artefact Approval (via QWG) |  |  |  |  |  |  | baseline start 2024-04-30 → 2025-04-08; baseline finish 2024-04-30 → 2025-04-08 |
| 1679 | Final Document updates post QWG review |  |  |  |  |  |  | baseline start 2024-05-01 → 2025-04-09; baseline finish 2024-05-01 → 2025-04-09 |
| 1680 | Submit final version to QAG |  |  |  |  |  |  | baseline start 2024-05-02 → 2025-04-10; baseline finish 2024-05-02 → 2025-04-10 |
| 1681 | E2E Sandbox Test Data Approach and Plan |  |  |  |  |  |  | baseline start 2024-05-09 → 2025-04-16; baseline finish 2024-05-09 → 2025-04-16 |
| 1682 | **UIT Stub Specification and Delivery** |  | 2024-10-18 → 2024-11-29 A (+42d) | 230d → 260d | 89% → 100% | 829d → none |  |  |
| 1683 | **Qualification Test Stubs** |  | 2024-10-18 → 2024-11-29 A (+42d) | 230d → 260d | 89% → 100% | 829d → none |  |  |
| 1685 | Build & Test |  | 2024-08-16 A |  | 90% → 100% | 33.75d → none |  |  |
| 1686 | Prepare for release |  | 2024-10-18 → 2024-11-29 A (+42d) | 45d → 75d | 75% → 100% | 829d → none |  | baseline finish 2024-10-18 → 2024-11-29 |
| 1687 | Non-SIT LDSO Test Harness Released | 2024-10-18 → 2024-11-29 A (+42d) | 2024-10-18 → 2024-11-29 A (+42d) |  | 0% → 100% | 829d → none |  | baseline start 2024-10-18 → 2024-11-29; baseline finish 2024-10-18 → 2024-11-29 |
| 1688 | **Environments (UIT)** |  | 2025-07-04 → 2025-06-06 (-28d) | 700d → 680d | 44% → 50% | 644d → 664d |  |  |

| ID | Task | Start | Finish | Duration | Complete | Total float | Predecessors | Other |
| --- | --- | --- | --- | --- | --- | --- | --- | --- |
| 1689 | **Central Party (Avanade) Environments (UIT)** |  | 2024-09-27 A |  | 97% → 100% | 844d → none |  | was named Central Party (Avenade) Environments (UIT) |
| 1690 | Central Party (Avandae) environment preparation (incl. security certificates and security compliance) |  |  |  |  |  |  | was named Central Party (Avendae) environment preparation (incl. security certificates and security compliance) |
| 1692 | Central Party (Avanade) UIT environment connectivity proving | 2024-08-26 A | 2024-09-27 A |  | 0% → 100% | 843d → none |  | was named Central Party (Avenade) UIT environment connectivity proving |
| 1693 | Deployment of MHHS solution code to UIT environments | 2024-07-29 A | 2024-07-30 A |  | 0% → 100% | 886d → none |  |  |
| 1694 | Central Party (Avanade) UIT environment Regression Testing | 2024-07-31 A | 2024-07-31 A |  | 0% → 100% | 886d → none |  | was named Central Party (Avenade) UIT environment Regression Testing |
| 1701 | **SI Environments (UIT)** |  | 2025-07-04 → 2024-09-30 (-277d) | 688d → 489d | 69% → 99% | 644d → 843d |  |  |
| 1705 | Coordinate Central Parties' UIT environment connectivity proving | 2024-08-26 A | 2024-09-30 A |  | 0% → 100% | 843d → none |  |  |
| 1737 | **SIT PPs Early Sandbox Testing Execution (SIT-A)** | 2025-02-07 → 2025-08-08 (+182d) | 2026-04-24 → 2025-10-24 (-182d) | 316d → 56d |  | 434d → 564d |  | was named SIT PPs Early Sandbox Testing Execution |
| 1738 | SIT PPs E2E Sandbox Testing Start | 2025-02-10 → 2025-08-08 (+179d) | 2025-02-10 → 2025-08-08 (+179d) |  |  | 749d → 619d | 1732FS+5d → 1732FS+5d, 1549 | baseline start 2025-02-10 → 2025-08-08; baseline finish 2025-02-10 → 2025-08-08 |
| 1739 | SIT PPs E2E Sandbox Testing Execution | 2025-02-07 → 2025-08-08 (+182d) | 2026-04-24 → 2025-10-24 (-182d) | 316d → 56d |  | 434d → 564d |  |  |
| 1742 | Central systems ready for migrating MPANs (M10) |  |  |  |  |  | 1631FS+20d, 2856, 2611FS+2d, 2608, 2623, 2610, 2590, 2594 → 1631FS+20d, 2856, 2611FS+2d, 2608, 2623, 2590, 2594 | constraint start no earlier than 2025-08-13 → none |
| 1754 | **NON SIT LDSO QUALIFICATION** |  | 2025-08-22 → 2025-09-19 (+28d) | 469d? → 489d? | 67% → 65% | 609d → 589d |  |  |
| 1784 | **Test Execution Schedule** |  | 2024-11-29 A |  | 99% → 100% | 799d → none |  |  |
| 1790 | Qualification Testing for Non-SIT LDSOs (Functional, Migration, NFT, Operational) Test Execution Schedule Complete | 2024-11-29 A | 2024-11-29 A |  | 0% → 100% | 799d → none |  |  |
| 1800 | **Test Data** |  |  |  | 44% → 65% |  |  |  |
| 1807 | Test Data Loaded | 2024-08-12 A |  |  | 0% → 90% |  |  |  |
| 1814 | **Pre-Integration Testing** |  | 2024-11-29 → 2025-01-24 (+56d) | 218d → 258d | 90% → 84% | 799d → 759d |  |  |
| 1818 | PIT Execution (Functional and Migration) |  |  |  | 16% → 90% |  |  | was named PIT Execution |
| 1820 | Non-SIT LDSO Participants have submitted functional PIT Test Completion Report & evidence for QT Entry​ |  |  |  |  |  |  | was named Non-SIT LDSO Participants have submitted PIT Test Completion Report & evidence for QT Entry​ |
| 1834 | **Test Environment** |  | 2024-11-29 A |  | 37% → 100% | 67d → none |  |  |
| 1836 | Central System (DIP Env & Helix Test Harness) Test Environment DBT |  | 2024-11-29 A |  | 47% → 100% | 67d → none |  |  |
| 1837 | Coordinate LDSO Environment Preparation |  | 2024-11-29 A |  | 14% → 100% | 67d → none |  |  |
| 1840 | LDSO Test Environments Connection Confirmed to UIT Environment | 2024-11-29 A | 2024-11-29 A |  | 0% → 100% | 67d → none |  |  |
| 1841 | **Test Readiness** |  |  |  | 31% → 90% |  |  |  |
| 1844 | LDSO Update Readiness Report & Final Assurance by Programme |  |  |  | 20% → 95% | 42d → 10d |  |  |
| 1849 | **Test Window** | 2025-01-06 A | 2025-05-16 → 2025-08-22 (+98d) | 94d? → 165d? |  | 42d → 609d |  |  |
| 1850 | **All Non-SIT LDSOs Qualification Testing** | 2025-01-06 A |  | 94d? → 94d |  | 42d → 1d |  |  |
| 1851 | Non-SIT LDSO QT Test Execution Starts | 2025-01-06 A | 2025-01-06 A |  | 0% → 100% | 42d → none |  |  |
| 1861 | Qualification Testing for Non-SIT LDSOs (Functional, Migration, NFT, Operational) 1 End |  |  |  |  | 38d → 1d | Non-SIT LDSO QT - Regression Testing → 1852, 1853, 1854, 1855, 1856, 1857, 1858, 1859, 1860 |  |
| 1867 | **Non-SIT LDSO Qualification Closure** | 2025-05-30 → 2025-08-25 (+87d) | 2025-08-22 → 2025-09-19 (+28d) | 61d → 20d |  | 22d → 589d |  |  |
| 1868 | Non-SIT LDSO Qualification Learned Captured | 2025-05-30 → 2025-08-25 (+87d) | 2025-06-19 → 2025-09-12 (+85d) |  |  | 38d → 589d | 1866 → 1866, 1959 |  |
| 1869 | Non-SIT LDSO Qualification Closure Down | 2025-06-20 → 2025-09-15 (+87d) | 2025-06-26 → 2025-09-19 (+85d) |  |  | 38d → 589d |  |  |
| 1870 | **S & A QUALIFICATION** |  |  | 843d → 843d? | 32% → 56% |  |  |  |
| 1871 | **MHHS Qualification - Qualification Deliverables** |  | 2025-08-14 → 2025-10-17 (+64d) | 463d → 509d | 60% → 95% | 615d → 4d |  |  |
| 1872 | **BSC & REC Assessment Criteria** |  | 2025-08-14 A |  | 23% → 100% | 615d → none |  |  |
| 1878 | Assessment Criteria (Functional, Non-Functional, Migration, Operational) Approved by REC PAB and BSC PAB | 2024-08-29 A | 2025-08-14 A |  | 0% → 100% | 615d → none |  |  |
| 1899 | **Qualification Assessment Document** |  | 2025-03-07 → 2025-10-17 (+224d) | 316d → 476d | 81% → 87% | 633d → 4d |  |  |
| 1918 | **Qualification Assessment Document Portal** |  | 2025-03-07 → 2025-10-17 (+224d) | 285d → 445d | 65% → 77% | 633d → 4d |  |  |
| 1924 | SIT Participant QAD Application Creation in Portal | 2024-08-12 → 2024-12-09 A (+119d) | 2024-08-23 → 2024-12-20 A (+119d) |  | 0% → 100% | 773d → none | 1922FS+35d → 1922FS+120d | baseline start 2024-08-12 → 2024-12-09; baseline finish 2024-08-23 → 2024-12-20 |
| 1925 | Non-SIT LDSO Participant QAD Application Creation in Portal | 2024-08-12 → 2024-12-09 A (+119d) | 2024-08-23 → 2024-12-20 A (+119d) |  | 0% → 100% | 773d → none | 1922FS+35d → 1922FS+120d | baseline start 2024-08-12 → 2024-12-09; baseline finish 2024-08-23 → 2024-12-20 |
| 1926 | QT Wave 1 Participant QAD Application Creation in Portal | 2024-09-23 → 2025-04-21 (+210d) | 2024-10-04 → 2025-05-02 (+210d) |  |  | 36d → 6d | 1922FS+65d → 1922FS+215d | baseline start 2024-09-23 → 2025-04-21; baseline finish 2024-10-04 → 2025-05-02 |
| 1927 | QT Wave 2 Participant QAD Application Creation in Portal | 2024-10-28 → 2025-05-26 (+210d) | 2024-11-08 → 2025-06-06 (+210d) |  |  |  | 1922FS+90d → 1922FS+240d | baseline start 2024-10-28 → 2025-05-26; baseline finish 2024-11-08 → 2025-06-06 |
| 1928 | QT Wave 3 Participant QAD Application Creation in Portal | 2024-12-30 → 2025-07-28 (+210d) | 2025-01-10 → 2025-08-08 (+210d) |  |  | 0d → 9d | 1922FS+135d → 1922FS+285d | baseline start 2024-12-30 → 2025-07-28; baseline finish 2025-01-10 → 2025-08-08 |
| 1929 | QT Wave 4 Participant QAD Application Creation in Portal | 2025-02-24 → 2025-10-06 (+224d) | 2025-03-07 → 2025-10-17 (+224d) |  |  |  | 1922FS+175d → 1922FS+335d | baseline start 2025-02-24 → 2025-10-06; baseline finish 2025-03-07 → 2025-10-17 |
| 1932 | **MHHS Qualification - SIT Participants** | 2025-01-06 A | 2025-12-22 → 2025-12-18 (-4d) | 251d → 249d |  | 60d → 29d |  |  |
| 1933 | Initial QAD Submission Window opens | 2025-01-06 A | 2025-01-06 A |  | 0% → 100% | 773d → none | 1924FS+96d → 1924FS+10d |  |
| 1939 | SIT MVC Participants submit Final QAD (exc Test Reports) |  |  |  |  |  |  | was named SIT MVC Participants submit Final QAD |
| 1940 | Completion of Code Bodies review of Final QAD (MVC) |  |  |  |  |  | 1939, 1622FF → 1939 |  |
| 1941 | QAD Sign Off Deadline (MVC) + Test Reports |  |  |  |  |  | 1631, 1940 → 1631, 1940, 1622 | was named QAD Sign Off Deadline (MVC) |
| 1943 | **MHHS Qualification - SIT Non-MVC Participants** |  | 2025-12-22 → 2025-12-18 (-4d) | 156d → 154d |  | 25d → 29d |  |  |
| 1948 | REC Code Manager / BSC PAB Approval of Qualification (Non-MVC) | 2025-12-22 → 2025-12-18 (-4d) | 2025-12-22 → 2025-12-18 (-4d) |  |  | 25d → 29d | 1947FS+16d → 1947FS+14d |  |
| 1949 | **MHHS Qualification - Non-SIT LDSO** | 2025-01-06 A | 2025-09-11 → 2025-09-10 (-1d) | 179d → 178d |  | 71d → 9d |  |  |
| 1950 | Initial QAD Submission window opens | 2025-01-06 A | 2025-01-06 A |  | 0% → 100% | 773d → none | 1925FS+96d → 1925FS+11d |  |
| 1959 | QAD Sign Off Deadline (Non-SIT LDSOs) |  |  |  |  | 22d → 9d | 1958FS+5d, 1631 → 1958FS+5d, 1631, 1861 |  |
| 1960 | BSC PAB & REC Manager approval of Qualification for Non-SIT LDSOs | 2025-09-11 → 2025-09-10 (-1d) | 2025-09-11 → 2025-09-10 (-1d) |  |  | 595d → 9d | 1861, 1959FS+14d → 1959FS+13d | was named BSC PAB & REC Manager approval of Qualification for Non-SIT LDSOs (Start of Migration for Qualification Participants) |
| 1961 | **MHHS Qualification - Qualification Waves** |  |  | 814d → 814d? | 29% → 53% |  |  |  |
| 1962 | **Qualification Wave Prep** |  | 2025-12-26 → 2026-01-08 (+13d) | 530d → 539d? | 55% → 86% | 519d → 510d |  |  |
| 2000 | **Qualification Testing Framework (Test Stubs and Supporting UI)** |  | 2025-12-26 → 2026-01-08 (+13d) | 500d → 509d? | 50% → 84% | 519d → 510d |  | baseline finish 2025-12-26 → 2026-01-08 |
| 2001 | Proof of Concept for QTF Completion |  |  |  |  |  |  | constraint start no earlier than 2024-01-22 → finish no earlier than 2024-03-29 |
| 2002 | Discovery and Mobilisation |  |  |  |  |  |  | constraint none → finish no earlier than 2024-05-03 |
| 2005 | UI Wireframe |  |  |  |  |  | 1967FS+2d → none | constraint none → finish no earlier than 2024-06-28 |
| 2006 | UI Standards |  |  |  |  |  | 2005SS+13d → 2005FS+13d | constraint none → finish no earlier than 2024-06-28 |
| 2007 | Elexon Branding Sylesheet |  |  | 1d → 2d |  |  | 2002FS+10d → 2006FS+10d | constraint none → finish no earlier than 2024-05-20 |
| 2008 | Elexon Branding QTF Logo |  |  | 1d → 2d |  |  | 2002FS+20d → 2007FS+20d | constraint none → finish no earlier than 2024-06-03 |
| 2010 | Core UI Screens |  |  |  |  |  |  | constraint none → finish no earlier than 2024-08-02 |
| 2011 | Tooling (Trigger Files / Template Generators) |  |  |  |  |  |  | constraint none → finish no earlier than 2024-08-16 |
| 2012 | Database Schema |  |  |  |  |  |  | constraint none → finish no earlier than 2024-07-19 |
| 2013 | Core API's |  |  |  |  |  |  | constraint none → finish no earlier than 2024-08-02 |
| 2014 | QTF Test Cases DBT Refinement, Execution and Results Validation, Defect Management, Error Handling | 2024-07-03 → 2024-11-05 A (+125d) | 2025-01-01 → 2025-01-31 (+30d) | 131d → 64d | 0% → 75% | 762d → 735d | 1993FF, QAG Approval of QT Non-Functional Test Scenarios and Test Cases Batch 2FF, QAG Approval of QT Operational Test Scenarios and Test Cases Batch 1FF, QAG Approval of QT Operational Test Scenarios and Test Cases Batch 2FF → 1999FF, 1993FF, 1995SS | baseline start 2024-07-03 → 2024-11-05; baseline finish 2025-01-01 → 2025-01-31 |
| 2015 | **Environments** |  | 2025-01-21 → 2025-07-31 (+191d) | 202d → 339d | 54% → 98% | 762d → 625d |  | baseline finish 2025-01-21 → 2025-07-31 |

| ID | Task | Start | Finish | Duration | Complete | Total float | Predecessors | Other |
| --- | --- | --- | --- | --- | --- | --- | --- | --- |
| 2016 | **Azure Devops** |  | 2024-09-27 → 2024-12-11 A (+75d) | 120d → 173d | 42% → 100% | 216d → none |  | baseline finish 2024-09-27 → 2024-12-11 |
| 2018 | Elexon Instance Setup for QTF Build |  |  |  |  |  |  | constraint none → finish no earlier than 2024-04-19 |
| 2019 | Configuration and User Access |  |  |  |  |  |  | constraint none → finish no earlier than 2024-05-03 |
| 2020 | **MHHSP ADO Instance** |  | 2024-09-27 → 2024-12-11 A (+75d) | 49d → 102d | 24% → 100% | 216d → none |  | baseline finish 2024-09-27 → 2024-12-11 |
| 2021 | MHHSP Instance Setup for QTF Production |  | 2024-08-30 A |  | 41% → 100% | 216d → none |  | constraint none → finish no earlier than 2024-08-30 |
| 2022 | Configuration and User Access | 2024-09-02 A | 2024-09-27 → 2024-12-11 A (+75d) | 20d → 73d | 0% → 100% | 216d → none | 2021, 2128 → 2021 | constraint none → finish no earlier than 2024-09-27; baseline finish 2024-09-27 → 2024-12-11 |
| 2024 | Design |  |  |  |  |  |  | constraint none → finish no earlier than 2024-05-03 |
| 2025 | Build and Deployment |  |  |  |  |  |  | constraint none → finish no earlier than 2024-05-31 |
| 2026 | **Dev, Test & Prod Environment Requirements + Design** |  | 2024-10-18 → 2024-11-29 A (+42d) | 105d → 135d | 58% → 100% | 829d → none |  | baseline finish 2024-10-18 → 2024-11-29 |
| 2027 | Design (including Security Review) |  | 2024-08-30 → 2024-11-29 A (+91d) | 70d → 135d | 76% → 100% | 864d → none |  | constraint none → finish no earlier than 2024-08-30; baseline finish 2024-08-30 → 2024-11-29 |
| 2029 | Hub Deployment |  |  |  |  |  | 2027SS+10d → 2027FS+10d, 2028 | constraint none → finish no earlier than 2024-07-05 |
| 2030 | Development Envn. Deployment |  | 2024-08-30 → 2024-09-19 A (+20d) | 40d → 53.8d | 58% → 100% | 815d → none |  | constraint none → finish no earlier than 2024-08-30; baseline finish 2024-08-30 → 2024-09-19 |
| 2031 | Test Envn. Deployment | 2024-09-02 → 2024-09-19 A (+17d) | 2024-09-13 → 2024-10-03 A (+20d) |  | 0% → 100% | 815d → none |  | constraint none → finish no earlier than 2024-09-13; baseline start 2024-09-02 → 2024-09-19; baseline finish 2024-09-13 → 2024-10-03 |
| 2032 | Production Envn. Deployment | 2024-09-16 → 2024-10-03 A (+17d) | 2024-10-18 → 2024-11-07 A (+20d) |  | 0% → 100% | 815d → none |  | constraint none → finish no earlier than 2024-10-18; baseline start 2024-09-16 → 2024-10-03; baseline finish 2024-10-18 → 2024-11-07 |
| 2033 | **QTF Deployment into Production** | 2025-01-02 → 2025-02-03 (+32d) | 2025-01-21 → 2025-02-27 (+37d) | 14d → 19d |  | 762d → 735d |  | baseline start 2025-01-02 → 2025-02-03; baseline finish 2025-01-21 → 2025-04-25 |
| 2034 | App Deployment | 2025-01-02 → 2025-02-03 (+32d) | 2025-01-02 → 2025-02-07 (+36d) | 1d → 5d |  | 762d → 735d |  | constraint none → start no earlier than 2025-02-03; baseline start 2025-01-02 → 2025-02-03; baseline finish 2025-01-02 → 2025-02-07 |
| 2035 | Smoke Test | 2025-01-02 → 2025-02-10 (+39d) | 2025-01-03 → 2025-02-11 (+39d) |  |  | 762d → 735d | 2034SS → 2034 | constraint none → finish no earlier than 2025-02-04; baseline start 2025-01-02 → 2025-02-10; baseline finish 2025-01-03 → 2025-02-11 |
| 2036 | PEN Test | 2025-01-06 → 2025-02-12 (+37d) | 2025-01-07 → 2025-02-13 (+37d) |  |  | 762d → 735d |  | constraint none → finish no earlier than 2025-02-06; baseline start 2025-01-06 → 2025-02-12; baseline finish 2025-01-07 → 2025-02-13 |
| 2037 | Regression Test | 2025-01-08 → 2025-02-14 (+37d) | 2025-01-21 → 2025-02-27 (+37d) |  |  | 762d → 735d |  | constraint none → finish no earlier than 2025-02-20; baseline start 2025-01-08 → 2025-02-14; baseline finish 2025-01-21 → 2025-02-27 |
| 2038 | **DIP Onboarding (UIT)** | 2024-08-05 A → 2024-07-26 A (-10d) | 2024-09-24 → 2024-12-13 A (+80d) | 37d → 101d | 46% → 100% | 847d → none |  | baseline start 2024-08-05 → 2024-07-26; baseline finish 2024-09-24 → 2024-11-29 |
| 2048 | DIP UIT Test Stubs | 2024-08-28 → 2024-10-31 A (+64d) | 2024-09-24 → 2024-12-13 A (+80d) | 20d → 32d | 0% → 100% | 847d → none | Non-SIT S&A QTF Environments Connection Confirmed to UIT Environment → 2043, 2045, 2047 | constraint none → start no earlier than 2024-10-31; baseline start 2024-08-28 → 2024-10-17; baseline finish 2024-09-24 → 2024-11-29 |
| 2049 | **DTN Onboarding** |  | 2024-09-27 → 2024-10-25 A (+28d) | 95d → 115d | 47% → 100% | 844d → none |  | baseline finish 2024-09-27 → 2024-10-25 |
| 2050 | DTN Request Raised for Onboarding |  |  |  |  |  | 2024FS+10d → none | constraint none → start no earlier than 2024-05-20 |
| 2051 | Setup, configuration of New Host and Test Flags |  |  |  |  |  |  | constraint none → start no earlier than 2024-06-24 |
| 2054 | DTN Test Stubs | 2024-09-16 A | 2024-09-27 A |  | 0% → 100% | 844d → none | New VPN Connection → 2052 | constraint none → start no earlier than 2024-09-16 |
| 2065 | Sample MPAN Data + Attributes from Suppliers |  |  |  |  |  | 1974 → none | constraint none → finish no earlier than 2024-06-28 |
| 2076 | **Industry Standing Data (ISD)** |  | 2024-09-10 → 2024-11-01 A (+52d) | 33d → 71d? | 6% → 100% | 857d → none |  | baseline finish 2024-09-10 → 2024-11-01 |
| 2081 | First View of Migrated ISD Data | 2024-08-19 → 2024-09-23 A (+35d) | 2024-08-19 → 2024-09-27 A (+39d) | 1d → 5d | 0% → 100% | 857d → none | 2077 → 2080 | constraint start no earlier than 2024-08-19 → finish no earlier than 2024-09-27; baseline start 2024-08-19 → 2024-09-23; baseline finish 2024-08-19 → 2024-09-27 |
| 2083 | Final Cycle 3 Migrated ISD Data | 2024-08-20 → 2024-10-07 A (+48d) | 2024-08-20 → 2024-10-11 A (+52d) | 1d → 5d | 0% → 100% | 857d → none |  | constraint none → finish no earlier than 2024-10-11; baseline start 2024-08-20 → 2024-10-07; baseline finish 2024-08-20 → 2024-10-11 |
| 2084 | Create ISD Template inc. DIP ID | 2024-08-21 → 2024-09-16 A (+26d) | 2024-08-27 → 2024-11-01 A (+66d) | 5d → 35d? | 0% → 100% | 857d → none | 2083 → 2080 | constraint none → finish no earlier than 2024-11-01; baseline start 2024-08-21 → 2024-09-16; baseline finish 2024-08-27 → 2024-11-01 |
| 2085 | Publish Qualification ISD | 2024-08-28 → 2024-10-14 A (+47d) | 2024-09-10 → 2024-10-25 A (+45d) | 10d → 10d? | 0% → 100% | 857d → none | 2084 → 2083, 2080 | constraint none → finish no earlier than 2024-10-25; baseline start 2024-08-28 → 2024-10-14; baseline finish 2024-09-10 → 2024-10-25 |
| 2106 | **Wave 1 Test Data** |  | 2025-07-14 → 2025-07-15 (+1d) |  |  | 35d → none | none → 2092SS | baseline finish 2025-07-14 → 2025-07-15 |
| 2107 | Test Data Request + Templates Completed | 2025-05-12 → 2025-04-21 (-21d) | 2025-06-02 → 2025-05-12 (-21d) |  |  | 35d → 653d | 2153 → 2091SS | constraint none → finish no earlier than 2025-05-12; baseline start 2025-05-12 → 2025-04-21; baseline finish 2025-06-02 → 2025-05-12 |
| 2108 | Test Data Generated | 2025-06-03 → 2025-05-21 (-13d) | 2025-06-16 → 2025-06-03 (-13d) |  |  | 35d → 647d | 2107 → 2094, 2107 | constraint none → finish no earlier than 2025-06-03; baseline start 2025-06-03 → 2025-05-21; baseline finish 2025-06-16 → 2025-06-03 |
| 2109 | Test Data Loaded into QP Systems | 2025-06-17 → 2025-06-04 (-13d) | 2025-07-14 → 2025-07-01 (-13d) |  |  | 35d → 647d |  | constraint none → finish no earlier than 2025-06-17; baseline start 2025-06-17 → 2025-06-04; baseline finish 2025-07-14 → 2025-07-01 |
| 2110 | Test Data Loaded into QTF + ADO | 2025-06-17 → 2025-06-04 (-13d) | 2025-07-11 → 2025-06-30 (-11d) |  |  | 36d → 648d |  | constraint none → finish no earlier than 2025-06-17; baseline start 2025-06-17 → 2025-06-04; baseline finish 2025-07-11 → 2025-06-30 |
| 2111 | **Wave 2 Test Data** |  | 2025-09-02 → 2025-09-03 (+1d) |  |  | 39d → none |  | baseline finish 2025-09-02 → 2025-09-03 |
| 2112 | Test Data Request + Templates Completed | 2025-07-07 → 2025-06-16 (-21d) | 2025-07-28 → 2025-07-07 (-21d) |  |  | 39d → 617d | 2183 → none | constraint none → finish no earlier than 2025-07-07; baseline start 2025-07-07 → 2025-06-16; baseline finish 2025-07-28 → 2025-07-07 |
| 2113 | Test Data Generated | 2025-07-29 → 2025-07-16 (-13d) | 2025-08-11 → 2025-07-29 (-13d) |  |  | 39d → 611d |  | constraint none → finish no earlier than 2025-07-29; baseline start 2025-07-29 → 2025-07-16; baseline finish 2025-08-11 → 2025-07-29 |
| 2114 | Test Data Loaded into QP Systems | 2025-08-12 → 2025-07-30 (-13d) | 2025-09-02 → 2025-08-20 (-13d) |  |  | 39d → 611d |  | constraint none → finish no earlier than 2025-08-12; baseline start 2025-08-12 → 2025-07-30; baseline finish 2025-09-02 → 2025-08-20 |
| 2115 | Test Data Loaded into QTF + ADO | 2025-08-12 → 2025-07-30 (-13d) | 2025-09-02 → 2025-08-20 (-13d) |  |  | 39d → 611d |  | constraint none → finish no earlier than 2025-08-12; baseline start 2025-08-12 → 2025-07-30; baseline finish 2025-09-02 → 2025-08-20 |
| 2116 | **Wave 3 Test Data** |  | 2025-11-07 → 2025-11-10 (+3d) |  |  | 29d → none |  | baseline finish 2025-11-07 → 2025-11-10 |
| 2117 | Test Data Request + Templates Completed | 2025-09-08 → 2025-08-19 (-20d) | 2025-09-26 → 2025-09-08 (-18d) |  |  | 29d → 568d | 2213 → none | constraint none → finish no earlier than 2025-09-08; baseline start 2025-09-08 → 2025-08-19; baseline finish 2025-09-26 → 2025-09-08 |
| 2118 | Test Data Generated | 2025-09-29 → 2025-09-16 (-13d) | 2025-10-10 → 2025-09-29 (-11d) |  |  | 29d → 563d |  | constraint none → finish no earlier than 2025-09-29; baseline start 2025-09-29 → 2025-09-16; baseline finish 2025-10-10 → 2025-09-29 |
| 2119 | Test Data Loaded into QP Systems | 2025-10-13 → 2025-09-30 (-13d) | 2025-11-07 → 2025-10-27 (-11d) |  |  | 29d → 563d |  | constraint none → finish no earlier than 2025-10-13; baseline start 2025-10-13 → 2025-09-30; baseline finish 2025-11-07 → 2025-10-27 |
| 2120 | Test Data Loaded into QTF + ADO | 2025-10-13 → 2025-09-30 (-13d) | 2025-11-07 → 2025-10-27 (-11d) |  |  | 29d → 563d |  | constraint none → finish no earlier than 2025-10-13; baseline start 2025-10-13 → 2025-09-30; baseline finish 2025-11-07 → 2025-10-27 |
| 2121 | **Wave 4 Test Data** | 2025-10-27 → 2025-11-06 (+10d) | 2025-12-26 → 2026-01-08 (+13d) |  |  | 49d → none |  | baseline start 2025-10-27 → 2025-11-06; baseline finish 2025-12-26 → 2026-01-08 |
| 2122 | Test Data Request + Templates Completed | 2025-10-27 → 2025-10-17 (-10d) | 2025-11-14 → 2025-11-06 (-8d) |  |  | 49d → 525d | 2243 → none | constraint none → finish no earlier than 2025-11-06; baseline start 2025-10-27 → 2025-10-17; baseline finish 2025-11-14 → 2025-11-06 |
| 2123 | Test Data Generated | 2025-11-17 → 2025-11-14 (-3d) | 2025-11-28 → 2025-11-27 (-1d) |  |  | 49d → 520d |  | constraint none → finish no earlier than 2025-11-27; baseline start 2025-11-17 → 2025-11-14; baseline finish 2025-11-28 → 2025-11-27 |
| 2124 | Test Data Loaded into QP Systems | 2025-12-01 → 2025-11-28 (-3d) | 2025-12-26 → 2025-12-25 (-1d) |  |  | 49d → 520d |  | constraint none → finish no earlier than 2025-12-11; baseline start 2025-12-01 → 2025-11-28; baseline finish 2025-12-26 → 2025-12-25 |
| 2125 | Test Data Loaded into QTF + ADO | 2025-12-01 → 2025-11-28 (-3d) | 2025-12-26 → 2025-12-25 (-1d) |  |  | 49d → 520d |  | constraint none → finish no earlier than 2025-12-11; baseline start 2025-12-01 → 2025-11-28; baseline finish 2025-12-26 → 2025-12-25 |
| 2126 | **Governance** |  | 2024-12-27 → 2025-03-28 (+91d) | 130d → 195d | 29% → 81% | 779d → 714d |  | baseline finish 2024-12-27 → 2024-12-20 |
| 2127 | Onboarding Strategy and Develop Training Requirements & Materials Inc. Day in the Life |  | 2024-09-27 → 2024-12-13 A (+77d) | 65d → 120d | 43% → 100% | 844d → none |  | constraint none → finish no earlier than 2024-12-13; baseline finish 2024-09-27 → 2024-11-29 |
| 2128 | Design Approach & Set-Up ADO Tool for Test & Defect Management Tool |  | 2024-08-30 → 2024-07-26 A (-35d) | 45d → 20d | 62% → 100% | 216d → none |  | baseline finish 2024-08-30 → 2024-07-26 |
| 2129 | Knowledge Transfer, Training, Demonstrations, Documentation, Governance | 2024-09-02 → 2024-08-30 A (-3d) | 2024-12-27 → 2024-12-17 A (-10d) | 85d → 78d | 0% → 100% | 176d → none | 2127SS+45d → 2127SS+44d | baseline start 2024-09-02 → 2024-08-30; baseline finish 2024-12-27 → 2024-12-17 |
| 2133 | Qualification Testing Wave Readiness Confirmed | 2024-12-27 → 2025-08-21 (+237d) | 2024-12-27 → 2025-08-21 (+237d) |  |  | 176d → 611d | 2129 → 2161FS-2d | constraint none → finish no earlier than 2025-05-30; baseline start 2024-12-27 → 2025-08-21; baseline finish 2024-12-27 → 2025-08-21 |
| 2142 | **Qualification Wave 1** | 2025-03-24 → 2025-05-05 (+42d) | 2026-04-10 → 2026-04-15 (+5d) | 275d → 248d |  |  |  |  |
| 2143 | **Qualification Wave 1 QAD Prep** | 2025-03-24 → 2025-05-05 (+42d) | 2025-07-11 → 2025-08-22 (+42d) |  |  | 36d → 6d |  |  |
| 2144 | Initial QAD Submission window opens | 2025-03-24 → 2025-05-05 (+42d) | 2025-03-24 → 2025-05-05 (+42d) |  |  | 36d → 6d | 2141, 1926FS+121d → 2141, 1926FS+1d | constraint none → start no earlier than 2025-03-24; baseline start 2025-03-24 → 2025-05-05; baseline finish 2025-03-24 → 2025-05-05 |
| 2145 | Qualification Wave 1 Participants Submit Initial QAD | 2025-03-24 → 2025-05-05 (+42d) | 2025-05-30 → 2025-07-11 (+42d) |  |  | 36d → 6d |  | baseline start 2025-03-24 → 2025-05-05; baseline finish 2025-05-30 → 2025-07-11 |
| 2146 | Qualification Wave 1 Participants have submitted their initial QAD | 2025-06-02 → 2025-07-14 (+42d) | 2025-06-02 → 2025-07-14 (+42d) |  |  | 36d → 6d |  | baseline start 2025-06-02 → 2025-07-14; baseline finish 2025-06-02 → 2025-07-14 |
| 2147 | Code Bodies review of Wave 1 Participants Initial QAD | 2025-06-02 → 2025-07-14 (+42d) | 2025-07-11 → 2025-08-22 (+42d) |  |  | 36d → 6d |  | baseline start 2025-06-02 → 2025-07-14; baseline finish 2025-07-11 → 2025-08-22 |
| 2148 | Completion of Code Bodies review of Initial QAD | 2025-07-11 → 2025-08-22 (+42d) | 2025-07-11 → 2025-08-22 (+42d) |  |  | 36d → 6d |  | baseline start 2025-07-11 → 2025-08-22; baseline finish 2025-07-11 → 2025-08-22 |
| 2149 | **Qualification Wave 1 Test Prep** | 2025-04-14 → 2025-05-26 (+42d) | 2025-07-04 → 2025-08-15 (+42d) |  |  | 41d → 11d |  |  |
| 2150 | Confirmation from Qualification Wave 1 Participants that DIP onboarding has commenced | 2025-04-14 → 2025-05-26 (+42d) | 2025-04-14 → 2025-05-26 (+42d) |  |  | 61d → 31d |  | constraint start no earlier than 2025-04-14 → start no earlier than 2025-05-26; baseline start 2025-04-14 → 2025-05-26; baseline finish 2025-04-14 → 2025-05-26 |
| 2151 | Qualification Wave 1 Participants DIP Onboarding Window | 2025-04-14 → 2025-05-26 (+42d) | 2025-05-30 → 2025-07-11 (+42d) |  |  | 61d → 31d |  | baseline start 2025-04-14 → 2025-05-26; baseline finish 2025-05-30 → 2025-07-11 |
| 2152 | Confirmation from Qualification Wave 1 Participants that DIP onboarding has completed | 2025-05-30 → 2025-07-11 (+42d) | 2025-05-30 → 2025-07-11 (+42d) |  |  | 61d → 31d |  | baseline start 2025-05-30 → 2025-07-11; baseline finish 2025-05-30 → 2025-07-11 |
| 2153 | Qualification Wave 1 Participants' to provide status of PIT completion and submit QT Test Plan | 2025-05-12 → 2025-06-13 (+32d) | 2025-05-12 → 2025-06-13 (+32d) |  |  | 35d → 37d |  | constraint start no earlier than 2025-05-12 → start no earlier than 2025-06-13; baseline start 2025-05-12 → 2025-06-16; baseline finish 2025-05-12 → 2025-06-16 |
| 2154 | Review of Participants' PIT Status and QT Test Plan | 2025-05-12 → 2025-06-13 (+32d) | 2025-05-30 → 2025-07-03 (+34d) |  |  | 61d → 37d |  | baseline start 2025-05-12 → 2025-06-16; baseline finish 2025-05-30 → 2025-07-04 |
| 2155 | Qualification Test Plans for Wave 1 Participants approved | 2025-05-30 → 2025-07-03 (+34d) | 2025-05-30 → 2025-07-03 (+34d) |  |  | 61d → 37d |  | baseline start 2025-05-30 → 2025-07-04; baseline finish 2025-05-30 → 2025-07-04 |

| ID | Task | Start | Finish | Duration | Total float | Predecessors | Other |
| --- | --- | --- | --- | --- | --- | --- | --- |
| 2156 | Qualification Wave 1 Participants have submitted PIT Test Completion Report and evidence for QT Entry | 2025-06-02 → 2025-07-14 (+42d) | 2025-06-02 → 2025-07-14 (+42d) |  | 36d → 6d |  | constraint start no earlier than 2025-06-02 → start no earlier than 2025-07-14; baseline start 2025-06-02 → 2025-07-14; baseline finish 2025-06-02 → 2025-07-14 |
| 2157 | Review of Participants PIT Test Completion Report | 2025-06-02 → 2025-07-14 (+42d) | 2025-07-04 → 2025-08-15 (+42d) |  | 36d → 6d |  | baseline start 2025-06-02 → 2025-07-14; baseline finish 2025-07-04 → 2025-08-15 |
| 2158 | Onboarding to QTF & ADO | 2025-06-02 → 2025-07-14 (+42d) | 2025-07-04 → 2025-08-15 (+42d) |  | 41d → 11d | 2157SS, 2022 → 2157SS | baseline start 2025-06-02 → 2025-07-14; baseline finish 2025-07-04 → 2025-08-15 |
| 2159 | **Qualification Wave 1 QT Execution** | 2025-07-07 → 2025-08-18 (+42d) | 2026-01-02 → 2026-01-09 (+7d) | 130d → 105d | 10d → 6d |  | baseline start 2025-07-07 → 2025-08-18; baseline finish 2026-01-02 → 2026-01-09 |
| 2160 | Review Entry Criteria Evidence for each Wave 1 Participant | 2025-07-07 → 2025-08-18 (+42d) | 2025-07-11 → 2025-08-22 (+42d) |  | 36d → 6d |  | baseline start 2025-07-07 → 2025-08-18; baseline finish 2025-07-11 → 2025-08-22 |
| 2161 | Qualification Wave 1 Participant Test Readiness Confirmed | 2025-07-14 → 2025-08-22 (+39d) | 2025-07-14 → 2025-08-22 (+39d) |  | 35d → 6d | 2147, 2148, 2160FF, 2109, 2110 → 2147, 2148, 2160FF | baseline start 2025-07-14 → 2025-08-22; baseline finish 2025-07-14 → 2025-08-22 |
| 2162 | Qualification Wave 1 QT Execution Start |  |  |  |  | 2161, 2133, 2158, 1555FS+6d → 2161, 2158, 1555FS+6d |  |
| 2163 | Qualification Wave 1 QT Execution Window |  | 2026-01-02 → 2026-01-09 (+7d) | 95d → 100d |  |  | baseline finish 2026-01-02 → 2026-01-09 |
| 2164 | Qualification Wave 1 QT Projected Execution End | 2026-01-02 → 2026-01-09 (+7d) | 2026-01-02 → 2026-01-09 (+7d) |  |  |  | baseline start 2026-01-02 → 2026-01-09; baseline finish 2026-01-02 → 2026-01-09 |
| 2165 | **Qualification Wave 1 Exit** |  | 2026-04-10 → 2026-04-15 (+5d) | 165d → 168d |  |  | baseline finish 2026-04-10 → 2026-04-15 |
| 2167 | Qualification Wave 1 Participants submit their Final QAD |  | 2026-01-09 → 2026-01-16 (+7d) | 100d → 105d |  |  | baseline finish 2026-01-09 → 2026-01-16 |
| 2168 | Qualification Wave 1 Participants have submitted their final QAD | 2026-01-09 → 2026-01-16 (+7d) | 2026-01-09 → 2026-01-16 (+7d) |  |  |  | baseline start 2026-01-09 → 2026-01-16; baseline finish 2026-01-09 → 2026-01-16 |
| 2169 | Completion of Code Bodies review of Final QAD | 2026-01-12 → 2026-01-19 (+7d) | 2026-02-27 → 2026-03-06 (+7d) |  |  |  | baseline start 2026-01-12 → 2026-01-19; baseline finish 2026-02-27 → 2026-03-06 |
| 2170 | QAD Sign Off deadline | 2026-03-13 → 2026-03-20 (+7d) | 2026-03-13 → 2026-03-20 (+7d) |  |  |  | baseline start 2026-03-13 → 2026-03-20; baseline finish 2026-03-13 → 2026-03-20 |
| 2171 | Qualification Wave 1 Participants Qualification approved by BSC PAB and REC Manager | 2026-04-10 → 2026-04-15 (+5d) | 2026-04-10 → 2026-04-15 (+5d) |  |  | 2170FS+20d → 2170FS+18d | baseline start 2026-04-10 → 2026-04-15; baseline finish 2026-04-10 → 2026-04-15 |
| 2172 | **Qualification Wave 2** |  | 2026-05-27 → 2026-05-28 (+1d) | 253d → 254d |  |  | baseline finish 2026-05-27 → 2026-05-28 |
| 2174 | Initial QAD Submission window opens |  |  |  |  | 1927FS+151d → 1927FS+1d |  |
| 2179 | **Qualification Wave 2 Test Prep** | 2025-06-09 → 2025-07-21 (+42d) | 2025-08-29 → 2025-10-10 (+42d) |  | 42d → 12d |  | baseline start 2025-06-09 → 2025-07-21; baseline finish 2025-08-29 → 2025-10-10 |
| 2180 | Confirmation from Qualification Wave 2 Participants that DIP Onboarding has commenced | 2025-06-09 → 2025-07-21 (+42d) | 2025-06-09 → 2025-07-21 (+42d) |  | 61d → 31d |  | constraint start no earlier than 2025-06-09 → start no earlier than 2025-07-21; baseline start 2025-06-09 → 2025-07-21; baseline finish 2025-06-09 → 2025-07-21 |
| 2181 | Qualification Wave 2 Participants DIP Onboarding Window | 2025-06-09 → 2025-07-21 (+42d) | 2025-07-25 → 2025-09-05 (+42d) |  | 61d → 31d |  | baseline start 2025-06-09 → 2025-07-21; baseline finish 2025-07-25 → 2025-09-05 |
| 2182 | Confirmation from Qualificiation Wave 2 Participants that DIP onboarding has completed | 2025-07-25 → 2025-09-05 (+42d) | 2025-07-25 → 2025-09-05 (+42d) |  | 61d → 31d |  | baseline start 2025-07-25 → 2025-09-05; baseline finish 2025-07-25 → 2025-09-05 |
| 2183 | Qualification Wave 2 Participants' to provide status of PIT completion and submit QT Test Plan | 2025-07-07 → 2025-08-18 (+42d) | 2025-07-07 → 2025-08-18 (+42d) |  | 39d → 31d |  | constraint start no earlier than 2025-07-07 → start no earlier than 2025-08-18; baseline start 2025-07-07 → 2025-08-18; baseline finish 2025-07-07 → 2025-08-18 |
| 2184 | Review of Participants' PIT Status and QT Test Plan | 2025-07-07 → 2025-08-18 (+42d) | 2025-07-25 → 2025-09-05 (+42d) |  | 61d → 31d |  | baseline start 2025-07-07 → 2025-08-18; baseline finish 2025-07-25 → 2025-09-05 |
| 2185 | Qualification Test Plans for Wave 2 Participants approved | 2025-07-25 → 2025-09-05 (+42d) | 2025-07-25 → 2025-09-05 (+42d) |  | 61d → 31d |  | baseline start 2025-07-25 → 2025-09-05; baseline finish 2025-07-25 → 2025-09-05 |
| 2186 | Qualification Wave 2 Participants have submitted PIT Test Completion Report and evidence for QT entry | 2025-07-28 → 2025-09-08 (+42d) | 2025-07-28 → 2025-09-08 (+42d) |  | 36d → 6d |  | constraint start no earlier than 2025-07-28 → start no earlier than 2025-09-08; baseline start 2025-07-28 → 2025-09-08; baseline finish 2025-07-28 → 2025-09-08 |
| 2187 | Review of Participants' PIT Test Completion Report | 2025-07-28 → 2025-09-08 (+42d) | 2025-08-29 → 2025-10-10 (+42d) |  | 36d → 6d |  | baseline start 2025-07-28 → 2025-09-08; baseline finish 2025-08-29 → 2025-10-10 |
| 2188 | Onboarding to QTF & ADO | 2025-07-28 → 2025-09-08 (+42d) | 2025-08-29 → 2025-10-10 (+42d) |  | 42d → 12d |  | baseline start 2025-07-28 → 2025-09-08; baseline finish 2025-08-29 → 2025-10-10 |
| 2191 | Qualification Wave 2 Participant Test Readiness Confirmed |  |  |  |  | 2190, 2178, 2114, 2115 → 2190, 2178 |  |
| 2195 | **Qualification Wave 2 Exit** |  | 2026-05-27 → 2026-05-28 (+1d) | 158d → 159d |  |  | baseline finish 2026-05-27 → 2026-05-28 |
| 2201 | Qualification Wave 2 Participants Qualification approved by BSC PAB and REC Manager | 2026-05-27 → 2026-05-28 (+1d) | 2026-05-27 → 2026-05-28 (+1d) |  |  | 2200FS+27d → 2200FS+28d | baseline start 2026-05-27 → 2026-05-28; baseline finish 2026-05-27 → 2026-05-28 |
| 2202 | **Qualification Wave 3** | 2025-08-04 → 2025-08-11 (+7d) | 2026-07-23 → 2026-07-30 (+7d) |  | 5d → 9d |  | baseline start 2025-08-04 → 2025-08-11; baseline finish 2026-07-23 → 2026-07-30 |
| 2204 | Initial QAD Submission window opens |  |  |  | 0d → 9d | 1928FS+151d → 1928FS+1d |  |
| 2209 | **Qualification Wave 3 Test Prep** | 2025-08-04 → 2025-09-15 (+42d) | 2025-10-31 → 2025-12-12 (+42d) |  | 54d → 39d |  | baseline start 2025-08-04 → 2025-09-15; baseline finish 2025-10-31 → 2025-12-12 |
| 2210 | Confirmation from Qualification Wave 3 Participants that DIP Onboarding has commenced | 2025-08-04 → 2025-09-15 (+42d) | 2025-08-04 → 2025-09-15 (+42d) |  | 60d → 39d |  | constraint start no earlier than 2025-08-04 → start no earlier than 2025-09-15; baseline start 2025-08-04 → 2025-09-15; baseline finish 2025-08-04 → 2025-09-15 |
| 2211 | Qualification Wave 3 Participants DIP Onboarding window | 2025-08-04 → 2025-09-15 (+42d) | 2025-09-19 → 2025-10-31 (+42d) |  | 60d → 39d |  | baseline start 2025-08-04 → 2025-09-15; baseline finish 2025-09-19 → 2025-10-31 |
| 2212 | Confirmation from Qualification Wave 3 Participants that DIP onboarding has completed | 2025-09-22 → 2025-10-31 (+39d) | 2025-09-22 → 2025-10-31 (+39d) |  | 60d → 39d |  | baseline start 2025-09-22 → 2025-10-31; baseline finish 2025-09-22 → 2025-10-31 |
| 2213 | Qualification Wave 3 Participants' to provide status of PIT completion and submit QT Test Plan | 2025-09-08 → 2025-10-20 (+42d) | 2025-09-08 → 2025-10-20 (+42d) |  | 29d → 554d |  | constraint start no earlier than 2025-09-08 → start no earlier than 2025-10-20; baseline start 2025-09-08 → 2025-10-20; baseline finish 2025-09-08 → 2025-10-20 |
| 2214 | Review of Participants' PIT Status and QT Test Plan | 2025-09-08 → 2025-10-20 (+42d) | 2025-09-26 → 2025-11-07 (+42d) |  | 584d → 554d |  | baseline start 2025-09-08 → 2025-10-20; baseline finish 2025-09-26 → 2025-11-07 |
| 2215 | Qualification Test Plans for Wave 3 Participants approved | 2025-09-26 → 2025-11-07 (+42d) | 2025-09-26 → 2025-11-07 (+42d) |  | 584d → 554d |  | baseline start 2025-09-26 → 2025-11-07; baseline finish 2025-09-26 → 2025-11-07 |
| 2216 | Qualification Wave 3 Participants have submitted PIT Test Completion Report and evidence for QT Entry | 2025-09-29 → 2025-11-10 (+42d) | 2025-09-29 → 2025-11-10 (+42d) |  | 30d → 9d |  | constraint start no earlier than 2025-09-29 → start no earlier than 2025-11-10; baseline start 2025-09-29 → 2025-11-10; baseline finish 2025-09-29 → 2025-11-10 |
| 2217 | Review of Participants' PIT Test Completion Report | 2025-09-29 → 2025-11-10 (+42d) | 2025-10-31 → 2025-12-12 (+42d) |  | 30d → 9d |  | baseline start 2025-09-29 → 2025-11-10; baseline finish 2025-10-31 → 2025-12-12 |
| 2218 | Onboarding to QTF & ADO | 2025-09-29 → 2025-11-10 (+42d) | 2025-10-31 → 2025-12-12 (+42d) |  | 30d → 9d |  | baseline start 2025-09-29 → 2025-11-10; baseline finish 2025-10-31 → 2025-12-12 |
| 2221 | Qualification Wave 3 Participant Test Readiness confirmed |  |  |  | 0d → 9d | 2212, 2220FS-1d, 2119, 2120 → 2212, 2220 |  |
| 2222 | Qualification Wave 3 Execution Start | 2026-01-05 → 2026-01-12 (+7d) | 2026-01-05 → 2026-01-12 (+7d) |  | 0d → 9d | 2221FS+12d, 2218FS+1d → 2221FS+16d, 2218FS+1d | baseline start 2026-01-05 → 2026-01-12; baseline finish 2026-01-05 → 2026-01-12 |
| 2223 | Qualification Wave 3 QT Execution Window | 2026-01-05 → 2026-01-12 (+7d) |  | 95d → 90d | 5d → 14d |  | baseline start 2026-01-05 → 2026-01-12 |
| 2225 | **Qualification Wave 3 Exit** | 2026-01-05 → 2026-01-12 (+7d) | 2026-07-23 → 2026-07-30 (+7d) |  | 0d → 9d |  | baseline start 2026-01-05 → 2026-01-12; baseline finish 2026-07-23 → 2026-07-30 |
| 2226 | Final QAD Submission window opens | 2026-01-05 → 2026-01-12 (+7d) | 2026-01-05 → 2026-01-12 (+7d) |  | 0d → 9d |  | baseline start 2026-01-05 → 2026-01-12; baseline finish 2026-01-05 → 2026-01-12 |
| 2227 | Qualification Wave 3 Participants submit their Final QAD | 2026-01-05 → 2026-01-12 (+7d) |  | 100d → 95d | 0d → 9d |  | baseline start 2026-01-05 → 2026-01-12 |
| 2231 | Qualification Wave 3 Participants Qualification approved by BSC PAB and REC Manager | 2026-07-23 → 2026-07-30 (+7d) | 2026-07-23 → 2026-07-30 (+7d) |  | 0d → 9d | 2230FS+19d → 2230FS+24d | baseline start 2026-07-23 → 2026-07-30; baseline finish 2026-07-23 → 2026-07-30 |
| 2232 | **Qualification Wave 4** | 2025-09-22 → 2025-10-20 (+28d) |  | 354d → 334d | 24d → 4d |  | baseline start 2025-09-22 → 2025-10-20 |
| 2234 | Initial QAD Submission window opens |  |  |  |  | 1929FS+161d → 1929FS+1d |  |
| 2239 | **Qualification Wave 4 Test Prep** | 2025-09-22 → 2025-11-03 (+42d) | 2025-12-19 → 2026-02-13 (+56d) | 65d → 75d | 60d → 20d |  | baseline start 2025-09-22 → 2025-11-03; baseline finish 2025-12-19 → 2026-02-13 |
| 2240 | Confirmation from Qualification 4 Participants that DIP Onboarding has commenced | 2025-09-22 → 2025-11-03 (+42d) | 2025-09-22 → 2025-11-03 (+42d) |  | 79d → 54d |  | constraint start no earlier than 2025-09-22 → start no earlier than 2025-11-03; baseline start 2025-09-22 → 2025-11-03; baseline finish 2025-09-22 → 2025-11-03 |
| 2241 | Qualification Wave 4 Participants DIP Onboarding Window | 2025-09-22 → 2025-11-03 (+42d) | 2025-11-07 → 2025-12-19 (+42d) |  | 79d → 54d |  | baseline start 2025-09-22 → 2025-11-03; baseline finish 2025-11-07 → 2025-12-19 |
| 2242 | Confirmation from Qualification Wave 4 Participants that DIP onboarding has completed | 2025-11-07 → 2025-12-19 (+42d) | 2025-11-07 → 2025-12-19 (+42d) |  | 79d → 54d |  | baseline start 2025-11-07 → 2025-12-19; baseline finish 2025-11-07 → 2025-12-19 |
| 2243 | Qualification Wave 4 Participants' to provide status of PIT completion and submit QT Test Plan | 2025-10-27 → 2025-12-08 (+42d) | 2025-10-27 → 2025-12-08 (+42d) |  | 49d → 20d |  | constraint start no earlier than 2025-10-27 → start no earlier than 2025-12-08; baseline start 2025-10-27 → 2025-12-08; baseline finish 2025-10-27 → 2025-12-08 |
| 2244 | Review of Participants' PIT Status and QT Test Plan | 2025-10-27 → 2025-12-08 (+42d) | 2025-11-14 → 2026-01-09 (+56d) | 15d → 25d | 60d → 20d |  | baseline start 2025-10-27 → 2025-12-08; baseline finish 2025-11-14 → 2026-01-09 |
| 2245 | Qualification Test Plans for Qualification Wave 4 Participants approved | 2025-11-14 → 2026-01-09 (+56d) | 2025-11-14 → 2026-01-09 (+56d) |  | 60d → 20d |  | baseline start 2025-11-14 → 2026-01-09; baseline finish 2025-11-14 → 2026-01-09 |
| 2246 | Qualification Wave 4 Participants have submitted PIT Test Completion Report and evidence for QT entry | 2025-11-14 → 2026-01-09 (+56d) | 2025-11-14 → 2026-01-09 (+56d) |  | 60d → 20d |  | baseline start 2025-11-14 → 2026-01-09; baseline finish 2025-11-14 → 2026-01-09 |
| 2247 | Review of Participants' PIT Test Completion Report | 2025-11-17 → 2026-01-12 (+56d) | 2025-12-19 → 2026-02-13 (+56d) |  | 60d → 20d |  | baseline start 2025-11-17 → 2026-01-12; baseline finish 2025-12-19 → 2026-02-13 |
| 2248 | Onboarding to QTF & ADO | 2025-11-24 → 2026-01-12 (+49d) | 2025-12-19 → 2026-02-13 (+56d) | 20d → 25d | 55d → 20d |  | baseline start 2025-11-24 → 2026-01-12; baseline finish 2025-12-19 → 2026-02-13 |
| 2249 | **Qualification Wave 4 QT Execution** | 2026-02-23 → 2026-03-02 (+7d) | 2026-07-10 → 2026-07-17 (+7d) |  |  |  | baseline start 2026-02-23 → 2026-03-02; baseline finish 2026-07-10 → 2026-07-17 |
| 2250 | Review Entry Criteria Evidence for each Wave 4 Participant | 2026-02-23 → 2026-03-02 (+7d) | 2026-02-27 → 2026-03-06 (+7d) |  |  | 2238FF, 2242 → 2238FF+5d, 2242 | constraint start no earlier than 2026-01-05 → none; baseline start 2026-02-23 → 2026-03-02; baseline finish 2026-02-27 → 2026-03-06 |
| 2251 | Qualification Wave 4 Participant Test Readiness Confirmed | 2026-02-27 → 2026-03-06 (+7d) | 2026-02-27 → 2026-03-06 (+7d) |  |  | 2242, 2250, 2124, 2125 → 2242, 2250 | baseline start 2026-02-27 → 2026-03-06; baseline finish 2026-02-27 → 2026-03-06 |
| 2252 | Qualification Wave 4 QT Execution Start | 2026-03-02 → 2026-03-09 (+7d) | 2026-03-02 → 2026-03-09 (+7d) |  |  |  | baseline start 2026-03-02 → 2026-03-09; baseline finish 2026-03-02 → 2026-03-09 |
| 2253 | Qualification Wave 4 QT Execution Window | 2026-03-02 → 2026-03-09 (+7d) | 2026-07-10 → 2026-07-17 (+7d) |  |  |  | baseline start 2026-03-02 → 2026-03-09; baseline finish 2026-07-10 → 2026-07-17 |
| 2254 | Qualification Wave 4 Projected Execution End | 2026-07-10 → 2026-07-17 (+7d) | 2026-07-10 → 2026-07-17 (+7d) |  |  |  | baseline start 2026-07-10 → 2026-07-17; baseline finish 2026-07-10 → 2026-07-17 |
| 2255 | **Qualification Wave 4 Exit** | 2026-03-02 → 2026-03-09 (+7d) | 2026-09-18 → 2026-09-24 (+6d) | 145d → 144d |  |  | baseline start 2026-03-02 → 2026-03-09; baseline finish 2026-09-18 → 2026-09-24 |
| 2256 | Final QAD Submission window opens | 2026-03-02 → 2026-03-09 (+7d) | 2026-03-02 → 2026-03-09 (+7d) |  |  |  | baseline start 2026-03-02 → 2026-03-09; baseline finish 2026-03-02 → 2026-03-09 |
| 2257 | Qualification Wave 4 Participants submit their Final QAD | 2026-03-02 → 2026-03-09 (+7d) | 2026-07-17 → 2026-07-24 (+7d) |  |  |  | baseline start 2026-03-02 → 2026-03-09; baseline finish 2026-07-17 → 2026-07-24 |

| ID | Task | Start | Finish | Duration | Complete | Total float | Predecessors | Other |
| --- | --- | --- | --- | --- | --- | --- | --- | --- |
| 2258 | Qualification Wave 4 Participants have submitted their Final QAD | 2026-07-17 → 2026-07-24 (+7d) | 2026-07-17 → 2026-07-24 (+7d) |  |  |  |  | baseline start 2026-07-17 → 2026-07-24; baseline finish 2026-07-17 → 2026-07-24 |
| 2259 | Completion of Code Bodies review of Final QAD | 2026-07-20 → 2026-07-27 (+7d) | 2026-08-14 → 2026-08-21 (+7d) |  |  |  |  | baseline start 2026-07-20 → 2026-07-27; baseline finish 2026-08-14 → 2026-08-21 |
| 2260 | QAD Sign Off deadline | 2026-08-21 → 2026-08-28 (+7d) | 2026-08-21 → 2026-08-28 (+7d) |  |  |  |  | baseline start 2026-08-21 → 2026-08-28; baseline finish 2026-08-21 → 2026-08-28 |
| 2261 | Qualification Wave 4 Participants Qualification approved by BSC PAB and REC Manager | 2026-09-18 → 2026-09-24 (+6d) | 2026-09-18 → 2026-09-24 (+6d) |  |  |  | 2260FS+20d → 2260FS+19d | baseline start 2026-09-18 → 2026-09-24; baseline finish 2026-09-18 → 2026-09-24 |
| 2263 | All suppliers must be able to access MPANs under the new TOM (M14) |  |  |  |  |  | 2261FS+28d → 2261FS+24d |  |
| 2265 | **REGULATORY** |  |  |  | 93% → 99% |  |  |  |
| 2370 | **Ofgem preparation and enactment of SCR powers** |  | 2024-12-13 A |  | 71% → 100% | 789d → none |  |  |
| 2371 | **Preparation and enactment of SCR Powers** |  | 2024-12-11 A |  | 72% → 100% | 726d → none |  |  |
| 2379 | Each Code Body sends Modification Proposal Forms to Panel to approve Mod to go to consultation |  | 2024-09-16 A |  | 33% → 100% | 726d → none |  |  |
| 2380 | Modification Proposal approved by Panel for Consultation | 2024-09-17 A | 2024-09-17 A |  | 0% → 100% | 726d → none |  |  |
| 2381 | Draft Modification Report issued for consultation | 2024-09-18 A | 2024-09-18 A |  | 0% → 100% | 726d → none |  |  |
| 2382 | Consultation Close-out for representations | 2024-09-19 A | 2024-10-09 A |  | 0% → 100% | 726d → none |  |  |
| 2383 | Each Code Body reviews consultation response and drafts Modification Report | 2024-10-10 A | 2024-10-23 A |  | 0% → 100% | 726d → none |  |  |
| 2384 | Final Modification Report sent to Panel for decision with recommendation to approve | 2024-10-24 A | 2024-10-24 A |  | 0% → 100% | 726d → none |  |  |
| 2385 | Modification Panel decision | 2024-11-07 A | 2024-11-07 A |  | 0% → 100% | 726d → none |  |  |
| 2386 | Code Bodies Submit Final Modification/Change Reports | 2024-11-08 A | 2024-11-08 A |  | 0% → 100% | 726d → none |  |  |
| 2387 | Ofgem Reviews Final Modification/Change Reports | 2024-11-11 A | 2024-11-22 A |  | 0% → 100% | 726d → none |  |  |
| 2388 | Ofgem Drafts Decision/Direction Letters | 2024-11-18 A | 2024-12-10 A |  | 0% → 100% | 726d → none |  |  |
| 2389 | Ofgem Internally Signs Off the Decision/Direction Letters and Sends Them to the Code Bodies | 2024-12-11 A | 2024-12-11 A |  | 0% → 100% | 726d → none |  |  |
| 2390 | Ofgem decisions on M6 baselined code modification proposals (M7) | 2024-12-11 A | 2024-12-11 A |  | 0% → 100% | 726d → none |  |  |
| 2391 | Ofgem Publishes the Decisions/Directions | 2024-12-12 A | 2024-12-13 A |  | 0% → 100% | 789d → none |  |  |
| 2392 | **Deliver MHHS Code Changes** | 2024-11-12 A |  |  | 0% → 84% |  |  |  |
| 2393 | **Releases** | 2024-11-12 A |  |  | 0% → 84% |  |  |  |
| 2394 | Impacted codes make resourcing provisions and prepare to implement new Code via internal code body change processes | 2024-11-12 A |  |  | 0% → 90% |  |  |  |
| 2404 | **MIGRATION** |  | 2027-08-09 → 2027-08-03 (-6d) | 1246d → 1242d? | 35% → 37% | 98d → 102d |  |  |
| 2409 | **Migration Framework Agreed and Implemented** |  | 2025-01-23 → 2025-05-07 (+104d) | 256d → 330d? | 62% → 58% | 121d → 686d |  |  |
| 2424 | **Consultation 3 - Parameters** | 2024-07-09 A → 2024-11-18 A (+132d) | 2025-01-23 → 2025-02-25 (+33d) | 143d → 72d | 18% → 71% | 121d → 649d |  | baseline start 2024-07-09 → 2024-11-18; baseline finish 2025-01-23 → 2025-02-25 |
| 2425 | Prepare Artefacts for Consultation | 2024-07-09 A → 2024-11-18 A (+132d) | 2024-11-18 → 2024-12-19 A (+31d) | 95d → 24d | 23% → 100% | 121d → none | 2443SS+6d → none | was named Prepare Artefacts (9) for Consultation; baseline start 2024-07-09 → 2024-11-18; baseline finish 2024-11-18 → 2024-12-19 |
| 2426 | Industry Consultation | 2024-11-19 → 2024-12-20 A (+31d) | 2024-12-02 → 2025-01-17 (+46d) | 10d → 21d | 0% → 95% | 121d → 649d |  | baseline start 2024-11-19 → 2024-12-20; baseline finish 2024-12-02 → 2025-01-17 |
| 2427 | Triage Response | 2024-12-03 → 2025-01-20 (+48d) | 2024-12-16 → 2025-01-31 (+46d) |  |  | 121d → 649d |  | was named Triage and Action Comments; baseline start 2024-12-03 → 2025-01-20; baseline finish 2024-12-16 → 2025-01-31 |
| 2428 | Industry Assurance Review | 2024-12-17 → 2025-02-03 (+48d) | 2024-12-25 → 2025-02-11 (+48d) |  |  | 121d → 649d |  | baseline start 2024-12-17 → 2025-02-03; baseline finish 2024-12-25 → 2025-02-11 |
| 2429 | MWG Recommendation | 2025-01-06 → 2025-02-21 (+46d) | 2025-01-06 → 2025-02-21 (+46d) |  |  | 121d → 649d |  | baseline start 2025-01-06 → 2025-02-21; baseline finish 2025-01-06 → 2025-02-21 |
| 2431 | MCAG Approval of Migration Framework Artefacts (Baselined) | 2025-01-23 → 2025-02-25 (+33d) | 2025-01-23 → 2025-02-25 (+33d) |  |  | 121d → 649d | 2444, 2429FS+13d → 2444, 2429, 2430 | baseline start 2025-01-23 → 2025-02-25; baseline finish 2025-01-23 → 2025-02-25 |
| 2442 | **Migration Schedule Agreed and Maintained** |  | 2026-01-30 → 2025-07-18 (-196d) | 415d → 275d? | 14% → 57% | 494d → 359d |  |  |
| 2444 | Supplier Submissions |  | 2024-10-02 A |  | 11% → 100% | 202d → none |  |  |
| 2445 | Team Assess Responses | 2024-10-03 A | 2024-10-16 A |  | 0% → 100% | 552d → none |  |  |
| 2446 | Discuss and Agree Approach with Participants where necessary | 2024-10-17 A | 2024-10-22 A |  | 0% → 100% | 552d → none |  |  |
| 2449 | V1.0 of Migration Schedule Baseline Approved at MCAG | 2025-01-10 → 2025-07-18 (+189d) | 2025-01-10 → 2025-07-18 (+189d) |  |  | 494d → 359d | 2465, 2446 → 2448 | baseline start 2025-01-10 → 2025-07-18; baseline finish 2025-01-10 → 2025-07-18 |
| 2457 | Sprint Planning (Cycle 1) | 2025-06-16 → 2025-12-22 (+189d) | 2025-08-08 → 2026-02-13 (+189d) |  |  | 494d → 359d |  |  |
| 2458 | Sprint Planning (Cycle 2) | 2025-09-15 → 2026-03-23 (+189d) | 2025-11-07 → 2026-05-15 (+189d) |  |  | 494d → 359d |  |  |
| 2459 | Sprint Planning (Cycle 3) | 2025-12-08 → 2026-06-15 (+189d) | 2026-01-30 → 2026-08-07 (+189d) |  |  | 494d → 359d |  |  |
| 2460 | **Migration Control Centre Tooling** |  |  |  | 30% → 66% | 112d → 663d |  |  |
| 2461 | Data Source Definition |  | 2024-10-23 A |  | 46% → 100% | 112d → none |  |  |
| 2462 | Scheduling and Data Requirements |  | 2024-10-23 A |  | 46% → 100% | 112d → none |  |  |
| 2468 | **Migration Control Centre Mobilised and Ready** |  | 2025-04-14 → 2025-05-02 (+18d) | 185d → 199d |  | 112d → 649d |  |  |
| 2473 | Dress Rehearsal | 2025-04-14 → 2025-05-02 (+18d) | 2025-04-14 → 2025-05-02 (+18d) |  |  | 112d → 649d |  |  |
| 2474 | **PP's Prepared for Migration** |  | 2025-03-31 → 2025-05-01 (+31d) | 196d → 219d |  | 121d → 649d |  |  |
| 2477 | Guides Creation | 2025-01-28 → 2025-02-28 (+31d) | 2025-03-31 → 2025-05-01 (+31d) |  |  | 121d → 649d |  |  |
| 2478 | Support Channels | 2025-01-28 → 2025-02-28 (+31d) | 2025-03-31 → 2025-05-01 (+31d) |  |  | 121d → 649d |  |  |
| 2479 | **Migration Artefact Development and Publication** |  | 2025-09-03 → 2025-10-15 (+42d) | 743d → 773d | 80% → 91% | 601d → 571d |  |  |
| 2522 | **Data Cleanse Plan** |  | 2025-09-03 → 2025-10-15 (+42d) | 655d → 685d | 65% → 84% | 601d → 571d |  |  |
| 2526 | Monitor Programme Participant adherence to Data Cleanse Plan |  |  |  | 64% → 80% |  |  |  |
| 2527 | **MTDs** |  | 2025-01-31 → 2025-01-24 (-7d) | 120d → 115d | 45% → 98% | 754d → 759d |  |  |
| 2528 | **ESME ID** |  | 2024-12-20 A |  | 0% → 100% | 784d → none |  |  |
| 2530 | LDSO ‘full refresh’ between their Registration Service and the EES (ESME ID) | 2024-10-21 A | 2024-11-11 A |  | 0% → 100% | 784d → none |  |  |
| 2531 | Suppliers complete investigation of exceptions and resolution of exceptions | 2024-12-20 A | 2024-12-20 A |  | 0% → 100% | 784d → none |  |  |
| 2532 | ESME ID Complete | 2024-12-20 A | 2024-12-20 A |  | 0% → 100% | 784d → none |  |  |
| 2533 | **Meter Location and Number of Displayed Register Digits** |  | 2025-01-31 → 2025-01-24 (-7d) | 101d → 96d | 78% → 96% | 754d → 759d |  |  |
| 2535 | LDSO ‘full refresh’ between their Registration Service and the EES (Meter Location and Number of Displayed Register Digits) | 2024-10-28 A → 2024-10-21 A (-7d) | 2024-11-18 → 2024-11-15 A (-3d) |  | 75% → 100% | 754d → none |  |  |
| 2536 | Suppliers complete investigation of exceptions and resolution of exceptions | 2025-01-31 → 2025-01-24 (-7d) | 2025-01-31 → 2025-01-24 (-7d) |  |  | 754d → 759d | 2535FS+53d → 2535FS+49d |  |
| 2537 | Meter Location and Number of Displayed Register Digits Complete | 2025-01-31 → 2025-01-24 (-7d) | 2025-01-31 → 2025-01-24 (-7d) |  |  | 754d → 759d |  |  |
| 2538 | **Registration Data** |  | 2025-09-03 → 2025-10-15 (+42d) | 259d → 289d | 5% → 81% | 601d → 571d |  |  |
| 2539 | **Connection Type** |  | 2024-11-11 A |  | 6% → 100% | 813d → none |  |  |
| 2545 | Full MPAN refresh to ESS | 2024-10-21 A | 2024-11-11 A |  | 0% → 100% | 813d → none |  |  |
| 2546 | Connection Type Complete | 2024-11-11 A | 2024-11-11 A |  | 0% → 100% | 813d → none |  |  |
| 2547 | **Domestic Premises Indicator** | 2025-08-08 → 2025-09-19 (+42d) | 2025-09-03 → 2025-10-15 (+42d) |  |  | 601d → 571d |  |  |
| 2548 | The DCC to extract Domestic Premises Indicator from the CSS and provide a file to each LDSO and EES. | 2025-08-08 → 2025-09-19 (+42d) | 2025-08-11 → 2025-09-22 (+42d) |  |  | 601d → 571d | none → 1742FS-4d | baseline start 2025-08-08 → 2025-09-19; baseline finish 2025-08-11 → 2025-09-22 |
| 2549 | Each LDSO notifies the DCC of any exceptions | 2025-08-12 → 2025-09-23 (+42d) | 2025-08-12 → 2025-09-23 (+42d) |  |  | 601d → 571d |  | baseline start 2025-08-12 → 2025-09-23; baseline finish 2025-08-12 → 2025-09-23 |
| 2550 | Each LDSO and DCC completes investigation and resolution of exceptions | 2025-09-03 → 2025-10-15 (+42d) | 2025-09-03 → 2025-10-15 (+42d) |  |  | 601d → 571d |  | baseline start 2025-09-03 → 2025-10-15; baseline finish 2025-09-03 → 2025-10-15 |
| 2551 | Domestic Premises Indicator Complete | 2025-09-03 → 2025-10-15 (+42d) | 2025-09-03 → 2025-10-15 (+42d) |  |  | 601d → 571d |  | baseline start 2025-09-03 → 2025-10-15; baseline finish 2025-09-03 → 2025-10-15 |

| ID | Task | Start | Finish | Duration | Complete | Total float | Predecessors | Other |
| --- | --- | --- | --- | --- | --- | --- | --- | --- |
| 2552 | **Export / Import MPANs** |  | 2024-10-18 A |  | 99% → 100% | 829d → none |  |  |
| 2553 | **Linking of Export / Import MPANS** |  | 2024-10-18 A |  | 99% → 100% | 829d → none |  |  |
| 2557 | Each LDSO has linked al relevant import/export MPANS | 2024-10-18 A | 2024-10-18 A |  | 0% → 100% | 829d → none |  |  |
| 2558 | Linking of Export / Import MPANS Complete | 2024-10-18 A | 2024-10-18 A |  | 0% → 100% | 829d → none |  |  |
| 2582 | **Preparation for Cutover to Live** |  | 2025-10-22 → 2025-10-17 (-5d) | 344d → 341d |  | 566d → 569d |  |  |
| 2585 | **Development of Comms Approach and Declaration Guidance** | 2025-03-03 → 2025-04-28 (+56d) | 2025-06-19 → 2025-08-14 (+56d) |  |  | 74d → 34d |  |  |
| 2586 | Draft Cutover Comms Approach | 2025-03-03 → 2025-04-28 (+56d) | 2025-05-22 → 2025-07-17 (+56d) |  |  | 74d → 34d |  | constraint start no earlier than 2025-03-03 → start no earlier than 2025-04-28; baseline start 2025-03-03 → 2025-04-28; baseline finish 2025-05-22 → 2025-07-17 |
| 2587 | Draft Cutover Comms Approach shared | 2025-05-22 → 2025-07-17 (+56d) | 2025-05-22 → 2025-07-17 (+56d) |  |  | 74d → 34d |  | baseline start 2025-05-22 → 2025-07-17; baseline finish 2025-05-22 → 2025-07-17 |
| 2588 | Development of Implementation Group | 2025-03-03 → 2025-04-28 (+56d) | 2025-05-22 → 2025-07-17 (+56d) |  |  | 74d → 34d |  | constraint start no earlier than 2025-03-03 → start no earlier than 2025-04-28; baseline start 2025-03-03 → 2025-04-28; baseline finish 2025-05-22 → 2025-07-17 |
| 2589 | Implementation Group Established | 2025-05-22 → 2025-07-17 (+56d) | 2025-05-22 → 2025-07-17 (+56d) |  |  | 74d → 34d |  | baseline start 2025-05-22 → 2025-07-17; baseline finish 2025-05-22 → 2025-07-17 |
| 2590 | Finalised Cutover Comms Approach shared | 2025-06-19 → 2025-08-14 (+56d) | 2025-06-19 → 2025-08-14 (+56d) |  |  | 74d → 34d |  | baseline start 2025-06-19 → 2025-08-14; baseline finish 2025-06-19 → 2025-08-14 |
| 2591 | **Development of Cutover Plan requirements with Participants** | 2025-03-03 → 2025-04-28 (+56d) | 2025-08-06 → 2025-09-04 (+29d) | 113d → 94d |  | 40d → 19d |  |  |
| 2592 | Development of SIT Participant Cutover Plans | 2025-03-03 → 2025-04-28 (+56d) | 2025-05-22 → 2025-07-17 (+56d) |  |  | 40d → 19d |  | constraint start no earlier than 2025-03-03 → start no earlier than 2025-04-28; baseline start 2025-03-03 → 2025-04-28; baseline finish 2025-05-22 → 2025-07-17 |
| 2593 | SIT Participant Cutover Plans Ready | 2025-05-22 → 2025-07-17 (+56d) | 2025-05-22 → 2025-07-17 (+56d) |  |  | 40d → 19d |  | baseline start 2025-05-22 → 2025-07-17; baseline finish 2025-05-22 → 2025-07-17 |
| 2594 | Programme SIT Participant Cutover Plan Assurance | 2025-06-06 → 2025-07-18 (+42d) | 2025-08-06 → 2025-09-04 (+29d) | 44d → 35d |  | 40d → 19d | 2593FS+10d → 2593 | baseline start 2025-06-06 → 2025-07-18; baseline finish 2025-08-06 → 2025-09-17 |
| 2595 | **M10/M11 Cutover Activities** | 2025-04-14 → 2025-09-05 (+144d) |  | 119d → 15d |  | 112d → 12d |  |  |
| 2609 | MCC Tested and Ready to Operate | 2025-04-14 → 2025-09-19 (+158d) | 2025-04-14 → 2025-09-19 (+158d) |  |  | 112d → 590d | 2473 → none | constraint none → start no earlier than 2025-09-19; baseline start 2025-04-14 → 2025-09-19; baseline finish 2025-04-14 → 2025-09-19 |
| 2610 | MCC Operational | 2025-04-14 → 2025-09-19 (+158d) | 2025-04-14 → 2025-09-19 (+158d) |  |  | 122d → 590d |  | baseline start 2025-04-14 → 2025-09-19; baseline finish 2025-04-14 → 2025-09-19 |
| 2613 | **Cutover Governance M10** | 2025-07-30 → 2025-09-10 (+42d) |  | 41d → 11d |  | 39d → 8d |  |  |
| 2614 | Confirmation that Pre-migration Data Cleanse Activities have successfully taken place | 2025-07-30 → 2025-09-10 (+42d) | 2025-07-30 → 2025-09-10 (+42d) |  |  | 41d → 10d |  | constraint start no earlier than 2025-07-30 → start no earlier than 2025-09-10; baseline start 2025-07-30 → 2025-09-10; baseline finish 2025-07-30 → 2025-09-10 |
| 2615 | Confirmation of Helix E2E Settlement Testing Complete | 2025-08-01 → 2025-09-15 (+45d) | 2025-08-01 → 2025-09-15 (+45d) |  |  | 38d → 7d | 1559FS+85d → none | constraint none → start no earlier than 2025-09-15; baseline start 2025-08-01 → 2025-09-15; baseline finish 2025-08-01 → 2025-09-15 |
| 2616 | Confirmation of assurance of Helix E2E Settlement Testing | 2025-08-01 → 2025-09-15 (+45d) | 2025-08-01 → 2025-09-15 (+45d) |  |  | 38d → 7d | 1561FS+85d → none | constraint none → start no earlier than 2025-09-15; baseline start 2025-08-01 → 2025-09-15; baseline finish 2025-08-01 → 2025-09-15 |
| 2617 | Confirmation of Qualification Status for SIT MVC | 2025-09-12 → 2025-09-15 (+3d) | 2025-09-12 → 2025-09-15 (+3d) |  |  | 6d → 7d | 1631FS+15d → none | constraint none → start no earlier than 2025-09-15; baseline start 2025-09-12 → 2025-09-15; baseline finish 2025-09-12 → 2025-09-15 |
| 2618 | Confirmation of Qualification Status for Non-SIT LDSOs |  |  |  |  | 594d → 7d | 2623FS-5d → none | constraint none → start no earlier than 2025-09-15 |
| 2619 | Confirmation of Qualification Status of at least one Supplier and their contracted Agents | 2025-09-12 → 2025-09-15 (+3d) | 2025-09-12 → 2025-09-15 (+3d) |  |  | 6d → 7d | 2617 → none | constraint none → start no earlier than 2025-09-15; baseline start 2025-09-12 → 2025-09-15; baseline finish 2025-09-12 → 2025-09-15 |
| 2620 | Declaration from all Central Services and LDSOs that they are in a position to move forwards |  |  |  |  | 594d → 8d | 2623FS-5d, 1559, 1561 → none | constraint none → start no earlier than 2025-09-15 |
| 2621 | Market-wide Participant MHHS Migration Supporting Functionality is Live |  |  |  |  | 594d → 8d | 2599 → none | constraint none → start no earlier than 2025-09-15 |
| 2622 | TORWG (Recommendation from TORWG that the Programme should enter M10) | 2025-09-16 → 2025-09-17 (+1d) | 2025-09-16 → 2025-09-17 (+1d) |  |  | 6d → 5d | 2614, 2617FS+2d, 2619FS+2d, 2596, 2597, 2705, 2615, 2616 → 2614FS+1d, 2617FS+1d, 2619FS+1d, 2596FS+1d, 2597FS+1d, 2705FS+1d, 2615FS+1d, 2616FS+1d, 2618FS+1d, 2620, 2621 | baseline start 2025-09-16 → 2025-09-17; baseline finish 2025-09-16 → 2025-09-17 |
| 2630 | **Cutover Governance M11** |  | 2025-10-22 → 2025-10-17 (-5d) | 19d → 16d |  | 5d → 8d |  |  |
| 2635 | MCAG (Provide recommendation to PSG on M11 decision) | 2025-10-17 → 2025-10-15 (-2d) | 2025-10-17 → 2025-10-15 (-2d) |  |  | 5d → 8d | 2634FS+4d → 2634FS+2d | baseline start 2025-10-17 → 2025-10-15; baseline finish 2025-10-17 → 2025-10-15 |
| 2636 | PSG (OFGEM and PSG Decision to Confirm M11 and M12) | 2025-10-22 → 2025-10-17 (-5d) | 2025-10-22 → 2025-10-17 (-5d) |  |  | 5d → 8d | 2635FS+3d → 2635FS+2d | baseline start 2025-10-22 → 2025-10-17; baseline finish 2025-10-22 → 2025-10-17 |
| 2637 | **UMS / Advanced Migration** |  | 2027-05-07 → 2027-04-30 (-7d) | 402d → 397d |  | 0d → 5d |  |  |
| 2639 | SIT Non-MVC UMS / Advanced Migration | 2026-01-02 → 2025-12-29 (-4d) | 2027-04-02 → 2027-03-29 (-4d) |  |  | 25d → 29d |  |  |
| 2641 | Wave 2 UMS / Advanced Migration |  |  |  |  |  | 2774 → 2774FS-1d |  |
| 2642 | Wave 3 UMS / Advanced Migration | 2026-08-27 → 2026-08-14 (-13d) | 2027-05-07 → 2027-04-26 (-11d) |  |  | 0d → 9d |  |  |
| 2643 | Wave 4 UMS / Advanced Migration |  |  |  |  |  | 2822 → 2822FS-4d |  |
| 2644 | **Smart / Non-Smart Migration** |  | 2027-05-07 → 2027-04-30 (-7d) | 402d → 397d |  | 0d → 5d |  |  |
| 2646 | SIT Non-MVC Smart / Non-Smart Migration | 2026-01-02 → 2025-12-29 (-4d) | 2027-04-02 → 2027-03-29 (-4d) |  |  | 25d → 29d |  |  |
| 2648 | Wave 2 Smart / Non-Smart Migration |  |  |  |  |  | 2774 → 2774FS-1d |  |
| 2649 | Wave 3 Smart / Non-Smart Migration | 2026-08-27 → 2026-08-14 (-13d) | 2027-05-07 → 2027-04-26 (-11d) |  |  | 0d → 9d |  |  |
| 2650 | Wave 4 Smart / Non-Smart Migration |  |  |  |  |  | 2822 → 2822FS-4d |  |
| 2664 | **Migration - Tier 1 Milestones** |  | 2027-08-09 → 2027-08-03 (-6d) | 488d → 484d |  |  |  |  |
| 2671 | Full transition complete (M15) | 2027-05-07 → 2027-05-03 (-4d) | 2027-05-07 → 2027-05-03 (-4d) |  |  | 0d → 4d |  |  |
| 2672 | Full transition complete (M15*) - Late Exit | 2027-08-09 → 2027-08-03 (-6d) | 2027-08-09 → 2027-08-03 (-6d) |  |  | 98d → 102d |  |  |
| 2673 | **BUSINESS & OPERATIONAL READINESS** |  | 2027-12-23 → 2027-12-17 (-6d) | 1344d? → 1340d? |  | 0d → 4d |  |  |
| 2688 | **Service Activation** |  | 2026-10-22 → 2026-10-28 (+6d) | 1039d? → 1043d? |  | 305d → 301d |  |  |
| 2689 | **SIT MVC** | 2025-02-03 → 2022-10-31 (-826d) | 2025-09-22 → 2025-10-10 (+18d) | 166d? → 770d? |  | 163d → 574d |  |  |
| 2701 | MHHSP Confirms SIT MVC PPs MHHS Enabled | 2025-04-15 → 2022-10-31 (-897d) | 2025-04-15 → 2022-10-31 (-897d) |  |  | 112d → 753d | 2609 → none |  |
| 2703 | Add EFD to DIP |  |  |  |  |  |  | was named Add EDF to DIP |
| 2712 | **SIT MVC Service Activation Implementation MDD** | 2025-03-06 → 2025-09-22 (+200d) | 2025-03-25 → 2025-10-10 (+199d) | 14d → 15d |  | 717d → 574d |  |  |
| 2713 | MDD Manual Load | 2025-03-06 → 2025-09-22 (+200d) | 2025-03-14 → 2025-09-30 (+200d) |  |  | 724d → 574d | none → 2708 |  |
| 2714 | MDD Update | 2025-03-14 → 2025-10-01 (+201d) | 2025-03-25 → 2025-10-10 (+199d) |  |  | 717d → 574d | none → 2713 |  |
| 2715 | SIT MVC Service Activation Implementation MDD Complete | 2025-03-25 → 2025-10-10 (+199d) | 2025-03-25 → 2025-10-10 (+199d) |  |  | 717d → 574d | none → 2714 |  |
| 2716 | **SIT MVC Service Activation Hypercare** | 2025-03-03 → 2025-09-12 (+193d) | 2025-03-26 → 2025-10-10 (+198d) | 18d → 21d |  | 716d → 574d |  |  |
| 2717 | Service & Process Monitoring | 2025-03-03 → 2025-09-12 (+193d) | 2025-03-26 → 2025-10-07 (+195d) |  |  | 716d → 577d | none → 2703SS |  |
| 2718 | Daily Reporting | 2025-03-03 → 2025-09-12 (+193d) | 2025-03-26 → 2025-10-07 (+195d) |  |  | 716d → 577d | none → 2703SS |  |
| 2719 | Issue Management | 2025-03-03 → 2025-09-12 (+193d) | 2025-03-26 → 2025-10-07 (+195d) |  |  | 716d → 577d | none → 2703SS |  |
| 2720 | SA Hypercare Close Down Activities | 2025-03-03 → 2025-09-12 (+193d) | 2025-03-26 → 2025-10-07 (+195d) |  |  | 716d → 574d | none → 2703SS |  |
| 2721 | Handover to MHHSP | 2025-03-21 → 2025-10-08 (+201d) | 2025-03-25 → 2025-10-10 (+199d) |  |  | 717d → 574d | none → 2720 |  |
| 2722 | SIT MVC Service Activation Hypercare Complete | 2025-03-25 → 2025-10-10 (+199d) | 2025-03-25 → 2025-10-10 (+199d) |  |  | 717d → 574d | none → 2721 |  |
| 2723 | **SIT Non-MVC** |  | 2026-01-01 → 2026-01-19 (+18d) | 829d → 841d? |  | 515d → 503d |  |  |
| 2724 | **SIT Non-MVC Service Activation Preparation Tasks** |  | 2022-10-31 → 2025-02-28 (+851d) | 1d → 610d |  | 845d → 734d |  |  |
| 2725 | Helix Preparatory Activities Complete | 2022-10-31 → 2025-02-28 (+851d) | 2022-10-31 → 2025-02-28 (+851d) |  |  | 1344d → 734d | none → 2700 |  |
| 2727 | **SIT Non-MVC Service Activation Implementation** | 2025-12-23 → 2025-12-19 (-4d) | 2026-01-01 → 2025-12-29 (-3d) | 8d → 7d? |  | 25d → 29d |  |  |
| 2728 | Add EDF to DIP | 2025-12-23 → 2025-12-19 (-4d) | 2025-12-24 → 2025-12-19 (-5d) | 2d → 1d |  | 25d → 29d |  |  |
| 2729 | DIP Promoted to Production | 2025-12-25 → 2025-12-22 (-3d) | 2025-12-26 → 2025-12-22 (-4d) | 2d → 1d |  | 25d → 29d |  |  |
| 2731 | Create M16 in Customer Solution | 2025-12-29 → 2025-12-23 (-6d) | 2025-12-30 → 2025-12-24 (-6d) |  |  | 25d → 29d |  |  |
| 2732 | Publish ISD | 2025-12-31 → 2025-12-25 (-6d) | 2026-01-01 → 2025-12-26 (-6d) |  |  | 25d → 29d |  |  |
| 2734 | SIT Non-MVC Service Activation Implementation Complete | 2026-01-01 → 2025-12-26 (-6d) | 2026-01-01 → 2025-12-26 (-6d) |  |  | 25d → 29d |  |  |
| 2735 | **SIT Non-MVC Service Activation Implementation MDD** | 2025-06-05 → 2025-12-29 (+207d) | 2025-06-24 → 2026-01-16 (+206d) | 14d → 15d |  | 652d → 504d |  |  |

| ID | Task | Start | Finish | Duration | Total float | Predecessors | Other |
| --- | --- | --- | --- | --- | --- | --- | --- |
| 2736 | MDD Manual Load | 2025-06-05 → 2025-12-29 (+207d) | 2025-06-13 → 2026-01-06 (+207d) |  | 659d → 504d | none → 2732 |  |
| 2737 | MDD Update | 2025-06-13 → 2026-01-07 (+208d) | 2025-06-24 → 2026-01-16 (+206d) |  | 652d → 504d | none → 2736 |  |
| 2738 | SIT Non-MVC Service Activation Implementation MDD Complete | 2025-06-24 → 2026-01-16 (+206d) | 2025-06-24 → 2026-01-16 (+206d) |  | 652d → 504d | none → 2737 |  |
| 2739 | **Non-SIT MVC Service Activation Hypercare** | 2025-06-02 → 2025-12-19 (+200d) | 2025-06-26 → 2026-01-19 (+207d) | 19d → 22d | 650d → 503d |  |  |
| 2740 | Service& Process Monitoring | 2025-06-02 → 2025-12-19 (+200d) | 2025-06-25 → 2026-01-13 (+202d) |  | 651d → 507d | none → 2728SS |  |
| 2741 | Daily Reporting | 2025-06-02 → 2025-12-19 (+200d) | 2025-06-25 → 2026-01-13 (+202d) |  | 651d → 507d | none → 2728SS |  |
| 2742 | Issue Management | 2025-06-02 → 2025-12-19 (+200d) | 2025-06-25 → 2026-01-13 (+202d) |  | 651d → 507d | none → 2728SS |  |
| 2743 | SA Hypercare Close Down Activities | 2025-06-02 → 2025-12-19 (+200d) | 2025-06-25 → 2026-01-13 (+202d) |  | 651d → 503d | none → 2728SS |  |
| 2744 | Handover to MHHSP | 2025-06-23 → 2026-01-14 (+205d) | 2025-06-26 → 2026-01-19 (+207d) |  | 650d → 503d | none → 2743 |  |
| 2745 | Non-SIT MVC Service Activation Hypercare Complete (M) | 2025-06-25 → 2026-01-19 (+208d) | 2025-06-25 → 2026-01-19 (+208d) |  | 651d → 503d | none → 2744 |  |
| 2750 | Wave 1 Service Activation | 2026-04-13 → 2026-04-16 (+3d) |  | 24d → 21d |  |  |  |
| 2751 | **Wave 1 - Service Activation Implementation** |  | 2025-09-05 → 2026-04-27 (+234d) | 5d → 171d | 599d → 433d |  |  |
| 2752 | MHHSP Enabled Confirmation |  |  |  |  | none → 2726 |  |
| 2753 | PAB Approval | 2025-09-01 → 2026-04-16 (+227d) | 2025-09-02 → 2026-04-17 (+227d) |  | 602d → 439d | none → 2171 |  |
| 2754 | Add EFD to DIP | 2025-09-02 → 2026-04-16 (+226d) | 2025-09-03 → 2026-04-17 (+226d) |  | 601d → 422d | none → 2171 | was named Add EDF to DIP |
| 2755 | DIP Promoted to Production | 2025-09-03 → 2026-04-20 (+229d) | 2025-09-04 → 2026-04-21 (+229d) |  | 600d → 422d | none → 2754 |  |
| 2756 | Create M16 in Customer Solution | 2025-09-04 → 2026-04-22 (+230d) | 2025-09-05 → 2026-04-23 (+230d) |  | 599d → 422d | none → 2755 |  |
| 2757 | Publish ISD | 2025-09-04 → 2026-04-24 (+232d) | 2025-09-05 → 2026-04-27 (+234d) |  | 599d → 422d | none → 2756 |  |
| 2758 | Wave 1 - Service Activation Implementation Complete (M) | 2025-09-05 → 2026-04-27 (+234d) | 2025-09-05 → 2026-04-27 (+234d) |  | 599d → 433d | none → 2757 |  |
| 2759 | **Wave 1 - Service Activation Implementation MDD** | 2025-09-04 → 2026-04-28 (+236d) | 2025-09-17 → 2026-05-12 (+237d) | 10d → 11d | 591d → 422d |  |  |
| 2760 | MDD Manual Load | 2025-09-04 → 2026-04-28 (+236d) | 2025-09-10 → 2026-05-04 (+236d) |  | 596d → 422d | none → 2757 |  |
| 2761 | MDD Update | 2025-09-10 → 2026-05-05 (+237d) | 2025-09-17 → 2026-05-12 (+237d) |  | 591d → 422d | none → 2760 |  |
| 2762 | Wave 1 - Service Activation Implementation MDD Complete (M) | 2025-09-17 → 2026-05-12 (+237d) | 2025-09-17 → 2026-05-12 (+237d) |  | 591d → 422d | none → 2761 |  |
| 2763 | **Wave 1 - Service Activation Hypercare** | 2022-10-31 → 2025-09-01 (+1036d) | 2025-09-18 → 2026-05-05 (+229d) | 754d → 177d | 590d → 427d |  |  |
| 2764 | Service& Process Monitoring | 2025-09-01 → 2026-04-16 (+227d) | 2025-09-18 → 2026-05-05 (+229d) |  | 590d → 427d | none → 2754SS |  |
| 2765 | Daily Reporting | 2025-09-01 → 2026-04-16 (+227d) | 2025-09-18 → 2026-05-05 (+229d) |  | 590d → 427d | none → 2754SS |  |
| 2766 | Issue Management | 2025-09-01 → 2026-04-16 (+227d) | 2025-09-18 → 2026-05-05 (+229d) |  | 590d → 427d | none → 2754SS |  |
| 2768 | Handover to MHHSP | 2025-09-15 → 2025-09-19 (+4d) | 2025-09-18 → 2025-09-24 (+6d) |  | 590d → 586d | none → 2767 |  |
| 2769 | Non-SIT LDSO Service Activation Hypercare Complete (M) | 2022-10-31 → 2025-09-24 (+1059d) | 2022-10-31 → 2025-09-24 (+1059d) |  | 1344d → 586d | none → 2768 |  |
| 2770 | **Wave 2** |  | 2026-06-30 → 2026-07-01 (+1d) | 957d → 958d | 387d → 386d |  |  |
| 2771 | **SIT Non-MVC Service Activation Preparation Tasks** |  | 2026-06-30 → 2026-07-01 (+1d) | 957d → 958d | 387d → 386d |  |  |
| 2774 | Wave 2 Service Activation | 2026-05-28 → 2026-05-29 (+1d) | 2026-06-30 → 2026-07-01 (+1d) |  |  |  |  |
| 2775 | **Wave 2 - Service Activation Implementation** |  | 2025-11-07 → 2026-06-09 (+214d) | 5d → 157d | 554d → 402d |  |  |
| 2777 | PAB Approval | 2025-11-03 → 2026-05-29 (+207d) | 2025-11-04 → 2026-06-01 (+209d) |  | 557d → 408d | none → 2201 |  |
| 2778 | Add EFD to DIP | 2025-11-04 → 2026-05-29 (+206d) | 2025-11-05 → 2026-06-01 (+208d) |  | 556d → 402d | none → 2201 | was named Add EDF to DIP |
| 2779 | DIP Promoted to Production | 2025-11-05 → 2026-06-02 (+209d) | 2025-11-06 → 2026-06-03 (+209d) |  | 555d → 402d | none → 2778 |  |
| 2780 | Create M16 in Customer Solution | 2025-11-06 → 2026-06-04 (+210d) | 2025-11-07 → 2026-06-05 (+210d) |  | 554d → 402d | none → 2779 |  |
| 2781 | Publish ISD | 2025-11-06 → 2026-06-08 (+214d) | 2025-11-07 → 2026-06-09 (+214d) |  | 554d → 402d | none → 2780 |  |
| 2782 | Wave 2 - Service Activation Implementation Complete (M) | 2025-11-07 → 2026-06-09 (+214d) | 2025-11-07 → 2026-06-09 (+214d) |  | 554d → 402d | none → 2781 |  |
| 2794 | **Wave 3** |  | 2026-08-26 → 2026-08-13 (-13d) | 998d → 989d | 346d → 355d |  |  |
| 2795 | **SIT Non-MVC Service Activation Preparation Tasks** |  | 2026-08-26 → 2026-08-13 (-13d) | 998d → 989d | 346d → 355d |  |  |
| 2798 | Wave 3 Service Activation | 2026-07-24 → 2026-07-31 (+7d) | 2026-08-26 → 2026-08-13 (-13d) | 24d → 10d | 0d → 9d |  |  |
| 2799 | **Wave 3 - Service Activation Implementation** |  | 2025-12-30 → 2026-08-13 (+226d) | 7d → 169d | 517d → 355d |  |  |
| 2801 | PAB Approval | 2025-12-22 → 2026-07-31 (+221d) | 2025-12-23 → 2026-08-03 (+223d) |  | 522d → 355d | none → 2231 |  |
| 2802 | Add EFD to DIP | 2025-12-23 → 2026-08-04 (+224d) | 2025-12-24 → 2026-08-05 (+224d) |  | 521d → 355d | none → 2231, 2801 | was named Add EDF to DIP |
| 2803 | DIP Promoted to Production | 2025-12-29 → 2026-08-06 (+220d) | 2025-12-30 → 2026-08-07 (+220d) |  | 517d → 355d | none → 2802 |  |
| 2804 | Create M16 in Customer Solution | 2025-12-29 → 2026-08-10 (+224d) | 2025-12-30 → 2026-08-11 (+224d) |  | 517d → 355d | none → 2803 |  |
| 2805 | Publish ISD | 2025-12-29 → 2026-08-12 (+226d) | 2025-12-30 → 2026-08-13 (+226d) |  | 517d → 355d | none → 2804 |  |
| 2806 | Wave 3 - Service Activation Implementation Complete (M) | 2025-12-30 → 2026-08-13 (+226d) | 2025-12-30 → 2026-08-13 (+226d) |  | 517d → 355d | none → 2805 |  |
| 2818 | **Wave 4** |  | 2026-10-22 → 2026-10-28 (+6d) | 1039d → 1043d | 305d → 301d |  |  |
| 2819 | **SIT Non-MVC Service Activation Preparation Tasks** |  | 2026-10-22 → 2026-10-28 (+6d) | 1039d → 1043d | 305d → 301d |  |  |
| 2822 | Wave 4 Service Activation | 2026-09-21 → 2026-09-25 (+4d) | 2026-10-22 → 2026-10-28 (+6d) |  |  |  |  |
| 2823 | **Wave 4 - Service Activation Implementation** | 2025-03-03 → 2026-03-02 (+364d) | 2026-03-06 → 2026-10-07 (+215d) | 265d → 158d | 469d → 316d |  |  |
| 2825 | PAB Approval | 2025-03-03 → 2026-09-25 (+571d) | 2025-03-03 → 2026-09-25 (+571d) |  | 733d → 316d | none → 2261 |  |
| 2826 | Add EFD to DIP | 2026-03-03 → 2026-09-28 (+209d) | 2026-03-04 → 2026-09-29 (+209d) |  | 471d → 316d | none → 2825 | was named Add EDF to DIP |
| 2827 | DIP Promoted to Production | 2026-03-04 → 2026-09-30 (+210d) | 2026-03-05 → 2026-10-01 (+210d) |  | 470d → 316d | none → 2826 |  |
| 2828 | Create M16 in Customer Solution | 2026-03-05 → 2026-10-02 (+211d) | 2026-03-06 → 2026-10-05 (+213d) |  | 469d → 316d | none → 2827 |  |
| 2829 | Publish ISD | 2026-03-05 → 2026-10-06 (+215d) | 2026-03-06 → 2026-10-07 (+215d) |  | 469d → 316d | none → 2828 |  |
| 2830 | Wave 4 - Service Activation Implementation Complete (M) | 2026-03-06 → 2026-10-07 (+215d) | 2026-03-06 → 2026-10-07 (+215d) |  | 469d → 316d | none → 2829 |  |
| 2842 | **Non-SIT LDSO** |  | 2025-09-01 → 2025-09-18 (+17d) | 741d → 754d | 603d → 590d |  |  |
| 2853 | **SIT Non-MVC Service Activation Preparation Tasks** |  | 2025-09-01 → 2025-09-18 (+17d) | 741d → 754d | 603d → 590d |  |  |
| 2856 | Non-SIT LDSO Service Activation | 2025-08-25 → 2025-09-11 (+17d) | 2025-09-01 → 2025-09-18 (+17d) |  | 22d → 9d | BSC PAB & REC Manager approval of Qualification for Non-SIT LDSOs (Start of Migration for Qualification Participants), 2855 → 2855, 1960 |  |
| 2860 | Add EFD to DIP |  |  |  |  |  | was named Add EDF to DIP |
| 2877 | **Implement Early Life Support Plan** | 2025-01-06 → 2025-07-07 (+182d) | 2025-03-07 → 2025-09-19 (+196d) | 45d → 55d | 729d → 589d |  | baseline start 2025-01-06 → 2025-07-07; baseline finish 2025-03-07 → 2025-09-19 |
| 2878 | Implement Early Life Support Plan | 2025-01-06 → 2025-07-07 (+182d) | 2025-03-07 → 2025-09-19 (+196d) | 45d → 55d | 729d → 589d | 2684 → none | constraint start no earlier than 2025-01-06 → start no earlier than 2025-07-07; baseline start 2025-01-06 → 2025-07-07; baseline finish 2025-03-07 → 2025-09-19 |
| 2893 | **Transition to New Settlement Timetable (M16)** |  | 2027-12-23 → 2027-12-17 (-6d) | 566d → 562d | 0d → 4d |  |  |
| 2904 | **M16 Approval Window** |  | 2027-12-23 → 2027-12-17 (-6d) | 129d → 125d | 0d → 4d |  |  |
| 2906 | Cut over to new settlement timetable (M16) | 2027-07-02 → 2027-06-28 (-4d) | 2027-07-02 → 2027-06-28 (-4d) |  | 0d → 4d |  |  |
| 2907 | Maximum 6-month window for approval of M16 | 2027-07-05 → 2027-06-29 (-6d) | 2027-12-23 → 2027-12-17 (-6d) |  | 0d → 4d |  |  |
| 2908 | Cut over to new settlement timetable (M16*) - Late Exit | 2027-12-23 → 2027-12-17 (-6d) | 2027-12-23 → 2027-12-17 (-6d) |  | 0d → 4d |  |  |

| ID | Task | Start | Finish | Duration | Total float |
| --- | --- | --- | --- | --- | --- |
| 2909 | **EARLY LIVE RUNNING** | 2027-05-10 → 2027-05-04 (-6d) | 2027-07-09 → 2027-07-05 (-4d) |  | 119d → 123d |
| 2910 | **Early Live Running Stabilisation Period** | 2027-05-10 → 2027-05-04 (-6d) | 2027-07-09 → 2027-07-05 (-4d) |  | 119d → 123d |
| 2911 | Manage Early Live Running stabilisation period | 2027-05-10 → 2027-05-04 (-6d) | 2027-07-09 → 2027-07-05 (-4d) |  | 119d → 123d |
| 2912 | Monitor Early Live Running stabilisation period | 2027-05-10 → 2027-05-04 (-6d) | 2027-07-09 → 2027-07-05 (-4d) |  | 119d → 123d |
| 2913 | **PROGRAMME CLOSURE** | 2027-03-08 → 2027-03-02 (-6d) | 2027-06-25 → 2027-06-21 (-4d) |  | 129d → 133d |
| 2914 | **Handover Pack** | 2027-03-08 → 2027-03-02 (-6d) | 2027-06-25 → 2027-06-21 (-4d) |  | 129d → 133d |
| 2915 | **Draft Handover Pack (for M15)** | 2027-03-08 → 2027-03-02 (-6d) | 2027-04-30 → 2027-04-26 (-4d) |  | 169d → 173d |
| 2916 | Develop document | 2027-03-08 → 2027-03-02 (-6d) | 2027-04-02 → 2027-03-29 (-4d) |  | 169d → 173d |
| 2917 | Document review and update | 2027-04-05 → 2027-03-30 (-6d) | 2027-04-30 → 2027-04-26 (-4d) |  | 169d → 173d |
| 2918 | Draft Handover Pack approved | 2027-04-30 → 2027-04-26 (-4d) | 2027-04-30 → 2027-04-26 (-4d) |  | 169d → 173d |
| 2919 | **Master Handover Pack (for M16)** | 2027-05-03 → 2027-04-27 (-6d) | 2027-06-25 → 2027-06-21 (-4d) |  | 129d → 133d |
| 2920 | Update document | 2027-05-03 → 2027-04-27 (-6d) | 2027-05-28 → 2027-05-24 (-4d) |  | 129d → 133d |
| 2921 | Document review and update | 2027-05-31 → 2027-05-25 (-6d) | 2027-06-25 → 2027-06-21 (-4d) |  | 129d → 133d |
| 2922 | Master Handover Pack approved | 2027-06-25 → 2027-06-21 (-4d) | 2027-06-25 → 2027-06-21 (-4d) |  | 129d → 133d |
| 2923 | **Programme Lessons Learned** | 2027-03-08 → 2027-03-02 (-6d) | 2027-04-30 → 2027-04-26 (-4d) |  | 169d → 173d |
| 2924 | Develop document | 2027-03-08 → 2027-03-02 (-6d) | 2027-04-02 → 2027-03-29 (-4d) |  | 169d → 173d |
| 2925 | Document review and update | 2027-04-05 → 2027-03-30 (-6d) | 2027-04-30 → 2027-04-26 (-4d) |  | 169d → 173d |
| 2926 | Programme Lessons Learned document approved | 2027-04-30 → 2027-04-26 (-4d) | 2027-04-30 → 2027-04-26 (-4d) |  | 169d → 173d |
| 2927 | **Programme Closure Report** | 2027-03-08 → 2027-03-02 (-6d) | 2027-04-30 → 2027-04-26 (-4d) |  | 169d → 173d |
| 2928 | Develop document | 2027-03-08 → 2027-03-02 (-6d) | 2027-04-02 → 2027-03-29 (-4d) |  | 169d → 173d |
| 2929 | Document review and update | 2027-04-05 → 2027-03-30 (-6d) | 2027-04-30 → 2027-04-26 (-4d) |  | 169d → 173d |
| 2930 | Programme Closure Report approved | 2027-04-30 → 2027-04-26 (-4d) | 2027-04-30 → 2027-04-26 (-4d) |  | 169d → 173d |
| 2931 | **Benefit Realisation Report** | 2027-03-08 → 2027-03-02 (-6d) | 2027-05-07 → 2027-05-03 (-4d) |  | 164d → 168d |
| 2932 | Develop document | 2027-03-08 → 2027-03-02 (-6d) | 2027-04-02 → 2027-03-29 (-4d) |  | 164d → 168d |
| 2933 | Document review and update | 2027-04-05 → 2027-03-30 (-6d) | 2027-04-30 → 2027-04-26 (-4d) |  | 164d → 168d |
| 2934 | Benefit Realisation Report approved | 2027-05-07 → 2027-05-03 (-4d) | 2027-05-07 → 2027-05-03 (-4d) |  | 164d → 168d |
| 2935 | **Operating Model Gap Review with recommendations** | 2027-03-08 → 2027-03-02 (-6d) | 2027-05-07 → 2027-05-03 (-4d) |  | 164d → 168d |
| 2936 | Develop document | 2027-03-08 → 2027-03-02 (-6d) | 2027-04-02 → 2027-03-29 (-4d) |  | 164d → 168d |
| 2937 | Document review and update | 2027-04-05 → 2027-03-30 (-6d) | 2027-04-30 → 2027-04-26 (-4d) |  | 164d → 168d |
| 2938 | Operating Model Gap Review with recommendations approved | 2027-05-07 → 2027-05-03 (-4d) | 2027-05-07 → 2027-05-03 (-4d) |  | 164d → 168d |
| 2939 | **Post-Implementation Review** | 2027-03-08 → 2027-03-02 (-6d) | 2027-05-07 → 2027-05-03 (-4d) |  | 164d → 168d |
| 2940 | Develop document | 2027-03-08 → 2027-03-02 (-6d) | 2027-04-02 → 2027-03-29 (-4d) |  | 164d → 168d |
| 2941 | Document review and update | 2027-04-05 → 2027-03-30 (-6d) | 2027-04-30 → 2027-04-26 (-4d) |  | 164d → 168d |
| 2942 | Post-Implementation Review approved | 2027-05-07 → 2027-05-03 (-4d) | 2027-05-07 → 2027-05-03 (-4d) |  | 164d → 168d |
| 2943 | **Reinforcement Guide** | 2027-03-08 → 2027-03-02 (-6d) | 2027-05-07 → 2027-05-03 (-4d) |  | 164d → 168d |
| 2944 | Develop document | 2027-03-08 → 2027-03-02 (-6d) | 2027-04-02 → 2027-03-29 (-4d) |  | 164d → 168d |
| 2945 | Document review and update | 2027-04-05 → 2027-03-30 (-6d) | 2027-04-30 → 2027-04-26 (-4d) |  | 164d → 168d |
| 2946 | Reinforcement Guide approved | 2027-05-07 → 2027-05-03 (-4d) | 2027-05-07 → 2027-05-03 (-4d) |  | 164d → 168d |
| 2947 | **Material and Licenses Transfer** | 2027-04-05 → 2027-03-30 (-6d) | 2027-06-25 → 2027-06-21 (-4d) |  | 129d → 133d |
| 2948 | Transfer of Programme material to Elexon and perpetual licenses as appropriate | 2027-04-05 → 2027-03-30 (-6d) | 2027-06-25 → 2027-06-21 (-4d) |  | 129d → 133d |
| 2949 | **READINESS ASSESSMENTS** |  | 2027-06-17 → 2027-06-11 (-6d) | 988d → 984d | 135d → 139d |
| 2978 | **Readiness Assessment 9 - Ready for New Settlement Timetable and CP5 Check** | 2027-04-12 → 2027-04-06 (-6d) | 2027-06-17 → 2027-06-11 (-6d) |  | 135d → 139d |
| 2979 | Launch Readiness Assessment survey | 2027-04-12 → 2027-04-06 (-6d) | 2027-04-12 → 2027-04-06 (-6d) |  | 135d → 139d |
| 2980 | PPs submit survey responses | 2027-04-12 → 2027-04-06 (-6d) | 2027-04-30 → 2027-04-26 (-4d) |  | 135d → 139d |
| 2981 | Analyse survey responses | 2027-05-03 → 2027-04-27 (-6d) | 2027-05-21 → 2027-05-17 (-4d) |  | 135d → 139d |
| 2982 | Conduct deep-dive interviews (sample of PPs) | 2027-05-03 → 2027-04-27 (-6d) | 2027-05-21 → 2027-05-17 (-4d) |  | 135d → 139d |
| 2983 | Produce Readiness Assessment Reports (Overall Report & Individual Participant Reports) | 2027-05-24 → 2027-05-18 (-6d) | 2027-06-11 → 2027-06-07 (-4d) |  | 135d → 139d |
| 2984 | Readiness Assessment 9 - Readiness for New Settlement Timetable - Completed (incl. Readiness Assessment Report approval) | 2027-06-17 → 2027-06-11 (-6d) | 2027-06-17 → 2027-06-11 (-6d) |  | 135d → 139d |
| 2985 | **Readiness Assessments - Tier 1 Milestones** |  | 2027-06-17 → 2027-06-11 (-6d) | 517d → 513d | 135d → 139d |
| 2989 | Readiness Assessment 9 - Readiness for New Settlement Timetable - Completed (incl. Readiness Assessment Report approval) | 2027-06-17 → 2027-06-11 (-6d) | 2027-06-17 → 2027-06-11 (-6d) |  | 135d → 139d |
| 2990 | **CONTROL POINTS** |  | 2027-06-23 → 2027-06-17 (-6d) | 1204d → 1200d | 132d → 136d |
| 3000 | **Control Point 5 - Cut Over to New Settlement Timetable** | 2027-05-26 → 2027-05-20 (-6d) | 2027-06-23 → 2027-06-17 (-6d) |  | 132d → 136d |
| 3001 | Control Point 5 Preparation (incl. Control Point Report development and review) | 2027-05-26 → 2027-05-20 (-6d) | 2027-06-15 → 2027-06-09 (-6d) |  | 137d → 141d |
| 3002 | Control Point 5 - Cut Over to New Settlement Timetable (incl. Control Point Report approval) | 2027-06-23 → 2027-06-17 (-6d) | 2027-06-23 → 2027-06-17 (-6d) |  | 132d → 136d |
| 3003 | **Control Points - Tier 1 Milestones** |  | 2027-06-23 → 2027-06-17 (-6d) | 1184d → 1180d | 132d → 136d |
| 3007 | Control Point 5 - Cut Over to New Settlement Timetable (incl. Control Point Report approval) | 2027-06-23 → 2027-06-17 (-6d) | 2027-06-23 → 2027-06-17 (-6d) |  | 132d → 136d |
| 3008 | **MILESTONE RANGE CHECKPOINTS** |  | 2027-04-12 → 2027-04-06 (-6d) | 1160d? → 1156d? | 184d → 188d |
| 3013 | **M15 milestone checkpoint** | 2027-02-15 → 2027-02-09 (-6d) | 2027-02-15 → 2027-02-09 (-6d) |  | 224d → 228d |
| 3014 | M15 milestone checkpoint - date approval | 2027-02-15 → 2027-02-09 (-6d) | 2027-02-15 → 2027-02-09 (-6d) |  | 224d → 228d |
| 3015 | **M16 milestone checkpoint** |  | 2027-04-12 → 2027-04-06 (-6d) | 1160d? → 1156d? | 184d → 188d |
| 3016 | M16 milestone checkpoint - date approval | 2027-04-12 → 2027-04-06 (-6d) | 2027-04-12 → 2027-04-06 (-6d) |  | 184d → 188d |

## Version 4 (data date 2025-03-11, saved 2025-03-12, file MHHS-DEL1139 - MHHS Plan v6.20.mpp)

Last finish stays 2027-12-23. Complete tasks 1419 → 1635.

Added:

| ID | Task | Duration | Start | Finish | Predecessors | Constraint |
| --- | --- | --- | --- | --- | --- | --- |
| 158 | **Interim Release 8.8** | 26d? | 2025-02-05 A | 2025-03-12 A |  |  |
| 159 | Update baselined artefacts | 4d | 2025-02-05 A | 2025-02-10 A |  | start no earlier than 2025-02-05 |
| 160 | Interim Release 8.8 Published | 1d? | 2025-02-12 A | 2025-02-12 A | 159FS+1d |  |
| 161 | Interim Release 8.8 Deployed to SIT by Participants | 20d | 2025-02-13 A | 2025-03-12 A | 160 |  |
| 219 | Inform Orbus of iServer support termination | 1d? | 2025-07-03 A | 2025-07-03 A | 218 |  |
| 220 | Produce iServer decomissioning pack | 4d | 2025-07-04 A | 2025-07-09 A | 219 |  |
| 221 | Publish iServer decommising pack on the Clock | 1d? | 2025-07-31 | 2025-07-31 | 220FS+15d |  |
| 423 | **SIT Programme Participants PIT (SIT Operational Theme 3 (Batch 1))** | 76d | 2024-09-27 A | 2025-01-10 |  |  |
| 424 | **Test Approach & Plan** | 40d | 2024-09-27 A | 2024-11-21 A |  |  |
| 425 | SIT Operational PIT Test Approach& Plan (PIT) submitted to Programme for assurance | 0d | 2024-09-27 A | 2024-09-27 A |  | start no earlier than 2024-09-27 |
| 426 | SIT Operational Test approach and plan MHHS Review Completed | 0d | 2024-11-21 A | 2024-11-21 A | 425FS+40d |  |
| 427 | **Test Readiness Report** | 13d | 2024-10-04 | 2024-10-22 |  |  |
| 428 | Test readiness reporting | 13d | 2024-10-04 | 2024-10-22 | 425FS+5d |  |
| 429 | **Requirements to test Traceability Matrix (RTTM)** | 20d | 2024-11-01 A | 2024-11-29 A |  |  |
| 430 | SIT Operational PIT RTTM submitted to Programme for assurance | 0d | 2024-11-01 A | 2024-11-01 A | 425FS+26d |  |
| 431 | SIT Operational RTTM MHHS Review Completed | 0d | 2024-11-29 A | 2024-11-29 A | 430FS+20d |  |
| 432 | **Test Scenarios** | 20d | 2024-11-01 A | 2024-11-29 A |  |  |
| 433 | SIT Operational PIT test scenarios submitted to Programme for assurance | 0d | 2024-11-01 A | 2024-11-01 A | 425FS+26d |  |
| 434 | SIT Operational Test scenarios MHHS Review Completed | 0d | 2024-11-29 A | 2024-11-29 A | 433FS+20d |  |
| 435 | **PIT execution** | 58d | 2024-10-23 A | 2025-01-10 |  |  |
| 436 | PIT Test Execution Progress Report | 40d | 2024-10-23 | 2024-12-17 | 428 |  |
| 437 | PIT Execution | 39d | 2024-11-04 | 2024-12-26 | 433 |  |
| 438 | SIT Operational Theme 3 (Batch 1) PIT Completion Report submitted to Programme for assurance | 0d | 2025-01-10 A | 2025-01-10 A | 419, 420FS+30d |  |
| 439 | SIT Operational Theme 3 (Batch 1) PIT Completion Report MHHS Review Completed | 0d | 2025-01-10 A | 2025-01-10 A | 443, 448, 451, 455, 438 |  |
| 1153 | NFTWG paper day | 0d | 2025-02-11 A | 2025-02-11 A | 1152FS+4d |  |
| 1154 | NFTWG update on execution model | 0d | 2025-02-18 A | 2025-02-18 A | 1153FS+5d |  |
| 1160 | NFTWG paper day | 0d | 2025-03-11 A | 2025-03-11 A | 1159FS+24d |  |
| 1161 | NFTWG update on execution model | 0d | 2025-03-18 | 2025-03-18 | 1160FS+5d |  |
| 1172 | FTIG Recommendation | 0d | 2025-02-21 A | 2025-02-21 A | 1170FS+3d |  |
| 1181 | GLIG Recommendation | 0d | 2025-03-21 | 2025-03-21 | 1179FS+3d |  |
| 1309 | **Theme 3 Test Cases Approved** | 246d? | 2024-04-10 A | 2025-03-19 |  |  |
| 1336 | **Theme 3 (Batch 2) Supplementary** | 33d | 2025-02-03 A | 2025-03-19 |  |  |
| 1337 | Conclude DIP Onboarding / Offboarding Scope with DIP Manager | 5d | 2025-02-03 A | 2025-02-07 A |  | start no earlier than 2025-02-03 |
| 1338 | Develop DIP Onboarding / Offboarding Test Scenarios & Test Cases (Batch 2) Supplementary | 2d | 2025-02-10 A | 2025-02-11 A | 1337 |  |
| 1339 | SRO Review | 5d | 2025-02-12 A | 2025-02-18 A | 1338 |  |
| 1340 | Industry Consultation (Batch 2) Supplementary | 10d | 2025-02-19 A | 2025-03-04 A | 1339 |  |
| 1341 | SITWG Paper Day | 0d | 2025-02-27 A | 2025-02-27 A | 1340SS+7d, 1339FS+7d |  |
| 1342 | Review Feedback and Update | 1d | 2025-03-05 A | 2025-03-05 A | 1340 |  |
| 1343 | SITWG endorse Theme 3 (Batch 2) Supplementary | 0d | 2025-03-06 A | 2025-03-06 A | 1340, 1341, 1342FS+1d |  |
| 1344 | SITAG paper day | 0d | 2025-03-12 | 2025-03-12 | 1343FS+4d |  |
| 1345 | SITAG approve Theme 3 (Batch 2) Supplementary | 0d | 2025-03-19 | 2025-03-19 | 1344FS+5d |  |
| 1355 | **SIT Operational Programme RTTM (Theme 1, 2 & 3 (Batch 2))** | 626d | 2022-10-31 A | 2025-03-24 |  |  |
| 1356 | Develop SIT Operational (Theme 1, 2 & 3 (Batch 2)) RTTM | 36d | 2025-01-06 A | 2025-02-24 A |  | start no earlier than 2025-01-06 |
| 1357 | SRO review of SIT Operational (Theme 1, 2 & 3 (Batch 2)) RTTM | 9d | 2025-02-25 A | 2025-03-07 A | 1356 |  |
| 1358 | DIP Manager / Code Bodies / Full SRO to review | 10d | 2025-03-10 A | 2025-03-21 | 1357 |  |
| 1359 | Incorporate feedback | 10d | 2025-03-10 A | 2025-03-21 | 1358FF |  |
| 1360 | Reissued to DIP Manager / Code Bodies / SRO for review | 5d | 2022-10-31 | 2022-11-04 |  |  |
| 1361 | DIP Manager / Code Bodies / SRO acceptance of (Theme 1, 2 & 3 (Batch 2)) Operational RTTM | 0d | 2025-03-24 | 2025-03-24 | 1358FS+1d |  |
| 1362 | SIT Operational (Theme 1, 2 & 3 (Batch 2)) RTTM Complete | 0d | 2025-03-24 | 2025-03-24 | 1361 |  |
| 1369 | **SIT Operational Theme 1, 2 & 3 (Batch 2) DITL** | 23d | 2025-02-24 A | 2025-03-26 |  |  |
| 1370 | DITL + Familiarisation session development | 15d | 2025-02-24 A | 2025-03-14 |  | start no earlier than 2025-02-24 |
| 1371 | SRO Review | 5d | 2025-03-17 | 2025-03-21 | 1370 |  |
| 1372 | Post-SRO Review Changes | 3d | 2025-03-24 | 2025-03-26 | 1371 |  |
| 1373 | Familiarisation session Service Management test case schedule + mapping | 0d | 2025-03-26 | 2025-03-26 | 1372 |  |
| 1374 | Publish Cycle 3 DITL / Cycle 3 DITL Online Sessions for SIT PPs | 0d | 2025-03-26 | 2025-03-26 | 1373 |  |
| 1375 | **SIT Operational Defect Management** | 15d? | 2025-01-06 A | 2025-01-24 A |  |  |
| 1376 | Develop defect management approach | 10d? | 2025-01-06 A | 2025-01-17 A |  | start no earlier than 2025-01-06 |
| 1377 | Defect management approach agreed | 5d? | 2025-01-20 A | 2025-01-24 A | 1376 |  |
| 1391 | Execution Model shared with industry | 0d | 2025-03-17 | 2025-03-17 | 1390 |  |
| 1404 | FTIG recommendation | 0d | 2025-01-24 A | 2025-01-24 A | 1402FS+2d |  |
| 1405 | Republish Operational Theme 3 (Batch 1) Overarching Test Readiness Report with latest data and evidence | 1d? | 2025-01-27 A | 2025-01-27 A | 1403FS+2d |  |
| 1413 | GLIG recommendation | 0d | 2025-03-21 | 2025-03-21 | 1411FS+11d |  |
| 1422 | Non-Functional Themes 2 & 3 (LDSO's) Data Load | 15d | 2025-03-03 A | 2025-03-21 | 1146 |  |
| 1423 | Operational Themes 1, 2 & 3 (Batch 2) (LDSO's) Data Load | 20d? | 2025-03-03 A | 2025-03-28 | 1146 | start no earlier than 2025-01-06 |
| 1440 | Build Regression Core Pack | 17d | 2025-02-12 A | 2025-03-06 A | 1433, 1443FF | start no earlier than 2025-02-12 |
| 1448 | Regression Test Framework Core Pack - PP Walkthrough | 1d? | 2025-03-20 | 2025-03-20 | 1447SS | start no earlier than 2025-03-20 |
| 1449 | Regression Test Framework Core Pack - Q&A Drop in session | 1d? | 2025-03-27 | 2025-03-27 | 1447SS | start no earlier than 2025-03-27 |
| 1451 | Second industry review of Regression Core Pack | 5d | 2025-04-03 | 2025-04-09 | 1450 |  |
| 1453 | eSITWG paper day | 0d | 2025-04-10 | 2025-04-10 | 1452 |  |
| 1454 | eSITWG endorses regression Core Pack | 0d | 2025-04-15 | 2025-04-15 | 1453FS+3d |  |
| 1455 | Incorporate SITWG feedback into regression Core Pack | 2d | 2025-04-16 | 2025-04-17 | 1454 |  |
| 1456 | Regression Test Approach and Plan Uplift | 1d? | 2025-04-16 | 2025-04-16 | 1454 |  |
| 1457 | Industry Review on the Uplifted Test Approach and Plan | 4d | 2025-04-17 | 2025-04-22 | 1456 |  |
| 1559 | **SIT Scope Traceability** | 64d | 2025-01-27 A | 2025-04-24 |  |  |
| 1560 | Draft Scope Tracability document | 10d | 2025-01-27 A | 2025-02-07 A |  | start no earlier than 2025-01-27 |
| 1561 | LDP review | 2d | 2025-02-10 A | 2025-02-11 A | 1560 |  |
| 1562 | SRO review | 5d | 2025-02-12 A | 2025-02-18 A | 1561 |  |
| 1563 | Updates to reflect SRO feedback | 5d | 2025-02-12 A | 2025-02-18 A | 1562FF |  |
| 1564 | Industry Review | 10d | 2025-02-19 A | 2025-03-04 A | 1563 |  |
| 1566 | SITWG recommends Scope Tracability document | 0d | 2025-04-15 | 2025-04-15 | 1565FS+5d |  |
| 1567 | Update document to reflect industry consultation views | 8d | 2025-03-05 | 2025-03-14 | 1564 |  |
| 1568 | SITAG paper day | 0d | 2025-04-17 | 2025-04-17 | 1566FS+2d, 1567 |  |
| 1569 | SITAG approve SIT Scope Traceability document | 0d | 2025-04-24 | 2025-04-24 | 1568FS+5d |  |
| 1570 | SIT Scope Traceability Approved | 0d | 2025-04-24 | 2025-04-24 | 1569 |  |
| 1591 | SIT-A Settlement Testing Start | 0d | 2025-05-19 | 2025-05-19 | 1464FS+1d |  |
| 1592 | SIT-A Settlement Testing | 20d | 2025-05-20 | 2025-06-16 | 1591 |  |
| 1593 | SIT-A Settlement Decision Point Exit Criteria | 0d | 2025-06-13 | 2025-06-13 | 1592FS-2d |  |
| 1594 | SIT-A Settlement Testing Completed | 0d | 2025-06-13 | 2025-06-13 | 1593 |  |
| 1597 | Regression Execution | 5d | 2025-06-16 | 2025-06-20 | 1596FS-1d |  |
| 1601 | Regression Contingency Week | 5d | 2025-08-04 | 2025-08-08 | 1600 |  |
| 1609 | **Test design** | 125d | 2024-09-02 A | 2025-02-21 A |  |  |
| 1610 | SAT tests (Review and finalise) | 95d | 2024-09-02 A | 2025-01-10 A |  | start no earlier than 2024-09-02 |
| 1611 | Test Automation and Supporting Tools | 80d | 2024-11-04 A | 2025-02-21 A |  | start no earlier than 2024-11-04 |
| 1612 | SAT tests batch 3 | 50d | 2024-12-16 A | 2025-02-21 A |  | start no earlier than 2024-12-16 |
| 1613 | **Data and environment** | 120d? | 2024-08-19 A | 2025-01-31 A |  |  |
| 1614 | Data and environment requirements | 55d | 2024-08-19 A | 2024-11-01 A |  | start no earlier than 2024-08-19 |
| 1615 | Data sourcing | 95d | 2024-09-02 A | 2025-01-10 A |  | start no earlier than 2024-09-02 |
| 1616 | Environment data check | 15d? | 2025-01-13 A | 2025-01-31 A | 1615 |  |
| 1617 | **Execution** | 169d | 2024-11-11 A | 2025-07-03 |  |  |
| 1618 | Trial test runs | 50d | 2024-11-11 A | 2025-01-17 A |  | start no earlier than 2024-11-11 |
| 1619 | Test planning prioritisation | 14d | 2025-01-20 A | 2025-02-06 A | 1618 |  |
| 1620 | Programme agreement to start SAT testing | 0d | 2025-02-06 A | 2025-02-06 A | 1619 |  |
| 1621 | SAT Testing Start | 0d | 2025-02-06 A | 2025-02-06 A | 1620 |  |
| 1622 | SAT first run | 39d | 2025-02-07 A | 2025-04-02 | 1621 |  |
| 1623 | First run complete | 0d | 2025-04-02 | 2025-04-02 | 1622 |  |
| 1624 | SAT test second run | 30d | 2025-04-03 | 2025-05-14 | 1623 |  |
| 1625 | Second run complete | 0d | 2025-05-14 | 2025-05-14 | 1624 |  |
| 1626 | **Contingency test time** | 48d | 2025-04-07 | 2025-06-11 |  |  |
| 1627 | Demand Disconnection Event (DDE) | 20d | 2025-05-15 | 2025-06-11 | 1625 |  |
| 1628 | Trading Disputes | 20d | 2025-05-15 | 2025-06-11 | 1625 |  |
| 1629 | **NESO** | 48d | 2025-04-07 | 2025-06-11 |  |  |
| 1630 | P210 Test files to NESO | 0d | 2025-04-07 | 2025-04-07 |  | start no earlier than 2025-04-07 |
| 1631 | NESO | 20d | 2025-05-15 | 2025-06-11 | 1625 |  |
| 1632 | Estimated all SAT tests completed | 0d | 2025-06-11 | 2025-06-11 | 1627, 1628, 1631 |  |
| 1633 | Test Completion Report Drafting | 11d | 2025-06-12 | 2025-06-26 | 1632 |  |
| 1634 | Test Completion Report/Recommendation | 0d | 2025-06-26 | 2025-06-26 | 1633 |  |
| 1635 | SAT is signed off by the SAA Value Stream Lead / Head of Product (SAT complete) | 0d | 2025-07-03 | 2025-07-03 | 1634FS+5d |  |
| 1636 | **MHHS Programme Assurance of Helix E2E SAT** | 219d | 2024-09-02 | 2025-07-03 |  |  |
| 1637 | MHHS Programme Assurance Start | 0d | 2024-09-02 | 2024-09-02 | 1610SS |  |
| 1638 | Ongoing MHHS Programme Assurance | 219d | 2024-09-02 | 2025-07-03 | 1637 |  |
| 1639 | MHHS Programme Assurance End | 0d | 2025-07-03 | 2025-07-03 | 1638, 1635 |  |
| 1668 | Regression Test Execution Start | 0d | 2025-06-16 | 2025-06-16 | 1594FS+2d |  |
| 1669 | Regression Execution | 5d | 2025-06-16 | 2025-06-20 | 1668FS-1d |  |
| 1673 | Regression Contingency Week | 5d | 2025-08-04 | 2025-08-08 | 1672 |  |
| 1750 | Discussion at QWG to reconfirm value provided from E2E Sandbox (UIT) | 0d | 2025-03-11 | 2025-03-11 |  | finish no earlier than 2025-03-11 |
| 1751 | Create PPIR to request PP responses on subject to gather views | 5d | 2025-03-10 | 2025-03-14 |  | finish no earlier than 2025-03-14 |
| 1752 | PPIR shared to industry | 10d | 2025-03-17 | 2025-03-28 | 1751 | finish no earlier than 2025-03-28 |
| 1753 | Evaluate PPIR responses | 5d | 2025-03-31 | 2025-04-04 | 1752 |  |
| 1754 | Discuss PPIR results at QWG | 1d? | 2025-04-08 | 2025-04-08 | 1753SF-5d | finish no earlier than 2025-04-08 |
| 1828 | **M10 Readiness** | 50d? | 2025-01-06 A | 2025-03-14 |  |  |
| 1829 | Define guiding principles and approach | 15d? | 2025-01-06 A | 2025-01-24 A |  | start no earlier than 2025-01-06 |
| 1830 | Engage IPA | 10d | 2025-01-13 A | 2025-01-24 A |  | start no earlier than 2025-01-13 |
| 1831 | Mobilise Get to Go-Live Group | 10d | 2025-01-27 A | 2025-02-07 A | 1829, 1830 |  |
| 1832 | Progress against the M10 Readiness Criteria | 25d? | 2025-02-10 A | 2025-03-14 | 1831 |  |
| 1833 | **Downstream milestone feasibility assessment** | 50d? | 2025-01-06 A | 2025-03-14 |  |  |
| 1834 | Define guiding principles and approach to addressing points 1 - 3 | 20d? | 2025-01-06 A | 2025-01-31 A |  | start no earlier than 2025-01-06 |
| 1835 | Assess capacity within migration envelopes (Point 1 - Bringing M15 forwards) | 20d | 2025-01-20 A | 2025-02-14 A | 1834FF | start no earlier than 2025-01-20 |
| 1836 | Review M16 process (Point 3 - Bringing M16 forwards) | 25d? | 2025-01-20 A | 2025-02-21 A | 1834FF | start no earlier than 2025-01-20 |
| 1837 | Develop M16 process review findings | 10d | 2025-02-24 A | 2025-03-07 A | 1836 |  |
| 1838 | Agree M16 process review findings with Code Bodies | 5d | 2025-03-10 A | 2025-03-14 | 1837 |  |
| 1839 | Agree M16 process review findings with PAB | 5d | 2025-03-10 A | 2025-03-14 | 1837 |  |
| 1840 | Run PPIR with impacted parties (Point 2 - Bringing M14 forwards) | 10d | 2025-03-03 A | 2025-03-14 | 1835FS+10d |  |
| 1841 | **Checkpoint governance** | 21d | 2025-03-05 A | 2025-04-02 |  |  |
| 1842 | PSG Updated on progress | 0d | 2025-03-05 A | 2025-03-05 A | 1832SS | start no earlier than 2025-03-05 |
| 1843 | Review final M10 Readiness outputs with IPA | 5d | 2025-03-17 | 2025-03-21 | 1838, 1839, 1840, 1832 |  |
| 1844 | Review final M10 Readiness outputs with Ofgem | 8d | 2025-03-17 | 2025-03-26 | 1838, 1839, 1840, 1832, 1843SS |  |
| 1845 | QAG paper day | 0d | 2025-03-13 | 2025-03-13 | 1832SS | start no earlier than 2025-03-13 |
| 1846 | QAG recommend M10 Checkpoint | 0d | 2025-03-20 | 2025-03-20 | 1845FS+6d |  |
| 1847 | MCAG paper day | 0d | 2025-03-24 | 2025-03-24 | 1832FS+6d |  |
| 1848 | MCAG recommend M10 Checkpoint | 0d | 2025-04-01 | 2025-04-01 | 1847FS+6d |  |
| 1849 | PSG paper day | 0d | 2025-03-26 | 2025-03-26 | 1844 |  |
| 1850 | PSG M10 Checkpoint Meeting | 0d | 2025-04-02 | 2025-04-02 | 1849FS+5d, 1848, 1846, 1843, 1844 |  |
| 1851 | M10 Checkpoint complete | 0d | 2025-04-02 | 2025-04-02 | 1852FS-126d, 1850 |  |
| 2375 | **PAB dates** | 235d | 2025-01-23 A | 2025-12-18 |  |  |
| 2376 | PAB288 | 0d | 2025-01-23 A | 2025-01-23 A |  | start no earlier than 2025-01-23 |
| 2377 | PAB289 | 2d | 2025-02-26 A | 2025-02-27 A |  | start no earlier than 2025-02-26 |
| 2378 | PAB290 | 0d | 2025-03-12 | 2025-03-12 |  | start no earlier than 2025-03-12 |
| 2379 | PAB291 | 0d | 2025-03-27 | 2025-03-27 |  | start no earlier than 2025-03-27 |
| 2380 | PAB292 | 0d | 2025-04-09 | 2025-04-09 |  | start no earlier than 2025-04-09 |
| 2381 | PAB293 | 0d | 2025-04-24 | 2025-04-24 |  | start no earlier than 2025-04-24 |
| 2382 | PAB294 | 0d | 2025-05-14 | 2025-05-14 |  | start no earlier than 2025-05-14 |
| 2383 | PAB295 | 0d | 2025-05-29 | 2025-05-29 |  | start no earlier than 2025-05-29 |
| 2384 | PAB296 | 0d | 2025-06-11 | 2025-06-11 |  | start no earlier than 2025-06-11 |
| 2385 | PAB297 | 0d | 2025-06-26 | 2025-06-26 |  | start no earlier than 2025-06-26 |
| 2386 | PAB298 | 0d | 2025-07-16 | 2025-07-16 |  | start no earlier than 2025-07-16 |
| 2387 | PAB299 | 0d | 2025-07-31 | 2025-07-31 |  | start no earlier than 2025-07-31 |
| 2388 | PAB300 | 0d | 2025-08-13 | 2025-08-13 |  | start no earlier than 2025-08-13 |
| 2389 | PAB301 | 0d | 2025-08-28 | 2025-08-28 |  | start no earlier than 2025-08-28 |
| 2390 | PAB302 | 0d | 2025-09-10 | 2025-09-10 |  | start no earlier than 2025-09-10 |
| 2391 | PAB303 | 0d | 2025-09-25 | 2025-09-25 |  | start no earlier than 2025-09-25 |
| 2392 | PAB304 | 0d | 2025-10-15 | 2025-10-15 |  | start no earlier than 2025-10-15 |
| 2393 | PAB305 | 0d | 2025-10-30 | 2025-10-30 |  | start no earlier than 2025-10-30 |
| 2394 | PAB306 | 0d | 2025-11-12 | 2025-11-12 |  | start no earlier than 2025-11-12 |
| 2395 | PAB307 | 0d | 2025-11-27 | 2025-11-27 |  | start no earlier than 2025-11-27 |
| 2396 | PAB308 | 0d | 2025-12-18 | 2025-12-18 |  | start no earlier than 2025-12-18 |
| 2559 | MWG paper day | 0d | 2025-02-06 A | 2025-02-06 A | 2558 | start no earlier than 2025-02-06 |
| 2565 | Book MWG | 0d | 2025-02-07 A | 2025-02-07 A | 2564 |  |
| 2566 | Prepare Consultation 4 content | 9d | 2025-02-10 A | 2025-02-20 A | 2565 |  |
| 2567 | MWG paper day | 0d | 2025-02-20 A | 2025-02-20 A | 2566 |  |
| 2568 | MWG recommend Consultation 4 content go for industry consultation | 0d | 2025-03-04 A | 2025-03-04 A | 2567FS+8d |  |
| 2571 | Respond to comments and issue artefacts | 10d? | 2025-03-31 | 2025-04-11 | 2570 | finish no earlier than 2025-04-11 |
| 2573 | MCAG paper day | 0d | 2025-04-22 | 2025-04-22 | 2572 | finish no earlier than 2025-04-22 |
| 2578 | Schedule Production Complete | 0d | 2024-12-20 A | 2024-12-20 A | 2577 |  |
| 2579 | **V1.0 of Migration Schedule Baseline** | 81d | 2025-04-01 | 2025-07-22 |  |  |
| 2580 | Confirm Supplier Migration start dates, MPID groups (SIT & NonSIT) | 0d | 2025-04-01 | 2025-04-01 |  | start no earlier than 2025-04-01 |
| 2582 | **Supplier Commission 2** | 102d? | 2025-03-03 A | 2025-07-22 |  |  |
| 2583 | Confirm / validate contacts for all Suppliers | 22d | 2025-03-03 A | 2025-04-01 |  | start no earlier than 2025-03-03 |
| 2584 | Supplier submission issued | 0d | 2025-04-25 | 2025-04-25 | 2583FS+18d |  |
| 2585 | Supplier submission deadline | 0d | 2025-06-20 | 2025-06-20 | 2584FS+40d |  |
| 2586 | Second Supplier Submission complete | 0d | 2025-06-20 | 2025-06-20 | 2585 |  |
| 2587 | Publish and baseline Migration Schedule | 1d? | 2025-07-22 | 2025-07-22 | 2586FS+21d |  |
| 2588 | **Supplier Submission Support** | 29d? | 2025-04-25 | 2025-06-04 |  |  |
| 2589 | Support guides issued | 1d? | 2025-04-25 | 2025-04-25 |  | start no earlier than 2025-04-25 |
| 2590 | Envelope webinar | 0d | 2025-05-02 | 2025-05-02 | 2589FS+5d |  |
| 2591 | De-minimus webinar | 0d | 2025-05-02 | 2025-05-02 | 2590 |  |
| 2592 | Drop-in session 1 | 0d | 2025-05-14 | 2025-05-14 | 2591FS+8d |  |
| 2593 | Drop-in session 2 | 0d | 2025-05-28 | 2025-05-28 | 2592FS+10d |  |
| 2594 | Drop-in session 3 | 0d | 2025-06-04 | 2025-06-04 | 2593FS+5d |  |
| 2595 | Q+A documents from sessions published | 0d | 2025-06-04 | 2025-06-04 | 2594 |  |
| 2599 | **MCC Dress Rehersal 1 - Initialise Schedule (Weekly) Drop 1, 2** | 63d | 2025-04-18 | 2025-07-15 |  |  |
| 2600 | Issue Dress Rehearsal support information to Participants | 0d | 2025-04-18 | 2025-04-18 |  | start no earlier than 2025-04-18 |
| 2601 | Kestrel Webinar 1 | 0d | 2025-04-18 | 2025-04-18 | 2600 |  |
| 2602 | Onboard and connectivity testing - Dress Rehearsal with Suppliers (All SIT and Wave 1 mandatory) | 0d | 2025-04-25 | 2025-04-25 | 2601FS+6d |  |
| 2603 | Dress rehearsal start | 0d | 2025-04-28 | 2025-04-28 | 2602FS+1d |  |
| 2604 | Test execution report (weekly) | 0d | 2025-07-15 | 2025-07-15 | 2603FS+56d |  |
| 2605 | Dress rehearsal completion report | 0d | 2025-07-15 | 2025-07-15 | 2604 |  |
| 2606 | MCC Dress Rehersal 1 - complete | 0d | 2025-07-15 | 2025-07-15 | 2605 |  |
| 2607 | **MCC Dress Rehersal 2 - complete** | 35d | 2025-07-14 | 2025-08-29 |  |  |
| 2608 | Issue Dress Rehearsal support information to Participants | 0d | 2025-07-14 | 2025-07-14 |  | start no earlier than 2025-07-14 |
| 2609 | Kestrel Webinar 2 | 0d | 2025-07-14 | 2025-07-14 | 2608 |  |
| 2610 | Onboard and connectivity testing - Dress Rehearsal with Suppliers (remaining suppliers and non-supplier PPs) | 0d | 2025-07-21 | 2025-07-21 | 2609FS+6d |  |
| 2611 | Dress rehearsal start | 0d | 2025-07-21 | 2025-07-21 | 2610 |  |
| 2612 | Test execution report (weekly) | 0d | 2025-08-29 | 2025-08-29 | 2611FS+29d |  |
| 2613 | Dress rehearsal completion report | 0d | 2025-08-29 | 2025-08-29 | 2612 |  |
| 2614 | MCC Dress Rehersal 2 - complete | 0d | 2025-08-29 | 2025-08-29 | 2613 |  |
| 2615 | MCC Operational Complete | 0d | 2025-08-29 | 2025-08-29 | 2607, 2614 |  |
| 2674 | Suppliers complete Work Off plans | 105d | 2024-12-23 A | 2025-05-16 | 2673 | start no earlier than 2024-12-23 |
| 2680 | Suppliers complete Work Off plans | 123d | 2025-01-29 A | 2025-07-18 | 2679 | finish no earlier than 2025-07-18 |
| 2781 | **Migration Sprints** | 420d | 2025-09-25 | 2027-05-05 |  |  |
| 2782 | **Migration Sprint 0** | 94d | 2025-09-25 | 2026-02-03 |  |  |
| 2783 | Sprint 0 Planning start date | 6d | 2025-09-25 | 2025-10-02 |  | start no earlier than 2025-09-25 |
| 2784 | Issue Envelope | 0d | 2025-10-02 | 2025-10-02 | 2783 |  |
| 2785 | Supplier Submission Deadline | 0d | 2025-10-09 | 2025-10-09 | 2784FS+5d |  |
| 2786 | Baseline Schedule Publication | 0d | 2025-10-16 | 2025-10-16 | 2785FS+5d |  |
| 2787 | Migration Sprint 0 Schedule Baselined | 0d | 2025-10-16 | 2025-10-16 | 2786 |  |
| 2788 | Sprint Execution Start | 0d | 2025-10-23 | 2025-10-23 | 2787FS+5d, 2925, 2880 |  |
| 2789 | Sprint Execution | 73d | 2025-10-24 | 2026-02-03 | 2788 |  |
| 2790 | Sprint Execution End | 0d | 2026-02-03 | 2026-02-03 | 2789 |  |
| 2791 | **Migration Sprint 1** | 60d | 2026-01-07 | 2026-03-31 |  |  |
| 2792 | Sprint 1 Planning start date | 6d | 2026-01-07 | 2026-01-14 |  | start no earlier than 2026-01-07 |
| 2793 | Issue Envelope | 0d | 2026-01-14 | 2026-01-14 | 2792 |  |
| 2794 | Supplier Submission Deadline | 0d | 2026-01-21 | 2026-01-21 | 2793FS+5d |  |
| 2795 | Baseline Schedule Publication | 0d | 2026-01-28 | 2026-01-28 | 2794FS+5d |  |
| 2796 | Migration Sprint 1 Schedule Baselined | 0d | 2026-01-28 | 2026-01-28 | 2795 |  |
| 2797 | Sprint Execution Start | 0d | 2026-02-04 | 2026-02-04 | 2796FS+5d |  |
| 2798 | Sprint Execution | 39d | 2026-02-05 | 2026-03-31 | 2797 |  |
| 2799 | Sprint Execution End | 0d | 2026-03-31 | 2026-03-31 | 2798 |  |
| 2800 | **Migration Sprint 2** | 65d | 2026-03-04 | 2026-06-02 |  |  |
| 2801 | Sprint 2 Planning start date | 6d | 2026-03-04 | 2026-03-11 |  | start no earlier than 2026-03-04 |
| 2802 | Issue Envelope | 0d | 2026-03-11 | 2026-03-11 | 2801 |  |
| 2803 | Supplier Submission Deadline | 0d | 2026-03-18 | 2026-03-18 | 2802FS+5d |  |
| 2804 | Baseline Schedule Publication | 0d | 2026-03-25 | 2026-03-25 | 2803FS+5d |  |
| 2805 | Migration Sprint 2 Schedule Baselined | 0d | 2026-03-25 | 2026-03-25 | 2804 |  |
| 2806 | Sprint Execution Start | 0d | 2026-04-01 | 2026-04-01 | 2805FS+5d |  |
| 2807 | Sprint Execution | 44d | 2026-04-02 | 2026-06-02 | 2806 |  |
| 2808 | Non-SIT Participants Migration Start | 0d | 2026-05-15 | 2026-05-15 | 2964FS+1d |  |
| 2809 | Sprint Execution End | 0d | 2026-06-02 | 2026-06-02 | 2807 |  |
| 2810 | **Migration Sprint 3** | 65d | 2026-05-06 | 2026-08-04 |  |  |
| 2811 | Sprint 3 Planning start date | 6d | 2026-05-06 | 2026-05-13 |  | start no earlier than 2026-05-06 |
| 2812 | Issue Envelope | 0d | 2026-05-13 | 2026-05-13 | 2811 |  |
| 2813 | Supplier Submission Deadline | 0d | 2026-05-20 | 2026-05-20 | 2812FS+5d |  |
| 2814 | Baseline Schedule Publication | 0d | 2026-05-27 | 2026-05-27 | 2813FS+5d |  |
| 2815 | Migration Sprint 3 Schedule Baselined | 0d | 2026-05-27 | 2026-05-27 | 2814 |  |
| 2816 | Sprint Execution Start | 0d | 2026-06-03 | 2026-06-03 | 2815FS+5d |  |
| 2817 | Sprint Execution | 44d | 2026-06-04 | 2026-08-04 | 2816 |  |
| 2818 | Sprint Execution End | 0d | 2026-08-04 | 2026-08-04 | 2817 |  |
| 2819 | **Migration Sprint 4** | 65d | 2026-07-08 | 2026-10-06 |  |  |
| 2820 | Sprint 4 Planning start date | 6d | 2026-07-08 | 2026-07-15 |  | start no earlier than 2026-07-08 |
| 2821 | Issue Envelope | 0d | 2026-07-15 | 2026-07-15 | 2820 |  |
| 2822 | Supplier Submission Deadline | 0d | 2026-07-22 | 2026-07-22 | 2821FS+5d |  |
| 2823 | Baseline Schedule Publication | 0d | 2026-07-29 | 2026-07-29 | 2822FS+5d |  |
| 2824 | Migration Sprint 4 Schedule Baselined | 0d | 2026-07-29 | 2026-07-29 | 2823 |  |
| 2825 | Sprint Execution Start | 0d | 2026-08-05 | 2026-08-05 | 2824FS+5d |  |
| 2826 | Sprint Execution | 44d | 2026-08-06 | 2026-10-06 | 2825 |  |
| 2827 | Sprint Execution End | 0d | 2026-10-06 | 2026-10-06 | 2826 |  |
| 2828 | **Migration Sprint 5** | 60d | 2026-09-09 | 2026-12-01 |  |  |
| 2829 | Sprint 5 Planning start date | 6d | 2026-09-09 | 2026-09-16 |  | start no earlier than 2026-09-09 |
| 2830 | Issue Envelope | 0d | 2026-09-16 | 2026-09-16 | 2829 |  |
| 2831 | Supplier Submission Deadline | 0d | 2026-09-23 | 2026-09-23 | 2830FS+5d |  |
| 2832 | Baseline Schedule Publication | 0d | 2026-09-30 | 2026-09-30 | 2831FS+5d |  |
| 2833 | Migration Sprint 5 Schedule Baselined | 0d | 2026-09-30 | 2026-09-30 | 2832 |  |
| 2834 | Sprint Execution Start | 0d | 2026-10-07 | 2026-10-07 | 2833FS+5d |  |
| 2835 | Sprint Execution | 39d | 2026-10-08 | 2026-12-01 | 2834 |  |
| 2836 | Sprint Execution End | 0d | 2026-12-01 | 2026-12-01 | 2835 |  |
| 2837 | **Migration Sprint 6** | 65d | 2026-11-04 | 2027-02-02 |  |  |
| 2838 | Sprint 6 Planning start date | 6d | 2026-11-04 | 2026-11-11 |  | start no earlier than 2026-11-04 |
| 2839 | Issue Envelope | 0d | 2026-11-11 | 2026-11-11 | 2838 |  |
| 2840 | Supplier Submission Deadline | 0d | 2026-11-18 | 2026-11-18 | 2839FS+5d |  |
| 2841 | Baseline Schedule Publication | 0d | 2026-11-25 | 2026-11-25 | 2840FS+5d |  |
| 2842 | Migration Sprint 6 Schedule Baselined | 0d | 2026-11-25 | 2026-11-25 | 2841 |  |
| 2843 | Sprint Execution Start | 0d | 2026-12-02 | 2026-12-02 | 2842FS+5d |  |
| 2844 | Sprint Execution | 44d | 2026-12-03 | 2027-02-02 | 2843 |  |
| 2845 | Sprint Execution End | 0d | 2027-02-02 | 2027-02-02 | 2844 |  |
| 2846 | **Migration Sprint 7** | 65d | 2027-01-06 | 2027-04-06 |  |  |
| 2847 | Sprint 6 Planning start date | 6d | 2027-01-06 | 2027-01-13 |  | start no earlier than 2027-01-06 |
| 2848 | Issue Envelope | 0d | 2027-01-13 | 2027-01-13 | 2847 |  |
| 2849 | Supplier Submission Deadline | 0d | 2027-01-20 | 2027-01-20 | 2848FS+5d |  |
| 2850 | Baseline Schedule Publication | 0d | 2027-01-27 | 2027-01-27 | 2849FS+5d |  |
| 2851 | Migration Sprint 7 Schedule Baselined | 0d | 2027-01-27 | 2027-01-27 | 2850 |  |
| 2852 | Sprint Execution Start | 0d | 2027-02-03 | 2027-02-03 | 2851FS+5d |  |
| 2853 | Sprint Execution | 44d | 2027-02-04 | 2027-04-06 | 2852 |  |
| 2854 | Sprint Execution End | 0d | 2027-04-06 | 2027-04-06 | 2853 |  |
| 2855 | **Migration Sprint 8** | 48d | 2027-03-01 | 2027-05-05 |  |  |
| 2856 | Sprint 8 Planning start date | 6d | 2027-03-01 | 2027-03-08 |  | start no earlier than 2027-03-01 |
| 2857 | Issue Envelope | 0d | 2027-03-08 | 2027-03-08 | 2856 |  |
| 2858 | Supplier Submission Deadline | 0d | 2027-03-15 | 2027-03-15 | 2857FS+5d |  |
| 2859 | Baseline Schedule Publication | 0d | 2027-03-22 | 2027-03-22 | 2858FS+5d |  |
| 2860 | Migration Sprint 8 Schedule Baselined | 0d | 2027-03-22 | 2027-03-22 | 2859 |  |
| 2861 | Sprint Execution Start | 0d | 2027-03-29 | 2027-03-29 | 2860FS+5d |  |
| 2862 | Sprint Execution | 27d | 2027-03-30 | 2027-05-05 | 2861 |  |
| 2863 | Sprint Execution End | 0d | 2027-05-05 | 2027-05-05 | 2862 |  |
| 2902 | **Phase 1 - Preparation** | 840d? | 2022-10-31 | 2026-01-16 |  |  |

Removed: 1105 Production of NFT RTTM; 1106 Test Script updates identified; 1107 Test Scripts updates; 1108 RTTM Updated Additional RTTM WBS items; 1109 Removal of de-scoped TCs from the RTTMs; 1110 Update and stabilisation of all TC ADO IDs; 1111 Addition and integration of Role tags to reqs in the Role RTTMs; 1112 Update of the RTTM All sheet (porting of the individual RTTMs); 1113 Define Additional ADO Tags; 1114 Non-Functional RTTM ready for import into ADO; 1115 Further Interative Deepdive on the requirements to testcase mapping; 1116 Internal review; 1117 Issue Static RTTM to Code Bodies; 1118 Code Body Acceptance of RTTM; 1141 Non-Functional Themes 2 & 3 (LDSO's and DCC) Data Load; 1142 Operational Themes 1, 2 & 3 (Batch 2) (LDSO's and DCC) Data Load; 1335 Theme 3 Work-off plan; 1336 Test Scripts updates; 1337 RTTM Updated Additional RTTM WBS items; 1338 Removal of de-scoped TCs from the RTTMs; 1339 Update and stabilisation of all TC ADO IDs; 1340 Addition and integration of Role tags to reqs in the Role RTTMs; 1341 Update of the RTTM All sheet (porting of the individual RTTMs); 1342 Define Additional ADO Tags; 1343 Upload Operational RTTM to ADO; 1344 Further Interative Deepdive on the requirements to testcase mapping; 1345 Internal review; 1346 Issue Static RTTM to Code Bodies; 1347 Code Body Acceptance of RTTM; 1382 SITWG paper day; 1383 SITWG update on execution model; 1389 SITWG paper day; 1390 SITWG update on execution model; 1418 SITWG paper day; 1419 SITWG endorses regression suite doc; 1456 Publish (QIP); 1457 Review & UAT; 1458 QIP Training Material & User Guides; 1557 Programme agreement into Settlement Testing; 1558 Helix E2E Settlement Testing Execution; 1559 Helix E2E Settlement Testing Execution Complete; 1560 MHHSP Helix E2E Testing Assurance; 1561 MHHSP Helix E2E Testing Assurance Complete; 2405 Migration Period Plan Review 1 Completed; 2428 Industry Assurance Review; 2434 Test Approach; 2435 Test Plan; 2436 Other Framework items; 2443 Indicative Envelopes Issued; 2444 Supplier Submissions; 2445 Team Assess Responses; 2446 Discuss and Agree Approach with Participants where necessary; 2448 Schedule Production v2; 2452 Migration Planning Tool - Delivery; 2453 MPMT Build Sprints - MVP; 2454 Delivery Activity; 2455 MCC - Pilot; 2457 Sprint Planning (Cycle 1); 2458 Sprint Planning (Cycle 2); 2459 Sprint Planning (Cycle 3); 2460 Migration Control Centre Tooling; 2461 Data Source Definition; 2462 Scheduling and Data Requirements; 2463 Tool Phase 1; 2464 Data Requirements; 2465 Tool Phase 2; 2466 Data Source Provision; 2467 Tool - Internal and External Testing; 2468 Migration Control Centre Mobilised and Ready; 2469 Migration Control Centre TOM Definition; 2470 Access to Data; 2471 Migration Control Centre Delegation of Authority; 2472 Recruit and Train; 2473 Dress Rehearsal; 2637 UMS / Advanced Migration; 2638 SIT MVC UMS / Advanced Migration; 2639 SIT Non-MVC UMS / Advanced Migration; 2640 Wave 1 UMS / Advanced Migration; 2641 Wave 2 UMS / Advanced Migration; 2642 Wave 3 UMS / Advanced Migration; 2643 Wave 4 UMS / Advanced Migration; 2644 Smart / Non-Smart Migration; 2645 SIT MVC Smart / Non-Smart Migration; 2646 SIT Non-MVC Smart / Non-Smart Migration; 2647 Wave 1 Smart / Non-Smart Migration; 2648 Wave 2 Smart / Non-Smart Migration; 2649 Wave 3 Smart / Non-Smart Migration; 2650 Wave 4 Smart / Non-Smart Migration

Changed:

| ID | Task | Start | Finish | Duration | Complete | Total float | Predecessors | Other |
| --- | --- | --- | --- | --- | --- | --- | --- | --- |
| 1 | **PROGRAMME PLAN.** |  |  |  | 56% → 66% |  |  |  |
| 3 | **PROGRAMME MANAGEMENT** |  |  |  | 44% → 57% |  |  |  |
| 4 | **Programme Management** |  |  |  | 43% → 56% |  |  |  |
| 5 | Sprint-based prioritisation planning and execution |  |  |  | 43% → 56% |  |  |  |
| 6 | Programme governance secretariat |  |  |  | 43% → 56% |  |  |  |
| 7 | RAID management and reporting |  |  |  | 43% → 56% |  |  |  |
| 8 | Tracking against Programme outcomes and KPIs |  |  |  | 43% → 56% |  |  |  |
| 9 | Change control and reporting |  |  |  | 43% → 56% |  |  |  |
| 10 | Ongoing identification of lessons learned relating to the PMO and implementation of improvements |  |  |  | 43% → 56% |  |  |  |
| 11 | **Programme Internal Assurance Reviews** |  |  |  | 43% → 56% |  |  |  |
| 12 | Programme Internal Assurance Reviews |  |  |  | 43% → 56% |  |  |  |
| 13 | **Engagement with PPs** |  |  |  | 43% → 56% |  |  |  |
| 14 | Ongoing PP liaison activities |  |  |  | 43% → 56% |  |  |  |
| 15 | Milestone and Control Point objective setting |  |  |  | 43% → 56% |  |  |  |
| 16 | Reporting |  |  |  | 43% → 56% |  |  |  |
| 17 | **PP Engagement Events** |  |  |  | 43% → 56% |  |  |  |
| 18 | Bilateral meetings |  |  |  | 43% → 56% |  |  |  |
| 19 | Monthly webinars |  |  |  | 43% → 56% |  |  |  |
| 20 | Open days |  |  |  | 43% → 56% |  |  |  |
| 21 | **PP Communications** |  |  |  | 43% → 56% |  |  |  |
| 22 | The Clock updates (weekly) |  |  |  | 43% → 56% |  |  |  |
| 23 | Maintain and update content on public-facing Portal (and ongoing feedback reviews to identify and implement Portal improvements) |  |  |  | 43% → 56% |  |  |  |
| 24 | **Code Change Support / Other Programme Alignment** |  |  |  | 43% → 56% |  |  |  |
| 25 | Support DCC/BEIS on SEC change |  |  |  | 43% → 56% |  |  |  |
| 26 | Support on Smart Meters Act changes |  |  |  | 43% → 56% |  |  |  |
| 27 | Support DCC/RECCo on CSS change |  |  |  | 43% → 56% |  |  |  |
| 28 | Support Elexon on BSC change |  |  |  | 43% → 56% |  |  |  |
| 29 | Support code change inside & outside CCIAG |  |  |  | 43% → 56% |  |  |  |
| 30 | Support code change inside & outside CCAG |  |  |  | 43% → 56% |  |  |  |
| 45 | **DESIGN, BUILD & TEST (PIT)** |  |  |  | 79% → 83% |  |  |  |
| 46 | **Design Baseline & Enduring PP Support** |  |  |  | 71% → 79% |  |  |  |
| 56 | **Establish Design Change Management Processes** |  |  |  | 36% → 54% |  |  |  |
| 61 | Maintain E2E MHHS Design (post-M5 design change management processes operational) |  |  |  | 34% → 52% |  |  |  |
| 96 | **Design Artefact Releases** |  | 2025-01-24 → 2025-03-12 A (+47d) | 503d? → 536d? | 97% → 100% | 759d → none |  |  |
| 136 | **Interim release 8** |  | 2025-01-24 → 2025-03-12 A (+47d) | 248d? → 281d? | 84% → 100% | 759d → none |  |  |
| 146 | **Interim Release 8.5** |  | 2025-01-22 A |  | 73% → 100% | 761d → none |  |  |
| 149 | Interim Release 8.5 Deployed to SIT by Participants | 2025-01-20 A | 2025-01-22 A |  | 0% → 100% | 761d → none |  |  |
| 150 | **Interim Release 8.6** |  | 2025-01-22 A |  | 50% → 100% | 761d → none |  |  |
| 153 | Interim Release 8.6 Deployed to SIT by Participants | 2025-01-20 A | 2025-01-22 A |  | 0% → 100% | 761d → none |  |  |
| 154 | **Interim Release 8.7** | 2025-01-20 A | 2025-01-24 A |  | 0% → 100% | 759d → none |  |  |
| 155 | Update baselined artefacts | 2025-01-20 A | 2025-01-21 A |  | 0% → 100% | 759d → none |  |  |
| 156 | Interim Release 8.7 Published | 2025-01-22 A | 2025-01-22 A |  | 0% → 100% | 759d → none |  |  |
| 157 | Interim Release 8.7 Deployed to SIT by Participants | 2025-01-22 A | 2025-01-24 A |  | 0% → 100% | 759d → none |  |  |
| 179 | **PP Design, Build & Test (DBT)** |  |  |  | 83% → 74% |  |  |  |
| 191 | **Design Handover** | 2024-09-02 A → 2024-04-02 A (-153d) |  | 741d? → 850d? | 6% → 17% |  |  |  |
| 195 | **Knowledge Transfer** | 2024-09-02 → 2025-01-06 A (+126d) | 2024-10-28 → 2025-05-05 (+189d) | 41d? → 86d? | 0% → 10% | 823d → 688d |  |  |
| 196 | Elexon to document knowledge transfer requirements | 2024-09-02 → 2025-01-06 A (+126d) | 2024-09-12 → 2025-01-09 A (+119d) | 9d? → 4d | 0% → 100% | 834d → none |  | baseline start 2024-09-02 → 2025-01-06; baseline finish 2024-09-12 → 2025-01-09 |
| 197 | Review Requirements | 2024-09-13 → 2025-01-10 A (+119d) | 2024-09-19 → 2025-01-16 A (+119d) |  | 0% → 100% | 834d → none |  | baseline start 2024-09-13 → 2025-01-10; baseline finish 2024-09-19 → 2025-01-16 |
| 198 | Agree Success Criteria | 2024-09-20 → 2025-01-17 (+119d) | 2024-10-03 → 2025-02-28 (+148d) | 10d → 31d |  | 834d → 688d |  | baseline start 2024-09-20 → 2025-01-17; baseline finish 2024-10-03 → 2025-02-28 |
| 199 | Identify Key personel with Elexon | 2024-10-04 → 2025-03-03 (+150d) | 2024-10-08 → 2025-03-05 (+148d) |  |  | 834d → 688d |  | baseline start 2024-10-04 → 2025-03-03; baseline finish 2024-10-08 → 2025-03-05 |
| 200 | Draft Agenda for initial meeting | 2024-10-09 → 2025-03-06 (+148d) | 2024-10-09 → 2025-03-06 (+148d) |  |  | 834d → 688d |  | baseline start 2024-10-09 → 2025-03-06; baseline finish 2024-10-09 → 2025-03-06 |
| 201 | Define cadence for handover sessions | 2024-10-10 → 2025-03-07 (+148d) | 2024-10-11 → 2025-03-10 (+150d) |  |  | 834d → 688d |  | baseline start 2024-10-10 → 2025-03-07; baseline finish 2024-10-11 → 2025-03-10 |
| 202 | Share Design Information | 2024-09-02 → 2025-03-11 (+190d) | 2024-09-27 → 2025-04-07 (+192d) |  |  | 844d → 688d | none → 201 | baseline start 2024-09-02 → 2025-03-11; baseline finish 2024-09-27 → 2025-04-07 |
| 203 | Conduct Initial Handover Session | 2024-10-01 → 2025-04-08 (+189d) | 2024-10-28 → 2025-05-05 (+189d) |  |  | 823d → 688d | none → 202 | baseline start 2024-10-01 → 2025-04-08; baseline finish 2024-10-28 → 2025-05-05 |
| 204 | **Triage Sessions** | 2024-10-01 → 2024-04-02 (-182d) | 2025-04-01 → 2025-09-30 (+182d) | 131d? → 391d |  | 712d → 582d |  |  |
| 205 | Design Triage Sessions |  | 2025-04-01 → 2025-09-30 (+182d) | 131d? → 261d |  | 712d → 582d |  | baseline finish 2025-04-01 → 2025-09-30 |
| 206 | Test Triage Sessions | 2024-10-01 → 2024-04-02 (-182d) |  | 131d? → 261d |  |  |  |  |
| 210 | **FreshDesk** | 2025-02-03 → 2025-08-20 (+198d) | 2025-03-14 → 2025-09-24 (+194d) | 30d? → 26d? |  | 724d → 586d |  | baseline start 2025-02-03 → 2025-08-20; baseline finish 2025-03-14 → 2025-09-24 |
| 211 | Agree Indicative Handover of FreshDesk Calls to Service Now | 2025-02-03 → 2025-08-20 (+198d) | 2025-02-06 → 2025-08-25 (+200d) |  |  | 750d → 586d |  | constraint start no earlier than 2025-02-03 → start no earlier than 2025-08-20; baseline start 2025-02-03 → 2025-08-20; baseline finish 2025-02-06 → 2025-08-25 |
| 212 | Prepare Comms to Industry | 2025-02-07 → 2025-08-26 (+200d) | 2025-02-20 → 2025-09-08 (+200d) |  |  | 740d → 586d | none → 211 | baseline start 2025-02-07 → 2025-08-26; baseline finish 2025-02-20 → 2025-09-08 |
| 213 | Issue Comms to Industry | 2025-02-21 → 2025-09-09 (+200d) | 2025-02-21 → 2025-09-09 (+200d) |  |  | 739d → 586d | none → 212 | baseline start 2025-02-21 → 2025-09-09; baseline finish 2025-02-21 → 2025-09-09 |
| 214 | Redirect Design Mailbox to Service Now | 2025-03-03 → 2025-09-10 (+191d) | 2025-03-03 → 2025-09-10 (+191d) |  |  | 733d → 586d | none → 213 | baseline start 2025-03-03 → 2025-09-10; baseline finish 2025-03-03 → 2025-09-10 |
| 215 | Archive Freshdesk calls | 2025-03-03 → 2025-09-11 (+192d) | 2025-03-07 → 2025-09-17 (+194d) |  |  | 729d → 586d | none → 214 | baseline start 2025-03-03 → 2025-09-11; baseline finish 2025-03-07 → 2025-09-17 |
| 216 | Decommission FreshDesk | 2025-03-10 → 2025-09-18 (+192d) | 2025-03-14 → 2025-09-24 (+194d) |  |  | 724d → 586d | none → 215 | baseline start 2025-03-10 → 2025-09-18; baseline finish 2025-03-14 → 2025-09-24 |
| 217 | **iServer** |  |  |  | 5% → 88% |  |  |  |
| 218 | Gather Licensing information |  | 2025-03-03 A → 2025-07-02 A (+121d) | 1d? → 88d? |  |  |  | baseline finish 2025-03-03 → 2025-07-02 |
| 222 | Clear down old information |  | 2025-03-07 → 2025-03-03 (-4d) | 5d → 1d? |  | 715d → 731d |  | baseline start 2025-03-03 → 2025-08-11; baseline finish 2025-03-07 → 2025-08-11 |
| 223 | Clear down accounts |  |  |  |  | 715d → 727d |  | baseline start 2025-03-10 → 2025-08-12; baseline finish 2025-03-11 → 2025-08-13 |
| 224 | Identify Collaboration Base Design Dependencies on iServer | 2025-04-01 A | 2025-04-02 A |  | 0% → 100% | 701d → none |  | baseline start 2025-04-01 → 2025-08-14; baseline finish 2025-04-02 → 2025-08-15 |
| 225 | Remove Design dependencies | 2025-04-03 A |  |  | 0% → 20% |  |  | baseline start 2025-04-03 → 2025-08-18; baseline finish 2025-04-09 → 2025-08-22 |

| ID | Task | Start | Finish | Duration | Complete | Total float | Predecessors | Other |
| --- | --- | --- | --- | --- | --- | --- | --- | --- |
| 226 | Close down iServer |  |  |  |  |  |  | baseline start 2025-04-10 → 2025-08-25; baseline finish 2025-04-16 → 2025-08-29 |
| 319 | **SIT Participants DBT** |  |  |  | 89% → 80% | 734d → 739d |  |  |
| 354 | **All SIT Programme Participants PIT (SIT Functional)** |  |  |  | 77% → 62% | 734d → 739d |  |  |
| 403 | SIT Non-Functional PIT Completion Report submitted to Programme for assurance | 2024-11-29 A | 2024-11-29 A |  | 0% → 100% | 155d → none |  |  |
| 404 | SIT Non-Functional PIT Completion Report Theme 1 MHHS Review Completed |  | 2024-12-20 A |  | 50% → 100% | 155d → none |  |  |
| 405 | SIT Non-Functional PIT Completion Report Theme 2 & 3 MHHS Review Completed |  |  |  |  |  |  | baseline start none → 2025-02-21; baseline finish none → 2025-02-21 |
| 406 | **SIT Programme Participants PIT (SIT Operational Theme 1, 2, 3 (Batch 2))** |  |  |  |  |  |  | was named All SIT Programme Participants PIT (SIT Operational) |
| 412 | **Requirements to test Traceability Matrix (RTTM)** | 2024-11-01 A → 2024-11-01 |  |  |  |  |  |  |
| 413 | SIT Operational PIT RTTM submitted to Programme for assurance | 2024-11-01 A → 2024-11-01 | 2024-11-01 A → 2024-11-01 |  | 100% → 0% | none → 111d |  |  |
| 415 | **Test Scenarios** | 2024-11-01 A → 2024-11-01 |  |  |  | 111d → 0d |  |  |
| 416 | SIT Operational PIT test scenarios submitted to Programme for assurance | 2024-11-01 A → 2024-11-01 | 2024-11-01 A → 2024-11-01 |  | 100% → 0% | none → 0d |  |  |
| 421 | SIT Operational Theme 1, 2, 3 (Batch 2) PIT Completion Report submitted to Programme for assurance | 2025-01-10 → 2025-01-14 (+4d) | 2025-01-10 → 2025-01-14 (+4d) |  |  |  | 419, 420FS+30d → 419, 420FS+32d | was named SIT Operational PIT Completion Report submitted to Programme for assurance |
| 422 | SIT Operational Theme 1, 2, 3 (Batch 2) PIT Completion Report MHHS Review Completed |  |  |  |  |  | 409, 414, 417, 421FS+15d → 409, 414, 417, 421FS+13d | was named SIT Operational PIT Completion Report MHHS Review Completed; baseline start 2024-12-20 → 2025-01-31; baseline finish 2024-12-20 → 2025-01-31 |
| 491 | **DBT Monitoring and Assurance** |  |  |  | 69% → 85% |  |  |  |
| 492 | **Planning and DBT Progress Monitoring of PPs** |  |  |  | 67% → 89% |  |  |  |
| 493 | Monitor Non-SIT PPs Planning and DBT1 progress (to inform confirmation of Qualification Testing Tranche participants milestones) |  |  |  | 67% → 89% |  |  |  |
| 494 | **DBT Progress Monitoring of Consequential Change** |  |  |  | 51% → 71% |  |  |  |
| 495 | Monitor & report data cleanse progress |  |  |  | 51% → 71% |  |  |  |
| 496 | **Design Assurance** |  |  |  | 80% → 89% |  |  |  |
| 527 | **Non-SIT PPs design assurance** |  |  |  | 53% → 75% |  |  |  |
| 528 | Non-SIT PPs design assurance (risk-based sample) |  |  |  | 53% → 75% |  |  |  |
| 529 | **Test Assurance** |  |  |  | 71% → 87% |  |  |  |
| 530 | Non-SIT PPs test assurance |  |  |  | 71% → 87% |  |  |  |
| 537 | **SYSTEMS INTEGRATION TESTING (SIT)** |  |  |  | 72% → 76% |  |  |  |
| 538 | **SIT Preparation** |  |  |  | 93% → 98% |  |  |  |
| 539 | **Test Artefact Development** |  | 2024-08-21 A |  | 99% → 100% | 872d → none |  |  |
| 565 | **Test Traceability** |  | 2024-01-17 A |  | 98% → 100% | 1026d → none |  |  |
| 569 | SIT Functional Full Traceability & Coverage complete |  | 2024-01-17 A |  | 96% → 100% | 1026d → none |  |  |
| 619 | **SIT Stage-Specific Preparation** |  |  |  | 91% → 98% |  |  |  |
| 988 | **SIT Migration Testing Preparation** |  | 2025-02-07 A |  | 96% → 100% | 749d → none |  |  |
| 999 | **Test scenarios & Test Cases** |  | 2025-02-07 A |  | 88% → 100% | 749d → none |  |  |
| 1021 | **Gap analysis** |  | 2025-02-07 A |  | 75% → 100% | 749d → none |  |  |
| 1048 | **Test Case Rationalisation (Functional + Migration)** |  | 2025-02-07 A |  | 54% → 100% | 749d → none |  |  |
| 1050 | Baseline RTTMs |  | 2024-11-13 A |  | 90% → 100% | 811d → none |  |  |
| 1053 | Internal finalisation rationalisation workshop 2 |  |  |  |  |  |  | baseline finish 2024-11-15 → 2024-12-03 |
| 1054 | SRO walkthrough |  |  |  |  |  |  | baseline start 2024-11-21 → 2024-12-04; baseline finish 2024-11-21 → 2024-12-04 |
| 1055 | Code Bodies walkthrough |  |  |  |  |  |  | baseline start 2024-11-26 → 2024-12-04; baseline finish 2024-11-26 → 2024-12-04 |
| 1056 | Send invites to PPs for walkthrough |  |  |  |  |  |  | baseline start 2024-11-26 → 2024-12-04; baseline finish 2024-11-26 → 2024-12-04 |
| 1057 | PP walkthrough |  |  |  |  |  |  | baseline start 2024-12-03 → 2024-12-17; baseline finish 2024-12-03 → 2024-12-17 |
| 1059 | SITWG Paper Day |  |  |  |  |  |  | baseline start 2024-12-20 → 2025-01-14; baseline finish 2024-12-20 → 2025-01-14 |
| 1060 | SITWG recommendation on requirements / test case analysis doc | 2025-01-21 A | 2025-01-21 A |  | 0% → 100% | 749d → none |  | baseline start 2025-01-08 → 2025-01-21; baseline finish 2025-01-08 → 2025-01-21 |
| 1061 | Issue to SITAG / SITAG paper day | 2025-01-22 A | 2025-01-22 A |  | 0% → 100% | 749d → none |  | baseline start 2024-12-11 → 2025-01-22; baseline finish 2024-12-11 → 2025-01-22 |
| 1062 | Prepare ADO update | 2025-01-22 A | 2025-01-29 A |  | 0% → 100% | 756d → none |  | baseline start 2024-12-11 → 2025-01-22; baseline finish 2024-12-18 → 2025-01-29 |
| 1063 | Sign off by SITAG | 2025-01-29 A | 2025-01-29 A |  | 0% → 100% | 749d → none |  | baseline start 2024-12-18 → 2025-01-29; baseline finish 2024-12-18 → 2025-01-29 |
| 1064 | Update ADO | 2025-01-30 A | 2025-02-07 A |  | 0% → 100% | 749d → none |  | baseline start 2024-12-19 → 2025-01-30; baseline finish 2024-12-20 → 2025-02-07 |
| 1065 | Update all ADO reporting | 2025-01-30 A | 2025-02-07 A |  | 0% → 100% | 749d → none |  | baseline start 2024-12-19 → 2025-01-30; baseline finish 2024-12-20 → 2025-02-07 |
| 1066 | Update test cases | 2025-01-30 A | 2025-02-07 A |  | 0% → 100% | 749d → none |  | baseline start none → 2025-01-30; baseline finish none → 2025-02-07 |
| 1067 | Update RTTM | 2025-01-30 A | 2025-02-07 A |  | 0% → 100% | 749d → none |  | baseline start none → 2025-01-30; baseline finish none → 2025-02-07 |
| 1068 | Update master test case spreadsheet | 2025-01-30 A | 2025-02-07 A |  | 0% → 100% | 749d → none |  | baseline start none → 2025-01-30; baseline finish none → 2025-02-07 |
| 1069 | Test Case Rationalisation complete | 2025-02-07 A | 2025-02-07 A |  | 0% → 100% | 749d → none |  | baseline start 2024-12-20 → 2025-02-07; baseline finish 2024-12-20 → 2025-02-07 |
| 1092 | **SIT Non-Functional Preparation** |  |  |  | 73% → 99% |  |  |  |
| 1103 | **Test scenarios & Test Cases** |  |  |  | 85% → 100% |  |  |  |
| 1129 | **NFT (Theme 1, 2 and 3) DITL** |  | 2025-02-26 A |  | 44% → 100% | 736d → none |  |  |
| 1130 | DITL Development |  | 2025-02-14 A |  | 80% → 100% | 736d → none |  |  |
| 1131 | SRO Review | 2025-02-17 A | 2025-02-21 A |  | 0% → 100% | 736d → none |  |  |
| 1132 | Post-SRO Review Changes | 2025-02-24 A | 2025-02-26 A |  | 0% → 100% | 736d → none |  |  |
| 1133 | Programme DITL walkthrough with PPs on Theme 1, 2 and 3 | 2025-02-26 A | 2025-02-26 A |  | 0% → 100% | 736d → none |  | was named Programme walkthrough with Theme 1 PPs on DITL |
| 1134 | **NFT Performance Tool Theme 1 Setup** |  | 2025-03-12 A |  | 98% → 100% | 726d → none |  |  |
| 1139 | Theme 1 injection tool configuration and validation against SIT-B DIP (IR8.4) | 2025-03-10 A | 2025-03-12 A |  | 0% → 100% | 726d → none |  | was named Theme 1 injection tool configuration and validation against SIT-B DIP (IR8.X) |
| 1140 | **Environments (SIT B)** |  | 2025-02-28 A |  | 0% → 100% | 25d → none |  |  |
| 1145 | **Helix and Avanade Environments Upscale** | 2025-02-24 A | 2025-02-28 A |  | 0% → 100% | 25d → none |  |  |
| 1146 | Environment Uplift Window (Technical Check) | 2025-02-24 A | 2025-02-28 A |  | 0% → 100% | 25d → none |  | was named Environment Uplift Window; baseline start 2024-12-23 → 2025-02-24; baseline finish 2025-01-03 → 2025-02-28 |
| 1147 | **SIT Non-Functional Execution Model** |  | 2025-02-14 → 2025-03-18 (+32d) | 20d → 42d | 14% → 99% | 744d → 722d |  |  |
| 1148 | **Theme 1** |  | 2025-02-12 → 2025-02-18 A (+6d) | 18d → 22d | 23% → 100% | 746d → none |  |  |
| 1150 | SRO provide feedback | 2025-01-23 A | 2025-01-29 A |  | 0% → 100% | 746d → none |  |  |
| 1151 | Address SRO feedback on execution model | 2025-01-30 A | 2025-01-31 A |  | 0% → 100% | 746d → none |  |  |
| 1152 | Finalise execution model | 2025-02-03 A | 2025-02-05 A |  | 0% → 100% | 746d → none |  |  |
| 1155 | **Theme 2 & 3** |  | 2025-02-12 → 2025-03-18 (+34d) | 18d → 42d | 23% → 99% | 746d → 722d |  |  |
| 1157 | SRO provide feedback | 2025-01-23 A | 2025-01-29 A |  | 0% → 100% | 746d → none |  |  |
| 1158 | Address SRO feedback on execution model | 2025-01-30 A | 2025-01-31 A |  | 0% → 100% | 746d → none |  |  |

| ID | Task | Start | Finish | Duration | Complete | Total float | Predecessors | Other |
| --- | --- | --- | --- | --- | --- | --- | --- | --- |
| 1159 | Finalise execution model | 2025-02-03 A | 2025-02-05 A |  | 0% → 100% | 746d → none |  |  |
| 1162 | **SIT Non-Functional Progress reporting** | 2025-01-23 A | 2025-02-14 → 2025-02-21 A (+7d) | 17d → 22d | 0% → 100% | 130d → none |  |  |
| 1163 | Determine reporting methodology | 2025-01-23 A | 2025-01-24 A |  | 0% → 100% | 130d → none |  |  |
| 1164 | Implement reporting | 2025-01-27 A | 2025-02-14 → 2025-02-21 A (+7d) | 15d → 20d | 0% → 100% | 130d → none |  |  |
| 1165 | **SIT Non-Functional Test Readiness Report** | 2025-01-20 A → 2025-01-21 A (+1d) | 2025-03-27 → 2025-03-28 (+1d) |  | 7% → 86% | 716d → 60d |  |  |
| 1166 | **SIT Non-Functional Theme 1 Overarching Test Readiness Report** | 2025-01-21 A | 2025-02-28 A |  | 0% → 100% | 35d → none |  |  |
| 1167 | Develop Overarching SIT Non-Functional Theme 1 Overarching Test Readiness Report | 2025-01-21 A | 2025-02-04 A |  | 0% → 100% | 736d → none |  | baseline start 2024-12-02 → 2025-01-21; baseline finish 2024-12-20 → 2025-02-04 |
| 1168 | SRO review | 2025-02-05 A | 2025-02-11 A |  | 0% → 100% | 736d → none |  | baseline start 2025-01-10 → 2025-02-05; baseline finish 2025-01-16 → 2025-02-11 |
| 1169 | NFTWG paper day | 2025-02-11 A | 2025-02-11 A |  | 0% → 100% | 736d → none |  | baseline start 2025-01-16 → 2025-02-11; baseline finish 2025-01-16 → 2025-02-11 |
| 1170 | NFTWG review the Non-Functional Theme 1 Overarching Test Readiness Report | 2025-02-18 A | 2025-02-18 A |  | 0% → 100% | 736d → none |  | baseline start 2025-01-23 → 2025-02-18; baseline finish 2025-01-23 → 2025-02-18 |
| 1171 | Update Non-Functional Theme 1 Overarching Test Readiness Report following SRO / NFTWG feedback | 2025-02-19 A | 2025-02-26 A |  | 0% → 100% | 736d → none |  | baseline start 2025-01-17 → 2025-02-19; baseline finish 2025-02-12 → 2025-02-26 |
| 1173 | eSITAG paper day | 2025-02-26 A | 2025-02-26 A |  | 0% → 100% | 736d → none |  | baseline start 2025-02-12 → 2025-02-26; baseline finish 2025-02-12 → 2025-02-26 |
| 1174 | eSITAG approve Non-Functional Theme 1 Overarching Test Readiness Report | 2025-02-28 A | 2025-02-28 A |  | 0% → 100% | 6d → none |  |  |
| 1175 | **SIT Non-Functional Overarching Test Readiness Report Theme 2 & 3** | 2025-02-18 A | 2025-03-27 → 2025-03-28 (+1d) | 27d → 28d | 0% → 73% | 74d → 60d |  | baseline start 2025-01-13 → 2025-02-18 |
| 1176 | Develop Overarching SIT Non-Functional Overarching Test Readiness Report Theme 2 & 3 | 2025-02-18 A | 2025-03-04 A |  | 0% → 100% | 732d → none |  | baseline start 2025-01-13 → 2025-02-18; baseline finish 2025-02-04 → 2025-03-04 |
| 1177 | SRO review | 2025-03-05 A | 2025-03-11 A |  | 0% → 100% | 63d → none |  | baseline start 2025-02-05 → 2025-03-05; baseline finish 2025-02-11 → 2025-03-11 |
| 1178 | NFTWG paper day | 2025-03-11 A | 2025-03-11 A |  | 0% → 100% | 63d → none |  | baseline start 2025-02-11 → 2025-03-11; baseline finish 2025-02-11 → 2025-03-11 |
| 1179 | NFTWG review the Non-Functional Overarching Test Readiness Report Theme 2 & 3 |  |  |  |  | 63d → 61d |  | baseline start 2025-02-18 → 2025-03-18; baseline finish 2025-02-18 → 2025-03-18 |
| 1180 | Update Non-Functional Overarching Test Readiness Report Theme 2 & 3 following SRO / NFTWG feedback |  | 2025-03-25 → 2025-03-26 (+1d) | 5d → 6d |  | 63d → 61d |  | baseline start 2025-02-19 → 2025-03-19; baseline finish 2025-03-12 → 2025-03-26 |
| 1182 | eSITAG paper day | 2025-03-25 → 2025-03-26 (+1d) | 2025-03-25 → 2025-03-26 (+1d) |  |  | 63d → 61d | 1180 → 1180, 1181 | baseline start 2025-03-12 → 2025-03-26; baseline finish 2025-03-12 → 2025-03-26 |
| 1183 | eSITAG approve Non-Functional Overarching Test Readiness Report Theme 2 & 3 | 2025-03-27 → 2025-03-28 (+1d) | 2025-03-27 → 2025-03-28 (+1d) |  |  | 62d → 60d | 1421FS-2d, Non-Functional Themes 2 & 3 (LDSO's and DCC) Data Load, 1182 → 1182, 1421FS-1d, 1422 |  |
| 1184 | SIT Non-Functional Testing Preparation Complete Theme 1 | 2025-02-28 A | 2025-02-28 A |  | 0% → 100% | 734d → none |  |  |
| 1185 | SIT Non-Functional Testing Preparation Complete Theme 2 & 3 |  |  |  |  |  | 1421, Non-Functional Themes 2 & 3 (LDSO's and DCC) Data Load, 405FS+5d → 405FS+5d, 1421, 1422, 1161, 1164, 1139, 1133, 1128 |  |
| 1186 | **SIT Operational Preparation** |  | 2025-05-05 → 2025-03-28 (-38d) | 656d? → 630d? | 89% → 95% | 688d → 714d |  |  |
| 1197 | **Theme 1 & 2 Test Cases Approved** |  |  |  |  |  |  | was named Test scenarios & Test Cases |
| 1215 | **SIT Operations Manual** | 2022-10-31 A → 2022-10-31 | 2025-01-31 A | 589d? → 590d? | 97% → 100% | 755d → none |  |  |
| 1236 | **Version 3 (Final) SIT Operations Manual** |  | 2025-01-28 A |  | 99% → 100% | 757d → none |  |  |
| 1241 | January TORWG (SIT Operations Manual Agreement) [Assurance Meeting] | 2025-01-15 A | 2025-01-15 A |  | 0% → 100% | 757d → none |  |  |
| 1242 | January MCAG Paper Day (Final SIT Operations Manual Submitted) | 2025-01-21 A | 2025-01-21 A |  | 0% → 100% | 757d → none |  |  |
| 1243 | January MCAG (Final SIT Operations Manual Endorsement) [Advisory Group Sign-off] | 2025-01-28 A | 2025-01-28 A |  | 0% → 100% | 757d → none |  |  |
| 1249 | Incident Management Build & Configuration Complete |  |  |  |  |  |  | baseline start none → 2024-11-15; baseline finish none → 2024-11-15 |
| 1254 | Major Incident Management Build & Configuration Complete |  |  |  |  |  |  | baseline start none → 2025-01-14; baseline finish none → 2025-01-14 |
| 1259 | Knowledge Management Build & Configuration Complete |  |  |  |  |  |  | baseline start none → 2025-01-14; baseline finish none → 2025-01-14 |
| 1264 | Problem Management Build & Configuration Complete |  |  |  |  |  |  | baseline start none → 2025-01-14; baseline finish none → 2025-01-14 |
| 1269 | Change Management Build & Configuration Complete |  |  |  |  |  |  | baseline start none → 2025-01-14; baseline finish none → 2025-01-14 |
| 1274 | Service Catalogue Management Build & Configuration Complete |  |  |  |  |  |  | baseline start none → 2025-01-14; baseline finish none → 2025-01-14 |
| 1280 | **Incident Management Support** |  |  |  | 64% → 100% |  |  | baseline start none → 2022-10-31; baseline finish none → 2022-10-31 |
| 1283 | Helix Stakeholders Attendance at MHHS Defect Triage Meetings [Meeting Dates to be Confirmed] |  | 2025-01-17 A |  | 10% → 100% | 764d → none |  |  |
| 1284 | SIT Service Readiness (Elexon & Helix) Completed | 2025-01-17 A | 2025-01-17 A |  | 0% → 100% | 764d → none |  |  |
| 1285 | **SIT Service Readiness (External Parties)** |  | 2025-01-24 → 2025-01-31 A (+7d) | 80d → 85d | 99% → 100% | 759d → none |  |  |
| 1290 | SIT Service Readiness (External Parties) Completed | 2025-01-24 → 2025-01-31 A (+7d) | 2025-01-24 → 2025-01-31 A (+7d) |  | 0% → 100% | 759d → none | 1287FS+9d, 1288, 1289 → 1287FS+9d, 1288, 1289, 1307 |  |
| 1291 | **ServiceNow Support Portal Onboarding (Helix Suppliers & SIT Participants)** |  |  |  | 85% → 100% |  |  |  |
| 1297 | **ServiceNow Portal System Configuration** |  | 2025-01-07 → 2025-01-31 A (+24d) | 30d? → 48d? | 76% → 100% |  |  |  |
| 1298 | Create Supplier User Accounts |  | 2025-01-10 → 2025-01-31 A (+21d) | 33d → 48d | 86% → 100% | 760d → none |  | constraint finish no earlier than 2025-01-10 → finish no earlier than 2025-01-31 |
| 1299 | Assign appropriate access based on the supplier’s needs and security requirements (e.g., read-only access, submit requests, etc.). |  | 2025-01-10 → 2025-01-31 A (+21d) | 10d? → 25d? | 60% → 100% | 760d → none |  |  |
| 1300 | Configure Access Controls |  | 2025-01-10 → 2025-01-31 A (+21d) | 10d? → 25d? | 60% → 100% | 760d → none |  |  |
| 1301 | **ServiceNow Portal Training and Documentation** |  | 2025-01-10 → 2025-01-31 A (+21d) | 5d? → 20d? | 83% → 100% |  |  |  |
| 1302 | Provide Training to the Supplier | 2025-01-24 → 2025-01-31 A (+7d) | 2025-01-24 → 2025-01-31 A (+7d) |  | 0% → 100% | 759d → none |  | constraint start no earlier than 2025-01-24 → finish no earlier than 2025-01-31 |
| 1303 | Create Supplier Training Documentation |  | 2025-01-10 A → 2025-01-31 A (+21d) | 5d → 20d |  |  |  | constraint finish no earlier than 2025-01-10 → finish no earlier than 2025-01-31 |
| 1304 | **ServiceNow Portal Testing and Validation** |  | 2025-01-17 → 2025-01-31 A (+14d) | 8d? → 18d | 0% → 100% |  |  |  |
| 1305 | Conduct User Acceptance Testing (UAT) | 2025-01-24 → 2025-01-31 A (+7d) | 2025-01-24 → 2025-01-31 A (+7d) |  | 0% → 100% | 759d → none |  |  |
| 1306 | Validate Access and Security Controls | 2025-01-20 → 2025-01-28 A (+8d) | 2025-01-23 → 2025-01-31 A (+8d) |  | 0% → 100% | 760d → none | 1300FS+5d → none | constraint finish no earlier than 2025-01-16 → finish no earlier than 2025-01-31 |
| 1307 | ServiceNow Support Portal Onboarding (Helix Suppliers& SIT Participants) Completed | 2025-01-24 → 2025-01-31 A (+7d) | 2025-01-24 → 2025-01-31 A (+7d) |  | 0% → 100% | 759d → none |  |  |
| 1308 | Stage 1 - Helix SIT Operational Readiness Completed | 2025-01-31 A | 2025-01-31 A |  | 0% → 100% | 755d → none | none → 1290, 1275, 1243 |  |
| 1310 | **Theme 3 (Batch 2)** |  |  | 65d → 64d |  |  |  |  |
| 1321 | SITAG approve Theme 3 (Batch 2) |  |  | 1d → 0d |  |  | 1320FS+4d → 1320FS+5d |  |
| 1349 | **SIT Operational Programme RTTM (Theme 3 (Batch 1))** |  | 2025-01-24 A |  | 71% → 100% | 688d → none |  | was named SIT Operational Programme RTTM |
| 1350 | Develop SIT Operational Theme 3 (Batch 1) RTTM |  |  |  |  |  |  | was named Develop Manual SIT Operational RTTM |
| 1351 | SRO review of SIT Operational Theme 3 (Batch 1) RTTM | 2025-01-13 A | 2025-01-17 A |  | 0% → 100% | 688d → none |  | was named SRO review of Manual SIT Operational RTTM |
| 1352 | DIP Manager / Code Bodies / Full SRO to review | 2025-01-20 A | 2025-01-24 A |  | 0% → 100% | 688d → none |  |  |
| 1353 | DIP Manager / Code Bodies / Full SRO acceptance of Theme 3 (Batch 1) Operational RTTM | 2025-01-24 A | 2025-01-24 A |  | 0% → 100% | 688d → none |  | was named DIP Manager / Code Bodies / Full SRO acceptance of Operational RTTM |
| 1354 | SIT Operational Theme 3 (Batch 1) RTTM Complete | 2025-01-24 A | 2025-01-24 A |  | 0% → 100% | 688d → none |  | was named Manual SIT Operational RTTM Complete |
| 1363 | **SIT Operational Theme 3 (Batch 1) DITL** |  | 2025-01-28 A |  | 33% → 100% | 757d → none |  | was named SIT Operational DITL |
| 1364 | DITL + Familiarisation session development |  | 2025-01-15 A |  | 63% → 100% | 757d → none |  |  |
| 1365 | SRO Review | 2025-01-16 A | 2025-01-22 A |  | 0% → 100% | 757d → none |  |  |
| 1366 | Post-SRO Review Changes | 2025-01-23 A | 2025-01-24 A |  | 0% → 100% | 757d → none |  |  |
| 1367 | Familiarisation session Service Management test case schedule + mapping | 2025-01-24 A | 2025-01-24 A |  | 0% → 100% | 757d → none |  |  |
| 1368 | Publish Cycle 3 DITL / Cycle 3 DITL Online Sessions for SIT PPs | 2025-01-28 A | 2025-01-28 A |  | 0% → 100% | 757d → none |  | baseline start 2025-01-29 → 2025-01-28; baseline finish 2025-01-29 → 2025-01-28 |
| 1378 | **SIT Operational Execution Model** | 2024-08-05 A → 2024-08-05 |  | 43d → 43d? | 63% → 86% |  |  |  |
| 1379 | **Theme 3 (Batch 1)** |  |  |  | 99% → 100% |  |  |  |

| ID | Task | Start | Finish | Duration | Complete | Total float | Predecessors | Other |
| --- | --- | --- | --- | --- | --- | --- | --- | --- |
| 1384 | SITWG paper day | 2025-02-05 → 2025-01-14 A (-22d) | 2025-02-05 → 2025-01-14 A (-22d) |  | 0% → 100% | 746d → none | 1152 → 1383 | baseline start 2025-02-05 → 2025-01-14; baseline finish 2025-02-05 → 2025-01-14 |
| 1385 | SITWG update on execution model | 2025-02-12 → 2025-01-21 A (-22d) | 2025-02-12 → 2025-01-21 A (-22d) |  | 0% → 100% | 746d → none |  | baseline start 2025-02-12 → 2025-01-21; baseline finish 2025-02-12 → 2025-01-21 |
| 1386 | **Theme 1, 2 and 3 (Batch 2)** |  |  | 23d → 23d? | 0% → 58% |  |  |  |
| 1387 | Develop execution model Theme 1, 2 and 3 (Batch 2) | 2025-01-13 → 2025-02-03 A (+21d) | 2025-01-15 → 2025-02-14 A (+30d) | 3d → 10d | 0% → 100% | 746d → none |  | constraint start no earlier than 2025-01-13 → start no earlier than 2025-02-03; baseline start 2025-01-13 → 2025-02-03; baseline finish 2025-01-15 → 2025-02-14 |
| 1388 | SRO provide feedback | 2025-01-16 → 2025-02-25 A (+40d) | 2025-01-22 → 2025-03-03 (+40d) |  | 0% → 90% | 746d → 718d |  | constraint none → finish no earlier than 2025-01-21; baseline start 2025-01-16 → 2025-02-17; baseline finish 2025-01-22 → 2025-02-21 |
| 1389 | Address SRO feedback on execution model | 2025-01-23 → 2025-03-04 (+40d) | 2025-01-24 → 2025-03-10 (+45d) | 2d → 5d |  | 746d → 718d |  | baseline start 2025-01-23 → 2025-02-17; baseline finish 2025-01-24 → 2025-02-21 |
| 1390 | Finalise execution model | 2025-01-27 → 2025-03-11 (+43d) | 2025-01-29 → 2025-03-17 (+47d) | 3d → 5d |  | 746d → 718d |  | baseline start 2025-01-27 → 2025-02-24; baseline finish 2025-01-29 → 2025-02-27 |
| 1392 | SITWG update on execution model | 2025-02-12 → 2025-03-24 (+40d) | 2025-02-12 → 2025-03-24 (+40d) |  |  | 746d → 718d | 1565FS+5d → 1391FS+5d | constraint none → finish no earlier than 2025-03-06; baseline start 2025-02-12 → 2025-03-06; baseline finish 2025-02-12 → 2025-03-06 |
| 1393 | **SIT Operational Theme 3 (Batch 1) progress reporting** |  |  |  | 17% → 100% |  |  |  |
| 1395 | Implement reporting | 2024-12-23 A | 2025-01-03 → 2025-01-24 A (+21d) | 10d → 25d | 0% → 100% | 774d → none |  |  |
| 1396 | **SIT Operational Overarching Test Readiness Reports** | 2024-08-05 A → 2024-08-05 |  |  | 22% → 85% |  |  |  |
| 1397 | **SI SIT Operational Theme 3 (Batch 1) Overarching Test Readiness Report** | 2024-12-18 A | 2025-01-29 A | 31d → 31d? | 0% → 100% | 755d → none |  |  |
| 1398 | Develop Overarching SIT Operational Theme 3 (Batch 1) Overarching Test Readiness Report | 2024-12-18 A | 2025-01-14 A |  | 0% → 100% | 755d → none |  | baseline start 2024-12-23 → 2024-12-18; baseline finish 2025-01-15 → 2025-01-14 |
| 1399 | SRO review | 2025-01-08 A | 2025-01-14 A |  | 0% → 100% | 755d → none |  | baseline start 2025-01-16 → 2025-01-08; baseline finish 2025-01-22 → 2025-01-14 |
| 1400 | SITWG Paper day | 2025-01-14 A | 2025-01-14 A |  | 0% → 100% | 755d → none |  | baseline start none → 2025-01-14; baseline finish none → 2025-01-14 |
| 1401 | SITWG review the Operational Theme 3 (Batch 1) Overarching Test Readiness Report | 2025-01-21 A | 2025-01-21 A |  | 0% → 100% | 755d → none |  | baseline start none → 2025-01-21; baseline finish none → 2025-01-21 |
| 1402 | Update Operational Theme 3 (Batch 1) Overarching Test Readiness Report following SRO / SITWG feedback | 2025-01-22 A | 2025-01-22 A |  | 0% → 100% | 755d → none |  | baseline start 2025-01-16 → 2025-01-22 |
| 1403 | SITAG paper day | 2025-01-22 A | 2025-01-22 A |  | 0% → 100% | 755d → none |  |  |
| 1406 | SITAG approve Theme 3 (Batch 1) Test Readiness Report | 2025-01-29 A | 2025-01-29 A |  | 0% → 100% | 755d → none | 1403FS+5d → 1403FS+5d, 1243, 1405 |  |
| 1407 | **SI SIT Operational Theme 1, 2 and 3 (Batch 2) Overarching Test Readiness Report** | 2025-01-27 A |  |  | 0% → 74% | 70d → 714d |  |  |
| 1408 | Develop Overarching SIT Operational Theme 1, 2 and 3 (Batch 2) Overarching Test Readiness Report | 2025-01-27 A | 2025-02-21 A |  | 0% → 100% | 734d → none |  |  |
| 1409 | SRO review | 2025-02-24 A | 2025-02-28 A |  | 0% → 100% | 734d → none |  |  |
| 1410 | SITWG Paper day | 2025-02-27 A | 2025-02-27 A |  | 0% → 100% | 735d → none |  | baseline start none → 2025-02-27; baseline finish none → 2025-02-27 |
| 1411 | SITWG review the Operational Theme 1, 2 and 3 (Batch 2) Overarching Test Readiness Report | 2025-03-06 A | 2025-03-06 A |  | 0% → 100% | 717d → none |  | baseline start none → 2025-03-06; baseline finish none → 2025-03-06 |
| 1412 | Update Operational Theme 1, 2 and 3 (Batch 2) Overarching Test Readiness Report following SRO feedback | 2025-03-07 A |  |  | 0% → 23% |  |  | baseline start 2025-03-03 → 2025-03-07; baseline finish 2025-03-12 → 2025-03-25 |
| 1414 | eSITAG paper day |  |  |  |  |  |  | baseline start 2025-03-12 → 2025-03-26; baseline finish 2025-03-12 → 2025-03-26 |
| 1415 | eSITAG approve Operational Theme 1, 2 and 3 (Batch 2) Overarching Test Readiness Report |  |  |  |  |  | Operational Themes 1, 2 & 3 (Batch 2) (LDSO's and DCC) Data Load, 1424 → 1413, 1423, 1424 |  |
| 1416 | SIT Operational Theme 3 (Batch 1) Testing Preparation Complete | 2025-01-30 → 2025-01-31 A (+1d) | 2025-01-30 → 2025-01-31 A (+1d) |  | 0% → 100% | 755d → none | 1406FS+1d, 1307 → 1406, 1307 | baseline start 2025-01-17 → 2025-01-31; baseline finish 2025-01-17 → 2025-01-31 |
| 1417 | SIT Operational Theme 1, 2, 3 (Batch 2) Testing Preparation Complete |  |  |  |  |  | 422, 1203, 1209, 1335, 1415 → 422, 1203, 1209, 1335, 1415, 1395, 1374, 1362, 1345 |  |
| 1418 | **Test Data - Non-Functional and Operational (SIT B)** | 2025-02-24 A |  |  | 0% → 38% | 6d → 714d |  |  |
| 1419 | **Data Load** | 2025-02-24 A |  |  | 0% → 38% | 6d → 714d |  |  |
| 1420 | Non-Functional Theme 1 (Avenade) Data Load | 2025-02-24 A | 2025-02-28 A |  | 0% → 100% | 6d → none |  |  |
| 1426 | **Regression Test Preparation** |  |  |  | 10% → 59% |  |  | baseline start 2024-09-16 → 2024-11-18; baseline finish 2025-05-16 → 2024-11-19 |
| 1427 | **Regression Test Approach** |  |  |  | 22% → 100% |  |  | baseline start 2024-09-16 → 2024-11-18; baseline finish 2024-11-20 → 2024-11-29 |
| 1428 | Develop approach doc |  | 2025-01-15 → 2025-01-17 A (+2d) | 43d → 45d | 35% → 100% | 16d → none |  | baseline finish 2024-12-13 → 2025-01-17 |
| 1429 | SRO / LDP review of approach doc | 2025-01-16 → 2025-01-20 A (+4d) | 2025-01-22 → 2025-01-24 A (+2d) |  | 0% → 100% | 16d → none |  | baseline start 2024-12-16 → 2025-01-20; baseline finish 2024-12-18 → 2025-01-24 |
| 1430 | Incorporate SRO feedback into approach doc | 2025-01-16 → 2025-01-20 A (+4d) | 2025-01-22 → 2025-01-24 A (+2d) |  | 0% → 100% | 16d → none |  | baseline start 2024-12-19 → 2025-01-20; baseline finish 2024-12-20 → 2025-01-24 |
| 1431 | Industry review of approach | 2025-01-23 → 2025-01-27 A (+4d) | 2025-02-05 → 2025-02-07 A (+2d) |  | 0% → 100% | 16d → none |  | baseline start 2025-01-20 → 2025-01-27; baseline finish 2025-01-31 → 2025-02-07 |
| 1432 | Updates to approach doc on back of industry feedback | 2025-02-06 → 2025-02-10 A (+4d) | 2025-02-11 A | 4d → 2d | 0% → 100% | 16d → none |  | baseline start 2025-02-03 → 2025-02-10 |
| 1433 | eSITWG paper day | 2025-02-11 A | 2025-02-11 A |  | 0% → 100% | 16d → none |  | baseline start 2024-12-20 → 2025-02-11; baseline finish 2024-12-20 → 2025-02-11 |
| 1434 | eSITWG Recommendation | 2025-02-18 A | 2025-02-18 A |  | 0% → 100% | 735d → none |  | baseline start 2025-01-08 → 2025-02-18; baseline finish 2025-01-08 → 2025-02-18 |
| 1435 | Incorporate eSITWG feedback into approach doc | 2025-02-19 A | 2025-02-20 A |  | 0% → 100% | 735d → none |  | baseline start 2025-01-09 → 2025-02-19; baseline finish 2025-01-09 → 2025-02-20 |
| 1436 | eSITAG paper day | 2025-02-20 A | 2025-02-20 A |  | 0% → 100% | 735d → none |  | baseline start 2025-01-09 → 2025-02-20; baseline finish 2025-01-09 → 2025-02-20 |
| 1437 | eSITAG (inc SRO) Approval | 2025-02-28 A | 2025-02-28 A |  | 0% → 100% | 734d → none |  | baseline start 2025-01-16 → 2025-02-28; baseline finish 2025-01-16 → 2025-02-28 |
| 1438 | SIT Regression Testing Approach and Plan Approval | 2025-02-28 A | 2025-02-28 A |  | 0% → 100% | 734d → none |  | baseline start 2025-01-16 → 2025-02-28; baseline finish 2025-01-16 → 2025-02-28 |
| 1439 | **Regression Core Test Pack** | 2025-02-12 A | 2025-04-16 → 2025-04-24 (+8d) | 46d → 52d? | 0% → 47% | 16d → 695d |  | was named Regression Test Suite; baseline start 2025-01-17 → 2025-02-12; baseline finish 2025-03-18 → 2025-04-16 |
| 1441 | Build Regression Framework | 2025-02-12 A | 2025-02-28 → 2025-02-27 A (-1d) | 13d → 12d | 0% → 100% | 16d → none |  | was named Build Regression Test Suite; baseline start 2025-01-17 → 2025-02-12; baseline finish 2025-02-06 → 2025-02-28 |
| 1442 | SITWG paper day | 2025-02-27 A | 2025-02-27 A | 1d → 0d | 0% → 100% | 17d → none | 1441SS → 1441 | baseline start none → 2025-02-27; baseline finish none → 2025-02-27 |
| 1443 | SITWG provides feedback on Regression Framework approach | 2025-03-06 A | 2025-03-06 A |  | 0% → 100% | 17d → none |  | was named SITWG provides feedback on regression suite approach; baseline start none → 2025-03-06; baseline finish none → 2025-03-06 |
| 1444 | LDP walkthrough of Regression Core Pack | 2025-02-28 → 2025-02-27 A (-1d) | 2025-02-28 → 2025-03-03 A (+3d) | 1d → 3d | 0% → 100% | 734d → none | 1441FF → 1440SS | was named LDP walkthrough of Regression Test Suite; constraint none → start no earlier than 2025-02-27; baseline start 2025-03-17 → 2025-02-28; baseline finish 2025-03-18 → 2025-02-28 |
| 1445 | SRO Review of Regression Core Pack | 2025-03-03 → 2025-03-07 A (+4d) | 2025-03-07 → 2025-03-14 (+7d) | 5d → 6d | 0% → 25% | 16d → 724d | 1441 → 1440SS | was named SRO Review of regression suite doc; constraint none → start no earlier than 2025-03-07; baseline start 2025-02-07 → 2025-03-03; baseline finish 2025-02-20 → 2025-03-07 |
| 1446 | Incorporate SRO feedback into Regression Core Pack | 2025-03-03 → 2025-03-07 (+4d) | 2025-03-07 → 2025-03-14 (+7d) | 5d → 6d |  | 16d → 7d | 1445SS, 1443FF → 1445SS | was named Incorporate SRO feedback into regression suite doc; baseline start 2025-02-21 → 2025-03-03; baseline finish 2025-02-27 → 2025-03-07 |
| 1447 | Industry review of Regression Core Pack | 2025-03-10 → 2025-03-17 (+7d) | 2025-03-21 → 2025-03-28 (+7d) |  |  | 16d → 7d | 1446 → 1446, 1440 | was named Industry review of Regression Test Suite; constraint none → start no earlier than 2025-03-13; baseline start 2025-03-31 → 2025-03-10; baseline finish 2025-04-11 → 2025-03-21 |
| 1450 | Incorporate Industry feedback into Regression Core Pack | 2025-03-24 → 2025-03-31 (+7d) | 2025-03-27 → 2025-04-02 (+6d) | 4d → 3d |  | 16d → 7d | 1447 → 1447, 1448, 1449 | was named Incorporate Industry feedback into regression suite doc; baseline start 2025-04-14 → 2025-03-24; baseline finish 2025-04-16 → 2025-03-28 |
| 1452 | Incorporate industry feedback into regression Core Pack | 2025-04-04 → 2025-04-10 (+6d) | 2025-04-04 → 2025-04-10 (+6d) |  |  | 16d → 7d | SITWG endorses regression suite doc → 1451 | was named Incorporate SITWG feedback into regression suite doc; baseline start 2025-03-07 → 2025-04-07; baseline finish 2025-03-11 → 2025-04-08 |
| 1458 | eSITAG paper day | 2025-04-09 → 2025-04-17 (+8d) | 2025-04-09 → 2025-04-17 (+8d) |  |  | 13d → 7d | 1452 → 1455 | baseline start 2025-03-11 → 2025-04-17; baseline finish 2025-03-11 → 2025-04-17 |
| 1459 | eSITAG (inc SRO) Approval of regression Core Pack | 2025-04-16 → 2025-04-24 (+8d) | 2025-04-16 → 2025-04-24 (+8d) |  |  | 13d → 7d | 1458FS+5d → 1458FS+5d, 1457 | was named eSITAG (inc SRO) Approval of regression suite doc; baseline start 2025-03-18 → 2025-04-24; baseline finish 2025-03-18 → 2025-04-24 |
| 1460 | SIT Regression Approval | 2025-04-16 → 2025-04-24 (+8d) | 2025-04-16 → 2025-04-24 (+8d) |  |  | 13d → 7d |  | baseline start 2025-03-18 → 2025-04-24; baseline finish 2025-03-18 → 2025-04-24 |
| 1463 | Regression Test Data Load Start |  |  | 0d? → 0d |  |  |  |  |
| 1465 | **Single Instance ADO** |  | 2024-10-03 A |  | 98% → 100% | 840d → none |  |  |
| 1485 | **Reporting Changes - PowerBI & QIP** |  | 2024-09-24 A |  | 70% → 100% | 847d → none |  |  |
| 1514 | **SIT Execution** | 2022-10-31 A → 2023-10-30 A (+364d) | 2025-11-27 → 2025-11-26 (-1d) | 804d? → 543d? | 36% → 51% | 540d → 541d |  |  |
| 1531 | **SIT - Minimum Viable Cohort (MVC)** | 2022-10-31 A → 2024-03-11 A (+497d) |  | 735d? → 380d? | 35% → 54% |  |  |  |
| 1532 | **SIT Functional Testing (MVC)** | 2022-10-31 A → 2024-03-11 A (+497d) |  | 730d? → 375d? | 49% → 64% |  |  |  |
| 1534 | **SIT Functional Testing Execution (Minimum Viable Cohort)** | 2022-10-31 A → 2024-03-11 A (+497d) | 2025-08-15 → 2025-04-28 (-109d) | 730d? → 296d? | 49% → 88% | 614d → 693d |  |  |
| 1541 | **SIT Functional Testing back-up progress risk-assessment** | 2022-10-31 → 2024-10-07 A (+707d) | 2022-10-31 → 2024-10-15 A (+715d) | 0d → 7d? | 0% → 100% | 1344d → none |  |  |
| 1542 | Back-up risk-assessment of SIT Functional progress to assess whether Qualification Execution can start early | 2024-10-07 A | 2024-10-25 → 2024-10-07 A (-18d) | 15d → 1d? | 0% → 100% | 819d → none |  | baseline finish 2024-10-25 → 2024-10-07 |
| 1543 | Back-up SITAG decision on early Qualification Testing Execution start | 2024-11-01 → 2024-10-15 A (-17d) | 2024-11-01 → 2024-10-15 A (-17d) | 0d → 1d? | 0% → 100% | 819d → none |  | baseline start 2024-11-01 → 2024-10-15; baseline finish 2024-11-01 → 2024-10-15 |
| 1544 | **Cycle 3 (Defect retests and targeted regression testing)** |  |  |  | 41% → 74% |  |  |  |
| 1550 | Sprint 9 |  | 2025-01-17 A |  | 10% → 100% | 5d → none |  |  |

| ID | Task | Start | Finish | Duration | Complete | Total float | Predecessors | Other |
| --- | --- | --- | --- | --- | --- | --- | --- | --- |
| 1551 | Sprint 10 | 2025-01-20 A | 2025-01-31 A |  | 0% → 100% | 5d → none |  |  |
| 1552 | Sprint 11 | 2025-02-03 A | 2025-02-14 A |  | 0% → 100% | 5d → none |  |  |
| 1553 | Sprint 12 | 2025-02-17 A | 2025-02-28 A |  | 0% → 100% | 5d → none |  |  |
| 1554 | Sprint 13 (RTTM Gap Analysis + CR056) | 2025-03-03 A |  |  | 0% → 50% |  |  |  |
| 1558 | SIT Functional Cycle 3 Complete |  |  |  |  |  |  | baseline start none → 2025-04-28; baseline finish none → 2025-04-28 |
| 1565 | SITWG paper day | 2025-02-05 → 2025-04-08 (+62d) | 2025-02-05 → 2025-04-08 (+62d) |  |  | 746d → 695d | 1159 → 1563FS+35d | baseline start 2025-02-05 → 2025-04-08; baseline finish 2025-02-05 → 2025-04-08 |
| 1571 | **SIT Functional Settlement Testing** |  |  |  | 35% → 36% |  |  |  |
| 1572 | SIT-B Settlement Testing Cycle 2 | 2025-03-10 A |  |  | 0% → 5% |  |  | baseline start 2024-06-17 → 2025-03-10; baseline finish 2024-09-20 → 2025-06-13 |
| 1573 | **SIT-B Settlement Testing Cycle 3** |  | 2025-02-21 A |  | 68% → 100% | 664d → none | 1214 → none |  |
| 1574 | Sprint 5 |  |  |  |  |  | none → 1214 |  |
| 1582 | Sprint 9 |  | 2025-01-17 A |  | 50% → 100% | 6d → none |  |  |
| 1583 | Sprint 9 Review | 2025-01-20 A | 2025-01-20 A |  | 0% → 100% | 688d → none |  |  |
| 1584 | Sprint 10 | 2025-01-20 A | 2025-01-31 A |  | 0% → 100% | 6d → none |  |  |
| 1585 | Sprint 10 Review | 2025-02-03 A | 2025-02-03 A |  | 0% → 100% | 678d → none |  |  |
| 1586 | Sprint 11 | 2025-02-03 A | 2025-02-14 A |  | 0% → 100% | 6d → none |  |  |
| 1587 | Sprint 11 Review | 2025-02-14 A | 2025-02-14 A |  | 0% → 100% | 6d → none |  |  |
| 1588 | Sprint 12 | 2025-02-17 A | 2025-02-21 A |  | 0% → 100% | 6d → none |  |  |
| 1589 | End of Settlement Testing Cycle 3 | 2025-02-21 A | 2025-02-21 A |  | 0% → 100% | 6d → none |  |  |
| 1590 | **SIT-A Settlement Testing** |  | 2025-06-13 → 2025-06-16 (+3d) | 20d? → 20d |  |  | 1464 → none | was named SIT-A CoS Settlement Testing |
| 1596 | Regression Test Execution Start |  |  | 1d → 0d |  | 658d → 5d | 1464, 1590 → 1464FS+2d, 1594FS+2d |  |
| 1598 | Regression Sprint 1 | 2025-06-16 → 2025-06-23 (+7d) | 2025-06-27 → 2025-07-04 (+7d) |  |  |  | 1590, 1458 → 1597 | baseline start 2025-06-16 → 2025-06-23; baseline finish 2025-06-27 → 2025-07-04 |
| 1599 | Regression Sprint 2 | 2025-06-30 → 2025-07-07 (+7d) |  | 15d → 10d |  |  |  | baseline start 2025-06-30 → 2025-07-07 |
| 1600 | Regression Sprint 3 |  | 2025-08-08 → 2025-08-01 (-7d) | 15d → 10d |  |  |  | baseline finish 2025-08-08 → 2025-08-01 |
| 1602 | SIT Functional Testing End (Minimum Viable Cohort) (incl. confirmation that PPs have submitted their Test Completion Reports to Programme for assurance) |  |  |  |  |  | 1600 → 1601 |  |
| 1605 | Develop document |  |  |  |  |  |  | constraint none → start no earlier than 2025-07-21 |
| 1608 | **Helix E2E Settlement Assurance Testing (SAT)** | 2025-02-07 → 2024-08-19 A (-172d) | 2025-06-06 → 2025-07-03 (+27d) | 86d? → 229d? | 0% → 58% | 664d → 645d |  | was named Helix E2E Settlement Testing |
| 1640 | **SIT Migration Testing (MVC)** |  | 2025-08-22 → 2025-08-08 (-14d) | 380d? → 370d? | 54% → 67% | 609d → 619d |  |  |
| 1641 | SIT Migration Testing Start | 2024-03-11 A | 2024-03-11 A |  | 0% → 100% | 989d → none |  |  |
| 1642 | **SIT Migration Testing Execution (Minimum Viable Cohort)** |  | 2025-08-22 → 2025-08-08 (-14d) | 380d? → 370d? | 54% → 67% | 609d → 619d |  |  |
| 1649 | **SIT Migration Testing back-up progress risk-assessment** |  |  |  | 0% → 100% |  |  | was named SIT Functional Testing back-up progress risk-assessment |
| 1650 | Back-up risk-assessment of SIT Migration progress to assess whether Qualification Execution can start early | 2024-10-07 A | 2024-10-25 A |  | 0% → 100% | 819d → none |  |  |
| 1651 | Back-up SITAG decision on early Qualification Testing Execution start | 2024-11-01 A | 2024-11-01 A |  | 0% → 100% | 819d → none |  |  |
| 1652 | **Cycle 3 (Defect retests and targeted regression testing)** |  |  |  | 41% → 70% |  |  |  |
| 1658 | Sprint 9 |  | 2025-01-17 A |  | 10% → 100% | 5d → none |  |  |
| 1659 | Sprint 10 | 2025-01-20 A | 2025-01-31 A |  | 0% → 100% | 5d → none |  |  |
| 1660 | Sprint 11 | 2025-02-03 A | 2025-02-14 A |  | 0% → 100% | 5d → none |  |  |
| 1661 | Sprint 12 | 2025-02-17 A | 2025-02-28 A |  | 0% → 100% | 5d → none |  |  |
| 1667 | **SIT Migration MVC Regression Testing (code freeze)** |  | 2025-08-01 → 2025-08-08 (+7d) | 35d? → 40d? |  | 609d → 619d |  |  |
| 1670 | Regression Sprint 1 | 2025-06-16 → 2025-06-23 (+7d) | 2025-06-27 → 2025-07-04 (+7d) | 10d? → 10d |  | 609d → 619d | 1590 → 1669 | baseline start 2025-06-16 → 2025-06-23; baseline finish 2025-06-27 → 2025-07-04 |
| 1671 | Regression Sprint 2 | 2025-06-30 → 2025-07-07 (+7d) | 2025-07-11 → 2025-07-18 (+7d) |  |  | 609d → 619d |  | baseline start 2025-06-30 → 2025-07-07; baseline finish 2025-07-11 → 2025-07-18 |
| 1672 | Regression Sprint 3 | 2025-07-14 → 2025-07-21 (+7d) |  | 15d? → 10d |  | 609d → 619d |  |  |
| 1674 | SIT Migration Testing End (Minimum Viable Cohort) (incl. confirmation that PPs have submitted their Test Completion Reports to Programme for assurance) | 2025-08-01 → 2025-08-08 (+7d) | 2025-08-01 → 2025-08-08 (+7d) |  |  | 609d → 619d | 1672 → 1673 | baseline start 2025-08-01 → 2025-08-08; baseline finish 2025-08-01 → 2025-08-08 |
| 1675 | **SIT Migration Test Completion Report (Minimum Viable Cohort)** | 2025-07-14 → 2024-06-04 (-405d) | 2025-08-15 → 2024-07-08 (-403d) |  |  | 609d → 898d |  |  |
| 1676 | Develop document | 2025-07-14 → 2024-06-04 (-405d) | 2025-08-01 → 2024-06-24 (-403d) |  |  | 609d → 898d | 1674FF → none |  |
| 1677 | Review & agree document | 2025-08-04 → 2024-06-25 (-405d) | 2025-08-08 → 2024-07-01 (-403d) |  |  | 609d → 898d |  |  |
| 1678 | SIT Migration Testing Test Completion Report (Minimum Viable Cohort) Approved | 2025-08-15 → 2024-07-08 (-403d) | 2025-08-15 → 2024-07-08 (-403d) |  |  | 609d → 898d |  |  |
| 1679 | SIT Migration Testing End (Minimum Viable Cohort) (incl. confirmation that PPs have submitted their Test Completion Reports to Programme for assurance) | 2025-08-15 → 2025-03-14 (-154d) | 2025-08-15 → 2025-03-14 (-154d) |  |  | 609d → 720d |  |  |
| 1680 | Assurance of PPs Test Completion Reports | 2025-07-14 → 2025-02-07 (-157d) | 2025-08-22 → 2025-03-20 (-155d) |  |  | 609d → 720d |  |  |
| 1681 | **SIT Non-Functional Testing (all SIT PPs)** | 2025-03-03 A | 2025-06-05 → 2025-06-06 (+1d) | 69d? → 70d? | 0% → 11% | 6d → 60d |  |  |
| 1682 | Theme 1 (Helix and DIP Volume Testing) Start | 2025-03-03 A | 2025-03-03 A |  | 0% → 100% | 6d → none |  |  |
| 1683 | Theme 1 (Helix and DIP Volume Testing) Execution | 2025-03-03 A | 2025-03-21 A |  | 0% → 100% | 6d → none |  |  |
| 1684 | Theme 2 SIT Non-Functional Testing Start | 2025-03-27 → 2025-03-31 (+4d) | 2025-03-27 → 2025-03-31 (+4d) |  |  | 101d → 99d | 1164, 1539, 1098, 1102, 1109, 1115, 1121, Non-Functional Themes 2 & 3 (LDSO's and DCC) Data Load, 1589, 1183FS+1d → 1539, 1098, 1102, 1109, 1115, 1121, 1589, 1183FS+2d, 1422, 1164 |  |
| 1685 | Theme 2 SIT Non-Functional Testing Execution | 2025-03-27 → 2025-03-31 (+4d) | 2025-05-21 → 2025-05-23 (+2d) |  |  | 62d → 60d |  | baseline start 2025-05-01 → 2025-03-31; baseline finish 2025-06-25 → 2025-05-23 |
| 1686 | Theme 3 SIT Non-Functional Testing Start | 2025-03-27 → 2025-03-31 (+4d) | 2025-03-27 → 2025-03-31 (+4d) |  |  | 62d → 60d | Non-Functional Themes 2 & 3 (LDSO's and DCC) Data Load, 1183 → 1183FS+1d, 1422 |  |
| 1687 | Theme 3 SIT Non-Functional Testing Execution | 2025-03-27 → 2025-03-31 (+4d) | 2025-05-21 → 2025-05-23 (+2d) |  |  | 62d → 60d |  | baseline start 2025-05-02 → 2025-03-31; baseline finish 2025-06-26 → 2025-05-23 |
| 1689 | Assurance of PPs Test Completion Reports | 2025-05-02 → 2025-05-05 (+3d) | 2025-05-29 → 2025-05-30 (+1d) |  |  | 61d → 60d |  |  |
| 1690 | **SIT Non-Functional Testing Test Completion Report (all SIT PPs)** | 2025-05-02 → 2025-05-05 (+3d) | 2025-05-29 → 2025-05-30 (+1d) |  |  | 61d → 60d |  |  |
| 1691 | Develop document | 2025-05-02 → 2025-05-05 (+3d) |  |  |  | 61d → 60d |  |  |
| 1692 | Review & agree document | 2025-05-23 → 2025-05-26 (+3d) | 2025-05-29 → 2025-05-30 (+1d) |  |  | 61d → 60d |  |  |
| 1693 | SIT Non-Functional Testing Test Completion Report (all SIT PPs) Approved | 2025-06-05 → 2025-06-06 (+1d) | 2025-06-05 → 2025-06-06 (+1d) |  |  | 61d → 60d |  |  |
| 1694 | **SIT Operational Testing (all SIT PPs)** | 2025-02-03 A |  |  | 0% → 3% |  |  |  |
| 1695 | **Non-SIT B Testing** | 2025-02-03 A |  |  | 0% → 15% |  |  |  |
| 1696 | SIT Operational Testing Start (Theme 3 - Batch 1 (Service Management)) | 2025-02-03 A | 2025-02-03 A |  | 0% → 100% | 115d → none |  |  |
| 1697 | SIT Operational Testing Execution Window (Theme 3 - Batch 1 (Service Management)) | 2025-02-03 A |  |  | 0% → 15% |  |  |  |
| 1699 | SIT Operational Testing Start (SIT B) |  |  |  |  |  | 1417, 1192, 1196, 1203, 1209, 1335, Operational Themes 1, 2 & 3 (Batch 2) (LDSO's and DCC) Data Load, 1424, 1415FS+1d → 1417, 1192, 1196, 1203, 1209, 1335, 1415FS+1d, 1423, 1424 |  |
| 1713 | **SIT (non-MVC)** | 2025-06-16 A → 2025-06-13 (-3d) | 2025-11-27 → 2025-11-26 (-1d) |  | 10% → 0% | 29d → 505d |  |  |
| 1714 | **SIT Functional Testing (non-MVC)** | 2025-06-16 → 2025-06-13 (-3d) | 2025-11-14 → 2025-11-13 (-1d) |  |  | 29d → 505d |  |  |
| 1715 | **SIT Functional Testing Execution (non-MVC)** | 2025-06-16 → 2025-06-13 (-3d) | 2025-10-24 → 2025-10-23 (-1d) |  |  | 29d → 505d |  |  |
| 1716 | Test Execution (Cycle 3 Completion and Regression Testing) | 2025-06-16 → 2025-06-13 (-3d) | 2025-10-24 → 2025-10-23 (-1d) |  |  | 29d → 505d | 1590 → 1594 |  |
| 1717 | SIT Functional Testing End (non-MVC) (incl. confirmation that PPs have submitted their Test Completion Reports to Programme for assurance) | 2025-10-24 → 2025-10-23 (-1d) | 2025-10-24 → 2025-10-23 (-1d) |  |  | 29d → 505d |  |  |

| ID | Task | Start | Finish | Duration | Complete | Total float | Predecessors | Other |
| --- | --- | --- | --- | --- | --- | --- | --- | --- |
| 1718 | Assurance of PPs Test Completion Reports | 2025-11-03 → 2025-10-31 (-3d) | 2025-11-07 → 2025-11-06 (-1d) |  |  | 29d → 505d |  |  |
| 1719 | **SIT Functional Testing Test Completion Report (non-MVC)** | 2025-10-06 → 2025-10-03 (-3d) | 2025-11-07 → 2025-11-06 (-1d) |  |  | 29d → 505d |  |  |
| 1720 | Develop document | 2025-10-06 → 2025-10-03 (-3d) | 2025-10-24 → 2025-10-23 (-1d) |  |  | 34d → 510d |  |  |
| 1721 | Review & agree document | 2025-11-03 → 2025-10-31 (-3d) | 2025-11-07 → 2025-11-06 (-1d) |  |  | 29d → 505d |  |  |
| 1722 | SIT Functional Testing Test Completion Report (non-MVC) Approved | 2025-11-14 → 2025-11-13 (-1d) | 2025-11-14 → 2025-11-13 (-1d) |  |  | 29d → 505d |  |  |
| 1723 | **SIT Migration Testing (non-MVC)** | 2025-06-16 A → 2025-06-13 (-3d) | 2025-11-14 → 2025-11-13 (-1d) |  | 23% → 0% | 29d → 505d |  |  |
| 1724 | Test Execution (Cycle 3 Completion and Regression Testing) | 2025-06-16 A → 2025-06-13 (-3d) | 2025-10-24 → 2025-10-23 (-1d) |  | 28% → 0% | 29d → 505d | 1590 → 1594 |  |
| 1725 | SIT Migration Testing End (non-MVC) (incl. confirmation that PPs have submitted their Test Completion Reports to Programme for assurance) | 2025-10-24 → 2025-10-23 (-1d) | 2025-10-24 → 2025-10-23 (-1d) |  |  | 29d → 505d |  |  |
| 1726 | Assurance of PPs Test Completion Reports | 2025-11-03 → 2025-10-31 (-3d) | 2025-11-07 → 2025-11-06 (-1d) |  |  | 29d → 505d |  |  |
| 1727 | **SIT Migration Testing Test Completion Report (non-MVC)** | 2025-10-06 → 2025-10-03 (-3d) | 2025-11-07 → 2025-11-06 (-1d) |  |  | 29d → 505d |  |  |
| 1728 | Develop document | 2025-10-06 → 2025-10-03 (-3d) | 2025-10-24 → 2025-10-23 (-1d) |  |  | 34d → 510d |  |  |
| 1729 | Review & agree document | 2025-11-03 → 2025-10-31 (-3d) | 2025-11-07 → 2025-11-06 (-1d) |  |  | 29d → 505d |  |  |
| 1730 | SIT Migration Testing Test Completion Report (non-MVC Approved) | 2025-11-14 → 2025-11-13 (-1d) | 2025-11-14 → 2025-11-13 (-1d) |  |  | 29d → 505d |  |  |
| 1731 | **SIT non-MVC Test Exit Report** | 2025-10-27 → 2025-10-24 (-3d) | 2025-11-21 → 2025-11-20 (-1d) |  |  | 29d → 505d |  |  |
| 1732 | Develop document | 2025-10-27 → 2025-10-24 (-3d) | 2025-11-14 → 2025-11-13 (-1d) |  |  | 29d → 505d |  |  |
| 1733 | Review & agree document | 2025-11-17 → 2025-11-14 (-3d) | 2025-11-21 → 2025-11-20 (-1d) |  |  | 29d → 505d |  |  |
| 1734 | SIT non-MVC Complete | 2025-11-27 → 2025-11-26 (-1d) | 2025-11-27 → 2025-11-26 (-1d) |  |  | 29d → 505d |  |  |
| 1736 | **Test Artefact Development** |  | 2025-04-16 → 2025-04-17 (+1d) | 556d? → 557d? | 51% → 49% | 701d → 700d |  |  |
| 1737 | **E2E Sandbox Guidance** |  | 2025-03-24 → 2025-04-17 (+24d) | 539d? → 557d? | 71% → 72% | 718d → 700d |  |  |
| 1741 | Update E2E Sandbox guidance to reflect CR055 | 2025-01-13 A | 2025-02-20 → 2025-03-14 (+22d) | 29d → 45d | 0% → 25% | 718d → 713d |  | was named Update E2E Sandbox guidance to reflect CR55; constraint start no earlier than 2025-01-13 → finish no earlier than 2025-03-14 |
| 1742 | Internal SI review | 2025-02-21 → 2025-03-17 (+24d) | 2025-02-27 → 2025-03-21 (+22d) |  |  | 718d → 713d |  | constraint none → start no earlier than 2025-03-17 |
| 1743 | SRO / Code Bodies review | 2025-02-28 → 2025-03-24 (+24d) | 2025-03-06 → 2025-03-28 (+22d) |  |  | 718d → 713d |  | constraint none → finish no earlier than 2025-03-28 |
| 1744 | Submit version to QWG | 2025-03-07 → 2025-04-01 (+25d) | 2025-03-11 → 2025-04-01 (+21d) | 3d → 0d |  | 718d → 711d |  | constraint none → finish no earlier than 2025-04-01 |
| 1745 | Artefact Recommendation for Approval (via QWG) | 2025-03-11 → 2025-04-08 (+28d) | 2025-03-11 → 2025-04-08 (+28d) |  |  | 718d → 706d |  | was named Artefact Approval (via QWG); constraint none → finish no earlier than 2025-04-08 |
| 1746 | Final Document updates post QWG review | 2025-03-13 → 2025-04-09 (+27d) | 2025-03-13 → 2025-04-09 (+27d) |  |  | 718d → 706d | 1745FS+1d → 1745 | constraint none → start no earlier than 2025-04-09 |
| 1747 | Submit final version to QAG | 2025-03-17 → 2025-04-10 (+24d) | 2025-03-17 → 2025-04-10 (+24d) |  |  | 718d → 701d | 1746FS+1d → none | constraint none → finish no earlier than 2025-04-10 |
| 1748 | E2E Sandbox guidance update approved at QAG | 2025-03-24 → 2025-04-17 (+24d) | 2025-03-24 → 2025-04-17 (+24d) |  |  | 718d → 700d | 1747FS+4d → 1747FS+3d | was named E2E Sandbox guidance update approved; constraint none → finish no earlier than 2025-04-17 |
| 1749 | **E2E Sandbox Test Data Approach & Plan** |  |  | 68d → 68d? |  |  |  |  |
| 1823 | **SIT PPs Early Sandbox Testing Execution (SIT-A)** | 2025-08-08 → 2025-08-01 (-7d) | 2025-10-24 → 2025-10-17 (-7d) |  |  | 564d → 569d |  |  |
| 1824 | SIT PPs E2E Sandbox Testing Start | 2025-08-08 → 2025-08-01 (-7d) | 2025-08-08 → 2025-08-01 (-7d) |  |  | 619d → 624d |  |  |
| 1825 | SIT PPs E2E Sandbox Testing Execution | 2025-08-08 → 2025-08-01 (-7d) | 2025-10-24 → 2025-10-17 (-7d) |  |  | 564d → 569d |  |  |
| 1826 | **System Integration Testing - Tier 1 Milestones** | 2025-02-28 → 2025-01-06 A (-53d) |  | 214d? → 253d? | 0% → 84% | 154d → 521d |  |  |
| 1827 | **M10 Checkpoint** | 2025-02-28 → 2025-01-06 A (-53d) | 2025-02-28 → 2025-04-02 (+33d) | 1d? → 63d? | 0% → 84% | 734d → 711d | 1852FS-149d → none |  |
| 1864 | **NON SIT LDSO QUALIFICATION** |  |  |  | 65% → 84% |  |  |  |
| 1910 | **Test Data** |  |  |  | 65% → 84% |  |  |  |
| 1917 | Test Data Loaded |  | 2024-12-06 A |  | 90% → 100% | 679d → none |  |  |
| 1918 | Test Data Signed Off | 2024-12-06 A | 2024-12-06 A |  | 0% → 100% | 679d → none |  |  |
| 1919 | Test Execution Data Support | 2024-12-09 A |  |  | 0% → 50% |  |  |  |
| 1924 | **Pre-Integration Testing** |  | 2025-01-24 → 2025-01-31 (+7d) | 258d → 263d | 84% → 86% | 759d → 754d |  |  |
| 1928 | PIT Execution (Functional and Migration) |  | 2024-11-29 A |  | 90% → 100% |  |  |  |
| 1929 | PIT Execution (Non-Functional and Operational) |  | 2025-01-24 → 2025-01-31 (+7d) | 90d → 95d | 23% → 33% | 759d → 754d |  | constraint none → finish no earlier than 2025-01-31; baseline finish 2025-01-24 → 2025-01-31 |
| 1930 | Non-SIT LDSO Participants have submitted functional PIT Test Completion Report & evidence for QT Entry​ | 2024-11-29 A | 2024-11-29 A |  | 0% → 100% | 799d → none |  |  |
| 1931 | Non-SIT LDSO Participants have submitted non-functional PIT Test Completion Report | 2025-01-24 → 2025-01-31 (+7d) | 2025-01-24 → 2025-01-31 (+7d) |  |  | 759d → 754d |  | baseline start 2025-01-27 → 2025-01-31; baseline finish 2025-01-27 → 2025-01-31 |
| 1951 | **Test Readiness** |  | 2024-12-20 A |  | 90% → 100% | 784d → none |  |  |
| 1954 | LDSO Update Readiness Report & Final Assurance by Programme |  | 2024-12-12 A |  | 95% → 100% | 10d → none |  |  |
| 1955 | Final Test Readiness Report Submitted to MHHS Programme | 2024-12-13 A | 2024-12-13 A |  | 0% → 100% | 784d → none |  |  |
| 1956 | Final Programme Assurance of LDSO Test Readiness | 2024-12-13 A | 2024-12-20 A |  | 0% → 100% | 10d → none |  |  |
| 1957 | Qualification Testing for Non-SIT LDSOs (Functional, Migration, NFT, Operational) Programme Test Readiness confirmed | 2024-12-20 A | 2024-12-20 A |  | 0% → 100% | 784d → none |  |  |
| 1958 | Qualification Testing for Non-SIT LDSOs (Functional, Migration, NFT, Operational) Test Readiness Confirmed (Final Test Readiness Review for LDSO) | 2024-12-20 A | 2024-12-20 A |  | 0% → 100% | 10d → none |  |  |
| 1959 | **Test Window** |  |  |  | 0% → 62% |  |  |  |
| 1960 | **All Non-SIT LDSOs Qualification Testing** |  |  |  | 0% → 68% |  |  |  |
| 1962 | LDSO Alpha |  |  |  | 1% → 75% |  |  |  |
| 1963 | LDSO Bravo | 2025-01-06 A |  |  | 0% → 64% |  |  |  |
| 1964 | LDSO Charlie | 2025-01-06 A |  |  | 0% → 74% |  |  |  |
| 1965 | LDSO Delta |  |  |  | 1% → 61% |  |  |  |
| 1966 | LDSO Echo | 2025-01-06 A |  |  | 0% → 81% |  |  |  |
| 1967 | LDSO Foxtrot | 2025-01-20 A |  |  | 0% → 12% |  |  |  |
| 1968 | LDSO Golf | 2025-01-06 A |  |  | 0% → 97% |  |  |  |
| 1969 | LDSO Hotel |  |  |  | 1% → 67% |  |  |  |
| 1970 | LDSO India |  |  |  | 1% → 64% |  |  |  |
| 1980 | **S & A QUALIFICATION** |  |  |  | 56% → 60% |  |  |  |
| 2042 | **MHHS Qualification - SIT Participants** |  | 2025-12-18 → 2025-12-17 (-1d) | 249d → 248d | 0% → 21% | 29d → 505d |  |  |
| 2044 | SIT Participants submit Initial QAD | 2025-01-06 A | 2025-02-14 A |  | 0% → 100% | 60d → none |  |  |
| 2045 | Code Bodies review Initial QAD | 2025-02-14 A |  |  | 0% → 50% |  |  |  |
| 2053 | **MHHS Qualification - SIT Non-MVC Participants** |  | 2025-12-18 → 2025-12-17 (-1d) | 154d → 153d |  | 29d → 505d |  |  |
| 2057 | QAD Sign Off Deadline (Non-MVC) | 2025-11-28 → 2025-11-27 (-1d) | 2025-11-28 → 2025-11-27 (-1d) |  |  | 29d → 505d |  |  |
| 2058 | REC Code Manager / BSC PAB Approval of Qualification (Non-MVC) | 2025-12-18 → 2025-12-17 (-1d) | 2025-12-18 → 2025-12-17 (-1d) |  |  | 29d → 505d |  |  |
| 2059 | **MHHS Qualification - Non-SIT LDSO** |  |  |  | 0% → 40% |  |  |  |
| 2061 | Non-SIT LDSO Participants submit initial QAD | 2025-01-06 A | 2025-02-14 A |  | 0% → 100% | 58d → none |  |  |
| 2062 | Non-SIT LDSO QT Participants have submitted their initial QAD | 2025-02-14 A | 2025-02-14 A |  | 0% → 100% | 58d → none |  |  |

| ID | Task | Start | Finish | Duration | Complete | Total float | Predecessors | Other |
| --- | --- | --- | --- | --- | --- | --- | --- | --- |
| 2063 | Code Bodies review of Non-SIT LDSO participants Initial QAD | 2025-02-17 A |  |  | 0% → 50% | 58d → 83d |  |  |
| 2066 | Non-SIT LDSO Participants submit Final QAD | 2025-04-21 → 2025-04-07 (-14d) |  | 25d → 35d |  |  | 1974SS, 2065SS → 2065SS-1d |  |
| 2071 | **MHHS Qualification - Qualification Waves** |  |  |  | 53% → 57% |  |  |  |
| 2072 | **Qualification Wave Prep** |  | 2026-01-08 → 2026-02-06 (+29d) | 539d? → 560d? | 86% → 93% | 510d → 489d |  |  |
| 2104 | **QT Functional (inc NF and Operational) Test Scenarios and Test Cases** |  | 2025-01-30 → 2025-02-20 A (+21d) | 63d → 77d | 54% → 100% | 736d → none |  |  |
| 2106 | Issue Batch 3 for Consultation |  | 2024-12-16 A |  | 70% → 100% | 736d → none |  |  |
| 2107 | Update Batch 3 Post Consultation | 2024-12-17 A | 2025-01-13 A |  | 0% → 100% | 736d → none |  |  |
| 2108 | QWG Endorsement of Batch 3 | 2025-01-22 → 2025-02-11 A (+20d) | 2025-01-22 → 2025-02-11 A (+20d) |  | 0% → 100% | 736d → none | 2107FS+7d → 2107FS+21d | baseline start 2025-01-22 → 2025-02-11; baseline finish 2025-01-22 → 2025-02-11 |
| 2109 | QAG Approval of QT Functional Test Scenarios and Test Cases Batches 3 | 2025-01-30 → 2025-02-20 A (+21d) | 2025-01-30 → 2025-02-20 A (+21d) |  | 0% → 100% | 736d → none |  | constraint none → start no earlier than 2025-02-20; baseline start 2025-01-30 → 2025-02-20; baseline finish 2025-01-30 → 2025-02-20 |
| 2110 | **Qualification Testing Framework (Test Stubs and Supporting UI)** |  | 2026-01-08 → 2026-02-06 (+29d) | 509d? → 530d? | 84% → 92% | 510d → 489d |  |  |
| 2124 | QTF Test Cases DBT Refinement, Execution and Results Validation, Defect Management, Error Handling |  | 2025-01-31 → 2025-02-20 A (+20d) | 64d → 77d | 75% → 100% | 735d → none |  | baseline finish 2025-01-31 → 2025-02-20 |
| 2125 | **Environments** |  |  |  | 98% → 99% |  |  |  |
| 2143 | **QTF Deployment into Production** | 2025-02-03 → 2025-02-20 A (+17d) | 2025-02-27 → 2025-03-18 (+19d) |  | 0% → 74% | 735d → 722d |  |  |
| 2144 | App Deployment | 2025-02-03 → 2025-02-20 A (+17d) | 2025-02-07 → 2025-02-26 A (+19d) |  | 0% → 100% | 735d → none |  | baseline start 2025-02-03 → 2025-02-20; baseline finish 2025-02-07 → 2025-02-26 |
| 2145 | Smoke Test | 2025-02-10 → 2025-02-27 A (+17d) | 2025-02-11 → 2025-02-28 A (+17d) |  | 0% → 100% | 735d → none |  | baseline start 2025-02-10 → 2025-02-27; baseline finish 2025-02-11 → 2025-02-28 |
| 2146 | PEN Test | 2025-02-12 → 2025-03-03 A (+19d) | 2025-02-13 → 2025-03-04 A (+19d) |  | 0% → 100% | 735d → none |  | baseline start 2025-02-12 → 2025-03-03; baseline finish 2025-02-13 → 2025-03-04 |
| 2147 | Regression Test | 2025-02-14 → 2025-03-05 A (+19d) | 2025-02-27 → 2025-03-18 (+19d) |  | 0% → 50% | 735d → 722d |  | baseline start 2025-02-14 → 2025-03-05; baseline finish 2025-02-27 → 2025-03-18 |
| 2176 | **MPANs, DIP Messages, Settlement, Consumption, Reference** |  |  |  | 65% → 80% |  |  |  |
| 2196 | **BETA Testing 1 - Test Data** |  |  |  | 58% → 100% |  |  |  |
| 2206 | **BETA Testing 2 - Test Data** |  | 2025-01-22 A |  | 16% → 100% |  |  |  |
| 2208 | Load Example MPAN File |  | 2025-01-20 A |  | 20% → 100% | 761d → none |  |  |
| 2209 | Industry Standing Data (ISD) | 2025-01-08 A | 2025-01-15 A |  | 0% → 100% | 765d → none |  |  |
| 2210 | Market Domain Data (MDD) | 2025-01-08 A | 2025-01-15 A |  | 0% → 100% | 765d → none |  |  |
| 2211 | Load ISD / MDD Data | 2025-01-16 A | 2025-01-16 A |  | 0% → 100% | 765d → none |  |  |
| 2212 | Create QTC sets and Test MPANs via QTF | 2025-01-21 A | 2025-01-21 A |  | 0% → 100% | 761d → none |  |  |
| 2213 | Create QTC sets in ADO via QTF | 2025-01-21 A | 2025-01-21 A |  | 0% → 100% | 762d → none |  |  |
| 2214 | Provide Test MPANs (Suppliers only) allocated to specfic QTC's | 2025-01-21 A | 2025-01-21 A |  | 0% → 100% | 761d → none |  |  |
| 2215 | Load Test MPANs | 2025-01-22 A | 2025-01-22 A |  | 0% → 100% | 761d → none |  |  |
| 2217 | Test Data Request + Templates Completed | 2025-04-21 → 2025-06-02 (+42d) | 2025-05-12 → 2025-06-06 (+25d) | 16d → 5d |  | 653d → 440d |  | constraint finish no earlier than 2025-05-12 → start no earlier than 2025-06-02; baseline start 2025-04-21 → 2025-06-02; baseline finish 2025-05-12 → 2025-06-06 |
| 2218 | Test Data Generated | 2025-05-21 → 2025-06-09 (+19d) | 2025-06-03 → 2025-06-13 (+10d) | 10d → 5d |  | 647d → 440d |  | baseline start 2025-05-21 → 2025-06-09; baseline finish 2025-06-03 → 2025-06-13 |
| 2219 | Test Data Loaded into QP Systems | 2025-06-04 → 2025-06-16 (+12d) | 2025-07-01 → 2025-07-04 (+3d) | 20d → 15d |  | 647d → 440d |  | baseline start 2025-06-04 → 2025-06-16; baseline finish 2025-07-01 → 2025-07-04 |
| 2220 | Test Data Loaded into QTF + ADO | 2025-06-04 → 2025-07-07 (+33d) | 2025-06-30 → 2025-07-25 (+25d) | 19d → 15d |  | 648d → 440d | 2218 → 2218, 2219 | baseline start 2025-06-04 → 2025-07-07; baseline finish 2025-06-30 → 2025-07-25 |
| 2222 | Test Data Request + Templates Completed | 2025-06-16 → 2025-07-28 (+42d) | 2025-07-07 → 2025-08-01 (+25d) | 16d → 5d |  | 617d → 407d |  | constraint finish no earlier than 2025-07-07 → start no earlier than 2025-07-28; baseline start 2025-06-16 → 2025-07-28; baseline finish 2025-07-07 → 2025-08-01 |
| 2223 | Test Data Generated | 2025-07-16 → 2025-08-04 (+19d) | 2025-07-29 → 2025-08-08 (+10d) | 10d → 5d |  | 611d → 407d |  | baseline start 2025-07-16 → 2025-08-04; baseline finish 2025-07-29 → 2025-08-08 |
| 2224 | Test Data Loaded into QP Systems | 2025-07-30 → 2025-08-11 (+12d) | 2025-08-20 → 2025-08-29 (+9d) | 16d → 15d |  | 611d → 407d |  | baseline start 2025-07-30 → 2025-08-11; baseline finish 2025-08-20 → 2025-08-29 |
| 2225 | Test Data Loaded into QTF + ADO | 2025-07-30 → 2025-09-01 (+33d) | 2025-08-20 → 2025-09-19 (+30d) | 16d → 15d |  | 611d → 407d | 2223 → 2223, 2224 | baseline start 2025-07-30 → 2025-09-01; baseline finish 2025-08-20 → 2025-09-19 |
| 2227 | Test Data Request + Templates Completed | 2025-08-19 → 2025-10-20 (+62d) | 2025-09-08 → 2025-10-24 (+46d) | 15d → 5d |  | 568d → 376d |  | constraint finish no earlier than 2025-09-08 → start no earlier than 2025-10-20; baseline start 2025-08-19 → 2025-10-20; baseline finish 2025-09-08 → 2025-10-24 |
| 2228 | Test Data Generated | 2025-09-16 → 2025-10-27 (+41d) | 2025-09-29 → 2025-10-31 (+32d) | 10d → 5d |  | 563d → 376d |  | baseline start 2025-09-16 → 2025-10-27; baseline finish 2025-09-29 → 2025-10-31 |
| 2229 | Test Data Loaded into QP Systems | 2025-09-30 → 2025-11-03 (+34d) | 2025-10-27 → 2025-11-21 (+25d) | 20d → 15d |  | 563d → 376d |  | baseline start 2025-09-30 → 2025-11-03; baseline finish 2025-10-27 → 2025-11-21 |
| 2230 | Test Data Loaded into QTF + ADO | 2025-09-30 → 2025-11-24 (+55d) | 2025-10-27 → 2025-12-12 (+46d) | 20d → 15d |  | 563d → 376d | 2228 → 2228, 2229 | baseline start 2025-09-30 → 2025-11-24; baseline finish 2025-10-27 → 2025-12-12 |
| 2232 | Test Data Request + Templates Completed | 2025-10-17 → 2025-12-15 (+59d) | 2025-11-06 → 2025-12-19 (+43d) | 15d → 5d |  | 525d → 256d |  | constraint finish no earlier than 2025-11-06 → start no earlier than 2025-12-15; baseline start 2025-10-17 → 2025-12-15; baseline finish 2025-11-06 → 2025-12-19 |
| 2233 | Test Data Generated | 2025-11-14 → 2025-12-22 (+38d) | 2025-11-27 → 2025-12-26 (+29d) | 10d → 5d |  | 520d → 256d |  | baseline start 2025-11-14 → 2025-12-22; baseline finish 2025-11-27 → 2025-12-26 |
| 2234 | Test Data Loaded into QP Systems | 2025-11-28 → 2025-12-29 (+31d) | 2025-12-25 → 2026-01-16 (+22d) | 20d → 15d |  | 520d → 256d |  | baseline start 2025-11-28 → 2025-12-29; baseline finish 2025-12-25 → 2026-01-16 |
| 2235 | Test Data Loaded into QTF + ADO | 2025-11-28 → 2026-01-19 (+52d) | 2025-12-25 → 2026-02-06 (+43d) | 20d → 15d |  | 520d → 256d | 2233 → 2233, 2234 | baseline start 2025-11-28 → 2026-01-19; baseline finish 2025-12-25 → 2026-02-06 |
| 2236 | **Governance** |  |  |  | 81% → 96% |  |  |  |
| 2241 | BETA Testing 2 | 2025-01-08 A |  |  | 0% → 78% |  |  |  |
| 2272 | Qualification Wave 1 QT Execution Start |  |  |  |  | 5d → 419d | 2271, 2268, 1607FS+6d → 2271, 2268, 1607FS+6d, 2220 |  |
| 2302 | Qualification Wave 2 Execution Start |  |  |  |  | 6d → 386d | 2301FS+1d, 2298 → 2301FS+1d, 2298, 2225 |  |
| 2332 | Qualification Wave 3 Execution Start |  |  |  |  | 9d → 355d | 2331FS+16d, 2328FS+1d → 2331FS+16d, 2328FS+1d, 2230 |  |
| 2342 | **Qualification Wave 4** | 2025-10-20 → 2025-01-23 A (-270d) |  | 334d → 526d |  | 4d → 235d |  |  |
| 2362 | Qualification Wave 4 QT Execution Start |  |  |  |  | 4d → 235d | 2361FS+1d, 2358 → 2361FS+1d, 2358, 2235 |  |
| 2524 | **Deliver MHHS Code Changes** |  |  |  | 84% → 93% |  |  |  |
| 2525 | **Releases** |  |  |  | 84% → 93% |  |  |  |
| 2526 | Impacted codes make resourcing provisions and prepare to implement new Code via internal code body change processes |  | 2025-02-27 A |  | 90% → 100% | 735d → none |  |  |
| 2536 | **MIGRATION** |  | 2027-08-03 → 2027-08-09 (+6d) | 1242d? → 1246d? | 37% → 61% | 102d → 98d |  |  |
| 2540 | **Migration Framework Agreed and Implemented** |  | 2025-05-07 → 2025-04-29 (-8d) | 330d? → 324d? | 58% → 91% | 686d → 692d |  |  |
| 2555 | **Consultation 3 - Parameters** |  | 2025-02-25 A | 72d → 71d | 71% → 100% | 649d → none |  |  |
| 2557 | Industry Consultation |  | 2025-01-17 A |  | 95% → 100% | 649d → none |  |  |
| 2558 | Triage Response | 2025-01-20 A | 2025-01-31 A |  | 0% → 100% | 649d → none |  |  |
| 2560 | MWG Recommendation | 2025-02-21 → 2025-02-13 A (-8d) | 2025-02-21 → 2025-02-13 A (-8d) |  | 0% → 100% | 649d → none | Industry Assurance ReviewFS+8d → 2559FS+6d |  |
| 2561 | MCAG Paper Day | 2025-02-25 → 2025-02-18 A (-7d) | 2025-02-25 → 2025-02-18 A (-7d) |  | 0% → 100% | 649d → none | 2560FS+2d → 2560FS+3d |  |
| 2562 | MCAG Approval of Consultation 3 | 2025-02-25 A | 2025-02-25 A |  | 0% → 100% | 649d → none | Supplier Submissions, 2560, 2561 → 2560, 2561 | was named MCAG Approval of Migration Framework Artefacts (Baselined); constraint none → start no earlier than 2025-02-25 |
| 2563 | **Consultation 4** | 2025-01-07 A → 2025-01-20 A (+13d) | 2025-05-07 → 2025-04-29 (-8d) | 87d? → 72d? | 1% → 57% | 686d → 692d |  |  |
| 2564 | Agree Consultation 4 Plan | 2025-01-07 A → 2025-01-20 A (+13d) | 2025-05-07 → 2025-02-07 A (-89d) | 87d? → 15d | 1% → 100% | 686d → none |  | was named Prepare Artefacts; baseline start 2025-01-07 → 2025-01-20; baseline finish 2025-05-07 → 2025-02-07 |
| 2569 | Industry Consultation | 2025-03-12 → 2025-03-03 A (-9d) | 2025-03-25 → 2025-03-14 (-11d) |  | 0% → 70% | 697d → 694d | none → 2566 | constraint start no earlier than 2025-03-12 → finish no earlier than 2025-03-14 |
| 2570 | Comment responses by PPs | 2025-03-26 → 2025-03-17 (-9d) | 2025-04-08 → 2025-03-28 (-11d) |  |  | 697d → 694d |  | was named Triage Response; constraint none → finish no earlier than 2025-03-28 |
| 2572 | Assurance meeting | 2025-04-09 → 2025-04-22 (+13d) |  | 10d? → 0d |  | 697d → 692d | 2570 → 2571FS+5d | was named Assurance and MCAG Approval; constraint none → finish no earlier than 2025-04-22 |
| 2574 | MCAG Approval of Consultation 4 | 2025-04-22 → 2025-04-29 (+7d) | 2025-04-22 → 2025-04-29 (+7d) |  |  | 697d → 692d | 2572 → 2573FS+5d | was named Consultation 4 Approved; constraint none → finish no earlier than 2025-04-29 |
| 2575 | Framework Baselined at MCAG | 2025-04-22 → 2025-04-29 (+7d) | 2025-04-22 → 2025-04-29 (+7d) |  |  | 697d → 692d |  | constraint none → finish no earlier than 2025-04-29 |
| 2576 | **Migration Schedule Agreed and Maintained** |  | 2025-07-18 → 2024-12-20 A (-210d) | 275d? → 125d? | 57% → 100% | 359d → none |  | baseline start 2024-07-01 → 2022-10-31; baseline finish 2026-01-30 → 2024-12-20 |

| ID | Task | Start | Finish | Duration | Complete | Total float | Predecessors | Other |
| --- | --- | --- | --- | --- | --- | --- | --- | --- |
| 2577 | Schedule Production | 2024-11-18 A → 2024-07-01 A (-140d) |  | 25d? → 125d? |  |  |  | was named Schedule Production v1; baseline start 2024-11-18 → 2024-07-01 |
| 2581 | V1.0 of Migration Schedule Baseline Approved at MCAG | 2025-07-18 → 2025-07-22 (+4d) | 2025-07-18 → 2025-07-22 (+4d) |  |  | 359d → 632d | Schedule Production v2 → 2580FS+81d | baseline start 2025-07-18 → 2025-07-22; baseline finish 2025-07-18 → 2025-07-22 |
| 2597 | Migration Planning Management Tool Delivery |  |  | 265d? → 265d |  |  |  | was named MPMT Delivered |
| 2598 | **MCC Operational** | 2024-11-18 → 2025-04-18 (+151d) | 2024-11-18 → 2025-08-29 (+284d) | 1d? → 96d |  | 808d → 604d |  | was named MCC Stood up complete; baseline start 2024-11-18 → 2025-04-18; baseline finish 2024-11-18 → 2025-08-29 |
| 2616 | **PP's Prepared for Migration** |  | 2025-05-01 → 2025-04-30 (-1d) | 219d → 218d | 23% → 38% | 649d → 691d |  |  |
| 2617 | Prep for Envelope Webinar |  |  |  |  |  | Indicative Envelopes IssuedSS → none |  |
| 2619 | Guides Creation | 2025-02-28 → 2025-02-27 A (-1d) | 2025-05-01 → 2025-04-30 (-1d) |  | 0% → 20% | 649d → 691d |  | baseline start 2025-01-28 → 2025-02-27; baseline finish 2025-03-31 → 2025-04-30 |
| 2620 | Support Channels | 2025-02-28 → 2025-02-27 A (-1d) | 2025-05-01 → 2025-04-30 (-1d) |  | 0% → 20% | 649d → 691d |  | baseline start 2025-01-28 → 2025-02-27; baseline finish 2025-03-31 → 2025-04-30 |
| 2621 | **Migration Artefact Development and Publication** |  |  |  | 91% → 87% |  |  |  |
| 2664 | **Data Cleanse Plan** |  |  |  | 84% → 80% |  |  |  |
| 2668 | Monitor Programme Participant adherence to Data Cleanse Plan |  |  |  | 80% → 97% |  |  |  |
| 2669 | **MTDs** |  | 2025-01-24 → 2025-07-18 (+175d) | 115d → 240d | 98% → 46% | 759d → 634d |  |  |
| 2670 | **ESME ID** |  | 2024-12-20 A → 2025-05-16 (+147d) | 90d → 195d | 100% → 57% | none → 679d |  |  |
| 2675 | ESME ID Complete | 2024-12-20 A → 2025-05-16 (+147d) | 2024-12-20 A → 2025-05-16 (+147d) |  | 100% → 0% | none → 679d | 2673 → 2674 | baseline start 2024-12-20 → 2025-05-16; baseline finish 2024-12-20 → 2025-05-16 |
| 2676 | **Meter Location and Number of Displayed Register Digits** |  | 2025-01-24 → 2025-07-18 (+175d) | 96d → 221d | 96% → 36% | 759d → 634d |  |  |
| 2679 | Suppliers complete investigation of exceptions and resolution of exceptions | 2025-01-24 A | 2025-01-24 A |  | 0% → 100% | 759d → none |  |  |
| 2681 | Meter Location and Number of Displayed Register Digits Complete | 2025-01-24 → 2025-07-18 (+175d) | 2025-01-24 → 2025-07-18 (+175d) |  |  | 759d → 634d | 2679 → 2679, 2680 | baseline start 2025-01-31 → 2025-07-18; baseline finish 2025-01-31 → 2025-07-18 |
| 2726 | **Preparation for Cutover to Live** |  | 2025-10-17 → 2027-05-05 (+565d) | 341d → 744d |  | 569d → 166d |  |  |
| 2766 | TORWG (Recommendation from TORWG that the Programme should enter M10) |  |  |  |  |  | 2758FS+1d, 2761FS+1d, 2763FS+1d, 2740FS+1d, 2741FS+1d, 2919FS+1d, 2759FS+1d, 2760FS+1d, 2762FS+1d, 2764, 2765 → 2758FS+1d, 2761FS+1d, 2763FS+3d, 2740FS+1d, 2741FS+1d, 2919FS+1d, 2759FS+3d, 2760FS+3d, 2762FS+3d, 2764, 2765 |  |
| 2774 | **Cutover Governance M11** |  | 2025-10-17 → 2025-10-22 (+5d) | 16d → 19d |  | 8d → 5d |  |  |
| 2775 | Confirmation of Qualified Parties from Code Bodies |  | 2025-10-10 → 2025-10-14 (+4d) | 11d → 13d |  | 8d → 7d | 2773FS+1d → 2773FS+1d, 2391 |  |
| 2776 | Self-Declaration that MHHS Functionality will be deployed to Production by Qualified parties | 2025-10-10 → 2025-10-14 (+4d) | 2025-10-10 → 2025-10-14 (+4d) |  |  | 8d → 7d |  | constraint none → finish no earlier than 2025-10-14 |
| 2777 | Production Service Activation Activities have taken place | 2025-10-10 → 2025-10-14 (+4d) | 2025-10-10 → 2025-10-14 (+4d) |  |  | 8d → 7d |  | constraint none → finish no earlier than 2025-10-14 |
| 2778 | TORWG (Confirmation of Qualified Parties from TORWG) | 2025-10-13 → 2025-10-17 (+4d) | 2025-10-13 → 2025-10-17 (+4d) |  |  | 8d → 5d |  | constraint none → finish no earlier than 2025-10-17 |
| 2779 | MCAG (Provide recommendation to PSG on M11 decision) | 2025-10-15 → 2025-10-20 (+5d) | 2025-10-15 → 2025-10-20 (+5d) |  |  | 8d → 5d | 2778FS+2d → 2778FS+1d | constraint none → finish no earlier than 2025-10-20 |
| 2780 | PSG (OFGEM and PSG Decision to Confirm M11 and M12) | 2025-10-17 → 2025-10-22 (+5d) | 2025-10-17 → 2025-10-22 (+5d) |  |  | 8d → 5d |  |  |
| 2877 | **Migration - Tier 1 Milestones** |  | 2027-08-03 → 2027-08-09 (+6d) | 484d → 488d |  |  |  |  |
| 2884 | Full transition complete (M15) | 2027-05-03 → 2027-05-07 (+4d) | 2027-05-03 → 2027-05-07 (+4d) |  |  | 4d → 0d | SIT MVC UMS / Advanced Migration, SIT Non-MVC UMS / Advanced Migration, Wave 1 UMS / Advanced Migration, Wave 2 UMS / Advanced Migration, Wave 3 UMS / Advanced Migration, Wave 4 UMS / Advanced Migration, SIT MVC Smart / Non-Smart Migration, SIT Non-MVC Smart / Non-Smart Migration, Wave 1 Smart / Non-Smart Migration, Wave 2 Smart / Non-Smart Migration, Wave 3 Smart / Non-Smart Migration, Wave 4 Smart / Non-Smart MigrationFS+1d → 2863FS+2d |  |
| 2885 | Full transition complete (M15*) - Late Exit | 2027-08-03 → 2027-08-09 (+6d) | 2027-08-03 → 2027-08-09 (+6d) |  |  | 102d → 98d |  |  |
| 2886 | **BUSINESS & OPERATIONAL READINESS** |  | 2027-12-17 → 2027-12-23 (+6d) | 1340d? → 1344d? | 6% → 11% | 4d → 0d |  |  |
| 2887 | **Service Management** | 2023-09-19 A → 2022-10-31 A (-323d) | 2027-06-24 → 2026-01-14 (-526d) | 983d → 838d | 26% → 41% | 130d → 506d |  |  |
| 2892 | **Early Life Support Model** |  | 2024-07-30 → 2025-04-29 (+273d) | 110d → 305d | 82% → 97% | 887d → 692d |  |  |
| 2893 | Draft Document |  | 2024-06-10 → 2025-02-13 A (+248d) | 74d → 252d | 96% → 100% | 887d → none |  | constraint none → finish no earlier than 2025-02-13 |
| 2894 | Share Document with SRO | 2024-06-11 → 2025-02-14 A (+248d) | 2024-06-11 → 2025-02-14 A (+248d) |  | 0% → 100% | 887d → none |  | was named Share document with SRO |
| 2895 | Industry Consultation | 2024-06-18 → 2025-02-21 A (+248d) | 2024-07-02 → 2025-03-07 (+248d) |  | 0% → 30% | 887d → 709d |  |  |
| 2896 | Assurance Meeting | 2024-07-16 → 2025-04-03 (+261d) | 2024-07-16 → 2025-04-03 (+261d) |  |  | 887d → 700d |  | constraint none → finish no earlier than 2025-04-03 |
| 2897 | MCAG Approval of Early Life Support Model | 2024-07-30 → 2025-04-29 (+273d) | 2024-07-30 → 2025-04-29 (+273d) |  |  | 887d → 692d |  | constraint none → finish no earlier than 2025-04-29 |
| 2898 | **Service Management Arrangements Implementation** | 2025-09-25 → 2022-10-31 (-1060d) | 2027-06-24 → 2026-01-14 (-526d) | 456d → 838d |  | 130d → 506d |  |  |
| 2900 | Monitor Elexon implementation of Service Management arrangements | 2025-10-23 → 2022-10-31 (-1088d) | 2027-06-24 → 2024-07-01 (-1088d) |  |  | 130d → 908d | SIT MVC UMS / Advanced MigrationSS, SIT MVC Smart / Non-Smart MigrationSS → none |  |
| 2937 | **SIT Non-MVC** |  | 2026-01-19 → 2026-01-16 (-3d) | 841d? → 840d? |  | 503d → 504d |  |  |
| 2941 | **SIT Non-MVC Service Activation Implementation** | 2025-12-19 → 2025-12-18 (-1d) | 2025-12-29 → 2025-12-26 (-3d) |  |  | 29d → 505d |  |  |
| 2942 | Add EDF to DIP | 2025-12-19 → 2025-12-18 (-1d) | 2025-12-19 → 2025-12-18 (-1d) |  |  | 29d → 505d |  |  |
| 2943 | DIP Promoted to Production | 2025-12-22 → 2025-12-19 (-3d) | 2025-12-22 → 2025-12-19 (-3d) |  |  | 29d → 505d |  |  |
| 2944 | SIT non-MVC S&As Create Certificates and Test Connectivity | 2025-12-23 → 2025-12-22 (-1d) | 2025-12-23 → 2025-12-22 (-1d) |  |  | 522d → 523d |  | baseline start none → 2025-12-23; baseline finish none → 2025-12-23 |
| 2945 | Create M16 in Customer Solution | 2025-12-23 → 2025-12-22 (-1d) | 2025-12-24 → 2025-12-23 (-1d) |  |  | 29d → 505d |  |  |
| 2946 | Publish ISD | 2025-12-25 → 2025-12-24 (-1d) | 2025-12-26 → 2025-12-25 (-1d) |  |  | 29d → 505d |  |  |
| 2947 | SIT non-MVC S&As to update systems with ISD | 2025-12-29 → 2025-12-26 (-3d) | 2025-12-29 → 2025-12-26 (-3d) |  |  | 518d → 519d |  | baseline start none → 2025-12-29; baseline finish none → 2025-12-29 |
| 2948 | SIT Non-MVC Service Activation Implementation Complete | 2025-12-26 → 2025-12-25 (-1d) | 2025-12-26 → 2025-12-25 (-1d) |  |  | 29d → 520d |  |  |
| 2949 | **SIT Non-MVC Service Activation Implementation MDD** | 2025-12-29 → 2025-12-26 (-3d) | 2026-01-16 → 2026-01-15 (-1d) |  |  | 504d → 505d |  |  |
| 2950 | MDD Manual Load | 2025-12-29 → 2025-12-26 (-3d) | 2026-01-06 → 2026-01-05 (-1d) |  |  | 504d → 505d |  |  |
| 2951 | MDD Update | 2026-01-07 → 2026-01-06 (-1d) | 2026-01-16 → 2026-01-15 (-1d) |  |  | 504d → 505d |  |  |
| 2952 | SIT Non-MVC Service Activation Implementation MDD Complete | 2026-01-16 → 2026-01-15 (-1d) | 2026-01-16 → 2026-01-15 (-1d) |  |  | 504d → 505d |  |  |
| 2953 | **Non-SIT MVC Service Activation Hypercare** | 2025-12-19 → 2025-12-18 (-1d) | 2026-01-19 → 2026-01-16 (-3d) |  |  | 503d → 504d |  |  |
| 2954 | Service& Process Monitoring | 2025-12-19 → 2025-12-18 (-1d) | 2026-01-13 → 2026-01-12 (-1d) |  |  | 507d → 508d |  |  |
| 2955 | Daily Reporting | 2025-12-19 → 2025-12-18 (-1d) | 2026-01-13 → 2026-01-12 (-1d) |  |  | 507d → 508d |  |  |
| 2956 | Issue Management | 2025-12-19 → 2025-12-18 (-1d) | 2026-01-13 → 2026-01-12 (-1d) |  |  | 507d → 508d |  |  |
| 2957 | SA Hypercare Close Down Activities | 2025-12-19 → 2025-12-18 (-1d) | 2026-01-13 → 2026-01-12 (-1d) |  |  | 503d → 504d |  |  |
| 2958 | Handover to MHHSP | 2026-01-14 → 2026-01-13 (-1d) | 2026-01-19 → 2026-01-16 (-3d) |  |  | 503d → 504d |  |  |
| 2959 | Non-SIT MVC Service Activation Hypercare Complete (M) | 2026-01-19 → 2026-01-16 (-3d) | 2026-01-19 → 2026-01-16 (-3d) |  |  | 503d → 504d |  |  |
| 3107 | **Transition to New Settlement Timetable (M16)** |  | 2027-12-17 → 2027-12-23 (+6d) | 562d → 566d |  | 4d → 0d |  |  |
| 3118 | **M16 Approval Window** |  | 2027-12-17 → 2027-12-23 (+6d) | 125d → 129d |  | 4d → 0d |  |  |
| 3120 | Cut over to new settlement timetable (M16) | 2027-06-28 → 2027-07-02 (+4d) | 2027-06-28 → 2027-07-02 (+4d) |  |  | 4d → 0d |  |  |
| 3121 | Maximum 6-month window for approval of M16 | 2027-06-29 → 2027-07-05 (+6d) | 2027-12-17 → 2027-12-23 (+6d) |  |  | 4d → 0d |  |  |
| 3122 | Cut over to new settlement timetable (M16*) - Late Exit | 2027-12-17 → 2027-12-23 (+6d) | 2027-12-17 → 2027-12-23 (+6d) |  |  | 4d → 0d |  |  |
| 3123 | **EARLY LIVE RUNNING** | 2027-05-04 → 2027-05-10 (+6d) | 2027-07-05 → 2027-07-09 (+4d) |  |  | 123d → 119d |  |  |
| 3124 | **Early Live Running Stabilisation Period** | 2027-05-04 → 2027-05-10 (+6d) | 2027-07-05 → 2027-07-09 (+4d) |  |  | 123d → 119d |  |  |
| 3125 | Manage Early Live Running stabilisation period | 2027-05-04 → 2027-05-10 (+6d) | 2027-07-05 → 2027-07-09 (+4d) |  |  | 123d → 119d |  |  |
| 3126 | Monitor Early Live Running stabilisation period | 2027-05-04 → 2027-05-10 (+6d) | 2027-07-05 → 2027-07-09 (+4d) |  |  | 123d → 119d |  |  |
| 3127 | **PROGRAMME CLOSURE** | 2027-03-02 → 2027-03-08 (+6d) | 2027-06-21 → 2027-06-25 (+4d) |  |  | 133d → 129d |  |  |
| 3128 | **Handover Pack** | 2027-03-02 → 2027-03-08 (+6d) | 2027-06-21 → 2027-06-25 (+4d) |  |  | 133d → 129d |  |  |

| ID | Task | Start | Finish | Duration | Total float | Other |
| --- | --- | --- | --- | --- | --- | --- |
| 3129 | **Draft Handover Pack (for M15)** | 2027-03-02 → 2027-03-08 (+6d) | 2027-04-26 → 2027-04-30 (+4d) |  | 173d → 169d |  |
| 3130 | Develop document | 2027-03-02 → 2027-03-08 (+6d) | 2027-03-29 → 2027-04-02 (+4d) |  | 173d → 169d |  |
| 3131 | Document review and update | 2027-03-30 → 2027-04-05 (+6d) | 2027-04-26 → 2027-04-30 (+4d) |  | 173d → 169d |  |
| 3132 | Draft Handover Pack approved | 2027-04-26 → 2027-04-30 (+4d) | 2027-04-26 → 2027-04-30 (+4d) |  | 173d → 169d |  |
| 3133 | **Master Handover Pack (for M16)** | 2027-04-27 → 2027-05-03 (+6d) | 2027-06-21 → 2027-06-25 (+4d) |  | 133d → 129d |  |
| 3134 | Update document | 2027-04-27 → 2027-05-03 (+6d) | 2027-05-24 → 2027-05-28 (+4d) |  | 133d → 129d |  |
| 3135 | Document review and update | 2027-05-25 → 2027-05-31 (+6d) | 2027-06-21 → 2027-06-25 (+4d) |  | 133d → 129d |  |
| 3136 | Master Handover Pack approved | 2027-06-21 → 2027-06-25 (+4d) | 2027-06-21 → 2027-06-25 (+4d) |  | 133d → 129d |  |
| 3137 | **Programme Lessons Learned** | 2027-03-02 → 2027-03-08 (+6d) | 2027-04-26 → 2027-04-30 (+4d) |  | 173d → 169d |  |
| 3138 | Develop document | 2027-03-02 → 2027-03-08 (+6d) | 2027-03-29 → 2027-04-02 (+4d) |  | 173d → 169d |  |
| 3139 | Document review and update | 2027-03-30 → 2027-04-05 (+6d) | 2027-04-26 → 2027-04-30 (+4d) |  | 173d → 169d |  |
| 3140 | Programme Lessons Learned document approved | 2027-04-26 → 2027-04-30 (+4d) | 2027-04-26 → 2027-04-30 (+4d) |  | 173d → 169d |  |
| 3141 | **Programme Closure Report** | 2027-03-02 → 2027-03-08 (+6d) | 2027-04-26 → 2027-04-30 (+4d) |  | 173d → 169d |  |
| 3142 | Develop document | 2027-03-02 → 2027-03-08 (+6d) | 2027-03-29 → 2027-04-02 (+4d) |  | 173d → 169d |  |
| 3143 | Document review and update | 2027-03-30 → 2027-04-05 (+6d) | 2027-04-26 → 2027-04-30 (+4d) |  | 173d → 169d |  |
| 3144 | Programme Closure Report approved | 2027-04-26 → 2027-04-30 (+4d) | 2027-04-26 → 2027-04-30 (+4d) |  | 173d → 169d |  |
| 3145 | **Benefit Realisation Report** | 2027-03-02 → 2027-03-08 (+6d) | 2027-05-03 → 2027-05-07 (+4d) |  | 168d → 164d |  |
| 3146 | Develop document | 2027-03-02 → 2027-03-08 (+6d) | 2027-03-29 → 2027-04-02 (+4d) |  | 168d → 164d |  |
| 3147 | Document review and update | 2027-03-30 → 2027-04-05 (+6d) | 2027-04-26 → 2027-04-30 (+4d) |  | 168d → 164d |  |
| 3148 | Benefit Realisation Report approved | 2027-05-03 → 2027-05-07 (+4d) | 2027-05-03 → 2027-05-07 (+4d) |  | 168d → 164d |  |
| 3149 | **Operating Model Gap Review with recommendations** | 2027-03-02 → 2027-03-08 (+6d) | 2027-05-03 → 2027-05-07 (+4d) |  | 168d → 164d |  |
| 3150 | Develop document | 2027-03-02 → 2027-03-08 (+6d) | 2027-03-29 → 2027-04-02 (+4d) |  | 168d → 164d |  |
| 3151 | Document review and update | 2027-03-30 → 2027-04-05 (+6d) | 2027-04-26 → 2027-04-30 (+4d) |  | 168d → 164d |  |
| 3152 | Operating Model Gap Review with recommendations approved | 2027-05-03 → 2027-05-07 (+4d) | 2027-05-03 → 2027-05-07 (+4d) |  | 168d → 164d |  |
| 3153 | **Post-Implementation Review** | 2027-03-02 → 2027-03-08 (+6d) | 2027-05-03 → 2027-05-07 (+4d) |  | 168d → 164d |  |
| 3154 | Develop document | 2027-03-02 → 2027-03-08 (+6d) | 2027-03-29 → 2027-04-02 (+4d) |  | 168d → 164d |  |
| 3155 | Document review and update | 2027-03-30 → 2027-04-05 (+6d) | 2027-04-26 → 2027-04-30 (+4d) |  | 168d → 164d |  |
| 3156 | Post-Implementation Review approved | 2027-05-03 → 2027-05-07 (+4d) | 2027-05-03 → 2027-05-07 (+4d) |  | 168d → 164d |  |
| 3157 | **Reinforcement Guide** | 2027-03-02 → 2027-03-08 (+6d) | 2027-05-03 → 2027-05-07 (+4d) |  | 168d → 164d |  |
| 3158 | Develop document | 2027-03-02 → 2027-03-08 (+6d) | 2027-03-29 → 2027-04-02 (+4d) |  | 168d → 164d |  |
| 3159 | Document review and update | 2027-03-30 → 2027-04-05 (+6d) | 2027-04-26 → 2027-04-30 (+4d) |  | 168d → 164d |  |
| 3160 | Reinforcement Guide approved | 2027-05-03 → 2027-05-07 (+4d) | 2027-05-03 → 2027-05-07 (+4d) |  | 168d → 164d |  |
| 3161 | **Material and Licenses Transfer** | 2027-03-30 → 2027-04-05 (+6d) | 2027-06-21 → 2027-06-25 (+4d) |  | 133d → 129d |  |
| 3162 | Transfer of Programme material to Elexon and perpetual licenses as appropriate | 2027-03-30 → 2027-04-05 (+6d) | 2027-06-21 → 2027-06-25 (+4d) |  | 133d → 129d |  |
| 3163 | **READINESS ASSESSMENTS** |  | 2027-06-11 → 2027-06-17 (+6d) | 984d → 988d | 139d → 135d |  |
| 3171 | **Readiness Assessment 5 / 6 - Start of Qualification and Participant Readiness for M10 and M11 and CP3/CP4 check** | 2025-04-21 → 2025-04-28 (+7d) | 2025-06-24 → 2025-07-01 (+7d) |  | 652d → 647d |  |
| 3172 | Launch Readiness Assessment survey | 2025-04-21 → 2025-04-28 (+7d) | 2025-04-21 → 2025-04-28 (+7d) |  | 652d → 647d | constraint start no earlier than 2025-04-21 → start no earlier than 2025-04-28; baseline start 2025-04-21 → 2025-04-28; baseline finish 2025-04-21 → 2025-04-28 |
| 3173 | PPs submit survey responses | 2025-04-21 → 2025-04-28 (+7d) | 2025-05-09 → 2025-05-16 (+7d) |  | 652d → 647d | baseline start 2025-04-21 → 2025-04-28; baseline finish 2025-05-09 → 2025-05-16 |
| 3174 | Analyse survey responses | 2025-05-12 → 2025-05-19 (+7d) | 2025-05-30 → 2025-06-06 (+7d) |  | 652d → 647d | baseline start 2025-05-12 → 2025-05-19; baseline finish 2025-05-30 → 2025-06-06 |
| 3175 | Conduct deep-dive interviews (sample of PPs) | 2025-05-12 → 2025-05-19 (+7d) | 2025-05-30 → 2025-06-06 (+7d) |  | 652d → 647d | baseline start 2025-05-12 → 2025-05-19; baseline finish 2025-05-30 → 2025-06-06 |
| 3176 | Produce Readiness Assessment Reports (Overall Report & Individual Participant Reports) | 2025-06-02 → 2025-06-09 (+7d) | 2025-06-20 → 2025-06-27 (+7d) |  | 652d → 647d | baseline start 2025-06-02 → 2025-06-09; baseline finish 2025-06-20 → 2025-06-27 |
| 3177 | Readiness Assessment 5 / 6 - Start of Qualification and Participant Readiness for M10 and M11 and CP3/CP4 check (incl. Readiness Assessment Report approval) Completed | 2025-06-24 → 2025-07-01 (+7d) | 2025-06-24 → 2025-07-01 (+7d) |  | 652d → 647d | baseline start 2025-06-24 → 2025-07-01; baseline finish 2025-06-24 → 2025-07-01 |
| 3192 | **Readiness Assessment 9 - Ready for New Settlement Timetable and CP5 Check** | 2027-04-06 → 2027-04-12 (+6d) | 2027-06-11 → 2027-06-17 (+6d) |  | 139d → 135d |  |
| 3193 | Launch Readiness Assessment survey | 2027-04-06 → 2027-04-12 (+6d) | 2027-04-06 → 2027-04-12 (+6d) |  | 139d → 135d |  |
| 3194 | PPs submit survey responses | 2027-04-06 → 2027-04-12 (+6d) | 2027-04-26 → 2027-04-30 (+4d) |  | 139d → 135d |  |
| 3195 | Analyse survey responses | 2027-04-27 → 2027-05-03 (+6d) | 2027-05-17 → 2027-05-21 (+4d) |  | 139d → 135d |  |
| 3196 | Conduct deep-dive interviews (sample of PPs) | 2027-04-27 → 2027-05-03 (+6d) | 2027-05-17 → 2027-05-21 (+4d) |  | 139d → 135d |  |
| 3197 | Produce Readiness Assessment Reports (Overall Report & Individual Participant Reports) | 2027-05-18 → 2027-05-24 (+6d) | 2027-06-07 → 2027-06-11 (+4d) |  | 139d → 135d |  |
| 3198 | Readiness Assessment 9 - Readiness for New Settlement Timetable - Completed (incl. Readiness Assessment Report approval) | 2027-06-11 → 2027-06-17 (+6d) | 2027-06-11 → 2027-06-17 (+6d) |  | 139d → 135d |  |
| 3199 | **Readiness Assessments - Tier 1 Milestones** | 2025-06-24 → 2025-07-01 (+7d) | 2027-06-11 → 2027-06-17 (+6d) | 513d → 512d | 139d → 135d |  |
| 3200 | Readiness Assessment 6 - Start of Migration - Completed (incl. Readiness Assessment Report approval) | 2025-06-24 → 2025-07-01 (+7d) | 2025-06-24 → 2025-07-01 (+7d) |  | 652d → 647d | baseline start 2025-06-24 → 2025-07-01; baseline finish 2025-06-24 → 2025-07-01 |
| 3203 | Readiness Assessment 9 - Readiness for New Settlement Timetable - Completed (incl. Readiness Assessment Report approval) | 2027-06-11 → 2027-06-17 (+6d) | 2027-06-11 → 2027-06-17 (+6d) |  | 139d → 135d |  |
| 3204 | **CONTROL POINTS** |  | 2027-06-17 → 2027-06-23 (+6d) | 1200d → 1204d | 136d → 132d |  |
| 3214 | **Control Point 5 - Cut Over to New Settlement Timetable** | 2027-05-20 → 2027-05-26 (+6d) | 2027-06-17 → 2027-06-23 (+6d) |  | 136d → 132d |  |
| 3215 | Control Point 5 Preparation (incl. Control Point Report development and review) | 2027-05-20 → 2027-05-26 (+6d) | 2027-06-09 → 2027-06-15 (+6d) |  | 141d → 137d |  |
| 3216 | Control Point 5 - Cut Over to New Settlement Timetable (incl. Control Point Report approval) | 2027-06-17 → 2027-06-23 (+6d) | 2027-06-17 → 2027-06-23 (+6d) |  | 136d → 132d |  |
| 3217 | **Control Points - Tier 1 Milestones** |  | 2027-06-17 → 2027-06-23 (+6d) | 1180d → 1184d | 136d → 132d |  |
| 3221 | Control Point 5 - Cut Over to New Settlement Timetable (incl. Control Point Report approval) | 2027-06-17 → 2027-06-23 (+6d) | 2027-06-17 → 2027-06-23 (+6d) |  | 136d → 132d |  |
| 3222 | **MILESTONE RANGE CHECKPOINTS** |  | 2027-04-06 → 2027-04-12 (+6d) | 1156d? → 1160d? | 188d → 184d |  |
| 3227 | **M15 milestone checkpoint** | 2027-02-09 → 2027-02-15 (+6d) | 2027-02-09 → 2027-02-15 (+6d) |  | 228d → 224d |  |
| 3228 | M15 milestone checkpoint - date approval | 2027-02-09 → 2027-02-15 (+6d) | 2027-02-09 → 2027-02-15 (+6d) |  | 228d → 224d |  |
| 3229 | **M16 milestone checkpoint** |  | 2027-04-06 → 2027-04-12 (+6d) | 1156d? → 1160d? | 188d → 184d |  |
| 3230 | M16 milestone checkpoint - date approval | 2027-04-06 → 2027-04-12 (+6d) | 2027-04-06 → 2027-04-12 (+6d) |  | 188d → 184d |  |

## Version 5 (data date 2025-03-25, saved 2025-03-26, file MHHS-DEL1139 - MHHS Plan v6.21.mpp)

Last finish stays 2027-12-23. Complete tasks 1635 → 1683.

Added:

| ID | Task | Duration | Start | Finish | Predecessors | Constraint |
| --- | --- | --- | --- | --- | --- | --- |
| 162 | **Interim Release 8.9** | 45d | 2025-02-05 A | 2025-04-08 |  |  |
| 163 | Update baselined artefacts | 4d | 2025-02-05 A | 2025-02-10 A |  | start no earlier than 2025-02-05 |
| 164 | Interim Release 8.9 Published | 0d | 2025-03-11 A | 2025-03-11 A | 163FS+1d | finish no earlier than 2025-03-26 |
| 165 | Interim Release 8.9 Deployed to SIT by Participants | 20d | 2025-03-12 A | 2025-04-08 | 164 |  |
| 166 | **Interim Release 8.10** | 56d | 2025-02-05 A | 2025-04-23 |  |  |
| 167 | Update baselined artefacts | 4d | 2025-02-05 A | 2025-02-10 A |  | start no earlier than 2025-02-05 |
| 168 | Interim Release 8.10 Published | 1d | 2025-03-26 A | 2025-03-26 A | 167FS+1d | finish no earlier than 2025-03-26 |
| 169 | Interim Release 8.10 Deployed to SIT by Participants | 20d | 2025-03-27 | 2025-04-23 | 168 | finish no earlier than 2025-03-27 |
| 1830 | SIT PPs E2E Sandbox Testing End | 1d? | 2022-10-31 | 2022-10-31 |  |  |
| 2532 | **M8 Code Change Preperation** | 155d | 2025-01-31 A | 2025-09-05 |  |  |
| 2533 | Resources confirmed | 0d | 2025-01-31 A | 2025-01-31 A |  | finish no earlier than 2025-01-31 |
| 2534 | CDWG Endorsement | 0d | 2025-06-10 | 2025-06-10 |  | finish no earlier than 2025-06-10 |
| 2535 | CCAG Endorsement | 0d | 2025-06-25 | 2025-06-25 |  | finish no earlier than 2025-06-25 |
| 2536 | Send to Ofgem for SCR Direction | 0d | 2025-06-25 | 2025-06-25 |  | finish no earlier than 2025-06-25 |
| 2537 | Freeze M8 Change Control Log 1.0 and create V2.0 | 0d | 2025-07-02 | 2025-07-02 |  | finish no earlier than 2025-07-02 |
| 2538 | Agree Fast Track Code Change Process | 0d | 2025-07-02 | 2025-07-02 |  | finish no earlier than 2025-07-02 |
| 2539 | Ofgem direct SCR Code change | 0d | 2025-07-03 | 2025-07-03 |  | finish no earlier than 2025-07-03 |
| 2540 | Present to Panel | 0d | 2025-07-10 | 2025-07-10 |  | finish no earlier than 2025-07-10 |
| 2541 | Code Change Industry Consultation | 0d | 2025-07-29 | 2025-07-29 |  | finish no earlier than 2025-07-29 |
| 2542 | Panel Recommendation | 0d | 2025-08-14 | 2025-08-14 |  | finish no earlier than 2025-08-14 |
| 2543 | Ofgem Decision | 0d | 2025-09-05 | 2025-09-05 |  | finish no earlier than 2025-09-05 |
| 2775 | Confirmation that all LDSOs have deployed MPRS 9 to production | 0d | 2025-09-01 | 2025-09-01 |  | finish no earlier than 2025-09-01 |
| 2776 | Confirmation that population of Domestic Premises Indicator is complete | 0d | 2025-09-08 | 2025-09-08 | 2775 | finish no earlier than 2025-09-08 |
| 2778 | Confirmation that Market Segment has been populated for 95% of LDSO portfolios | 0d | 2025-09-12 | 2025-09-12 |  | finish no earlier than 2025-09-12 |

Removed: 1360 Reissued to DIP Manager / Code Bodies / SRO for review; 1392 SITWG update on execution model; 1686 Theme 3 SIT Non-Functional Testing Start; 1687 Theme 3 SIT Non-Functional Testing Execution

Changed:

| ID | Task | Start | Finish | Duration | Complete | Total float | Other |
| --- | --- | --- | --- | --- | --- | --- | --- |
| 96 | **Design Artefact Releases** |  | 2025-03-12 A → 2025-04-23 (+42d) | 536d? → 566d? | 100% → 94% | none → 696d |  |
| 136 | **Interim release 8** |  | 2025-03-12 A → 2025-04-23 (+42d) | 281d? → 311d? | 100% → 80% | none → 696d |  |
| 158 | **Interim Release 8.8** |  |  | 26d? → 26d |  |  |  |
| 160 | Interim Release 8.8 Published |  |  | 1d? → 1d |  |  |  |
| 545 | **SYSTEMS INTEGRATION TESTING (SIT)** |  |  |  | 76% → 77% |  |  |
| 546 | **SIT Preparation** |  |  |  | 98% → 99% |  |  |
| 627 | **SIT Stage-Specific Preparation** |  |  |  | 98% → 99% |  |  |
| 1155 | **SIT Non-Functional Execution Model** |  | 2025-03-18 A |  | 99% → 100% | 722d → none |  |
| 1163 | **Theme 2 & 3** |  | 2025-03-18 A |  | 99% → 100% | 722d → none |  |
| 1169 | NFTWG update on execution model | 2025-03-18 A | 2025-03-18 A |  | 0% → 100% | 722d → none |  |
| 1173 | **SIT Non-Functional Test Readiness Report** |  |  |  | 86% → 99% | 60d → 99d |  |
| 1183 | **SIT Non-Functional Overarching Test Readiness Report Theme 2 & 3** |  |  |  | 73% → 99% | 60d → 99d |  |
| 1187 | NFTWG review the Non-Functional Overarching Test Readiness Report Theme 2 & 3 | 2025-03-18 A | 2025-03-18 A |  | 0% → 100% | 61d → none |  |
| 1188 | Update Non-Functional Overarching Test Readiness Report Theme 2 & 3 following SRO / NFTWG feedback | 2025-03-19 A | 2025-03-26 A |  | 0% → 100% | 61d → none |  |
| 1189 | GLIG Recommendation | 2025-03-21 A | 2025-03-21 A |  | 0% → 100% | 64d → none |  |
| 1190 | eSITAG paper day | 2025-03-26 A | 2025-03-26 A |  | 0% → 100% | 61d → none |  |
| 1194 | **SIT Operational Preparation** |  |  |  | 95% → 99% |  |  |
| 1317 | **Theme 3 Test Cases Approved** |  | 2025-03-19 A |  | 99% → 100% | 33d → none |  |
| 1344 | **Theme 3 (Batch 2) Supplementary** |  | 2025-03-19 A |  | 99% → 100% | 33d → none |  |
| 1352 | SITAG paper day | 2025-03-12 A | 2025-03-12 A |  | 0% → 100% | 33d → none |  |
| 1353 | SITAG approve Theme 3 (Batch 2) Supplementary | 2025-03-19 A | 2025-03-19 A |  | 0% → 100% | 33d → none |  |
| 1363 | **SIT Operational Programme RTTM (Theme 1, 2 & 3 (Batch 2))** | 2022-10-31 A → 2025-01-06 A (+798d) | 2025-03-24 → 2025-03-28 (+4d) | 626d → 59d | 70% → 92% | 718d → 715d |  |
| 1366 | DIP Manager / Code Bodies / Full SRO to review |  |  |  | 20% → 75% |  |  |
| 1367 | Incorporate feedback |  |  |  | 20% → 75% |  |  |
| 1369 | SIT Operational (Theme 1, 2 & 3 (Batch 2)) RTTM Complete | 2025-03-24 → 2025-03-28 (+4d) | 2025-03-24 → 2025-03-28 (+4d) |  |  | 30d → 27d | constraint none → start no earlier than 2025-03-28 |
| 1376 | **SIT Operational Theme 1, 2 & 3 (Batch 2) DITL** |  |  |  | 52% → 99% |  |  |
| 1377 | DITL + Familiarisation session development |  | 2025-03-14 A |  | 80% → 100% | 28d → none |  |
| 1378 | SRO Review | 2025-03-17 A | 2025-03-21 A |  | 0% → 100% | 28d → none |  |
| 1379 | Post-SRO Review Changes | 2025-03-24 A | 2025-03-26 A |  | 0% → 100% | 28d → none |  |
| 1380 | Familiarisation session Service Management test case schedule + mapping | 2025-03-26 A | 2025-03-26 A |  | 0% → 100% | 28d → none |  |
| 1385 | **SIT Operational Execution Model** |  |  |  | 86% → 100% |  |  |
| 1393 | **Theme 1, 2 and 3 (Batch 2)** |  |  |  | 58% → 100% |  |  |
| 1395 | SRO provide feedback |  | 2025-03-03 A |  | 90% → 100% | 718d → none |  |
| 1396 | Address SRO feedback on execution model | 2025-03-04 A | 2025-03-10 A |  | 0% → 100% | 718d → none |  |
| 1397 | Finalise execution model | 2025-03-11 A | 2025-03-17 A |  | 0% → 100% | 718d → none |  |
| 1398 | Execution Model shared with industry | 2025-03-17 A | 2025-03-17 A |  | 0% → 100% | 718d → none |  |
| 1402 | **SIT Operational Overarching Test Readiness Reports** |  |  |  | 85% → 99% |  |  |
| 1413 | **SI SIT Operational Theme 1, 2 and 3 (Batch 2) Overarching Test Readiness Report** |  |  |  | 74% → 99% | 714d → 25d |  |
| 1418 | Update Operational Theme 1, 2 and 3 (Batch 2) Overarching Test Readiness Report following SRO feedback |  | 2025-03-25 A |  | 23% → 100% | 717d → none |  |
| 1419 | GLIG recommendation | 2025-03-21 A | 2025-03-21 A |  | 0% → 100% | 30d → none |  |
| 1420 | eSITAG paper day | 2025-03-26 A | 2025-03-26 A |  | 0% → 100% | 716d → none |  |
| 1424 | **Test Data - Non-Functional and Operational (SIT B)** |  |  |  | 38% → 82% |  |  |
| 1425 | **Data Load** |  |  |  | 38% → 82% |  |  |
| 1427 | Non-Functional Theme 2 & 3 (Helix, Avenade & PPs) Data Load | 2025-03-24 A |  |  | 0% → 40% |  |  |
| 1428 | Non-Functional Themes 2 & 3 (LDSO's) Data Load |  | 2025-03-21 A |  | 47% → 100% | 64d → none |  |
| 1429 | Operational Themes 1, 2 & 3 (Batch 2) (LDSO's) Data Load |  |  |  | 35% → 85% |  |  |
| 1430 | Operational Themes 1, 2 & 3 (Batch 2) (Helix, Avenade & PPs) Data Load | 2025-03-24 A |  |  | 0% → 40% |  |  |
| 1432 | **Regression Test Preparation** |  |  |  | 59% → 69% |  |  |
| 1445 | **Regression Core Test Pack** |  |  |  | 47% → 72% | 695d → 7d |  |
| 1451 | SRO Review of Regression Core Pack |  | 2025-03-14 A |  | 25% → 100% | 724d → none |  |
| 1452 | Incorporate SRO feedback into Regression Core Pack | 2025-03-07 A | 2025-03-14 A |  | 0% → 100% | 7d → none |  |
| 1453 | Industry review of Regression Core Pack | 2025-03-17 A |  |  | 0% → 70% |  | baseline start 2025-03-10 → 2025-03-17; baseline finish 2025-03-21 → 2025-03-28 |
| 1454 | Regression Test Framework Core Pack - PP Walkthrough | 2025-03-20 A | 2025-03-20 A |  | 0% → 100% | 13d → none |  |
| 1456 | Incorporate Industry feedback into Regression Core Pack |  |  |  |  |  | baseline start 2025-03-24 → 2025-03-31; baseline finish 2025-03-28 → 2025-04-02 |
| 1457 | Second industry review of Regression Core Pack |  |  |  |  |  | baseline start 2025-03-31 → 2025-04-03; baseline finish 2025-04-04 → 2025-04-09 |
| 1458 | Incorporate industry feedback into regression Core Pack |  |  |  |  |  | baseline start 2025-04-07 → 2025-04-10; baseline finish 2025-04-08 → 2025-04-10 |
| 1459 | eSITWG paper day |  |  |  |  |  | baseline start 2025-04-08 → 2025-04-10; baseline finish 2025-04-08 → 2025-04-10 |
| 1520 | **SIT Execution** |  |  |  | 51% → 54% |  |  |
| 1537 | **SIT - Minimum Viable Cohort (MVC)** |  |  |  | 54% → 58% |  |  |
| 1538 | **SIT Functional Testing (MVC)** |  |  |  | 64% → 67% |  |  |
| 1540 | **SIT Functional Testing Execution (Minimum Viable Cohort)** |  |  |  | 88% → 92% |  |  |
| 1550 | **Cycle 3 (Defect retests and targeted regression testing)** |  |  |  | 74% → 82% |  |  |
| 1560 | Sprint 13 (RTTM Gap Analysis + CR056) |  | 2025-03-14 A |  | 50% → 100% | 5d → none |  |
| 1561 | Sprint 14 (RTTM Gap Analysis + CR056) | 2025-03-17 A |  |  | 0% → 70% |  |  |
| 1565 | **SIT Scope Traceability** |  |  |  | 80% → 99% |  |  |
| 1573 | Update document to reflect industry consultation views | 2025-03-05 A | 2025-03-14 A |  | 0% → 100% | 719d → none |  |
| 1614 | **Helix E2E Settlement Assurance Testing (SAT)** |  |  |  | 58% → 60% |  |  |
| 1623 | **Execution** |  |  |  | 40% → 46% |  |  |
| 1628 | SAT first run |  |  |  | 46% → 77% |  |  |
| 1642 | **MHHS Programme Assurance of Helix E2E SAT** | 2024-09-02 A |  |  |  |  |  |

| ID | Task | Start | Finish | Duration | Complete | Total float | Predecessors | Other |
| --- | --- | --- | --- | --- | --- | --- | --- | --- |
| 1643 | MHHS Programme Assurance Start | 2024-09-02 A | 2024-09-02 A |  | 0% → 100% | 645d → none |  |  |
| 1646 | **SIT Migration Testing (MVC)** |  | 2025-08-08 → 2025-08-22 (+14d) | 370d? → 380d? | 67% → 71% | 619d → 609d |  |  |
| 1648 | **SIT Migration Testing Execution (Minimum Viable Cohort)** |  | 2025-08-08 → 2025-08-22 (+14d) | 370d? → 380d? | 67% → 71% | 619d → 609d |  |  |
| 1658 | **Cycle 3 (Defect retests and targeted regression testing)** |  |  |  | 70% → 83% |  |  |  |
| 1668 | Sprint 13 | 2025-03-03 A | 2025-03-14 A |  | 0% → 100% | 5d → none |  |  |
| 1669 | Sprint 14 (RTTM Gap Analysis + CR056) | 2025-03-17 A |  |  | 0% → 70% |  |  |  |
| 1681 | **SIT Migration Test Completion Report (Minimum Viable Cohort)** | 2024-06-04 → 2025-07-14 (+405d) | 2024-07-08 → 2025-08-15 (+403d) |  |  | 898d → 609d |  |  |
| 1682 | Develop document | 2024-06-04 → 2025-07-14 (+405d) | 2024-06-24 → 2025-08-01 (+403d) |  |  | 898d → 609d | none → 1677SS | constraint none → start no earlier than 2025-07-14 |
| 1683 | Review & agree document | 2024-06-25 → 2025-08-04 (+405d) | 2024-07-01 → 2025-08-08 (+403d) |  |  | 898d → 609d |  |  |
| 1684 | SIT Migration Testing Test Completion Report (Minimum Viable Cohort) Approved | 2024-07-08 → 2025-08-15 (+403d) | 2024-07-08 → 2025-08-15 (+403d) |  |  | 898d → 609d |  |  |
| 1685 | SIT Migration Testing End (Minimum Viable Cohort) (incl. confirmation that PPs have submitted their Test Completion Reports to Programme for assurance) | 2025-03-14 → 2025-08-15 (+154d) | 2025-03-14 → 2025-08-15 (+154d) |  |  | 720d → 609d |  |  |
| 1686 | Assurance of PPs Test Completion Reports | 2025-02-07 → 2025-07-14 (+157d) | 2025-03-20 → 2025-08-22 (+155d) |  |  | 720d → 609d |  |  |
| 1687 | **SIT Non-Functional Testing (all SIT PPs)** |  |  |  | 11% → 16% |  |  |  |
| 1690 | Theme 2 & 3 SIT Non-Functional Testing Start |  |  |  |  |  |  | was named Theme 2 SIT Non-Functional Testing Start |
| 1691 | Theme 2 & 3 SIT Non-Functional Testing Execution |  |  |  |  |  |  | was named Theme 2 SIT Non-Functional Testing Execution |
| 1692 | SIT Non-Functional Testing End (all SIT PPs) (incl. confirmation that PPs have submitted their Test Completion Reports to Programme for assurance) |  |  |  |  |  | 1691FF, Theme 3 SIT Non-Functional Testing ExecutionFF → 1691FF |  |
| 1698 | **SIT Operational Testing (all SIT PPs)** |  |  |  | 3% → 17% |  |  |  |
| 1699 | **Non-SIT B Testing** |  | 2025-03-07 A |  | 15% → 100% | 115d → none |  |  |
| 1701 | SIT Operational Testing Execution Window (Theme 3 - Batch 1 (Service Management)) |  | 2025-03-07 A |  | 15% → 100% | 115d → none |  |  |
| 1739 | **UIT Environment Preparation** |  |  |  | 51% → 52% |  |  |  |
| 1740 | **Test Artefact Development** |  |  |  | 49% → 66% |  |  |  |
| 1741 | **E2E Sandbox Guidance** |  |  |  | 72% → 96% |  |  |  |
| 1745 | Update E2E Sandbox guidance to reflect CR055 |  | 2025-03-14 A |  | 25% → 100% | 713d → none |  | baseline finish 2025-02-20 → 2025-03-14 |
| 1746 | Internal SI review | 2025-03-17 A | 2025-03-21 A |  | 0% → 100% | 713d → none |  | baseline start 2025-02-21 → 2025-03-17; baseline finish 2025-02-27 → 2025-03-21 |
| 1747 | SRO / Code Bodies review | 2025-03-24 A |  |  | 0% → 40% |  |  | baseline start 2025-02-28 → 2025-03-24; baseline finish 2025-03-06 → 2025-03-28 |
| 1748 | Submit version to QWG |  |  |  |  |  |  | baseline start 2025-03-07 → 2025-04-01; baseline finish 2025-03-11 → 2025-04-01 |
| 1749 | Artefact Recommendation for Approval (via QWG) |  |  |  |  |  |  | baseline start 2025-03-11 → 2025-04-08; baseline finish 2025-03-11 → 2025-04-08 |
| 1750 | Final Document updates post QWG review |  |  |  |  |  |  | baseline start 2025-03-13 → 2025-04-09; baseline finish 2025-03-13 → 2025-04-09 |
| 1751 | Submit final version to QAG |  |  |  |  |  |  | baseline start 2025-03-17 → 2025-04-10; baseline finish 2025-03-17 → 2025-04-10 |
| 1752 | E2E Sandbox guidance update approved at QAG |  |  |  |  |  |  | baseline start 2025-03-24 → 2025-04-17; baseline finish 2025-03-24 → 2025-04-17 |
| 1753 | **E2E Sandbox Test Data Approach & Plan** | 2025-01-13 A |  |  |  |  |  |  |
| 1754 | Discussion at QWG to reconfirm value provided from E2E Sandbox (UIT) | 2025-03-11 A | 2025-03-11 A |  | 0% → 100% | 727d → none |  |  |
| 1756 | PPIR shared to industry | 2025-03-17 → 2025-03-24 (+7d) | 2025-03-28 → 2025-04-04 (+7d) |  |  | 709d → 704d |  | constraint finish no earlier than 2025-03-28 → start no earlier than 2025-03-24 |
| 1757 | Evaluate PPIR responses | 2025-03-31 → 2025-04-07 (+7d) | 2025-04-04 → 2025-04-11 (+7d) |  |  | 709d → 704d |  |  |
| 1827 | **SIT PPs Early Sandbox Testing Execution (SIT-A)** | 2025-08-01 → 2022-10-31 (-1005d) |  | 56d → 775d? |  |  |  |  |
| 1828 | SIT PPs E2E Sandbox Testing Start |  |  |  |  |  |  | baseline start 2025-08-08 → 2025-08-01; baseline finish 2025-08-08 → 2025-08-01 |
| 1831 | **System Integration Testing - Tier 1 Milestones** |  |  |  | 84% → 99% |  |  |  |
| 1832 | **M10 Checkpoint** |  |  |  | 84% → 99% |  |  |  |
| 1833 | **M10 Readiness** |  | 2025-03-14 A |  | 92% → 100% | 711d → none |  |  |
| 1837 | Progress against the M10 Readiness Criteria |  | 2025-03-14 A |  | 80% → 100% | 711d → none |  |  |
| 1838 | **Downstream milestone feasibility assessment** |  | 2025-03-14 A |  | 91% → 100% | 711d → none |  |  |
| 1843 | Agree M16 process review findings with Code Bodies |  | 2025-03-14 A |  | 40% → 100% | 711d → none |  |  |
| 1844 | Agree M16 process review findings with PAB |  | 2025-03-14 A |  | 40% → 100% | 711d → none |  |  |
| 1845 | Run PPIR with impacted parties (Point 2 - Bringing M14 forwards) |  | 2025-03-14 A |  | 70% → 100% | 711d → none |  |  |
| 1846 | **Checkpoint governance** |  |  |  | 0% → 99% |  |  |  |
| 1848 | Review final M10 Readiness outputs with IPA | 2025-03-17 A | 2025-03-21 A |  | 0% → 100% | 711d → none |  |  |
| 1849 | Review final M10 Readiness outputs with Ofgem | 2025-03-17 A | 2025-03-26 A |  | 0% → 100% | 711d → none |  |  |
| 1850 | QAG paper day | 2025-03-13 A | 2025-03-13 A |  | 0% → 100% | 720d → none |  |  |
| 1851 | QAG recommend M10 Checkpoint | 2025-03-20 A | 2025-03-20 A |  | 0% → 100% | 720d → none |  |  |
| 1852 | MCAG paper day | 2025-03-24 A | 2025-03-24 A |  | 0% → 100% | 712d → none |  |  |
| 1869 | **NON SIT LDSO QUALIFICATION** |  |  |  | 84% → 83% |  |  |  |
| 1964 | **Test Window** |  |  |  | 62% → 64% |  |  |  |
| 1965 | **All Non-SIT LDSOs Qualification Testing** |  |  |  | 68% → 70% |  |  |  |
| 1967 | LDSO Alpha |  |  |  | 75% → 79% |  |  |  |
| 1968 | LDSO Bravo |  | 2025-03-27 → 2025-05-05 (+39d) | 59d → 86d | 64% → 54% | 36d → 9d |  | constraint none → finish no earlier than 2025-05-05; baseline finish 2025-03-27 → 2025-05-05 |
| 1969 | LDSO Charlie |  |  |  | 74% → 92% |  |  |  |
| 1970 | LDSO Delta |  |  |  | 61% → 65% |  |  |  |
| 1971 | LDSO Echo |  | 2025-04-10 A |  | 81% → 100% | 26d → none |  |  |
| 1972 | LDSO Foxtrot |  | 2025-03-20 → 2025-05-15 (+56d) | 44d → 84d |  | 41d → 1d |  | constraint none → finish no earlier than 2025-05-15 |
| 1973 | LDSO Golf |  |  |  | 97% → 99% |  |  |  |
| 1974 | LDSO Hotel |  | 2025-03-07 → 2025-05-05 (+59d) | 45d → 86d | 67% → 59% | 50d → 9d |  | constraint none → finish no earlier than 2025-05-05; baseline finish 2025-03-07 → 2025-05-05 |
| 1975 | LDSO India |  |  |  | 64% → 77% |  |  |  |
| 1985 | **S & A QUALIFICATION** |  |  |  | 60% → 61% |  |  |  |
| 2047 | **MHHS Qualification - SIT Participants** |  |  |  | 21% → 23% |  |  |  |
| 2050 | Code Bodies review Initial QAD |  |  |  | 50% → 64% |  |  |  |
| 2064 | **MHHS Qualification - Non-SIT LDSO** |  |  |  | 40% → 43% |  |  |  |
| 2068 | Code Bodies review of Non-SIT LDSO participants Initial QAD |  |  |  | 50% → 63% |  |  |  |
| 2241 | **Governance** |  |  |  | 96% → 97% |  |  |  |
| 2246 | BETA Testing 2 |  |  |  | 78% → 86% |  |  |  |
| 2383 | PAB290 | 2025-03-12 A | 2025-03-12 A |  | 0% → 100% | 727d → none |  |  |

| ID | Task | Start | Finish | Duration | Complete | Total float | Predecessors | Other |
| --- | --- | --- | --- | --- | --- | --- | --- | --- |
| 2530 | **Releases** |  | 2025-12-24 → 2025-02-27 A (-300d) | 292d → 78d | 93% → 100% | 521d → none |  |  |
| 2544 | **Main Code Release** | 2025-09-17 → 2025-09-15 (-2d) |  | 71d → 73d |  |  |  |  |
| 2545 | Release preparation (e.g. preparing release documentation) | 2025-09-17 → 2025-09-15 (-2d) | 2025-09-24 → 2025-09-22 (-2d) |  |  | 586d → 588d |  |  |
| 2546 | Implement new code on day of code release | 2025-09-24 → 2025-09-22 (-2d) | 2025-09-24 → 2025-09-22 (-2d) |  |  | 586d → 588d |  |  |
| 2547 | Code changes delivered (M8) | 2025-09-24 → 2025-09-22 (-2d) | 2025-09-24 → 2025-09-22 (-2d) |  |  |  | 2527, 2506, 1857SS → 2527, 2506, 1857SS-3d, 2543 | constraint none → finish no earlier than 2025-09-22 |
| 2548 | Code changes delivered (M8*) late exit |  |  |  |  |  | 2547FS+65d → 2547FS+67d |  |
| 2553 | **MIGRATION** |  |  |  | 61% → 63% |  |  |  |
| 2557 | **Migration Framework Agreed and Implemented** |  |  |  | 91% → 93% |  |  |  |
| 2580 | **Consultation 4** |  |  |  | 57% → 67% |  |  |  |
| 2586 | Industry Consultation |  | 2025-03-14 A |  | 70% → 100% | 694d → none |  |  |
| 2587 | Comment responses by PPs | 2025-03-17 A |  |  | 0% → 20% |  |  |  |
| 2591 | MCAG Approval of Consultation 4 |  |  |  |  |  |  | baseline start 2025-04-22 → 2025-04-29; baseline finish 2025-04-22 → 2025-04-29 |
| 2592 | Framework Baselined at MCAG |  |  |  |  |  |  | baseline start 2025-04-22 → 2025-04-29; baseline finish 2025-04-22 → 2025-04-29 |
| 2599 | **Supplier Commission 2** |  |  |  | 30% → 52% |  |  |  |
| 2600 | Confirm / validate contacts for all Suppliers |  |  |  | 32% → 55% |  |  |  |
| 2613 | **MCC Stood up** | 2024-11-18 A |  |  | 0% → 30% |  |  |  |
| 2614 | Migration Planning Management Tool Delivery | 2024-11-18 A |  |  | 0% → 30% |  |  |  |
| 2633 | **PP's Prepared for Migration** |  |  |  | 38% → 47% |  |  |  |
| 2636 | Guides Creation |  |  |  | 20% → 31% |  |  |  |
| 2637 | Support Channels |  |  |  | 20% → 31% |  |  |  |
| 2638 | **Migration Artefact Development and Publication** |  |  |  | 87% → 89% |  |  |  |
| 2681 | **Data Cleanse Plan** |  |  |  | 80% → 83% |  |  |  |
| 2686 | **MTDs** |  |  |  | 46% → 55% |  |  |  |
| 2687 | **ESME ID** |  |  |  | 57% → 69% |  |  |  |
| 2691 | Suppliers complete Work Off plans |  |  |  | 50% → 64% |  |  |  |
| 2693 | **Meter Location and Number of Displayed Register Digits** |  |  |  | 36% → 43% |  |  |  |
| 2697 | Suppliers complete Work Off plans |  |  |  | 24% → 33% |  |  |  |
| 2774 | **Cutover Governance M10** | 2025-09-10 → 2025-09-01 (-9d) |  | 11d → 17d |  |  |  |  |
| 2777 | Confirmation that Pre-migration Data Cleanse Activities have successfully taken place |  |  |  |  |  | none → 2776 |  |
| 2779 | Confirmation of Helix E2E Settlement Testing Complete |  |  |  |  |  | none → 2778 |  |
| 2795 | Confirmation of Qualified Parties from Code Bodies |  |  |  |  |  |  | baseline finish 2025-10-10 → 2025-10-14 |
| 2796 | Self-Declaration that MHHS Functionality will be deployed to Production by Qualified parties |  |  |  |  |  |  | baseline start 2025-10-10 → 2025-10-14; baseline finish 2025-10-10 → 2025-10-14 |
| 2797 | Production Service Activation Activities have taken place |  |  |  |  |  |  | baseline start 2025-10-10 → 2025-10-14; baseline finish 2025-10-10 → 2025-10-14 |
| 2798 | TORWG (Confirmation of Qualified Parties from TORWG) |  |  |  |  |  |  | baseline start 2025-10-13 → 2025-10-17; baseline finish 2025-10-13 → 2025-10-17 |
| 2799 | MCAG (Provide recommendation to PSG on M11 decision) |  |  |  |  |  |  | baseline start 2025-10-15 → 2025-10-20; baseline finish 2025-10-15 → 2025-10-20 |
| 2800 | PSG (OFGEM and PSG Decision to Confirm M11 and M12) |  |  |  |  |  |  | baseline start 2025-10-17 → 2025-10-22; baseline finish 2025-10-17 → 2025-10-22 |
| 2907 | **Service Management** |  |  |  | 41% → 42% |  |  |  |
| 2912 | **Early Life Support Model** |  |  |  | 97% → 99% |  |  |  |
| 2915 | Industry Consultation |  | 2025-03-07 A |  | 30% → 100% | 709d → none |  |  |
| 3114 | Central Parties BCDRs in Place |  |  |  |  |  | 2547FS-40d → 2547FS-38d |  |

## Version 6 (data date 2025-04-08, saved 2025-04-10, file MHHS-DEL1139 - MHHS Plan v6.221.mpp)

Last finish stays 2027-12-23. Complete tasks 1683 → 1735.

Added:

| ID | Task | Duration | Start | Finish | Predecessors | Constraint |
| --- | --- | --- | --- | --- | --- | --- |
| 1705 | SIT Operational Testing Execution Theme 1 | 70d | 2025-03-31 A | 2025-07-04 | 1703FS-1d | finish no earlier than 2025-07-04 |
| 1706 | SIT Operational Testing Execution Theme 2 | 45d | 2025-05-05 | 2025-07-04 | 1703 | finish no earlier than 2025-07-04 |
| 1707 | SIT Operational Testing Execution Theme 3 Batch 2 | 20d | 2025-06-09 | 2025-07-04 | 1703 | start no earlier than 2025-06-09 |
| 1860 | M10 Checkpoint 2 Complete | 0d | 2025-07-02 | 2025-07-02 |  | finish no earlier than 2025-07-02 |
| 1861 | **M10 Acceptance Criteria** | 358d | 2024-05-28 A | 2025-10-10 |  |  |
| 1862 | End of SIT MVC testing | 0d | 2025-08-22 | 2025-08-22 | 1719 | finish no earlier than 2025-08-22 |
| 1863 | IPA M10 Assurance Report developed and agreed | 0d | 2025-09-19 | 2025-09-19 |  | finish no earlier than 2025-09-19 |
| 1864 | Non-SIT LDSO Qualification Testing complete | 0d | 2025-05-16 | 2025-05-16 | 2013 | finish no earlier than 2025-05-16 |
| 1865 | A minimum of 1 supplier & required contracted agents are qualified and ready to operate under new MHHS arrangements | 0d | 2025-09-12 | 2025-09-12 |  | finish no earlier than 2025-09-12 |
| 1866 | All LDSOs qualified | 0d | 2025-09-10 | 2025-09-10 |  | finish no earlier than 2025-09-10 |
| 1867 | All pre-migration data cleanse activities complete | 0d | 2025-08-13 | 2025-08-13 |  | finish no earlier than 2025-08-13 |
| 1868 | All data migration activities set out in the cutover plan complete | 0d | 2025-09-24 | 2025-09-24 |  | finish no earlier than 2025-09-24 |
| 1869 | ISD fully populated by Elexon | 0d | 2025-09-22 | 2025-09-22 |  | finish no earlier than 2025-09-22 |
| 1870 | Significant Code Review Powers (SCR) enacted by Ofgem (M7) and updates to regulatory code ready to be implemented at M8 | 0d | 2024-12-11 A | 2024-12-11 A | 2564 | finish no earlier than 2024-12-11 |
| 1871 | Migration Schedule approved | 0d | 2025-08-19 | 2025-08-19 |  | finish no earlier than 2025-08-19 |
| 1872 | Migration Framework approved | 0d | 2025-04-30 | 2025-04-30 |  | finish no earlier than 2025-04-30 |
| 1873 | Migration Control Centre (MCC) delegation of authority approved | 0d | 2025-04-30 | 2025-04-30 |  | finish no earlier than 2025-04-30 |
| 1874 | Migration incentives implemented | 0d | 2025-04-30 | 2025-04-30 |  | finish no earlier than 2025-04-30 |
| 1875 | MCC tested and ready to operate | 0d | 2025-09-19 | 2025-09-19 |  | finish no earlier than 2025-09-19 |
| 1876 | Service Delivery Operating Model in place | 0d | 2025-09-19 | 2025-09-19 |  | finish no earlier than 2025-09-19 |
| 1877 | Service Delivery Operating Model in place (Self-Certification) | 0d | 2025-07-03 | 2025-07-03 |  | finish no earlier than 2025-07-03 |
| 1878 | Early Life Support Model defined | 0d | 2025-04-29 | 2025-04-29 | 2982 | finish no earlier than 2025-03-31 |
| 1879 | Early Life Support Model arrangements in place and operational | 0d | 2025-09-12 | 2025-09-12 |  | finish no earlier than 2025-09-12 |
| 1880 | Early Life Support Model arrangements in place and operational (Self-Certification) | 0d | 2025-09-12 | 2025-09-12 |  | finish no earlier than 2025-09-12 |
| 1881 | M10/M11 Cutover Plan in place | 0d | 2024-05-28 | 2024-05-28 |  | finish no earlier than 2024-05-28 |
| 1882 | Central Programme Party Cutover Plans in place | 0d | 2025-07-15 | 2025-07-15 |  | finish no earlier than 2025-07-15 |
| 1883 | Production environment in place for LDSOs and Central Parties | 0d | 2025-09-22 | 2025-09-22 |  | finish no earlier than 2025-09-22 |
| 1884 | Service activation complete to DIP Production environment for Central Parties and LDSOs | 0d | 2025-10-10 | 2025-10-10 |  | finish no earlier than 2025-10-10 |
| 1885 | Cutover Plan executed | 0d | 2025-09-23 | 2025-09-23 |  | finish no earlier than 2025-09-23 |
| 1886 | M10 Risk Assessment undertaken | 0d | 2025-09-03 | 2025-09-03 |  | finish no earlier than 2025-09-03 |
| 1887 | Roles and responsibilities post-M10 agreed and accepted | 0d | 2025-09-19 | 2025-09-19 |  | finish no earlier than 2025-09-19 |
| 1888 | M10 Work off plan agreed (if required) | 0d | 2025-09-19 | 2025-09-19 |  | finish no earlier than 2025-09-19 |
| 1889 | Qualification Operating Model in place and operational for all post-M10 activities | 0d | 2025-09-19 | 2025-09-19 |  | finish no earlier than 2025-09-19 |
| 1890 | Programme Governance updated to reflect required changes to support Programme delivery post-M10. | 0d | 2025-07-01 | 2025-07-01 |  | finish no earlier than 2025-07-01 |
| 1891 | All Suppliers and Agents have made the necessary changes to support losing an MPAN via the Forward Migration Process and gaining an MPAN via the Reverse Migration Process. | 0d | 2025-09-19 | 2025-09-19 |  | finish no earlier than 2025-09-19 |
| 1892 | Performance Assurance measures are understood and in place to maintain BAU performance during the Migration period. | 0d | 2025-09-12 | 2025-09-12 |  | finish no earlier than 2025-09-12 |
| 1893 | Programme monitoring, assurance and escalation process for beyond M10 is in place and operational | 0d | 2025-09-12 | 2025-09-12 |  | finish no earlier than 2025-09-12 |
| 2750 | **Connection Type and Meter Type Misalignments** | 433d | 2025-03-03 A | 2026-10-28 |  |  |
| 2751 | **Traditional Meters installed on Current Transformers** | 433d | 2025-03-03 A | 2026-10-28 |  |  |
| 2752 | Suppliers investigate all MPANs with Traditional Meters installed on a Current Transformer Connection Type | 65d | 2025-03-03 A | 2025-05-30 |  | finish no earlier than 2025-05-30 |
| 2753 | Suppliers to raise the relevant SDEP cases with LDSOs in pot 3 | 0d | 2025-05-30 | 2025-05-30 |  | finish no earlier than 2025-05-30 |
| 2754 | Suppliers to have ensured that Meter Operators have sent the necessary D0312s for MPANs in pot 2 | 21d | 2025-06-02 | 2025-06-30 | 2752 | start no earlier than 2025-06-02 |
| 2755 | LDSOs will be required to have corrected all of these Connection Types in pot 3 | 40d | 2025-06-02 | 2025-07-25 | 2753 | start no earlier than 2025-06-02 |
| 2756 | Suppliers to have completed meter exchanges for those MPANs in pot 1 | 368d | 2025-06-02 | 2026-10-28 | 2752 | start no earlier than 2025-06-02 |
| 2757 | Traditional Meters installed on Current Transformers complete | 0d | 2026-10-28 | 2026-10-28 | 2756 | finish no earlier than 2026-10-28 |
| 2758 | **CHECK Meters** | 66d | 2025-03-03 A | 2025-06-02 |  |  |
| 2759 | Suppliers and their appointed Meter Operator investigate MPANs within their portfolio that have incorrectly populated meters with the Meter Type CHECK within MPRS. Meter Operators are required to send a D0312 to remove the CHECK meter from MPRS. | 65d | 2025-03-03 A | 2025-05-30 |  | finish no earlier than 2025-05-30 |
| 2760 | Once CHECK meters are either removed from MPRS or the Meter Type is changed to a valid Meter Type, the LDSO should check that the Connection Type assigned to the MPAN is still valid. | 65d | 2025-03-03 | 2025-05-30 |  | finish no earlier than 2025-05-30 |
| 2761 | Suppliers confirm to the Programme that they have completed this activity | 0d | 2025-06-02 | 2025-06-02 | 2759 | finish no earlier than 2025-06-02 |
| 2762 | CHECK Meters complete | 0d | 2025-06-02 | 2025-06-02 | 2760 | finish no earlier than 2025-06-02 |
| 2763 | **Smart Meter Types installed on CT Connection Types** | 90d | 2025-03-21 A | 2025-07-25 |  |  |
| 2764 | Programme shares data via email with LDSOs and Suppliers on the total number of misalignments to inform work they will have to complete | 0d | 2025-03-21 A | 2025-03-21 A |  | finish no earlier than 2025-03-21 |
| 2765 | LDSOs investigate Connection Type misalignments and correct where appropriate | 50d | 2025-03-24 | 2025-05-30 | 2764 | finish no earlier than 2025-05-30 |
| 2766 | LDSOs raise SDEP queries with Suppliers where they believe there is an issue | 0d | 2025-05-30 | 2025-05-30 | 2765 | finish no earlier than 2025-05-30 |
| 2767 | Suppliers resolve all issues | 40d | 2025-06-02 | 2025-07-25 | 2766 | finish no earlier than 2025-07-25 |
| 2768 | Smart Meter Types installed on CT Connection Types complete | 0d | 2025-07-25 | 2025-07-25 | 2767 | finish no earlier than 2025-07-25 |
| 2769 | **Linked Import / Export MPANs** | 105d | 2025-03-03 A | 2025-07-25 |  |  |
| 2770 | LDSOs review and correct linked Import / Export MPANs with Different Connection Types | 105d | 2025-03-03 A | 2025-07-25 |  | finish no earlier than 2025-07-25 |
| 2771 | LDSOs, Import and Export Suppliers review and correct linked Import / Export MPANs with meters in the Advanced and Traditional or Smart Meter Groups | 105d | 2025-03-03 A | 2025-07-25 |  | finish no earlier than 2025-07-25 |
| 2772 | Linked Import / Export MPANs complete | 0d | 2025-07-25 | 2025-07-25 | 2770, 2771 | finish no earlier than 2025-07-25 |
| 2773 | **Related MPANs** | 105d | 2025-03-03 A | 2025-07-25 |  |  |
| 2774 | LDSOs review and correct related MPANs with different Connection Types | 80d | 2025-03-03 A | 2025-06-20 |  |  |
| 2775 | Suppliers unrelate any MPANs required | 25d | 2025-06-23 | 2025-07-25 | 2774 | finish no earlier than 2025-07-25 |
| 2776 | Suppliers should investigate Related MPANs within different meter groups and verify that they are correct or request that their Meter Operators update the Meter Types where they are incorrect | 105d | 2025-03-03 A | 2025-07-25 |  | start no earlier than 2025-03-03 |
| 2777 | Related MPANs complete | 0d | 2025-07-25 | 2025-07-25 | 2775, 2776 | finish no earlier than 2025-07-25 |

Changed:

| ID | Task | Start | Finish | Duration | Complete | Total float | Predecessors | Other |
| --- | --- | --- | --- | --- | --- | --- | --- | --- |
| 45 | **DESIGN, BUILD & TEST (PIT)** |  |  |  | 83% → 84% |  |  |  |
| 96 | **Design Artefact Releases** |  | 2025-04-23 A |  | 94% → 100% | 696d → none |  |  |
| 136 | **Interim release 8** |  | 2025-04-23 A |  | 80% → 100% | 696d → none |  |  |
| 162 | **Interim Release 8.9** |  | 2025-04-08 A |  | 58% → 100% | 707d → none |  |  |
| 165 | Interim Release 8.9 Deployed to SIT by Participants |  | 2025-04-08 A |  | 50% → 100% | 707d → none |  |  |
| 166 | **Interim Release 8.10** |  | 2025-04-23 A |  | 20% → 100% | 696d → none |  |  |
| 169 | Interim Release 8.10 Deployed to SIT by Participants | 2025-03-27 A | 2025-04-23 A |  | 0% → 100% | 696d → none |  |  |
| 187 | **PP Design, Build & Test (DBT)** |  |  |  | 74% → 75% |  |  |  |
| 327 | **SIT Participants DBT** |  |  |  | 80% → 85% |  |  |  |
| 362 | **All SIT Programme Participants PIT (SIT Functional)** |  |  |  | 62% → 70% |  |  |  |
| 396 | **All SIT Programme Participants PIT (SIT Non Functional)** |  |  |  | 63% → 76% |  |  |  |
| 397 | **Test Approach & Plan** |  | 2024-11-22 A |  | 0% → 100% | 799d → none |  |  |
| 399 | SIT Non-Functional Test approach and plan MHHS Review Completed |  | 2024-11-22 A |  | 0% → 100% | 799d → none |  |  |
| 402 | **Requirements to test Traceability Matrix (RTTM)** |  | 2024-11-29 A |  | 0% → 100% | 794d → none |  |  |
| 404 | SIT Non-Functional RTTM MHHS Review Completed | 2024-11-29 A | 2024-11-29 A |  | 0% → 100% | 794d → none |  |  |
| 405 | **Test Scenarios** |  | 2024-11-29 A |  | 0% → 100% | 794d → none |  |  |
| 407 | SIT Non-Functional Test scenarios MHHS Review Completed | 2024-11-29 A | 2024-11-29 A |  | 0% → 100% | 794d → none |  |  |
| 408 | **PIT execution** |  |  |  | 61% → 75% |  |  |  |
| 409 | PIT Test Execution Progress Report |  |  |  | 56% → 75% |  |  |  |
| 410 | PIT Execution |  |  |  | 66% → 75% |  |  |  |
| 414 | **SIT Programme Participants PIT (SIT Operational Theme 1, 2, 3 (Batch 2))** |  |  |  | 46% → 75% | 66d → 754d |  |  |
| 418 | **Test Readiness Report** |  |  |  | 42% → 75% | 0d → 12d |  |  |
| 419 | Test readiness reporting |  |  |  | 42% → 75% | 0d → 12d |  |  |
| 426 | **PIT execution** |  |  |  | 47% → 75% | 66d → 754d |  |  |
| 427 | PIT Test Execution Progress Report |  |  |  | 45% → 75% | 104d → 792d |  |  |
| 428 | PIT Execution |  |  |  | 49% → 75% | 66d → 754d |  |  |
| 502 | **DBT Progress Monitoring of Consequential Change** |  |  |  | 71% → 74% |  |  |  |
| 503 | Monitor & report data cleanse progress |  |  |  | 71% → 74% |  |  |  |
| 1100 | **SIT Non-Functional Preparation** |  | 2025-03-28 A |  | 99% → 100% | 714d → none |  |  |
| 1173 | **SIT Non-Functional Test Readiness Report** |  | 2025-03-28 A |  | 99% → 100% | 99d → none |  |  |
| 1183 | **SIT Non-Functional Overarching Test Readiness Report Theme 2 & 3** |  | 2025-03-28 A |  | 99% → 100% | 99d → none |  |  |
| 1191 | eSITAG approve Non-Functional Overarching Test Readiness Report Theme 2 & 3 | 2025-03-28 A | 2025-03-28 A |  | 0% → 100% | 99d → none |  |  |
| 1193 | SIT Non-Functional Testing Preparation Complete Theme 2 & 3 | 2025-03-28 A | 2025-03-28 A |  | 0% → 100% | 714d → none |  |  |
| 1194 | **SIT Operational Preparation** | 2022-10-31 A → 2022-10-31 |  |  |  |  |  |  |
| 1363 | **SIT Operational Programme RTTM (Theme 1, 2 & 3 (Batch 2))** |  |  |  | 92% → 97% |  |  |  |
| 1366 | DIP Manager / Code Bodies / Full SRO to review |  |  |  | 75% → 90% | 30d → 718d |  |  |
| 1367 | Incorporate feedback |  |  |  | 75% → 90% |  |  |  |
| 1376 | **SIT Operational Theme 1, 2 & 3 (Batch 2) DITL** |  | 2025-03-26 A |  | 99% → 100% | 28d → none |  |  |
| 1381 | Publish Cycle 3 DITL / Cycle 3 DITL Online Sessions for SIT PPs | 2025-03-26 A | 2025-03-26 A |  | 0% → 100% | 28d → none |  |  |
| 1402 | **SIT Operational Overarching Test Readiness Reports** |  |  |  | 99% → 100% |  |  |  |
| 1413 | **SI SIT Operational Theme 1, 2 and 3 (Batch 2) Overarching Test Readiness Report** |  | 2025-03-28 A |  | 99% → 100% | 25d → none |  |  |
| 1421 | eSITAG approve Operational Theme 1, 2 and 3 (Batch 2) Overarching Test Readiness Report | 2025-03-28 A | 2025-03-28 A |  | 0% → 100% | 25d → none |  |  |
| 1423 | SIT Operational Theme 1, 2, 3 (Batch 2) Testing Preparation Complete | 2025-03-28 A | 2025-03-28 A |  | 0% → 100% | 26d → none |  |  |
| 1424 | **Test Data - Non-Functional and Operational (SIT B)** |  | 2025-03-28 A |  | 82% → 100% | 714d → none |  |  |
| 1425 | **Data Load** |  | 2025-03-28 A |  | 82% → 100% | 714d → none |  |  |
| 1427 | Non-Functional Theme 2 & 3 (Helix, Avenade & PPs) Data Load |  | 2025-03-28 A |  | 40% → 100% | 6d → none |  |  |
| 1429 | Operational Themes 1, 2 & 3 (Batch 2) (LDSO's) Data Load |  | 2025-03-28 A |  | 85% → 100% | 25d → none |  |  |
| 1430 | Operational Themes 1, 2 & 3 (Batch 2) (Helix, Avenade & PPs) Data Load |  | 2025-03-28 A |  | 40% → 100% | 25d → none |  |  |
| 1431 | Non-Functional and Operational Test Data Preparation Complete | 2025-03-28 A | 2025-03-28 A |  | 0% → 100% | 714d → none |  |  |
| 1432 | **Regression Test Preparation** |  |  |  | 69% → 80% |  |  |  |
| 1445 | **Regression Core Test Pack** |  |  | 52d? → 51d? | 72% → 89% | 7d → 696d |  |  |
| 1453 | Industry review of Regression Core Pack |  | 2025-03-28 A |  | 70% → 100% | 7d → none |  |  |
| 1455 | Regression Test Framework Core Pack - Q&A Drop in session | 2025-03-27 A | 2025-03-27 A |  | 0% → 100% | 8d → none |  |  |
| 1456 | Incorporate Industry feedback into Regression Core Pack | 2025-03-31 A | 2025-04-02 A |  | 0% → 100% | 7d → none |  |  |
| 1457 | Second industry review of Regression Core Pack | 2025-04-03 A | 2025-04-09 A |  | 0% → 100% | 7d → none |  |  |
| 1459 | SITWG paper day | 2025-04-10 → 2025-04-08 A (-2d) | 2025-04-10 → 2025-04-08 A (-2d) |  | 0% → 100% | 7d → none | 1458 → none | was named eSITWG paper day; constraint none → finish no earlier than 2025-04-08 |
| 1460 | SITWG endorses regression Core Pack |  |  |  |  | 7d → 9d |  | was named eSITWG endorses regression Core Pack; constraint none → finish no earlier than 2025-04-15 |
| 1461 | Incorporate SITWG feedback into regression Core Pack |  |  |  |  | 7d → 700d |  | constraint none → start no earlier than 2025-04-16 |
| 1462 | Regression Test Approach and Plan Uplift |  |  | 1d? → 0d |  |  |  | constraint none → start no earlier than 2025-04-16 |
| 1463 | Industry Review on the Uplifted Test Approach and Plan |  | 2025-04-22 → 2025-04-23 (+1d) | 4d → 5d |  | 9d → 8d |  | constraint none → finish no earlier than 2025-04-23 |
| 1464 | SITAG paper day | 2025-04-17 → 2025-04-15 (-2d) | 2025-04-17 → 2025-04-15 (-2d) |  |  | 7d → 10d | 1461 → none | was named eSITAG paper day; constraint finish no earlier than 2025-04-09 → start no earlier than 2025-04-15 |
| 1465 | SITAG (inc SRO) Approval of regression Core Pack |  |  |  |  | 7d → 8d |  | was named eSITAG (inc SRO) Approval of regression Core Pack; constraint finish no earlier than 2025-04-16 → start no earlier than 2025-04-24 |
| 1467 | **Regression Test Data Load Window (SIT Functional and Migration) - SIT A** |  |  |  | 0% → 21% |  |  |  |
| 1468 | Data Load preparation activities | 2025-03-31 A |  |  | 0% → 35% |  |  |  |
| 1537 | **SIT - Minimum Viable Cohort (MVC)** |  |  |  | 58% → 57% |  |  |  |
| 1538 | **SIT Functional Testing (MVC)** |  |  |  | 67% → 71% |  |  |  |
| 1540 | **SIT Functional Testing Execution (Minimum Viable Cohort)** |  | 2025-04-28 A |  | 92% → 100% | 693d → none |  |  |
| 1550 | **Cycle 3 (Defect retests and targeted regression testing)** |  |  |  | 82% → 100% |  |  |  |
| 1561 | Sprint 14 (RTTM Gap Analysis + CR056) |  | 2025-03-28 A |  | 70% → 100% | 5d → none |  |  |
| 1562 | Sprint 15 (Contingency 1) | 2025-03-31 A | 2025-04-11 A |  | 0% → 100% | 5d → none |  |  |

| ID | Task | Start | Finish | Duration | Complete | Total float | Predecessors | Other |
| --- | --- | --- | --- | --- | --- | --- | --- | --- |
| 1563 | Sprint 16 (Contingency 2) | 2025-04-14 A | 2025-04-25 A |  | 0% → 100% | 5d → none |  |  |
| 1564 | SIT Functional Cycle 3 Complete | 2025-04-28 A | 2025-04-28 A |  | 0% → 100% | 693d → none |  |  |
| 1571 | SITWG paper day | 2025-04-08 A | 2025-04-08 A |  | 0% → 100% | 695d → none |  | constraint none → start no earlier than 2025-04-08 |
| 1646 | **SIT Migration Testing (MVC)** |  |  |  | 71% → 75% |  |  |  |
| 1648 | **SIT Migration Testing Execution (Minimum Viable Cohort)** |  |  |  | 71% → 75% |  |  |  |
| 1658 | **Cycle 3 (Defect retests and targeted regression testing)** |  |  |  | 83% → 96% |  |  |  |
| 1669 | Sprint 14 (RTTM Gap Analysis + CR056) |  | 2025-03-28 A |  | 70% → 100% | 5d → none |  |  |
| 1670 | Sprint 15 (Contingency 1) | 2025-03-31 A |  |  | 0% → 70% | 5d → 7d |  |  |
| 1671 | Sprint 16 (Contingency 2) | 2025-04-14 A |  |  | 0% → 70% |  |  |  |
| 1672 | SIT Migration Cycle 3 Complete | 2025-04-25 A |  |  | 0% → 70% |  |  |  |
| 1687 | **SIT Non-Functional Testing (all SIT PPs)** |  |  |  | 16% → 22% |  |  |  |
| 1690 | Theme 2 & 3 SIT Non-Functional Testing Start | 2025-03-31 A | 2025-03-31 A |  | 0% → 100% | 99d → none |  |  |
| 1691 | Theme 2 & 3 SIT Non-Functional Testing Execution | 2025-03-31 A |  |  | 0% → 15% |  |  |  |
| 1698 | **SIT Operational Testing (all SIT PPs)** |  |  |  | 17% → 11% |  |  |  |
| 1702 | **SIT B Testing** | 2025-03-31 A |  |  | 0% → 3% | 25d → 30d |  |  |
| 1703 | SIT Operational Testing Start (SIT B) | 2025-03-31 A | 2025-03-31 A |  | 0% → 100% | 25d → none |  |  |
| 1710 | SIT Operational Testing End (all SIT PPs) (incl. confirmation that PPs have submitted their Test Completion Reports to Programme for assurance) |  |  |  |  |  | 1709FS+5d, 1701 → 1709FS+5d, 1701, 1705, 1706, 1707 |  |
| 1743 | **Test Artefact Development** |  |  |  | 66% → 73% |  |  |  |
| 1756 | **E2E Sandbox Test Data Approach & Plan** |  |  | 68d? → 68d | 0% → 22% |  |  |  |
| 1758 | Create PPIR to request PP responses on subject to gather views | 2025-03-10 A | 2025-03-14 A |  | 0% → 100% | 709d → none |  |  |
| 1759 | PPIR shared to industry | 2025-03-24 A | 2025-04-04 → 2025-04-03 A (-1d) | 10d → 9d | 0% → 100% | 704d → none |  | baseline start 2025-03-17 → 2025-03-24; baseline finish 2025-03-28 → 2025-04-03 |
| 1760 | Evaluate PPIR responses | 2025-04-07 → 2025-04-04 A (-3d) | 2025-04-11 → 2025-04-07 A (-4d) | 5d → 2d | 0% → 100% | 704d → none | 1759 → none | constraint none → start no earlier than 2025-04-04; baseline start 2025-03-31 → 2025-04-04; baseline finish 2025-04-04 → 2025-04-07 |
| 1761 | Discuss PPIR results at QWG |  |  | 1d? → 1d |  |  |  |  |
| 1830 | **SIT PPs Early Sandbox Testing Execution (SIT-A)** | 2022-10-31 → 2025-08-11 (+1015d) | 2025-10-17 → 2025-10-24 (+7d) | 775d? → 55d |  | 569d → 564d |  |  |
| 1831 | SIT PPs E2E Sandbox Testing Start | 2025-08-01 → 2025-08-11 (+10d) | 2025-08-01 → 2025-08-11 (+10d) |  |  | 624d → 618d | 1825FS+5d, 1606 → 1825FS+5d, 1607 | constraint start no earlier than 2025-02-10 → finish no earlier than 2025-08-11; baseline start 2025-08-01 → 2025-08-11; baseline finish 2025-08-01 → 2025-08-11 |
| 1832 | SIT PPs E2E Sandbox Testing Execution | 2025-08-01 → 2025-08-11 (+10d) | 2025-10-17 → 2025-10-24 (+7d) | 56d → 55d |  | 569d → 564d |  |  |
| 1833 | SIT PPs E2E Sandbox Testing End | 2022-10-31 → 2025-10-24 (+1089d) | 2022-10-31 → 2025-10-24 (+1089d) | 1d? → 0d |  | 1343d → 564d | none → 1832 | baseline start none → 2025-10-24; baseline finish none → 2025-10-24 |
| 1834 | **System Integration Testing - Tier 1 Milestones** | 2025-01-06 A → 2024-05-28 A (-223d) |  | 253d? → 411d? |  |  |  |  |
| 1835 | **M10 Checkpoint 1** |  | 2025-04-02 A |  | 99% → 100% | 711d → none |  | was named M10 Checkpoint |
| 1849 | **Checkpoint governance** |  | 2025-04-02 A |  | 99% → 100% | 711d → none |  |  |
| 1856 | MCAG recommend M10 Checkpoint | 2025-04-01 A | 2025-04-01 A |  | 0% → 100% | 712d → none |  |  |
| 1857 | PSG paper day | 2025-03-26 A | 2025-03-26 A |  | 0% → 100% | 711d → none |  |  |
| 1858 | PSG M10 Checkpoint Meeting | 2025-04-02 A | 2025-04-02 A |  | 0% → 100% | 711d → none |  |  |
| 1859 | M10 Checkpoint 1 complete | 2025-04-02 A | 2025-04-02 A |  | 0% → 100% | 711d → none |  | was named M10 Checkpoint complete |
| 1906 | **NON SIT LDSO QUALIFICATION** |  |  |  | 83% → 87% |  |  |  |
| 2001 | **Test Window** |  |  |  | 64% → 77% |  |  |  |
| 2002 | **All Non-SIT LDSOs Qualification Testing** |  |  |  | 70% → 84% |  |  |  |
| 2004 | LDSO Alpha |  |  |  | 79% → 85% |  |  |  |
| 2005 | LDSO Bravo |  |  |  | 54% → 85% |  |  |  |
| 2006 | LDSO Charlie |  | 2025-05-07 A |  | 92% → 100% | 7d → none |  |  |
| 2007 | LDSO Delta |  |  |  | 65% → 74% |  |  |  |
| 2009 | LDSO Foxtrot |  |  |  | 12% → 40% |  |  | baseline finish 2025-03-20 → 2025-05-15 |
| 2010 | LDSO Golf |  | 2025-04-07 → 2025-04-25 (+18d) | 66d → 80d |  | 29d → 15d |  | constraint none → finish no earlier than 2025-04-25; baseline finish 2025-04-07 → 2025-04-25 |
| 2011 | LDSO Hotel |  |  |  | 59% → 91% |  |  |  |
| 2012 | LDSO India |  |  |  | 77% → 84% |  |  |  |
| 2022 | **S & A QUALIFICATION** |  |  |  | 61% → 62% |  |  |  |
| 2084 | **MHHS Qualification - SIT Participants** |  |  |  | 23% → 30% |  |  |  |
| 2087 | Code Bodies review Initial QAD |  | 2025-04-04 A |  | 64% → 100% | 60d → none |  |  |
| 2088 | Completion of Code Bodies review of Initial QAD | 2025-04-04 A | 2025-04-04 A |  | 0% → 100% | 60d → none |  |  |
| 2089 | **MHHS Qualification - SIT MVC Participants** | 2025-04-07 A |  |  | 0% → 4% |  |  |  |
| 2090 | Final QAD Submission Window (MVC) opens | 2025-04-07 A | 2025-04-07 A |  | 0% → 100% | 60d → none |  |  |
| 2091 | SIT MVC Participants submit Final QAD (exc Test Reports) | 2025-04-07 A |  |  | 0% → 8% |  |  |  |
| 2096 | Final QAD Submission Window (Non-MVC) opens |  |  |  |  |  |  | constraint none → start no earlier than 2025-04-07 |
| 2101 | **MHHS Qualification - Non-SIT LDSO** |  |  |  | 43% → 56% |  |  |  |
| 2105 | Code Bodies review of Non-SIT LDSO participants Initial QAD |  | 2025-04-04 A |  | 63% → 100% | 83d → none |  |  |
| 2106 | Completion of Code Bodies review of Initial QAD | 2025-04-04 A | 2025-04-04 A |  | 0% → 100% | 83d → none |  |  |
| 2107 | Final QAD Submission window opens | 2025-04-07 A | 2025-04-07 A |  | 0% → 100% | 83d → none |  |  |
| 2108 | Non-SIT LDSO Participants submit Final QAD | 2025-04-07 A |  |  | 0% → 6% |  |  |  |
| 2114 | **Qualification Wave Prep** |  |  |  | 93% → 94% |  |  |  |
| 2152 | **Qualification Testing Framework (Test Stubs and Supporting UI)** |  |  |  | 92% → 93% |  |  |  |
| 2167 | **Environments** |  |  |  | 99% → 100% | 625d → none |  |  |
| 2185 | **QTF Deployment into Production** |  | 2025-03-18 A |  | 74% → 100% | 722d → none |  |  |
| 2189 | Regression Test |  | 2025-03-18 A |  | 50% → 100% | 722d → none |  |  |
| 2218 | **MPANs, DIP Messages, Settlement, Consumption, Reference** |  |  |  | 80% → 81% |  |  |  |
| 2278 | **Governance** |  | 2025-03-28 A |  | 97% → 100% | 714d → none |  |  |
| 2283 | BETA Testing 2 |  | 2025-03-28 A |  | 86% → 100% | 714d → none |  |  |
| 2284 | Qualification Testing Framework Readiness Confirmed | 2025-03-28 A | 2025-03-28 A |  | 0% → 100% | 714d → none |  |  |
| 2421 | PAB291 | 2025-03-27 A | 2025-03-27 A |  | 0% → 100% | 716d → none |  |  |
| 2584 | Code changes delivered (M8) |  |  |  |  |  |  | baseline start 2025-09-24 → 2025-09-22; baseline finish 2025-09-24 → 2025-09-22 |
| 2590 | **MIGRATION** |  |  |  | 63% → 55% |  |  |  |

| ID | Task | Start | Finish | Duration | Complete | Total float | Predecessors | Other |
| --- | --- | --- | --- | --- | --- | --- | --- | --- |
| 2594 | **Migration Framework Agreed and Implemented** |  |  |  | 93% → 99% |  |  |  |
| 2617 | **Consultation 4** |  |  |  | 67% → 94% |  |  |  |
| 2624 | Comment responses by PPs |  | 2025-03-28 A |  | 20% → 100% | 694d → none |  |  |
| 2625 | Respond to comments and issue artefacts | 2025-03-31 A |  |  | 0% → 70% |  |  |  |
| 2633 | **V1.0 of Migration Schedule Baseline** | 2025-04-01 A |  |  |  |  |  |  |
| 2634 | Confirm Supplier Migration start dates, MPID groups (SIT & NonSIT) | 2025-04-01 A | 2025-04-01 A |  | 0% → 100% | 632d → none |  |  |
| 2636 | **Supplier Commission 2** |  |  |  | 52% → 96% |  |  |  |
| 2637 | Confirm / validate contacts for all Suppliers |  | 2025-04-01 A |  | 55% → 100% | 632d → none |  |  |
| 2675 | **Migration Artefact Development and Publication** |  | 2025-10-15 → 2026-10-28 (+378d) | 773d → 1043d | 89% → 55% | 571d → 301d |  |  |
| 2718 | **Data Cleanse Plan** |  |  |  | 83% → 87% |  |  |  |
| 2722 | Monitor Programme Participant adherence to Data Cleanse Plan |  | 2025-03-28 A |  | 97% → 100% | 714d → none |  |  |
| 2723 | **MTDs** |  |  |  | 55% → 62% |  |  |  |
| 2724 | **ESME ID** |  |  |  | 69% → 77% |  |  |  |
| 2728 | Suppliers complete Work Off plans |  |  |  | 64% → 73% |  |  |  |
| 2730 | **Meter Location and Number of Displayed Register Digits** |  |  |  | 43% → 50% |  |  |  |
| 2734 | Suppliers complete Work Off plans |  |  |  | 33% → 41% |  |  |  |
| 2745 | **Domestic Premises Indicator** | 2025-09-19 → 2025-09-05 (-14d) |  | 19d → 29d |  |  |  |  |
| 2746 | The DCC to extract Domestic Premises Indicator from the CSS and provide a file to each LDSO and EES. | 2025-09-19 → 2025-09-05 (-14d) | 2025-09-22 → 2025-09-08 (-14d) |  |  | 571d → 597d | 1894FS-4d → 1894FS-14d | constraint start no earlier than 2025-08-08 → start no earlier than 2025-09-05; baseline start 2025-09-19 → 2025-09-05; baseline finish 2025-09-22 → 2025-09-08 |
| 2747 | Each LDSO notifies the MHHS Programme SI of any exceptions which have occurred because of the data load and the reason for that exception | 2025-09-23 → 2025-09-24 (+1d) | 2025-09-23 → 2025-09-24 (+1d) |  |  | 571d → 586d |  | was named Each LDSO notifies the DCC of any exceptions; constraint none → start no earlier than 2025-09-24; baseline start 2025-09-23 → 2025-09-24; baseline finish 2025-09-23 → 2025-09-24 |
| 2748 | Each LDSO and DCC completes investigation and resolution of exceptions |  |  |  |  |  | 2746FS+15d, 2747FS+15d → none | constraint none → start no earlier than 2025-10-15 |
| 2749 | Domestic Premises Indicator Complete | 2025-10-15 → 2025-09-24 (-21d) | 2025-10-15 → 2025-09-24 (-21d) |  |  | 571d → 586d | 2748 → 2747 | constraint none → finish no earlier than 2025-09-24; baseline start 2025-10-15 → 2025-09-24; baseline finish 2025-10-15 → 2025-09-24 |
| 2778 | **Export / Import MPANs** |  | 2024-10-18 A → 2025-08-13 (+299d) | 151d → 363d | 100% → 99% | none → 617d |  |  |
| 2981 | Assurance Meeting | 2025-04-03 A | 2025-04-03 A |  | 0% → 100% | 700d → none |  | baseline start 2024-07-16 → 2025-04-03; baseline finish 2024-07-16 → 2025-04-03 |
| 2982 | MCAG Approval of Early Life Support Model |  |  |  |  |  |  | baseline start 2024-07-30 → 2025-04-29; baseline finish 2024-07-30 → 2025-04-29 |
| 3307 | **MILESTONE RANGE CHECKPOINTS** | 2022-10-31 → 2025-07-31 (+1004d) |  | 1160d? → 442d |  |  |  |  |
| 3314 | **M16 milestone checkpoint** | 2022-10-31 → 2027-04-12 (+1624d) |  | 1160d? → 0d |  |  |  |  |

## Version 7 (data date 2025-04-22, saved 2025-04-23, file MHHS-DEL1139 - MHHS Plan v6.23.mpp)

Last finish stays 2027-12-23. Complete tasks 1735 → 1756.

Added:

| ID | Task | Duration | Start | Finish | Predecessors | Constraint |
| --- | --- | --- | --- | --- | --- | --- |
| 2017 | Non-SIT LDSO Regression Testing | 26d | 2025-05-16 | 2025-06-20 | 2014 |  |
| 2817 | Central Party Cutover Plan Assurance | 45d | 2025-04-14 A | 2025-06-13 | 2815FF | start no earlier than 2025-04-14 |
| 2818 | Consolidated MHHS Cutover Plan Developed | 20d | 2025-05-19 | 2025-06-13 | 2815 | start no earlier than 2025-05-19 |
| 2819 | LDSO Cutover Plan Assurance | 15d | 2025-06-30 | 2025-07-18 | 2816FF | start no earlier than 2025-06-30 |
| 2820 | SIT Supplier and SIT Agent Cutover Plan Assurance | 40d | 2025-06-30 | 2025-08-22 | 2816FF | start no earlier than 2025-06-30 |

Removed: 1704 SIT Operational Testing Execution Theme 3 Batch 2; 1708 SIT Operational Testing Execution Theme 1; 1709 SIT Operational Testing Execution Theme 2; 2016 LDSOs Develop & Submit Test Report (QT Test Completion Report)

Changed:

| ID | Task | Start | Finish | Duration | Complete | Total float | Predecessors | Other |
| --- | --- | --- | --- | --- | --- | --- | --- | --- |
| 187 | **PP Design, Build & Test (DBT)** |  |  |  | 75% → 77% |  |  |  |
| 327 | **SIT Participants DBT** |  |  |  | 85% → 89% |  |  |  |
| 362 | **All SIT Programme Participants PIT (SIT Functional)** |  |  |  | 70% → 78% |  |  |  |
| 396 | **All SIT Programme Participants PIT (SIT Non Functional)** |  |  |  | 76% → 98% |  |  |  |
| 408 | **PIT execution** |  | 2025-02-21 A |  | 75% → 100% | 739d → none |  |  |
| 409 | PIT Test Execution Progress Report |  | 2024-11-21 A |  | 75% → 100% | 805d → none |  |  |
| 410 | PIT Execution |  | 2024-11-29 A |  | 75% → 100% | 799d → none |  |  |
| 413 | SIT Non-Functional PIT Completion Report Theme 2 & 3 MHHS Review Completed | 2025-02-21 A | 2025-02-21 A |  | 0% → 100% | 739d → none |  |  |
| 414 | **SIT Programme Participants PIT (SIT Operational Theme 1, 2, 3 (Batch 2))** |  |  |  | 75% → 90% |  |  |  |
| 418 | **Test Readiness Report** |  |  |  | 75% → 90% | 12d → 18d |  |  |
| 419 | Test readiness reporting |  |  |  | 75% → 90% | 12d → 18d |  |  |
| 426 | **PIT execution** |  |  |  | 75% → 90% |  |  |  |
| 427 | PIT Test Execution Progress Report |  |  |  | 75% → 90% |  |  |  |
| 428 | PIT Execution |  |  |  | 75% → 90% |  |  |  |
| 545 | **SYSTEMS INTEGRATION TESTING (SIT)** |  |  |  | 77% → 78% |  |  |  |
| 1194 | **SIT Operational Preparation** |  | 2025-03-28 → 2025-04-25 (+28d) | 630d? → 650d? | 99% → 97% | 714d → 694d |  |  |
| 1363 | **SIT Operational Programme RTTM (Theme 1, 2 & 3 (Batch 2))** |  | 2025-03-28 → 2025-04-25 (+28d) | 59d → 80d | 97% → 56% | 715d → 694d |  |  |
| 1366 | DIP Manager / Code Bodies / Full SRO to review |  | 2025-03-21 → 2025-04-24 (+34d) | 10d → 34d | 90% → 26% | 718d → 694d |  |  |
| 1367 | Incorporate feedback |  | 2025-03-21 → 2025-04-24 (+34d) | 10d → 34d | 90% → 26% | 719d → 695d |  |  |
| 1368 | DIP Manager / Code Bodies / SRO acceptance of (Theme 1, 2 & 3 (Batch 2)) Operational RTTM | 2025-03-24 → 2025-04-25 (+32d) | 2025-03-24 → 2025-04-25 (+32d) |  |  | 718d → 694d |  |  |
| 1369 | SIT Operational (Theme 1, 2 & 3 (Batch 2)) RTTM Complete | 2025-03-28 → 2025-04-25 (+28d) | 2025-03-28 → 2025-04-25 (+28d) |  |  | 715d → 694d |  |  |
| 1423 | SIT Operational Theme 1, 2, 3 (Batch 2) Testing Preparation Complete |  |  |  |  |  | 430, 1211, 1217, 1343, 1421, 1401, 1381, 1369, 1353 → 430, 1211, 1217, 1343, 1421, 1401, 1381, 1353 |  |
| 1432 | **Regression Test Preparation** |  |  |  | 80% → 90% |  |  |  |
| 1445 | **Regression Core Test Pack** |  |  | 51d? → 52d? | 89% → 99% | 696d → 7d |  |  |
| 1458 | Incorporate industry feedback into regression Core Pack | 2025-04-10 A | 2025-04-10 A |  | 0% → 100% | 705d → none |  |  |
| 1460 | SITWG endorses regression Core Pack | 2025-04-15 A | 2025-04-15 A |  | 0% → 100% | 9d → none |  |  |
| 1461 | Incorporate SITWG feedback into regression Core Pack | 2025-04-16 A | 2025-04-17 A |  | 0% → 100% | 700d → none |  |  |
| 1462 | Regression Test Approach and Plan Uplift | 2025-04-16 A | 2025-04-16 A |  | 0% → 100% | 9d → none |  |  |
| 1463 | Industry Review on the Uplifted Test Approach and Plan | 2025-04-17 A | 2025-04-23 A |  | 0% → 100% | 8d → none |  |  |
| 1464 | SITAG paper day | 2025-04-15 → 2025-04-17 A (+2d) | 2025-04-15 → 2025-04-17 A (+2d) |  | 0% → 100% | 10d → none |  | constraint start no earlier than 2025-04-15 → finish no earlier than 2025-04-17 |
| 1467 | **Regression Test Data Load Window (SIT Functional and Migration) - SIT A** |  |  |  | 21% → 50% |  |  |  |
| 1468 | Data Load preparation activities |  |  |  | 35% → 85% |  |  |  |
| 1520 | **SIT Execution** |  |  |  | 54% → 57% |  |  |  |
| 1537 | **SIT - Minimum Viable Cohort (MVC)** |  |  |  | 57% → 61% |  |  |  |
| 1572 | SITWG recommends Scope Tracability document | 2025-04-15 A | 2025-04-15 A |  | 0% → 100% | 695d → none |  |  |
| 1574 | SITAG paper day | 2025-04-17 A | 2025-04-17 A |  | 0% → 100% | 695d → none |  |  |
| 1646 | **SIT Migration Testing (MVC)** |  |  |  | 75% → 77% |  |  |  |
| 1648 | **SIT Migration Testing Execution (Minimum Viable Cohort)** |  |  |  | 75% → 77% |  |  |  |
| 1658 | **Cycle 3 (Defect retests and targeted regression testing)** |  | 2025-04-25 A |  | 96% → 100% | 694d → none |  |  |
| 1670 | Sprint 15 (Contingency 1) |  | 2025-04-11 A |  | 70% → 100% | 7d → none |  |  |
| 1671 | Sprint 16 (Contingency 2) |  | 2025-04-25 A |  | 70% → 100% | 5d → none |  |  |
| 1672 | SIT Migration Cycle 3 Complete |  | 2025-04-25 A |  | 70% → 100% | 694d → none |  |  |
| 1678 | Regression Sprint 3 |  |  |  |  |  |  | baseline start 2025-07-14 → 2025-07-21 |
| 1679 | Regression Contingency Week |  |  |  |  |  |  | baseline start none → 2025-08-04; baseline finish none → 2025-08-08 |
| 1687 | **SIT Non-Functional Testing (all SIT PPs)** |  |  |  | 22% → 37% |  |  |  |
| 1691 | Theme 2 & 3 SIT Non-Functional Testing Execution |  |  |  | 15% → 50% |  |  |  |
| 1698 | **SIT Operational Testing (all SIT PPs)** |  | 2025-07-25 → 2025-07-18 (-7d) | 125d? → 120d? | 11% → 24% | 25d → 30d |  |  |
| 1702 | **SIT B Testing** |  |  | 70d? → 70d | 3% → 18% |  |  |  |
| 1704 | SIT Operational Testing Execution Theme 1 |  |  |  | 9% → 35% |  |  |  |
| 1707 | SIT Operational Testing End (all SIT PPs) (incl. confirmation that PPs have submitted their Test Completion Reports to Programme for assurance) | 2025-07-11 → 2025-07-04 (-7d) | 2025-07-11 → 2025-07-04 (-7d) |  |  | 25d → 30d | SIT Operational Testing Execution Theme 2FS+5d, 1701, 1704, 1705, 1706 → 1701, 1704, 1705, 1706 |  |
| 1708 | Assurance of PPs Test Completion Reports | 2025-06-09 → 2025-06-02 (-7d) | 2025-07-18 → 2025-07-11 (-7d) |  |  | 25d → 30d |  |  |
| 1709 | **SIT Operational Testing Test Completion Report (all SIT PPs)** | 2025-06-23 → 2025-06-16 (-7d) | 2025-07-18 → 2025-07-11 (-7d) |  |  | 25d → 30d |  |  |
| 1710 | Develop document | 2025-06-23 → 2025-06-16 (-7d) | 2025-07-11 → 2025-07-04 (-7d) |  |  | 25d → 30d |  |  |
| 1711 | Review & agree document | 2025-07-14 → 2025-07-07 (-7d) | 2025-07-18 → 2025-07-11 (-7d) |  |  | 25d → 30d |  |  |
| 1712 | SIT Operational Testing Test Completion Report (all SIT PPs) Approved | 2025-07-25 → 2025-07-18 (-7d) | 2025-07-25 → 2025-07-18 (-7d) |  |  | 25d → 30d |  |  |
| 1740 | **Test Artefact Development** |  |  |  | 73% → 74% |  |  |  |
| 1753 | **E2E Sandbox Test Data Approach & Plan** |  |  |  | 22% → 23% |  |  |  |
| 1758 | Discuss PPIR results at QWG | 2025-04-08 A | 2025-04-08 A |  | 0% → 100% | 707d → none |  |  |
| 1827 | **SIT PPs Early Sandbox Testing Execution (SIT-A)** | 2025-08-11 → 2025-07-21 (-21d) |  | 55d → 70d |  |  |  |  |
| 1828 | SIT PPs E2E Sandbox Testing Start | 2025-08-11 → 2025-07-21 (-21d) | 2025-08-11 → 2025-07-21 (-21d) |  |  | 618d → 634d | 1822FS+5d, 1607 → 1822FS+5d, 1605 | constraint finish no earlier than 2025-08-11 → start no earlier than 2025-07-21 |
| 1829 | SIT PPs E2E Sandbox Testing Execution | 2025-08-11 → 2025-07-21 (-21d) |  | 55d → 70d |  |  |  | constraint start no earlier than 2024-11-04 → start no earlier than 2025-07-21; baseline start 2025-02-07 → 2025-08-11; baseline finish 2026-04-24 → 2025-10-24 |
| 1858 | **M10 Acceptance Criteria** |  |  |  |  |  |  | baseline start none → 2024-05-28; baseline finish none → 2025-10-10 |
| 1859 | End of SIT MVC testing |  |  |  |  |  |  | baseline start none → 2025-08-22; baseline finish none → 2025-08-22 |
| 1860 | IPA M10 Assurance Report developed and agreed |  |  |  |  |  |  | baseline start none → 2025-09-19; baseline finish none → 2025-09-19 |
| 1861 | Non-SIT LDSO Qualification Testing complete |  |  |  |  |  |  | baseline start none → 2025-05-16; baseline finish none → 2025-05-16 |
| 1862 | A minimum of 1 supplier & required contracted agents are qualified and ready to operate under new MHHS arrangements |  |  |  |  |  |  | baseline start none → 2025-09-12; baseline finish none → 2025-09-12 |
| 1863 | All LDSOs qualified |  |  |  |  |  |  | baseline start none → 2025-09-10; baseline finish none → 2025-09-10 |
| 1864 | All pre-migration data cleanse activities complete |  |  |  |  |  |  | baseline start none → 2025-08-13; baseline finish none → 2025-08-13 |
| 1865 | All data migration activities set out in the cutover plan complete |  |  |  |  |  |  | baseline start none → 2025-09-24; baseline finish none → 2025-09-24 |
| 1866 | ISD fully populated by Elexon |  |  |  |  |  |  | baseline start none → 2025-09-22; baseline finish none → 2025-09-22 |

| ID | Task | Start | Finish | Duration | Complete | Total float | Predecessors | Other |
| --- | --- | --- | --- | --- | --- | --- | --- | --- |
| 1867 | Significant Code Review Powers (SCR) enacted by Ofgem (M7) and updates to regulatory code ready to be implemented at M8 |  |  |  |  |  |  | baseline start none → 2024-12-11; baseline finish none → 2024-12-11 |
| 1868 | Migration Schedule approved |  |  |  |  |  |  | baseline start none → 2025-08-19; baseline finish none → 2025-08-19 |
| 1869 | Migration Framework approved |  |  |  |  |  |  | baseline start none → 2025-04-30; baseline finish none → 2025-04-30 |
| 1870 | Migration Control Centre (MCC) delegation of authority approved |  |  |  |  |  |  | baseline start none → 2025-04-30; baseline finish none → 2025-04-30 |
| 1871 | Migration incentives implemented |  |  |  |  |  |  | baseline start none → 2025-04-30; baseline finish none → 2025-04-30 |
| 1872 | MCC tested and ready to operate |  |  |  |  |  |  | baseline start none → 2025-09-19; baseline finish none → 2025-09-19 |
| 1873 | Service Delivery Operating Model in place |  |  |  |  |  |  | baseline start none → 2025-09-19; baseline finish none → 2025-09-19 |
| 1874 | Service Delivery Operating Model in place (Self-Certification) |  |  |  |  |  |  | baseline start none → 2025-07-03; baseline finish none → 2025-07-03 |
| 1875 | Early Life Support Model defined |  |  |  |  |  |  | baseline start none → 2025-04-29; baseline finish none → 2025-04-29 |
| 1876 | Early Life Support Model arrangements in place and operational |  |  |  |  |  |  | baseline start none → 2025-09-12; baseline finish none → 2025-09-12 |
| 1877 | Early Life Support Model arrangements in place and operational (Self-Certification) |  |  |  |  |  |  | baseline start none → 2025-09-12; baseline finish none → 2025-09-12 |
| 1878 | M10/M11 Cutover Plan in place |  |  |  |  |  |  | baseline start none → 2024-05-28; baseline finish none → 2024-05-28 |
| 1879 | Central Programme Party Cutover Plans in place |  |  |  |  |  |  | baseline start none → 2025-07-15; baseline finish none → 2025-07-15 |
| 1880 | Production environment in place for LDSOs and Central Parties |  |  |  |  |  |  | baseline start none → 2025-09-22; baseline finish none → 2025-09-22 |
| 1881 | Service activation complete to DIP Production environment for Central Parties and LDSOs |  |  |  |  |  |  | baseline start none → 2025-10-10; baseline finish none → 2025-10-10 |
| 1882 | Cutover Plan executed |  |  |  |  |  |  | baseline start none → 2025-09-23; baseline finish none → 2025-09-23 |
| 1883 | M10 Risk Assessment undertaken |  |  |  |  |  |  | baseline start none → 2025-09-03; baseline finish none → 2025-09-03 |
| 1884 | Roles and responsibilities post-M10 agreed and accepted |  |  |  |  |  |  | baseline start none → 2025-09-19; baseline finish none → 2025-09-19 |
| 1885 | M10 Work off plan agreed (if required) |  |  |  |  |  |  | baseline start none → 2025-09-19; baseline finish none → 2025-09-19 |
| 1886 | Qualification Operating Model in place and operational for all post-M10 activities |  |  |  |  |  |  | baseline start none → 2025-09-19; baseline finish none → 2025-09-19 |
| 1887 | Programme Governance updated to reflect required changes to support Programme delivery post-M10. |  |  |  |  |  |  | baseline start none → 2025-07-01; baseline finish none → 2025-07-01 |
| 1888 | All Suppliers and Agents have made the necessary changes to support losing an MPAN via the Forward Migration Process and gaining an MPAN via the Reverse Migration Process. |  |  |  |  |  |  | baseline start none → 2025-09-19; baseline finish none → 2025-09-19 |
| 1889 | Performance Assurance measures are understood and in place to maintain BAU performance during the Migration period. |  |  |  |  |  |  | baseline start none → 2025-09-12; baseline finish none → 2025-09-12 |
| 1890 | Programme monitoring, assurance and escalation process for beyond M10 is in place and operational |  |  |  |  |  |  | baseline start none → 2025-09-12; baseline finish none → 2025-09-12 |
| 1891 | Central systems ready for migrating MPANs (M10) |  |  |  |  |  | 1716FS+20d, 3156, 2838FS+2d, 2835, 2853, 2813, 2821 → 1716FS+20d, 3156, 2838FS+2d, 2835, 2853, 2813, 2821, 2820 |  |
| 1903 | **NON SIT LDSO QUALIFICATION** |  | 2025-09-19 → 2025-08-22 (-28d) | 489d? → 469d? | 87% → 92% | 589d → 609d |  |  |
| 1963 | **Pre-Integration Testing** |  |  |  | 86% → 97% |  |  |  |
| 1968 | PIT Execution (Non-Functional and Operational) |  |  |  | 33% → 85% |  |  |  |
| 1998 | **Test Window** |  |  |  | 77% → 87% |  |  |  |
| 1999 | **All Non-SIT LDSOs Qualification Testing** |  |  |  | 84% → 95% |  |  |  |
| 2001 | LDSO Alpha |  |  |  | 85% → 97% |  |  |  |
| 2002 | LDSO Bravo |  |  |  | 85% → 99% |  |  |  |
| 2003 | LDSO Charlie |  | 2025-05-07 A → 2025-05-07 |  | 100% → 96% | none → 7d |  |  |
| 2004 | LDSO Delta |  |  |  | 74% → 93% |  |  |  |
| 2006 | LDSO Foxtrot |  |  |  | 40% → 72% |  |  |  |
| 2007 | LDSO Golf |  | 2025-04-25 A |  | 99% → 100% | 15d → none |  |  |
| 2008 | LDSO Hotel |  | 2025-05-05 A |  | 91% → 100% | 9d → none |  |  |
| 2009 | LDSO India |  |  |  | 84% → 99% |  |  |  |
| 2012 | **Test Result Assurance** | 2025-04-21 → 2025-04-04 A (-17d) | 2025-05-29 → 2025-05-16 (-13d) | 29d → 30d | 0% → 43% | 650d → 649d |  |  |
| 2013 | Test Reports Reviewed By MHHS & Code Bodies & Finalised | 2025-05-16 → 2025-04-04 A (-42d) | 2025-05-29 → 2025-05-16 (-13d) | 10d → 30d | 0% → 43% | 650d → 649d | LDSOs Develop & Submit Test Report (QT Test Completion Report) → 2010FF | baseline start 2025-05-16 → 2025-04-04; baseline finish 2025-05-29 → 2025-05-16 |
| 2014 | Non-SIT LDSOs submission deadline for their QT Test Completion Report to MHHS Programme | 2025-05-29 → 2025-05-16 (-13d) | 2025-05-29 → 2025-05-16 (-13d) |  |  | 650d → 649d |  | baseline start 2025-05-29 → 2025-05-16; baseline finish 2025-05-29 → 2025-05-16 |
| 2015 | **Non-SIT LDSO Qualification Closure** | 2025-08-25 → 2025-05-16 (-101d) | 2025-09-19 → 2025-06-27 (-84d) | 20d → 31d |  | 589d → 649d |  |  |
| 2016 | Non-SIT LDSO Qualification Learned Captured | 2025-08-25 → 2025-05-16 (-101d) | 2025-09-12 → 2025-05-29 (-106d) | 15d → 10d |  | 589d → 670d | 2014, 2108 → 2014 | constraint none → start no earlier than 2025-04-16; baseline start 2025-05-30 → 2025-05-16; baseline finish 2025-06-19 → 2025-05-29 |
| 2018 | Non-SIT LDSO Qualification Closure Down | 2025-09-15 → 2025-06-23 (-84d) | 2025-09-19 → 2025-06-27 (-84d) |  |  | 589d → 649d | 2016 → 2017 | constraint none → finish no earlier than 2025-06-26; baseline start 2025-06-20 → 2025-06-23; baseline finish 2025-06-26 → 2025-06-27 |
| 2048 | **Qualification Assessment Document** |  |  |  | 87% → 88% |  |  |  |
| 2067 | **Qualification Assessment Document Portal** |  |  |  | 77% → 78% |  |  |  |
| 2075 | QT Wave 1 Participant QAD Application Creation in Portal | 2025-04-21 A |  |  | 0% → 20% |  |  |  |
| 2081 | **MHHS Qualification - SIT Participants** |  |  |  | 30% → 32% |  |  |  |
| 2086 | **MHHS Qualification - SIT MVC Participants** |  |  |  | 4% → 14% |  |  |  |
| 2088 | SIT MVC Participants submit Final QAD (exc Test Reports) |  |  |  | 8% → 25% |  |  |  |
| 2097 | REC Code Manager / BSC PAB Approval of Qualification (Non-MVC) |  |  |  |  |  |  | baseline start 2025-12-22 → 2025-12-17; baseline finish 2025-12-22 → 2025-12-17 |
| 2098 | **MHHS Qualification - Non-SIT LDSO** |  |  |  | 56% → 60% |  |  |  |
| 2105 | Non-SIT LDSO Participants submit Final QAD |  |  |  | 6% → 20% |  |  |  |
| 2419 | PAB292 | 2025-04-09 A | 2025-04-09 A |  | 0% → 100% | 707d → none |  |  |
| 2587 | **MIGRATION** |  |  |  | 55% → 58% |  |  |  |
| 2588 | **Regulatory Governance** |  | 2025-01-01 → 2025-06-27 (+177d) | 198d → 325d | 47% → 73% | 776d → 649d |  |  |
| 2589 | Incentive Mods Created |  | 2024-08-30 A |  | 85% → 100% | 776d → none |  |  |
| 2590 | Incentives Implemented | 2024-09-02 → 2025-03-31 A (+210d) | 2025-01-01 → 2025-06-27 (+177d) | 88d → 65d | 0% → 26% | 776d → 649d |  | constraint start no earlier than 2024-07-02 → start no earlier than 2025-03-31; baseline start 2024-09-02 → 2025-03-31; baseline finish 2025-01-01 → 2025-06-27 |
| 2614 | **Consultation 4** |  |  |  | 94% → 99% |  |  |  |
| 2622 | Respond to comments and issue artefacts |  | 2025-04-11 A |  | 70% → 100% | 694d → none |  |  |
| 2623 | Assurance meeting | 2025-04-22 A | 2025-04-22 A |  | 0% → 100% | 692d → none |  |  |
| 2624 | MCAG paper day | 2025-04-22 A | 2025-04-22 A |  | 0% → 100% | 692d → none |  |  |
| 2635 | Supplier submission issued |  |  |  |  |  |  | constraint none → start no earlier than 2025-04-25 |
| 2647 | **MCC Stood up** |  |  |  | 30% → 40% |  |  |  |
| 2648 | Migration Planning Management Tool Delivery |  |  |  | 30% → 40% |  |  |  |
| 2649 | **MCC Operational** | 2025-04-18 → 2025-04-23 (+5d) |  | 96d → 93d |  |  |  |  |
| 2650 | **MCC Dress Rehersal 1 - Initialise Schedule (Weekly) Drop 1, 2** | 2025-04-18 → 2025-04-23 (+5d) |  | 63d → 60d |  |  |  |  |
| 2651 | Issue Dress Rehearsal support information to Participants | 2025-04-18 → 2025-04-23 (+5d) | 2025-04-18 → 2025-04-23 (+5d) |  |  |  |  | constraint start no earlier than 2025-04-18 → start no earlier than 2025-04-23; baseline start 2025-04-18 → 2025-04-23; baseline finish 2025-04-18 → 2025-04-23 |
| 2652 | Kestrel Webinar 1 | 2025-04-18 → 2025-04-23 (+5d) | 2025-04-18 → 2025-04-23 (+5d) |  |  |  |  | baseline start 2025-04-18 → 2025-04-23; baseline finish 2025-04-18 → 2025-04-23 |
| 2653 | Onboard and connectivity testing - Dress Rehearsal with Suppliers (All SIT and Wave 1 mandatory) |  |  |  |  |  | 2652FS+6d → 2652FS+3d |  |

| ID | Task | Start | Finish | Duration | Complete | Total float | Predecessors | Other |
| --- | --- | --- | --- | --- | --- | --- | --- | --- |
| 2667 | **SIT Participant's Prepared for Migration** |  |  |  | 47% → 49% |  |  | was named PP's Prepared for Migration |
| 2670 | Guides Creation |  | 2025-04-30 → 2025-04-24 (-6d) | 45d → 41d | 31% → 34% | 691d → 695d |  | constraint none → finish no earlier than 2025-04-24 |
| 2672 | **Migration Artefact Development and Publication** |  |  |  | 55% → 60% |  |  |  |
| 2715 | **Data Cleanse Plan** |  |  |  | 87% → 90% |  |  |  |
| 2720 | **MTDs** |  |  |  | 62% → 70% |  |  |  |
| 2721 | **ESME ID** |  |  |  | 77% → 85% |  |  |  |
| 2725 | Suppliers complete Work Off plans |  |  |  | 73% → 83% |  |  |  |
| 2727 | **Meter Location and Number of Displayed Register Digits** |  |  |  | 50% → 57% |  |  |  |
| 2731 | Suppliers complete Work Off plans |  |  |  | 41% → 49% |  |  |  |
| 2747 | **Connection Type and Meter Type Misalignments** |  |  |  | 14% → 24% |  |  |  |
| 2748 | **Traditional Meters installed on Current Transformers** |  |  |  | 5% → 7% |  |  |  |
| 2749 | Suppliers investigate all MPANs with Traditional Meters installed on a Current Transformer Connection Type |  |  |  | 42% → 57% |  |  |  |
| 2755 | **CHECK Meters** |  |  |  | 21% → 57% |  |  |  |
| 2756 | Suppliers and their appointed Meter Operator investigate MPANs within their portfolio that have incorrectly populated meters with the Meter Type CHECK within MPRS. Meter Operators are required to send a D0312 to remove the CHECK meter from MPRS. |  |  |  | 42% → 57% |  |  |  |
| 2757 | Once CHECK meters are either removed from MPRS or the Meter Type is changed to a valid Meter Type, the LDSO should check that the Connection Type assigned to the MPAN is still valid. | 2025-03-03 A |  |  | 0% → 57% |  |  |  |
| 2760 | **Smart Meter Types installed on CT Connection Types** |  |  |  | 0% → 24% |  |  |  |
| 2762 | LDSOs investigate Connection Type misalignments and correct where appropriate | 2025-03-24 A |  |  | 0% → 44% |  |  |  |
| 2766 | **Linked Import / Export MPANs** |  |  |  | 26% → 30% |  |  |  |
| 2767 | LDSOs review and correct linked Import / Export MPANs with Different Connection Types |  |  |  | 26% → 30% |  |  |  |
| 2768 | LDSOs, Import and Export Suppliers review and correct linked Import / Export MPANs with meters in the Advanced and Traditional or Smart Meter Groups |  |  |  | 26% → 30% |  |  |  |
| 2770 | **Related MPANs** |  |  |  | 26% → 35% |  |  |  |
| 2771 | LDSOs review and correct related MPANs with different Connection Types |  |  |  | 34% → 46% |  |  |  |
| 2773 | Suppliers should investigate Related MPANs within different meter groups and verify that they are correct or request that their Meter Operators update the Meter Types where they are incorrect |  |  |  | 26% → 35% |  |  |  |
| 2805 | **Preparation for Cutover to Live** |  |  |  | 0% → 3% |  |  |  |
| 2806 | **Central Systems Prepare for Cutover to Live** |  |  |  | 0% → 7% |  |  |  |
| 2808 | **Development of Comms Approach and Declaration Guidance** | 2025-04-28 A |  |  | 0% → 3% |  |  |  |
| 2809 | Draft Cutover Comms Approach | 2025-04-28 A |  |  | 0% → 5% |  |  |  |
| 2814 | **Development of Cutover Plan requirements with Participants** | 2025-04-28 → 2025-04-11 A (-17d) | 2025-09-04 → 2025-08-22 (-13d) | 94d → 96d | 0% → 10% | 19d → 609d |  |  |
| 2815 | Development of Central Parties Cutover Plans | 2025-04-28 → 2025-04-11 A (-17d) | 2025-07-17 → 2025-05-16 (-62d) | 59d → 26d | 0% → 31% | 19d → 659d |  | was named Development of SIT Participant Cutover Plans; constraint start no earlier than 2025-04-28 → start no earlier than 2025-04-11 |
| 2816 | Development of Programme Participant Cutover Plans | 2025-07-17 → 2025-04-11 A (-97d) | 2025-07-17 → 2025-06-27 (-20d) | 0d → 56d | 0% → 14% | 19d → 33d | 2815 → 2815SS | was named SIT Participant Cutover Plans Ready; constraint none → finish no earlier than 2025-06-27 |
| 2821 | Programme SIT Participant Cutover Plan Assurance | 2025-07-18 → 2025-06-30 (-18d) | 2025-09-04 → 2025-08-15 (-20d) |  |  | 19d → 33d |  |  |

## Version 8 (data date 2025-05-06, saved 2025-05-07, file MHHS-DEL1139 - MHHS Plan v6.24 (1).mpp)

Last finish stays 2027-12-23. Complete tasks 1756 → 1789.

Added:

| ID | Task | Duration | Start | Finish | Predecessors | Constraint |
| --- | --- | --- | --- | --- | --- | --- |
| 1611 | Programme drafts Functional & Migration Overarching Report Proformas | 15d | 2025-04-28 A | 2025-05-16 | 1564 |  |
| 1612 | Functional & Migration Overarching Proformas shared with PPs | 0d | 2025-05-16 | 2025-05-16 | 1611 |  |
| 1613 | PPs complete and return Completion Report Proformas | 10d | 2025-05-19 | 2025-05-30 | 1612 |  |
| 1614 | PPs Completion Report Proforma deadline | 0d | 2025-05-30 | 2025-05-30 | 1613 |  |
| 1615 | Programme drafts Functional & Migration Overarching Completion Report | 20d | 2025-05-19 | 2025-06-13 | 1612, 1614FF |  |
| 1616 | SITWG Review status of Functional & Migration Overarching Completion Report | 0d | 2025-06-05 | 2025-06-05 |  | start no earlier than 2025-06-05 |
| 1617 | SRO Review Functional & Migration Overarching Completion Report | 5d | 2025-06-02 | 2025-06-06 | 1615SS | start no earlier than 2025-06-02 |
| 1618 | SITAG endorses the Functional & Migration Overarching Test Completion Report | 0d | 2025-06-18 | 2025-06-18 | 1615FS+3d, 1616 |  |
| 1619 | **SIT Settlement and Regression Test Completion Report** | 35d | 2025-06-30 | 2025-08-15 |  |  |
| 1620 | Programme drafts Settlement and Regression Completion Report Proformas (when Participant completes Regression testing) | 30d | 2025-06-30 | 2025-08-08 | 1604SS | start no earlier than 2025-06-30 |
| 1621 | Settlement and Regression Completion Proformas shared with PPs | 0d | 2025-08-08 | 2025-08-08 | 1620 |  |
| 1622 | PPs complete and return Completion Report Proformas | 30d | 2025-07-07 | 2025-08-15 | 1620SS, 1707SS | start no earlier than 2025-07-07 |
| 1623 | PPs Completion Report Proforma deadline | 0d | 2025-08-15 | 2025-08-15 | 1622, 1709 |  |
| 1624 | Programme drafts Settlement and Regression Overarching Completion Report | 30d | 2025-07-07 | 2025-08-15 | 1622SS, 1709SS |  |
| 1625 | SITWG Review status of Settlement and Regression Overarching Completion Report | 0d | 2025-08-07 | 2025-08-07 |  | start no earlier than 2025-08-07 |
| 1626 | SRO Review Settlement and Regression Overarching Completion Report | 5d | 2025-08-04 | 2025-08-08 | 1624SS | start no earlier than 2025-08-04 |
| 1698 | Programme drafts Functional & Migration Completion Report Proformas | 15d | 2025-04-28 A | 2025-05-16 | 1688 | finish no earlier than 2025-05-16 |
| 1699 | Functional & Migration Completion Proformas shared with PPs | 0d | 2025-05-16 | 2025-05-16 | 1698 | start no earlier than 2025-05-16 |
| 1700 | PPs complete and return Completion Report Proformas | 10d | 2025-05-19 | 2025-05-30 | 1699 | finish no earlier than 2025-05-30 |
| 1701 | PPs Completion Report Proforma deadline | 0d | 2025-05-30 | 2025-05-30 | 1700 | start no earlier than 2025-05-30 |
| 1702 | Programme drafts Functional & Migration Overarching Completion Report | 20d | 2025-05-19 | 2025-06-13 | 1699, 1700FF | finish no earlier than 2025-06-13 |
| 1703 | SITWG Review status of Functional & Migration Overarching Completion Report | 0d | 2025-06-05 | 2025-06-05 | 1702SS | start no earlier than 2025-06-05 |
| 1704 | SRO Review Functional & Migration Overarching Completion Report | 5d | 2025-06-02 | 2025-06-06 | 1702SS | finish no earlier than 2025-06-06 |
| 1705 | SITAG endorses the Functional & Migration Overarching Test Completion Report | 0d | 2025-06-18 | 2025-06-18 | 1702FS+3d, 1703 |  |
| 1706 | **SIT Settlement and Regression Test Completion Report** | 35d | 2025-06-30 | 2025-08-15 |  |  |
| 1707 | Programme drafts Settlement and Regression Completion Report Proformas (when Participant completes Regression testing) | 30d | 2025-06-30 | 2025-08-08 | 1692SS | finish no earlier than 2025-08-08 |
| 1708 | Settlement and Regression Completion Proformas shared with PPs | 0d | 2025-08-08 | 2025-08-08 | 1707 | start no earlier than 2025-08-08 |
| 1709 | PPs complete and return Completion Report Proformas | 30d | 2025-07-07 | 2025-08-15 | 1707SS | finish no earlier than 2025-08-15 |
| 1710 | PPs Completion Report Proforma deadline | 0d | 2025-08-15 | 2025-08-15 | 1709 | start no earlier than 2025-08-15 |
| 1711 | Programme drafts Settlement and Regression Overarching Completion Report | 30d | 2025-07-07 | 2025-08-15 | 1709SS | finish no earlier than 2025-08-15 |
| 1712 | SITWG Review status of Settlement and Regression Overarching Completion Report | 0d | 2025-08-07 | 2025-08-07 |  | start no earlier than 2025-08-07 |
| 1713 | SRO Review Settlement and Regression Overarching Completion Report | 5d | 2025-08-04 | 2025-08-08 | 1711SS | start no earlier than 2025-08-04 |
| 1718 | SITAG Approves Functional & Migration (Post-Regression) Overarching Test Completion Report | 0d | 2025-08-15 | 2025-08-15 | 1711, 1717, 1695, 1705 |  |
| 1728 | Programme drafts Non-Functional Completion Report Proformas | 15d | 2025-05-26 | 2025-06-13 | 1725 |  |
| 1729 | Non-Functional Completion Proformas shared with PPs | 0d | 2025-06-13 | 2025-06-13 | 1728 | start no earlier than 2025-06-09 |
| 1730 | PPs complete and return Completion Report Proformas | 15d | 2025-06-09 | 2025-06-27 | 1728SS | finish no earlier than 2025-06-27 |
| 1731 | PPs Completion Report Proforma deadline | 0d | 2025-06-27 | 2025-06-27 | 1730 |  |
| 1732 | Programme drafts Non-Functional Overarching Completion Report | 15d | 2025-06-16 | 2025-07-04 | 1730SS | start no earlier than 2025-06-16 |
| 1733 | SITWG Review status of Non-Functional Overarching Completion Report | 0d | 2025-07-03 | 2025-07-03 |  | start no earlier than 2025-07-03 |
| 1734 | SRO Review Non-Functional Overarching Completion Report | 5d | 2025-06-23 | 2025-06-27 | 1732SS | start no earlier than 2025-06-23 |
| 1750 | Programme drafts Operational Completion Report Proformas (when Participant completes Operational testing) | 30d | 2025-06-02 | 2025-07-11 | 1744SS | start no earlier than 2025-06-02 |
| 1751 | All Operational Completion Proformas have been shared with PPs | 0d | 2025-07-11 | 2025-07-11 | 1750 |  |
| 1752 | PPs complete and return Completion Report Proformas | 30d | 2025-06-16 | 2025-07-25 | 1750SS | start no earlier than 2025-06-16 |
| 1753 | PPs Completion Report Proforma deadline | 0d | 2025-07-25 | 2025-07-25 | 1752 |  |
| 1754 | Programme drafts Operational Overarching Completion Report | 30d | 2025-06-23 | 2025-08-01 | 1752SS | start no earlier than 2025-06-23 |
| 1755 | SITWG Review status of Operational Overarching Completion Report | 0d | 2025-07-03 | 2025-07-03 |  | start no earlier than 2025-07-03 |
| 1756 | SRO Review Operational Overarching Completion Report | 5d | 2025-07-21 | 2025-07-25 | 1754SS | start no earlier than 2025-07-21 |
| 2066 | **SERVICE MANAGEMENT** | 130d | 2025-03-03 A | 2025-09-01 |  |  |
| 2067 | **Stage 2 - M10 Readiness** | 130d | 2025-03-03 A | 2025-09-01 |  |  |
| 2068 | **Service Model Design (Cross Party Service Desk)** | 105d | 2025-03-03 A | 2025-07-25 |  |  |
| 2069 | **Cross Party Service Desk** | 56d | 2025-03-03 A | 2025-05-20 |  |  |
| 2070 | Cross Party Service Desk Definition and Design | 24d | 2025-03-03 A | 2025-04-03 A |  |  |
| 2071 | Cross Party Service Desk Design Document MHHS Review | 0d | 2025-04-03 A | 2025-04-03 A | 2070 | start no earlier than 2025-04-03 |
| 2072 | Cross Party Service Desk Model Issued | 0d | 2025-04-07 A | 2025-04-07 A | 2071 | start no earlier than 2025-04-07 |
| 2073 | Cross Party Service Desk Model Reissued | 0d | 2025-04-15 A | 2025-04-15 A | 2072 | start no earlier than 2025-04-15 |
| 2074 | **Cross Party Service Desk Consultation** | 31d | 2025-04-07 A | 2025-05-20 |  |  |
| 2075 | Cross Party Service Desk Consultation | 16d | 2025-04-07 A | 2025-04-28 A | 2071, 2073FF | finish no earlier than 2025-04-28 |
| 2076 | Cross Party Service Desk Consultation Completed | 0d | 2025-04-28 A | 2025-04-28 A | 2075 | start no earlier than 2025-03-28 |
| 2077 | Cross Party Service Desk Model Updates (Feedback Review) | 8d | 2025-04-29 A | 2025-05-08 | 2076 | start no earlier than 2025-04-23 |
| 2078 | Cross Party Service Desk Model Spotlight at Elexon Service Management Steering Group | 0d | 2025-05-07 | 2025-05-07 | 2077FF-1d | start no earlier than 2025-05-07 |
| 2079 | Updated Consultation Documents Shared with MHHS and Industry | 0d | 2025-05-08 | 2025-05-08 | 2077 | start no earlier than 2025-04-14 |
| 2080 | TORWG Post-Consultation Update (CPSD) | 0d | 2025-05-14 | 2025-05-14 | 2079 | start no earlier than 2025-05-14 |
| 2081 | Updated Consultation Documents Released to Industry for eTORWG | 0d | 2025-05-16 | 2025-05-16 | 2080FS+3d, 2124 |  |
| 2082 | CPSD, Operating Hours & Triage Updates Endorsement (eTORWG) | 0d | 2025-05-20 | 2025-05-20 | 2081 | start no earlier than 2025-05-20 |
| 2083 | Cross Party Service Desk Model Completed | 0d | 2025-05-20 | 2025-05-20 | 2082 | start no earlier than 2025-03-28 |
| 2084 | **Service Documentation** | 64d | 2025-04-29 A | 2025-07-25 |  |  |
| 2085 | Operations Manual and LLSD Updates Post-Consultation | 13d | 2025-04-29 A | 2025-05-15 | 2076 | start no earlier than 2025-04-23 |
| 2086 | Service User LLSD Version 1.2 | 0d | 2025-05-15 | 2025-05-15 | 2085 |  |
| 2087 | Operations Manual Version 1.2 | 0d | 2025-05-15 | 2025-05-15 | 2085 |  |
| 2088 | Post-ORT Operations Manual and LLSD Updates | 10d | 2025-07-14 | 2025-07-25 | 2086, 2087 | start no earlier than 2025-07-14 |
| 2089 | M10 Operations Manual Version 2.0 & LLSD ORT Learning | 0d | 2025-07-25 | 2025-07-25 | 2088 | start no earlier than 2025-04-01 |
| 2090 | **Operational Readiness Testing** | 109d | 2025-03-03 A | 2025-07-31 |  |  |
| 2091 | **ORT Design** | 72d | 2025-03-03 A | 2025-06-10 |  |  |
| 2092 | ORT Test Scope and Approach | 25d | 2025-03-03 A | 2025-04-04 A | 2070FF | start no earlier than 2025-03-03 |
| 2093 | ORT Test Approach Shared with MHHS (Initial Review) | 0d | 2025-04-02 A | 2025-04-02 A | 2092FS-3d | start no earlier than 2025-04-02 |
| 2094 | ORT Test Scenarios Shared with MHHS (Initial Review) | 0d | 2025-04-02 A | 2025-04-02 A | 2092FS-3d | start no earlier than 2025-04-02 |
| 2095 | ORT Test Scope and Approach Documents Shared with Industry | 0d | 2025-04-07 A | 2025-04-07 A | 2094 | start no earlier than 2025-04-07 |
| 2096 | **ORT Test Scope and Approach Consultation (Test Scope and Approach & Test Scripts)** | 30d | 2025-04-08 A | 2025-05-20 |  |  |
| 2097 | ORT Test Scope and Approach Consultation | 15d | 2025-04-08 A | 2025-04-28 A | 2095 | finish no earlier than 2025-04-28 |
| 2098 | ORT Test Scope and Approach Consultation Completed | 0d | 2025-04-28 A | 2025-04-28 A | 2097 | start no earlier than 2025-03-28 |
| 2099 | ORT Test Scope and Approach Updates (Feedback Review) | 8d | 2025-04-29 A | 2025-05-08 | 2098 | start no earlier than 2025-04-14 |
| 2100 | Updated ORT Test Scope and Approach Documents Shared with MHHS and Industry | 0d | 2025-05-08 | 2025-05-08 | 2099 | start no earlier than 2025-04-14 |
| 2101 | TORWG Post-Consultation Update (ORT Approach) | 0d | 2025-05-14 | 2025-05-14 | 2100 | start no earlier than 2025-05-14 |
| 2102 | Updated ORT Test Scope and Approach Documents Released to Industry for eSITWG | 0d | 2025-05-16 | 2025-05-16 | 2100, 2101 | start no earlier than 2025-05-16 |
| 2103 | ORT Test Scope and Approach Endorsement (eSITWG) | 0d | 2025-05-20 | 2025-05-20 | 2102 | start no earlier than 2025-05-20 |
| 2104 | ORT Test Script Production and Updates | 23d | 2025-04-08 A | 2025-05-08 | 2098FF, 2099FF, 2075FF | start no earlier than 2025-04-07 |
| 2105 | ORT Test Scripts Shared | 0d | 2025-05-08 | 2025-05-08 | 2104 | start no earlier than 2025-05-07 |
| 2106 | **ORT Test Scripts Consultation** | 25d | 2025-05-07 | 2025-06-10 |  |  |
| 2107 | ORT Spotlight (Test Approach) at Elexon Service Management Helix Steering Group | 0d | 2025-05-07 | 2025-05-07 |  | start no earlier than 2025-05-07 |
| 2108 | ORT Test Scripts Consultation | 5d | 2025-05-09 | 2025-05-15 | 2104, 2105 | start no earlier than 2025-05-01 |
| 2109 | ORT Test Scripts Consultation Completed | 0d | 2025-05-15 | 2025-05-15 | 2108 | start no earlier than 2025-03-28 |
| 2110 | ORT Test Scripts Updates (Feedback Review) | 5d | 2025-05-16 | 2025-05-22 | 2109 | start no earlier than 2025-04-02 |
| 2111 | ORT Test Scipts Updates Shared with MHHS and Industry | 0d | 2025-05-22 | 2025-05-22 | 2110 | start no earlier than 2025-04-14 |
| 2112 | Industry Assurance Review Session Post-Consultation Update (ORT Test Scripts) | 0d | 2025-05-30 | 2025-05-30 | 2111FS+6d | start no earlier than 2025-04-14 |
| 2113 | Updated ORT Test Script Consultation Documents Released to industry for eSITWG | 0d | 2025-06-03 | 2025-06-03 | 2112FS+2d | start no earlier than 2025-04-04 |
| 2114 | ORT Test Scripts and Readiness Spotlight at Elexon Service Management Steering Group | 0d | 2025-06-04 | 2025-06-04 | 2113FS+1d | start no earlier than 2025-04-22 |
| 2115 | ORT Test Scipt Updates Endorsement (eSITWG) | 0d | 2025-06-10 | 2025-06-10 | 2113FS+5d | start no earlier than 2025-04-14 |
| 2116 | **ORT Preparation** | 32d | 2025-05-01 A | 2025-06-13 |  |  |
| 2117 | ORT Participant/User Scheduling | 12d | 2025-05-01 A | 2025-05-16 |  | start no earlier than 2025-05-01 |
| 2118 | ORT Participant/User Scheduling Completed | 0d | 2025-05-16 | 2025-05-16 | 2117 | start no earlier than 2025-03-28 |
| 2119 | ORT Training and Preparation | 6d | 2025-06-04 | 2025-06-11 | 2097, 2104, 2107, 2111 | start no earlier than 2025-06-04 |
| 2120 | ORT DITL Session | 0d | 2025-06-12 | 2025-06-12 | 2109FS+2d, 2112 | start no earlier than 2025-06-12 |
| 2121 | ORT Orientation (JiT) | 0d | 2025-06-13 | 2025-06-13 | 2119FS+2d | start no earlier than 2025-05-30 |
| 2122 | **ORT Execution** | 20d | 2025-06-16 | 2025-07-11 |  |  |
| 2123 | ORT Execution | 20d | 2025-06-16 | 2025-07-11 | 2119, 2121, 2103 | start no earlier than 2025-06-02 |
| 2124 | ORT Execution Completed | 0d | 2025-07-11 | 2025-07-11 | 2123 | start no earlier than 2025-03-28 |
| 2125 | **ORT Exit** | 14d | 2025-07-14 | 2025-07-31 | 2103, 2110, 2113, 2117 |  |
| 2126 | ORT Wrap Up | 5d | 2025-07-14 | 2025-07-18 | 2124 | start no earlier than 2025-04-22 |
| 2127 | ORT Exit Report | 10d | 2025-07-14 | 2025-07-25 | 2124 | start no earlier than 2025-04-02 |
| 2128 | ORT Exit Report Shared with Participants | 0d | 2025-07-25 | 2025-07-25 | 2127 | start no earlier than 2025-04-22 |
| 2129 | ORT eSITAG Exit Report Endorsement | 0d | 2025-07-31 | 2025-07-31 | 2128FS+4d | start no earlier than 2025-04-02 |
| 2130 | **Service Go-Live Governance** | 22d | 2025-07-31 | 2025-09-01 |  |  |
| 2131 | Service Management Go/No Go Decision | 0d | 2025-07-31 | 2025-07-31 | 2091, 2097, 2120, 2126 | start no earlier than 2025-07-31 |
| 2132 | Helix Service Management Live | 0d | 2025-09-01 | 2025-09-01 | 2131 | start no earlier than 2025-09-01 |
| 2204 | **SIT / LDSO Pathway 1** | 16d | 2025-07-23 | 2025-08-13 |  |  |
| 2207 | **SIT / LDSO Pathway 2** | 16d | 2025-08-07 | 2025-08-28 |  |  |
| 2208 | QAD Sign Off Deadline + Test Reports | 0d | 2025-08-07 | 2025-08-07 | 2203, 1692FF | start no earlier than 2025-08-07 |
| 2209 | REC Code Manager / BSC PAB Approval of Qualification (M10-Ready) | 0d | 2025-08-28 | 2025-08-28 | 2208FS+16d |  |
| 2210 | **SIT / LDSO Pathway 3** | 13d | 2025-08-22 | 2025-09-10 |  |  |
| 2211 | QAD Sign Off Deadline + Test Reports | 0d | 2025-08-22 | 2025-08-22 | 2203, 1763, 1692FF |  |
| 2212 | REC Code Manager / BSC PAB Approval of Qualification (M10-Ready) | 2d | 2025-09-09 | 2025-09-10 | 2211FS+11d |  |
| 2213 | 'M10-Ready SIT Participants are qualified' | 0d | 2025-09-10 | 2025-09-10 | 2212 |  |
| 2214 | **MHHS Qualification - M11-Ready** | 137d? | 2025-04-07 A | 2025-10-15 |  |  |
| 2215 | Final QAD Submission Window opens | 0d | 2025-04-07 A | 2025-04-07 A | 2198, 2194, 2199FS+1d |  |
| 2216 | SIT MVC Participants submit Final QAD (exc Test Reports) | 44d | 2025-04-08 | 2025-06-06 | 2215 |  |
| 2217 | Completion of Code Bodies review of Final QAD (M11-Ready) | 20d? | 2025-06-09 | 2025-07-04 | 2216 |  |
| 2218 | **SIT Pathway 4** | 16d | 2025-09-04 | 2025-09-25 |  |  |
| 2219 | QAD Sign Off Deadline + Test Reports | 0d | 2025-09-04 | 2025-09-04 | 2217, 1692FF | start no earlier than 2025-09-04 |
| 2220 | REC Code Manager / BSC PAB Approval of Qualification (M11-Ready) | 0d | 2025-09-25 | 2025-09-25 | 2219FS+16d |  |
| 2221 | **SIT Pathway 5** | 16d | 2025-09-24 | 2025-10-15 |  |  |
| 2222 | QAD Sign Off Deadline + Test Reports | 0d | 2025-09-24 | 2025-09-24 | 2217, 1692FF | start no earlier than 2025-09-24 |
| 2223 | REC Code Manager / BSC PAB Approval of Qualification | 0d | 2025-10-15 | 2025-10-15 | 2222FS+16d |  |
| 2224 | 'M11-Ready SIT Participants are qualified' | 0d | 2025-10-15 | 2025-10-15 | 2223 |  |
| 2229 | **SIT Pathway 6** | 15d | 2025-11-27 | 2025-12-17 |  |  |

Removed: 2745 Each LDSO and DCC completes investigation and resolution of exceptions; 2821 Programme SIT Participant Cutover Plan Assurance

Changed:

| ID | Task | Start | Finish | Duration | Complete | Total float | Predecessors | Other |
| --- | --- | --- | --- | --- | --- | --- | --- | --- |
| 545 | **SYSTEMS INTEGRATION TESTING (SIT)** |  |  |  | 78% → 76% |  |  |  |
| 1194 | **SIT Operational Preparation** |  |  |  | 97% → 98% |  |  |  |
| 1363 | **SIT Operational Programme RTTM (Theme 1, 2 & 3 (Batch 2))** |  |  |  | 56% → 75% |  |  |  |
| 1366 | DIP Manager / Code Bodies / Full SRO to review |  |  |  | 26% → 90% |  |  |  |
| 1432 | **Regression Test Preparation** |  |  |  | 90% → 95% |  |  |  |
| 1445 | **Regression Core Test Pack** |  | 2025-04-24 A |  | 99% → 100% | 7d → none |  |  |
| 1465 | SITAG (inc SRO) Approval of regression Core Pack | 2025-04-24 A | 2025-04-24 A |  | 0% → 100% | 7d → none |  |  |
| 1466 | SIT Regression Approval | 2025-04-24 A | 2025-04-24 A |  | 0% → 100% | 7d → none |  |  |
| 1467 | **Regression Test Data Load Window (SIT Functional and Migration) - SIT A** |  |  |  | 50% → 76% |  |  |  |
| 1468 | Data Load preparation activities |  | 2025-04-25 A |  | 85% → 100% | 6d → none |  |  |
| 1469 | Regression Test Data Load Start | 2025-04-28 A | 2025-04-28 A |  | 0% → 100% | 5d → none |  |  |
| 1470 | Regression Test Data Load Window | 2025-04-29 A |  |  | 0% → 43% |  |  |  |
| 1520 | **SIT Execution** |  |  |  | 57% → 49% |  |  |  |
| 1537 | **SIT** |  |  |  | 61% → 52% |  |  | was named SIT - Minimum Viable Cohort (MVC) |
| 1538 | **SIT Functional Testing (MVC)** |  |  |  | 71% → 58% |  |  |  |
| 1540 | **SIT Functional Testing Execution (Minimum Viable Cohort)** |  |  | 296d? → 295d? |  |  |  |  |
| 1564 | SIT Functional Cycle 3 Complete |  |  | 1d? → 0d |  |  |  |  |
| 1565 | **SIT Scope Traceability** |  | 2025-04-24 A |  | 99% → 100% | 695d → none |  |  |
| 1575 | SITAG approve SIT Scope Traceability document | 2025-04-24 A | 2025-04-24 A |  | 0% → 100% | 695d → none |  |  |
| 1576 | SIT Scope Traceability Approved | 2025-04-24 A | 2025-04-24 A |  | 0% → 100% | 695d → none |  |  |
| 1577 | **SIT Functional Settlement Testing** |  |  |  | 36% → 25% |  |  |  |
| 1601 | **SIT Functional Regression Testing (code freeze)** |  |  |  |  |  |  | was named SIT Functional MVC Regression Testing (code freeze) |
| 1607 | Regression Contingency Week |  |  |  |  |  | 1606 → 1606, 1620FF |  |
| 1608 | SIT Functional Testing End (incl. confirmation that PPs have submitted their Test Completion Reports to Programme for assurance) |  |  |  |  |  |  | was named SIT Functional Testing End (Minimum Viable Cohort) (incl. confirmation that PPs have submitted their Test Completion Reports to Programme for assurance) |
| 1610 | **SIT Functional & Migration Overarching Completion Report** | 2025-07-21 → 2025-04-28 A (-84d) | 2025-08-15 → 2025-06-18 (-58d) | 20d → 38d | 0% → 14% | 5d → 656d |  | was named SIT Functional Test Completion Report (Minimum Viable Cohort) |
| 1629 | SIT Functional Testing Test Completion Report Approved |  |  |  |  |  | 1628FF → 1628FF, 1624, 1625, 1607 | was named SIT Functional Testing Test Completion Report (Minimum Viable Cohort) Approved |
| 1662 | **SIT Migration Testing** |  |  |  | 77% → 57% |  |  | was named SIT Migration Testing (MVC) |
| 1664 | **SIT Migration Testing Execution** |  |  |  | 77% → 57% |  |  | was named SIT Migration Testing Execution (Minimum Viable Cohort) |
| 1689 | **SIT Migration Regression Testing (code freeze)** |  |  |  |  | 614d → 40d |  | was named SIT Migration MVC Regression Testing (code freeze) |
| 1695 | Regression Contingency Week |  |  |  |  |  | 1694 → 1694, 1707FF |  |
| 1696 | SIT Migration Testing End (incl. confirmation that PPs have submitted their Test Completion Reports to Programme for assurance) |  |  |  |  |  |  | was named SIT Migration Testing End (Minimum Viable Cohort) (incl. confirmation that PPs have submitted their Test Completion Reports to Programme for assurance) |
| 1697 | **SIT Functional & Migration Test Completion Report** | 2025-07-14 → 2025-04-28 A (-77d) | 2025-08-15 → 2025-06-18 (-58d) | 25d → 38d | 0% → 14% | 609d → 656d |  | was named SIT Migration Test Completion Report (Minimum Viable Cohort) |
| 1716 | SIT Migration Testing Test Completion Report Approved |  |  |  |  |  |  | was named SIT Migration Testing Test Completion Report (Minimum Viable Cohort) Approved |
| 1717 | SIT Migration Testing End (incl. confirmation that PPs have submitted their Test Completion Reports to Programme for assurance) |  |  |  |  |  | 1714FF, 1716 → 1714FF, 1716, 1711 | was named SIT Migration Testing End (Minimum Viable Cohort) (incl. confirmation that PPs have submitted their Test Completion Reports to Programme for assurance) |
| 1720 | **SIT Non-Functional Testing (all SIT PPs)** |  | 2025-06-06 → 2025-07-09 (+33d) | 70d? → 93d? | 37% → 27% | 60d → 641d |  |  |
| 1724 | Theme 2 & 3 SIT Non-Functional Testing Execution |  |  |  | 50% → 60% |  |  |  |
| 1727 | **SIT Non-Functional Testing Test Completion Report (all SIT PPs)** |  | 2025-05-30 → 2025-07-04 (+35d) | 20d → 45d |  |  |  |  |
| 1737 | SIT Non-Functional Testing Test Completion Report (all SIT PPs) Approved | 2025-06-06 → 2025-07-09 (+33d) | 2025-06-06 → 2025-07-09 (+33d) |  |  | 60d → 37d | 1736FF+5d → 1736FF+5d, 1732FS+3d |  |
| 1738 | **SIT Operational Testing (all SIT PPs)** |  | 2025-07-18 → 2025-08-06 (+19d) | 120d? → 133d? | 24% → 19% | 30d → 621d |  |  |
| 1742 | **SIT B Testing** |  |  |  | 18% → 24% |  |  |  |
| 1744 | SIT Operational Testing Execution Theme 1 |  |  |  | 35% → 45% |  |  |  |
| 1745 | SIT Operational Testing Execution Theme 2 | 2025-05-05 A |  |  | 0% → 2% |  |  |  |
| 1749 | **SIT Operational Testing Test Completion Report (all SIT PPs)** | 2025-06-16 → 2025-06-02 (-14d) | 2025-07-11 → 2025-08-01 (+21d) | 20d → 45d |  | 30d → 32d |  |  |
| 1759 | SIT Operational Testing Test Completion Report (all SIT PPs) Approved | 2025-07-18 → 2025-08-06 (+19d) | 2025-07-18 → 2025-08-06 (+19d) |  |  | 30d → 17d | 1758FF+5d → 1758FF+5d, 1754FS+3d |  |
| 1760 | **SIT Test Exit Report** |  |  |  |  |  |  | was named SIT MVC Test Exit Report |
| 1763 | SIT Complete (SIT Test Exit Report Approved) |  |  |  |  |  |  | was named SIT Minimum Viable Cohort Complete (SIT Minimum Viable Cohort Test Exit Report Approved) |
| 1764 | **SIT (Contingency)** |  |  |  |  |  |  | was named SIT (non-MVC) |
| 1765 | **SIT Functional Testing (Contingency)** |  |  |  |  |  |  | was named SIT Functional Testing (non-MVC) |
| 1766 | **SIT Functional Testing Execution (Contingency)** |  |  |  |  |  |  | was named SIT Functional Testing Execution (non-MVC) |
| 1768 | SIT Functional Testing End (Contingency) (incl. confirmation that PPs have submitted their Test Completion Reports to Programme for assurance) |  |  |  |  |  |  | was named SIT Functional Testing End (non-MVC) (incl. confirmation that PPs have submitted their Test Completion Reports to Programme for assurance) |
| 1770 | **SIT Functional Testing Test Completion Report (Contingency)** |  |  |  |  |  |  | was named SIT Functional Testing Test Completion Report (non-MVC) |
| 1773 | SIT Functional Testing Test Completion Report (Contingency) Approved |  |  |  |  |  |  | was named SIT Functional Testing Test Completion Report (non-MVC) Approved |
| 1774 | **SIT Migration Testing (Contingency)** |  |  |  |  |  |  | was named SIT Migration Testing (non-MVC) |
| 1776 | SIT Migration Testing End (Contingency) (incl. confirmation that PPs have submitted their Test Completion Reports to Programme for assurance) |  |  |  |  |  |  | was named SIT Migration Testing End (non-MVC) (incl. confirmation that PPs have submitted their Test Completion Reports to Programme for assurance) |
| 1778 | **SIT Migration Testing Test Completion Report (Contingency)** |  |  |  |  |  |  | was named SIT Migration Testing Test Completion Report (non-MVC) |
| 1781 | SIT Migration Testing Test Completion Report (Contingency) Approved |  |  |  |  |  |  | was named SIT Migration Testing Test Completion Report (non-MVC Approved) |
| 1782 | **SIT Contingency Test Exit Report** |  |  |  |  |  |  | was named SIT non-MVC Test Exit Report |
| 1785 | SIT Contingency Complete |  |  |  |  |  |  | was named SIT non-MVC Complete |
| 1916 | Migration Framework approved | 2025-04-30 A | 2025-04-30 A |  | 0% → 100% | 691d → none |  |  |
| 1917 | Migration Control Centre (MCC) delegation of authority approved | 2025-04-30 A | 2025-04-30 A |  | 0% → 100% | 691d → none |  |  |
| 1918 | Migration incentives implemented | 2025-04-30 A | 2025-04-30 A |  | 0% → 100% | 691d → none |  |  |
| 1922 | Early Life Support Model defined | 2025-04-29 A | 2025-04-29 A |  | 0% → 100% | 692d → none |  |  |
| 1925 | M10/M11 Cutover Plan in place | 2024-05-28 A | 2024-05-28 A |  | 0% → 100% | 932d → none |  |  |
| 1938 | Central systems ready for migrating MPANs (M10) |  |  |  |  |  | 1763FS+20d, 3288, 2970FS+2d, 2967, 2985, 2946, Programme SIT Participant Cutover Plan Assurance, 2953 → 1763FS+20d, 3288, 2970FS+2d, 2967, 2985, 2946, 2953 |  |
| 2045 | **Test Window** |  |  |  | 87% → 88% |  |  |  |
| 2046 | **All Non-SIT LDSOs Qualification Testing** |  |  |  | 95% → 96% | 1d → 0d |  |  |
| 2048 | LDSO Alpha |  | 2025-05-05 A |  | 97% → 100% | 9d → none |  |  |
| 2049 | LDSO Bravo |  | 2025-05-05 A |  | 99% → 100% | 9d → none |  |  |
| 2051 | LDSO Delta |  | 2025-04-30 A |  | 93% → 100% | 12d → none |  |  |
| 2056 | LDSO India |  | 2025-05-05 A |  | 99% → 100% | 9d → none |  |  |

| ID | Task | Start | Finish | Duration | Complete | Total float | Predecessors | Other |
| --- | --- | --- | --- | --- | --- | --- | --- | --- |
| 2061 | Non-SIT LDSOs submission deadline for their QT Test Completion Report to MHHS Programme |  |  |  |  |  | 2060, 2046 → 2060, 2046, 2057 |  |
| 2133 | **S & A QUALIFICATION** |  |  |  | 62% → 61% |  |  |  |
| 2134 | **MHHS Qualification - Qualification Deliverables** |  |  |  | 95% → 96% |  |  |  |
| 2162 | **Qualification Assessment Document** |  |  |  | 88% → 90% |  |  |  |
| 2181 | **Qualification Assessment Document Portal** |  |  |  | 78% → 82% |  |  |  |
| 2189 | QT Wave 1 Participant QAD Application Creation in Portal |  | 2025-05-02 A |  | 20% → 100% | 420d → none |  |  |
| 2195 | **MHHS Qualification - SIT Participants** |  |  | 248d → 248d? | 32% → 25% | 505d → 526d |  |  |
| 2200 | **MHHS Qualification - M10-Ready** |  | 2025-09-11 → 2025-09-10 (-1d) | 114d → 113d | 14% → 13% | 5d → 596d |  | was named MHHS Qualification - SIT MVC Participants |
| 2201 | Final QAD Submission Window opens |  |  |  |  |  |  | was named Final QAD Submission Window (MVC) opens |
| 2203 | Completion of Code Bodies review of Final QAD (M10-Ready) |  |  |  |  |  |  | was named Completion of Code Bodies review of Final QAD (MVC) |
| 2205 | QAD Sign Off Deadline + Test Reports | 2025-08-22 → 2025-07-23 (-30d) | 2025-08-22 → 2025-07-23 (-30d) |  |  | 5d → 616d | 1763, 2203, 1747 → 2203, 1692FF | was named QAD Sign Off Deadline (MVC) + Test Reports; constraint start no earlier than 2025-07-11 → start no earlier than 2025-07-23; baseline start 2025-08-22 → none; baseline finish 2025-08-22 → none |
| 2206 | REC Code Manager / BSC PAB Approval of Qualification | 2025-09-11 → 2025-08-13 (-29d) | 2025-09-11 → 2025-08-13 (-29d) |  |  | 5d → 616d | 2205FS+14d → 2205FS+16d | was named REC Code Manager / BSC PAB Approval of Qualification (MVC); baseline start 2025-09-11 → none; baseline finish 2025-09-11 → none |
| 2225 | **MHHS Qualification - Not M11-Ready** |  |  |  |  |  |  | was named MHHS Qualification - SIT Non-MVC Participants |
| 2226 | Final QAD Submission Window opens |  |  |  |  |  |  | was named Final QAD Submission Window (Non-MVC) opens |
| 2227 | SIT Not M11-Ready Participants submit Final QAD |  |  |  |  |  |  | was named SIT Non-MVC Participants submit Final QAD |
| 2228 | Completion of Code Bodies review of Final QAD (Not M11-Ready) |  |  |  |  |  |  | was named Completion of Code Bodies review of Final QAD (Non-MVC) |
| 2230 | QAD Sign Off Deadline (Not M11-Ready) |  |  |  |  |  |  | was named QAD Sign Off Deadline (Non-MVC) |
| 2231 | REC Code Manager / BSC PAB Approval of Qualification (Not M11-Ready) |  |  |  |  |  |  | was named REC Code Manager / BSC PAB Approval of Qualification (Non-MVC) |
| 2232 | **MHHS Qualification - Non-SIT LDSO (M10-Ready)** |  |  |  |  |  |  | was named MHHS Qualification - Non-SIT LDSO |
| 2239 | Non-SIT LDSO Participants submit Final QAD |  |  |  |  |  | 2238SS-1d → 2238SS-1d, 2057 | constraint none → finish no earlier than 2025-05-23 |
| 2554 | PAB293 | 2025-04-24 A | 2025-04-24 A |  | 0% → 100% | 696d → none |  |  |
| 2721 | **MIGRATION** |  |  |  | 58% → 60% |  |  |  |
| 2725 | **Migration Framework Agreed and Implemented** |  | 2025-04-29 A |  | 99% → 100% | 692d → none |  |  |
| 2748 | **Consultation 4** |  | 2025-04-29 A |  | 99% → 100% | 692d → none |  |  |
| 2759 | MCAG Approval of Consultation 4 | 2025-04-29 A | 2025-04-29 A |  | 0% → 100% | 692d → none |  |  |
| 2760 | Framework Baselined at MCAG | 2025-04-29 A | 2025-04-29 A |  | 0% → 100% | 692d → none |  |  |
| 2806 | **Migration Artefact Development and Publication** |  |  |  | 60% → 65% |  |  |  |
| 2849 | **Data Cleanse Plan** |  | 2025-10-15 → 2025-09-24 (-21d) | 685d → 670d | 90% → 92% | 571d → 586d |  |  |
| 2854 | **MTDs** |  |  |  | 70% → 77% |  |  |  |
| 2855 | **ESME ID** |  |  |  | 85% → 93% |  |  |  |
| 2859 | Suppliers complete Work Off plans |  |  |  | 83% → 92% |  |  |  |
| 2861 | **Meter Location and Number of Displayed Register Digits** |  |  |  | 57% → 64% |  |  |  |
| 2865 | Suppliers complete Work Off plans |  |  |  | 49% → 57% |  |  |  |
| 2867 | **Registration Data** |  | 2025-10-15 → 2025-09-24 (-21d) | 289d → 274d | 81% → 85% | 571d → 586d |  |  |
| 2876 | **Domestic Premises Indicator** |  | 2025-10-15 → 2025-09-24 (-21d) | 29d → 14d |  | 571d → 586d |  |  |
| 2880 | **Connection Type and Meter Type Misalignments** |  |  |  | 24% → 32% |  |  |  |
| 2881 | **Traditional Meters installed on Current Transformers** |  |  |  | 7% → 10% |  |  |  |
| 2882 | Suppliers investigate all MPANs with Traditional Meters installed on a Current Transformer Connection Type |  |  |  | 57% → 72% |  |  |  |
| 2888 | **CHECK Meters** |  |  |  | 57% → 72% |  |  |  |
| 2889 | Suppliers and their appointed Meter Operator investigate MPANs within their portfolio that have incorrectly populated meters with the Meter Type CHECK within MPRS. Meter Operators are required to send a D0312 to remove the CHECK meter from MPRS. |  |  |  | 57% → 72% |  |  |  |
| 2890 | Once CHECK meters are either removed from MPRS or the Meter Type is changed to a valid Meter Type, the LDSO should check that the Connection Type assigned to the MPAN is still valid. |  |  |  | 57% → 72% |  |  |  |
| 2893 | **Smart Meter Types installed on CT Connection Types** |  |  |  | 24% → 36% |  |  |  |
| 2895 | LDSOs investigate Connection Type misalignments and correct where appropriate |  |  |  | 44% → 64% |  |  |  |
| 2899 | **Linked Import / Export MPANs** |  |  |  | 30% → 45% |  |  |  |
| 2900 | LDSOs review and correct linked Import / Export MPANs with Different Connection Types |  |  |  | 30% → 45% |  |  |  |
| 2901 | LDSOs, Import and Export Suppliers review and correct linked Import / Export MPANs with meters in the Advanced and Traditional or Smart Meter Groups |  |  |  | 30% → 45% |  |  |  |
| 2903 | **Related MPANs** |  |  |  | 35% → 45% |  |  |  |
| 2904 | LDSOs review and correct related MPANs with different Connection Types |  |  |  | 46% → 59% |  |  |  |
| 2906 | Suppliers should investigate Related MPANs within different meter groups and verify that they are correct or request that their Meter Operators update the Meter Types where they are incorrect |  |  |  | 35% → 45% |  |  |  |
| 2938 | **Preparation for Cutover to Live** |  |  |  | 3% → 8% |  |  |  |
| 2939 | **Central Systems Prepare for Cutover to Live** |  |  |  | 7% → 19% |  |  |  |
| 2941 | **Development of Comms Approach and Declaration Guidance** |  |  |  | 3% → 6% |  |  |  |
| 2942 | Draft Cutover Comms Approach |  |  |  | 5% → 12% |  |  |  |
| 2947 | **Development of Cutover Plan requirements with Participants** |  |  |  | 10% → 26% |  |  |  |
| 2948 | Development of Central Parties Cutover Plans |  |  |  | 31% → 69% |  |  |  |
| 2949 | Development of Programme Participant Cutover Plans |  |  |  | 14% → 32% | 33d → 68d |  |  |
| 2950 | Central Party Cutover Plan Assurance |  |  |  | 16% → 38% |  |  |  |
| 3110 | **Early Life Support Model** |  | 2025-04-29 A |  | 99% → 100% | 692d → none |  |  |
| 3115 | MCAG Approval of Early Life Support Model | 2025-04-29 A | 2025-04-29 A |  | 0% → 100% | 692d → none |  |  |
| 3135 | Add EFD to DIP |  |  |  |  |  | 2206SS, 3133, 3132 → 3133, 3132, 2212SS+3d |  |

## Version 9 (data date 2025-05-21, saved 2025-05-22, file MHHS-DEL1139 - MHHS Plan v6.251.mpp)

Last finish stays 2027-12-23. Complete tasks 1789 → 1840.

Added:

| ID | Task | Duration | Start | Finish | Predecessors | Constraint |
| --- | --- | --- | --- | --- | --- | --- |
| 1612 | SRO Review PP Exit Reports | 2d | 2025-05-22 | 2025-05-23 | 1611SS | start no earlier than 2025-05-22 |
| 1626 | SRO Review SI SIT Settlement and Regression Overarching Exit Report | 5d | 2025-08-04 | 2025-08-08 | 1625SS | start no earlier than 2025-08-04 |
| 1631 | SITAG Approves SI SIT Functional & Migration (Post-Regression) Overarching Test Exit Report | 0d | 2025-08-20 | 2025-08-20 | 1629FF, 1625, 1627, 1607 | finish no earlier than 2025-08-20 |
| 1701 | SRO Review PP Exit Reports | 2d | 2025-05-22 | 2025-05-23 | 1700SS | start no earlier than 2025-05-22 |
| 1716 | SITWG Review status of SI SIT Settlement and Regression Overarching Exit Report | 0d | 2025-08-12 | 2025-08-12 |  | finish no earlier than 2025-08-12 |
| 1737 | SITWG Review status of SI SIT Non-Functional Overarching Exit Report | 0d | 2025-07-03 | 2025-07-03 |  | start no earlier than 2025-07-03 |
| 1741 | SITAG Approves SI SIT Non-Functional Overarching Test Exit Report | 0d | 2025-07-16 | 2025-07-16 | 1739FF+5d, 1735FS+3d | start no earlier than 2025-07-16 |
| 1751 | **SIT Operational Testing Re-test Theme 3 (Batch 1)** | 30d | 2025-05-05 A | 2025-06-13 |  |  |
| 1752 | SRO Review of re-testing approach | 10d | 2025-05-05 A | 2025-05-16 A |  | start no earlier than 2025-05-05 |
| 1753 | Scripts uploaded to ADO / Project Created | 5d | 2025-05-19 A | 2025-05-23 | 1752 |  |
| 1754 | SIT Operational Testing Re-test Execution Theme 3 (Batch 1) | 5d | 2025-06-09 | 2025-06-13 | 1753 | start no earlier than 2025-06-09 |
| 1768 | SITAG Approves SI SIT Operational Testing Test Exit Report | 0d | 2025-08-06 | 2025-08-06 | 1766FF+5d, 1762FS+3d | start no earlier than 2025-08-06 |
| 1881 | **Sandbox Testing Execution (UIT) - LDSO Participants** | 169d | 2025-06-02 | 2026-01-22 |  |  |
| 1882 | Sandbox Testing Start (UIT) - LDSO Participants | 0d | 2025-06-02 | 2025-06-02 | 1876 | finish no earlier than 2025-06-02 |
| 1883 | Sandbox Testing Execution (UIT) - LDSO Participants | 169d | 2025-06-02 | 2026-01-22 | 1882SS-1d | start no earlier than 2024-11-04 |
| 1884 | Sandbox Testing End (UIT) - LDSO Participants | 0d | 2026-01-22 | 2026-01-22 | 1883 |  |
| 2253 | QAD Finalisation | 45d | 2025-06-23 | 2025-08-22 | 2252 |  |
| 2813 | M11 Readiness Checkpoint | 45d | 2025-07-28 | 2025-09-26 |  | finish no earlier than 2025-09-26 |
| 3131 | **Phase 1 - Preparation** | 1d? | 2022-10-31 A | 2022-10-31 |  |  |
| 3132 | **Business Service Activation Governance, Planning & Scope** | 1d | 2022-10-31 | 2022-10-31 |  |  |
| 3133 | Create and Confirm SA Scope | 9d | 2024-06-03 A | 2024-06-13 A |  | start no earlier than 2024-06-03 |
| 3134 | POAP Service Activation | 13d | 2024-06-03 A | 2024-06-19 A |  | start no earlier than 2024-06-03 |
| 3135 | Service Activation Working Group | 62d | 2024-04-04 A | 2024-06-28 A |  | start no earlier than 2024-04-04 |
| 3136 | Business Readiness Governance Framework | 42d | 2024-08-02 A | 2024-09-30 A |  | start no earlier than 2024-08-02 |
| 3137 | Service Activation Governance Framework Completed | 0d | 2024-09-30 A | 2024-09-30 A | 3133, 3134, 3135, 3136 |  |
| 3138 | **Service Activation High Level Process Models** | 1d | 2022-10-31 | 2022-10-31 |  |  |
| 3139 | Transition Process Model | 70d | 2024-04-02 A | 2024-07-08 A |  | start no earlier than 2024-04-02 |
| 3140 | Migration Process Model | 14d | 2024-08-13 A | 2024-08-30 A |  | start no earlier than 2024-08-13 |
| 3141 | Enduring Process Model | 44d | 2024-06-03 A | 2024-08-01 A |  | start no earlier than 2024-06-03 |
| 3142 | Service Activation High Level Process Models Completed | 0d | 2024-08-30 A | 2024-08-30 A | 3139, 3140, 3141 |  |
| 3143 | **Target Operating Model for Service Activation** | 1d? | 2022-10-31 | 2022-10-31 |  |  |
| 3144 | MHHSP Engagement Team understanding | 25d | 2024-06-21 A | 2024-07-25 A |  | start no earlier than 2024-06-21 |
| 3145 | Define and produce organisation model for Service Activation in Elexon | 83d | 2024-06-21 A | 2024-10-15 A |  | start no earlier than 2024-06-21 |
| 3146 | Implement Target Operating model | 1d | 2024-10-15 A | 2024-10-15 A |  | start no earlier than 2024-10-15 |
| 3147 | Target Operating Model for Service Activation Completed | 0d | 2024-10-15 A | 2024-10-15 A | 3144, 3145, 3146 |  |
| 3148 | **SIT Operational Testing for Service Activation** | 5d | 2024-08-12 A | 2024-08-16 A |  |  |
| 3149 | Review and validate test cases | 5d | 2024-08-12 A | 2024-08-16 A |  | start no earlier than 2024-08-12 |
| 3150 | SIT Operational Testing for Service Activation Completed | 0d | 2024-08-16 A | 2024-08-16 A | 3149 |  |
| 3151 | **Operational Readiness E2E Testing** | 1d | 2022-10-31 | 2022-10-31 |  |  |
| 3152 | Define Service Activation Scenarios & Scripts | 25d | 2024-07-29 A | 2024-08-30 A |  | start no earlier than 2024-07-29 |
| 3153 | Define Service Activation Test plan | 10d | 2024-08-19 A | 2024-08-30 A |  | start no earlier than 2024-08-19 |
| 3154 | Test Execution [Placeholder] | 26d | 2025-04-01 | 2025-05-06 |  | start no earlier than 2025-04-01 |
| 3155 | Service Activation Test Scenarios Completed | 0d | 2025-05-06 | 2025-05-06 | 3154 |  |
| 3156 | **Operational Training for Service Activation** | 1d | 2022-10-31 | 2022-10-31 |  |  |
| 3157 | Training Execution [Placeholder] | 153d | 2024-11-13 | 2025-06-13 |  | start no earlier than 2024-11-13 |
| 3158 | Service Activation Training Completed | 0d | 2025-07-25 | 2025-07-25 |  | start no earlier than 2025-07-25 |
| 3159 | **Service Activation Readiness** | 1d | 2022-10-31 | 2022-10-31 |  |  |
| 3160 | Dress Rehearsal 1 | 2d | 2025-08-04 | 2025-08-05 | 3137, 3142, 3155, 3158, 3150 | start no earlier than 2025-08-04 |
| 3161 | Dress Rehearsal 1 Complete | 0d | 2025-08-05 | 2025-08-05 | 3160 |  |
| 3162 | Dress Rehearsal 2 | 2d | 2025-08-11 | 2025-08-12 | 3161FS+3d |  |
| 3163 | Dress Rehearsal 2 Complete | 0d | 2025-08-12 | 2025-08-12 | 3162 |  |
| 3164 | **Service Activation Go / No Go** | 1d? | 2022-10-31 | 2022-10-31 |  |  |
| 3165 | **Final Service Activation Go/No Go Decision** | 1d? | 2022-10-31 | 2022-10-31 |  |  |
| 3166 | DIP Team Ready | 1d? | 2025-08-22 | 2025-08-22 | 3160, 3162 | start no earlier than 2025-08-22 |
| 3167 | DIP Technical Onboarding Processes Completed | 0d | 2025-08-22 | 2025-08-22 |  | start no earlier than 2025-08-22 |
| 3168 | PM Team Ready | 1d? | 2025-08-21 | 2025-08-22 | 3160, 3162 | finish no earlier than 2025-08-22 |
| 3169 | Operational Support Ready (Ops Control Centre, Account Managers) | 1d? | 2025-08-21 | 2025-08-22 |  | finish no earlier than 2025-08-22 |
| 3170 | Service Management Activity Completed (Resolver Groups) | 1d? | 2025-08-21 | 2025-08-22 |  | finish no earlier than 2025-08-22 |
| 3171 | Process 1.1.1 ISD and Related LWIs Completed | 0d | 2025-08-22 | 2025-08-22 |  | start no earlier than 2025-08-22 |
| 3172 | Service Activation Go / No Go | 0d | 2025-08-22 | 2025-08-22 | 3167, 3171 |  |
| 3173 | **SOLR Consultation** | 1d | 2022-10-31 | 2022-10-31 | 3172 |  |
| 3174 | SOLR workshop 1 | 1d | 2024-04-10 A | 2024-04-10 A |  | start no earlier than 2024-04-10 |
| 3175 | SOLR workshop 2 | 1d | 2024-04-29 A | 2024-04-29 A |  | start no earlier than 2024-04-29 |
| 3176 | SOLR consultation | 23d | 2024-04-30 | 2024-05-30 |  | start no earlier than 2024-04-30 |
| 3177 | SOLR comms to MHHS for review | 0d | 2024-05-07 | 2024-05-07 |  | start no earlier than 2024-05-07 |
| 3178 | **MDR Process** | 1d | 2022-10-31 | 2022-10-31 |  |  |
| 3179 | MDR workshop 1 | 1d | 2025-04-16 A | 2025-04-16 A |  | start no earlier than 2024-04-16 |
| 3180 | MDR workshop 2 | 1d | 2025-04-30 A | 2025-04-30 A |  | start no earlier than 2024-04-30 |
| 3181 | MDR consultation | 18d | 2025-05-07 A | 2025-05-30 |  | start no earlier than 2024-05-07 |
| 3182 | **Phase 2 - Implementation** | 751d? | 2022-10-31 A | 2025-09-15 |  |  |
| 3183 | **Non-SIT LDSO & SIT MVC Data Loading (M10 Ready)** | 317d | 2024-06-07 A | 2025-08-25 |  |  |
| 3184 | Define Non-SIT LDSO Upfront Activities | 6d | 2024-06-07 A | 2024-06-14 A |  | finish no earlier than 2024-06-15 |
| 3185 | **Perform Non-SIT LDSO Activities (M10 Ready)** | 7d | 2025-08-15 | 2025-08-25 |  |  |
| 3186 | Create Entity Forms in Customer Solution | 2d | 2025-08-22 | 2025-08-25 |  | start no earlier than 2025-08-22 |
| 3187 | DIP - Add EFD to DIP | 2d | 2025-08-15 | 2025-08-18 |  | start no earlier than 2025-08-15 |
| 3188 | DIP - Promote to production Environment | 2d | 2025-08-19 | 2025-08-20 | 3187 |  |
| 3189 | DIP - Enable Technology capabilities for participants | 2d | 2025-08-15 | 2025-08-18 |  | start no earlier than 2025-08-15 |
| 3190 | ISD - Replicate Entity Forms from CS | 2d | 2025-08-15 | 2025-08-18 |  | start no earlier than 2025-08-15 |
| 3191 | ISD - Replicate Entity Forms from CS Completed | 0d | 2025-08-18 | 2025-08-18 | 3190, 3189 |  |
| 3192 | MDD - Load MHHS roles | 2d | 2025-08-15 | 2025-08-18 |  | start no earlier than 2025-08-15 |
| 3193 | Non-SIT LDSO Service Activation Data Loading Completed | 0d | 2025-08-25 | 2025-08-25 | 3190, 3191, 3192, 3185, 3187, 3188 |  |
| 3194 | **Non-SIT LDSO & SIT MCV Activation Preparation Tasks (M10 Ready)** | 1d? | 2022-10-31 | 2022-10-31 | 3186, 3188, 3189, 3193 |  |
| 3195 | Identify Resources | 1d | 2025-08-25 | 2025-08-25 | 3184, 3193FS-1d | start no earlier than 2025-08-25 |
| 3196 | Confirmation from Qualification of Wave Participants Complete | 0d | 2025-08-25 | 2025-08-25 |  | start no earlier than 2025-08-25 |
| 3197 | Agree & Understand Support Model | 1d | 2025-08-26 | 2025-08-26 |  | start no earlier than 2025-08-26 |
| 3198 | Confirm Training complete | 0d | 2025-08-27 | 2025-08-27 |  | start no earlier than 2025-08-27 |
| 3199 | Confirm IDNOs gobal sigin comleted prior to M10 | 1d | 2025-08-28 | 2025-08-28 |  | start no earlier than 2025-08-28 |
| 3200 | Engagement / Communications with Participants | 1d | 2025-08-29 | 2025-08-29 |  | start no earlier than 2025-08-29 |
| 3201 | **Internal Communications** | 1d | 2022-10-31 | 2022-10-31 |  |  |
| 3202 | Agree Content for Livewire | 1d | 2025-09-01 | 2025-09-01 |  | start no earlier than 2025-09-01 |
| 3203 | Publish Content for Livewire | 0d | 2025-09-01 | 2025-09-01 |  | start no earlier than 2025-09-01 |
| 3204 | Validate User Access | 1d | 2025-09-02 | 2025-09-02 |  | start no earlier than 2025-09-02 |
| 3205 | Target Systems and Environments Ready | 1d | 2025-09-03 | 2025-09-03 |  | start no earlier than 2025-09-03 |
| 3206 | Publish the guidence with Parties | 1d | 2025-09-04 | 2025-09-04 |  | start no earlier than 2025-09-04 |
| 3207 | Provide LWIs | 1d? | 2025-09-05 | 2025-09-05 |  | start no earlier than 2025-09-05 |
| 3208 | Business Readiness Governance Approval | 1d | 2025-09-05 | 2025-09-05 |  | start no earlier than 2025-09-05 |
| 3209 | Non-SIT LDSO & SIT MVC Service Activation Preparation Completed | 2d | 2025-09-05 | 2025-09-08 | 3195, 3197, 3198, 3199, 3200, 3201, 3204, 3205, 3206, 3208FS-1d |  |
| 3210 | **Non-SIT LDSO & SIT MVC Service Activation Implementation (M10 Ready Pathway 1)** | 1d? | 2022-10-31 | 2022-10-31 |  |  |
| 3211 | PAB Approval Completed | 0d | 2025-08-13 | 2025-08-13 | 2217 |  |
| 3212 | MHHSP Enabled Confirmation | 0d | 2025-08-13 | 2025-08-13 | 3211 |  |
| 3213 | Add EFD (ISD Calendar Date) to DIP | 1d | 2025-09-08 | 2025-09-08 | 3204, 3205, 3208, 3211, 3212, 3207 |  |
| 3214 | DIP Promoted to Production | 1d | 2025-09-09 | 2025-09-09 | 3213 |  |
| 3215 | Create M16 in Customer Solution Started | 0d | 2022-10-31 | 2022-10-31 |  |  |
| 3216 | Create M16 in Customer Solution | 1d | 2025-09-08 | 2025-09-08 | 3215SS, 3219SS |  |
| 3217 | DIP Production Success Checks | 1d? | 2022-10-31 | 2022-10-31 |  |  |
| 3218 | 1st ISD Publish Started | 0d | 2022-10-31 | 2022-10-31 |  |  |
| 3219 | 1st ISD Publish | 6d | 2025-09-08 | 2025-09-15 | 3213SS, 3218SS |  |
| 3220 | Go-Live ISD | 1d? | 2022-10-31 | 2022-10-31 |  |  |
| 3221 | Non-SIT LDSO SIT MVC Service Activation Implementation Completed | 0d | 2025-09-15 | 2025-09-15 | 3211, 3213, 3214, 3216, 3219 |  |
| 3222 | **Non-SIT LDSO & SIT MVC Service Activation Implementation MDD (M10 Ready)** | 1d | 2022-10-31 | 2022-10-31 | 3221 |  |
| 3223 | MDD Final Circular Completed | 0d | 2022-10-31 | 2022-10-31 |  |  |
| 3224 | MDD Manual Update | 3d | 2022-10-31 | 2022-11-02 | 3223SF |  |
| 3225 | MDD Publish | 6d | 2022-10-31 | 2022-11-07 | 3224SF |  |
| 3226 | MDD Go Live | 0d | 2022-11-07 | 2022-11-07 | 3225 |  |
| 3227 | Non-SIT LDSO & SIT MVC Service Activation Implementation MDD Completed | 0d | 2022-11-07 | 2022-11-07 | 3223, 3224, 3225, 3226 |  |
| 3228 | **Non-SIT LDSO & SIT MVC Service Activation Hypercare (M10 Ready)** | 1d | 2022-10-31 | 2022-10-31 | 3211, 3227 |  |
| 3229 | Monitoring | 54d | 2022-11-08 | 2023-01-20 | 3227 |  |
| 3230 | Reporting | 54d | 2022-11-08 | 2023-01-20 | 3227 |  |
| 3231 | Issue Management | 54d | 2022-11-08 | 2023-01-20 | 3227 |  |
| 3232 | Closed Down Activities | 1d | 2022-11-08 | 2022-11-08 | 3229SS, 3230SS, 3231SS |  |
| 3233 | Inform MHHSP | 1d | 2022-11-08 | 2022-11-08 | 3232SS |  |
| 3234 | Non-SIT LDSO Service &SIT MVC Activation Hypercare Completed | 0d | 2023-01-20 | 2023-01-20 | 3229, 3230, 3231, 3232, 3233 |  |
| 3235 | **Non-SIT LDSO & SIT MVC Service Activation Retro and Go/No-Go (M11 Ready)** | 1d | 2022-10-31 | 2022-10-31 |  |  |
| 3236 | Review | 0d | 2023-01-20 | 2023-01-20 | 3234 |  |
| 3237 | Lessons Learned | 5d | 2023-01-23 | 2023-01-27 | 3236 |  |
| 3238 | SIT Non-MVC Service Activation Readiness Review Against Entry/Exit Criteria | 5d | 2023-01-30 | 2023-02-03 | 3237 |  |
| 3239 | **SIT Non-MVC Service Activation Preparation Tasks (M11 Not Ready)** | 1d | 2022-10-31 | 2022-10-31 |  |  |
| 3240 | Review Entry/Exit Criteria & Lessons Learned | 0d | 2022-10-31 | 2022-10-31 |  |  |
| 3241 | Identify Resources | 1d | 2022-10-31 | 2022-10-31 |  |  |
| 3242 | Confirmation from Qualification of Wave Participants Complete | 0d | 2022-10-31 | 2022-10-31 |  |  |
| 3243 | Agree & Understand Support Model | 2d | 2022-10-31 | 2022-11-01 |  |  |
| 3244 | Confirm Training complete | 1d | 2022-10-31 | 2022-10-31 |  |  |
| 3245 | Engagement / Communications with Participants | 1d | 2022-10-31 | 2022-10-31 |  |  |
| 3246 | **Internal Communications** | 1d | 2022-10-31 | 2022-10-31 |  |  |
| 3247 | Agree Content for Livewire | 1d | 2022-10-31 | 2022-10-31 |  |  |
| 3248 | Publish Content for Livewire | 0d | 2022-10-31 | 2022-10-31 |  |  |
| 3249 | Validate User Access | 1d | 2022-10-31 | 2022-10-31 |  |  |
| 3250 | Target Systems and Environments Ready | 1d | 2022-10-31 | 2022-10-31 |  |  |
| 3251 | Provide LWIs | 1d | 2022-10-31 | 2022-10-31 |  |  |
| 3252 | Business Readiness Governance Approval | 1d | 2022-10-31 | 2022-10-31 |  |  |
| 3253 | SIT Non-MVC Service Activation Preparation Tasks Completed | 0d | 2022-11-01 | 2022-11-01 | 3241, 3243, 3244, 3245, 3246, 3249, 3250, 3251, 3252 |  |
| 3254 | **SIT Non-MVC Service Activation Implementation (M11 Not Ready)** | 1d | 2022-10-31 | 2022-10-31 |  |  |
| 3255 | MHHSP Enabled Confirmation | 1d | 2022-10-31 | 2022-10-31 |  |  |
| 3256 | PAB Approval | 0d | 2022-10-31 | 2022-10-31 |  |  |
| 3257 | Add EFD(ISD Calendar Date) to DIP | 2d | 2022-11-01 | 2022-11-02 | 3249, 3250, 3251, 3252, 3255, 3256 |  |
| 3258 | DIP Promoted to Production | 1d | 2022-11-01 | 2022-11-01 | 3257SS |  |
| 3259 | Create M16 in Customer Solution | 1d | 2022-10-31 | 2022-10-31 |  |  |
| 3260 | DIP Production Success Checks | 7d | 2022-11-03 | 2022-11-11 | 3257, 3259 |  |
| 3261 | Publish ISD | 5d | 2022-11-01 | 2022-11-07 | 3257SS |  |
| 3262 | Go Live ISD | 0d | 2022-11-07 | 2022-11-07 | 3261 |  |
| 3263 | SIT Non-MVC Service Activation Implementation Completed | 0d | 2022-11-11 | 2022-11-11 | 3255, 3256, 3257, 3258, 3259, 3260, 3261, 3262 |  |
| 3264 | **SIT Non-MVC Service Activation Implementation MDD (M11 Not Ready)** | 1d | 2022-10-31 | 2022-10-31 |  |  |
| 3265 | MDD Final Circular | 0d | 2022-10-31 | 2022-10-31 | 3256 |  |
| 3266 | MDD Manual Update | 3d | 2022-10-31 | 2022-11-02 | 3265SF |  |
| 3267 | MDD Publish | 5d | 2022-10-31 | 2022-11-04 | 3266SF |  |
| 3268 | MDD Go Live | 0d | 2022-11-04 | 2022-11-04 | 3267 |  |
| 3269 | SIT Non-MVC Service Activation Implementation MDD Completed | 0d | 2022-11-04 | 2022-11-04 | 3265, 3268 |  |
| 3270 | **SIT Non-MVC Service Activation Hypercare (M11 Not Ready)** | 1d | 2022-10-31 | 2022-10-31 |  |  |
| 3271 | Monitoring | 11d | 2022-10-31 | 2022-11-14 |  |  |
| 3272 | Reporting | 11d | 2022-10-31 | 2022-11-14 |  |  |
| 3273 | Issue Management | 11d | 2022-10-31 | 2022-11-14 |  |  |
| 3274 | Closed Down Activities | 3d | 2022-10-31 | 2022-11-02 | 3271SS, 3272SS, 3273SS |  |
| 3275 | Inform MHHSP | 2d | 2022-10-31 | 2022-11-01 | 3274SS |  |
| 3276 | Non-SIT LDSO Service Activation Hypercare Completed | 0d | 2022-11-14 | 2022-11-14 | 3271, 3272, 3273, 3274, 3275 |  |
| 3277 | **SIT Non-MVC Service Activation Retro & Go/No Go (M11 Not Ready)** | 1d | 2022-10-31 | 2022-10-31 |  |  |
| 3278 | Review | 0d | 2022-10-31 | 2022-10-31 |  |  |
| 3279 | Lessons Learned | 5d | 2022-10-31 | 2022-11-04 | 3278SS |  |
| 3280 | Wave 1 - Service Activation Readiness Review Against Entry/Exit Criteria | 5d | 2022-11-07 | 2022-11-11 | 3279 |  |

Removed: 1626 SRO Review Settlement and Regression Overarching Completion Report; 1712 SITWG Review status of Settlement and Regression Overarching Completion Report; 1733 SITWG Review status of Non-Functional Overarching Completion Report; 1809 Submit proposed version to QWG; 1810 Discuss document at QWG; 2944 Development of Implementation Group; 2945 Implementation Group Established

Changed:

| ID | Task | Start | Finish | Duration | Complete | Total float | Predecessors | Other |
| --- | --- | --- | --- | --- | --- | --- | --- | --- |
| 113 | Publish updated baselined artefacts |  | 2023-06-12 A → 2023-06-06 A (-6d) |  |  |  |  |  |
| 546 | **SIT Preparation** |  | 2025-05-16 → 2025-05-23 (+7d) | 665d? → 670d? |  | 679d → 674d |  |  |
| 627 | **SIT Stage-Specific Preparation** |  | 2025-05-16 → 2025-05-23 (+7d) | 665d? → 670d? |  | 679d → 674d |  |  |
| 639 | Development of test scenarios |  | 2023-04-28 A → 2023-01-02 A (-116d) |  |  |  |  |  |
| 640 | Review test scenarios with SIT Working Group |  | 2023-08-09 A → 2023-02-15 A (-175d) |  |  |  |  |  |
| 1194 | **SIT Operational Preparation** |  | 2025-04-25 → 2025-05-23 (+28d) | 650d? → 670d? |  | 694d → 674d |  |  |
| 1363 | **SIT Operational Programme RTTM (Theme 1, 2 & 3 (Batch 2))** |  | 2025-04-25 → 2025-05-23 (+28d) | 80d → 100d |  | 694d → 674d |  |  |
| 1369 | SIT Operational (Theme 1, 2 & 3 (Batch 2)) RTTM Complete | 2025-04-25 → 2025-05-23 (+28d) | 2025-04-25 → 2025-05-23 (+28d) |  |  | 694d → 674d |  | constraint start no earlier than 2025-03-28 → finish no earlier than 2025-05-23 |
| 1432 | **Regression Test Preparation** |  |  |  | 95% → 100% |  |  |  |
| 1467 | **Regression Test Data Load Window (SIT Functional and Migration) - SIT A** |  |  |  | 76% → 100% |  |  |  |
| 1470 | Regression Test Data Load Window |  | 2025-05-16 A |  | 43% → 100% | 5d → none |  |  |
| 1520 | **SIT Execution** |  |  |  | 49% → 52% |  |  |  |
| 1537 | **SIT** |  | 2025-08-22 → 2025-08-27 (+5d) | 380d? → 383d? | 52% → 54% | 609d → 606d |  |  |
| 1538 | **SIT Functional Testing (MVC)** |  | 2025-08-15 → 2025-08-20 (+5d) | 375d? → 378d? | 58% → 61% | 614d → 611d |  |  |
| 1577 | **SIT Functional Settlement Testing** |  |  |  | 25% → 29% |  |  |  |
| 1596 | **SIT-A Settlement Testing** | 2025-05-19 A |  |  | 0% → 10% | 5d → 10d |  |  |
| 1597 | SIT-A Settlement Testing Start | 2025-05-19 A | 2025-05-19 A |  | 0% → 100% | 5d → none |  |  |
| 1598 | SIT-A Settlement Testing | 2025-05-20 A |  |  | 0% → 10% | 5d → 10d |  |  |
| 1608 | SIT Functional Testing End |  |  |  |  | 5d → 10d |  | was named SIT Functional Testing End (incl. confirmation that PPs have submitted their Test Completion Reports to Programme for assurance) |
| 1610 | **SIT Functional & Migration Overarching Exit Report** |  |  |  | 14% → 36% |  |  | was named SIT Functional & Migration Overarching Completion Report |
| 1611 | Programme drafts Functional & Migration PP Exit Report |  | 2025-05-16 → 2025-05-23 (+7d) | 15d → 20d | 47% → 90% | 656d → 674d |  | was named Programme drafts Functional & Migration Overarching Report Proformas; baseline start none → 2025-04-28; baseline finish none → 2025-05-23 |
| 1613 | Functional & Migration PP Exit Reports shared with PPs | 2025-05-16 → 2025-05-23 (+7d) | 2025-05-16 → 2025-05-23 (+7d) |  |  | 656d → 658d | 1611 → 1612 | was named Functional & Migration Overarching Proformas shared with PPs; constraint none → finish no earlier than 2025-05-23; baseline start none → 2025-05-23; baseline finish none → 2025-05-23 |
| 1614 | PPs complete and return Exit Reports | 2025-05-19 → 2025-05-26 (+7d) | 2025-05-30 → 2025-06-06 (+7d) |  |  | 666d → 661d |  | was named PPs complete and return Completion Report Proformas; constraint none → start no earlier than 2025-05-26; baseline start none → 2025-05-26; baseline finish none → 2025-06-06 |
| 1615 | PPs Exit Report submission deadline | 2025-05-30 → 2025-06-06 (+7d) | 2025-05-30 → 2025-06-06 (+7d) |  |  | 666d → 661d |  | was named PPs Completion Report Proforma deadline; constraint none → start no earlier than 2025-06-06; baseline start none → 2025-06-06; baseline finish none → 2025-06-06 |
| 1616 | Programme drafts SI SIT Functional & Migration Overarching Exit Report | 2025-05-19 → 2025-05-26 (+7d) | 2025-06-13 → 2025-06-11 (-2d) | 20d → 13d |  | 656d → 658d |  | was named Programme drafts Functional & Migration Overarching Completion Report; constraint none → start no earlier than 2025-05-26; baseline start none → 2025-05-26; baseline finish none → 2025-06-11 |
| 1617 | SITWG Review status of SI SIT Functional & Migration Overarching Exit Report |  |  |  |  |  | none → 1616SS | was named SITWG Review status of Functional & Migration Overarching Completion Report; baseline start none → 2025-06-05; baseline finish none → 2025-06-05 |
| 1618 | SRO Review SI SIT Functional & Migration Overarching Exit Report |  |  |  |  |  |  | was named SRO Review Functional & Migration Overarching Completion Report; baseline start none → 2025-06-02; baseline finish none → 2025-06-06 |
| 1619 | SITAG endorses the SI SIT Functional & Migration Overarching Test Exit Report |  |  |  |  |  |  | was named SITAG endorses the Functional & Migration Overarching Test Completion Report; constraint none → finish no earlier than 2025-06-18; baseline start none → 2025-06-18; baseline finish none → 2025-06-18 |
| 1620 | **SIT Settlement and Regression Test Exit Report** |  | 2025-08-15 → 2025-08-20 (+5d) | 35d → 38d |  | 5d → 10d |  | was named SIT Settlement and Regression Test Completion Report; baseline start none → 2025-06-30; baseline finish none → 2025-08-15 |
| 1621 | Programme drafts Settlement and Regression PP Exit Reports (when Participant completes Regression testing) |  |  |  |  | 5d → 10d |  | was named Programme drafts Settlement and Regression Completion Report Proformas (when Participant completes Regression testing); baseline start none → 2025-06-30; baseline finish none → 2025-08-08 |
| 1622 | All Settlement and Regression PP Exit Reports shared with PPs |  |  |  |  |  |  | was named Settlement and Regression Completion Proformas shared with PPs; baseline start none → 2025-08-08; baseline finish none → 2025-08-08 |
| 1623 | PPs complete and return Exit Reports |  | 2025-08-15 → 2025-08-08 (-7d) | 30d → 25d |  | 5d → 15d |  | was named PPs complete and return Completion Report Proformas; baseline start none → 2025-07-07; baseline finish none → 2025-08-08 |
| 1624 | PPs Exit Report and Regression Exit Decleration submission deadline | 2025-08-15 → 2025-08-08 (-7d) | 2025-08-15 → 2025-08-08 (-7d) |  |  | 614d → 619d | 1623, 1712 → 1623 | was named PPs Completion Report Proforma deadline; constraint none → finish no earlier than 2025-08-08; baseline start none → 2025-08-08; baseline finish none → 2025-08-08 |
| 1625 | Programme drafts SI SIT Settlement and Regression Overarching Exit Report |  | 2025-08-15 → 2025-08-08 (-7d) | 30d → 25d |  | 5d → 15d |  | was named Programme drafts Settlement and Regression Overarching Completion Report; baseline start none → 2025-07-07; baseline finish none → 2025-08-08 |
| 1627 | SITWG Review status of SI SIT Settlement and Regression Overarching Exit Report | 2025-08-07 → 2025-08-12 (+5d) | 2025-08-07 → 2025-08-12 (+5d) |  |  | 12d → 13d | none → 1625 | was named SITWG Review status of Settlement and Regression Overarching Completion Report; constraint start no earlier than 2025-08-07 → finish no earlier than 2025-08-12; baseline start none → 2025-08-12; baseline finish none → 2025-08-12 |
| 1630 | SI SIT Functional Testing Test Exit Report Approved | 2025-08-15 → 2025-08-20 (+5d) | 2025-08-15 → 2025-08-20 (+5d) |  |  | 5d → 8d |  | was named SIT Functional Testing Test Completion Report Approved; constraint none → start no earlier than 2025-08-20; baseline start 2025-08-15 → 2025-08-20; baseline finish 2025-08-15 → 2025-08-20 |
| 1664 | **SIT Migration Testing** |  | 2025-08-22 → 2025-08-27 (+5d) | 380d? → 383d? | 57% → 61% | 609d → 606d |  |  |
| 1666 | **SIT Migration Testing Execution** |  | 2025-08-22 → 2025-08-27 (+5d) | 380d? → 383d? | 57% → 61% | 609d → 606d |  |  |
| 1699 | **SIT Functional & Migration Test Exit Report** |  |  |  | 14% → 36% |  |  | was named SIT Functional & Migration Test Completion Report |
| 1700 | Programme drafts Functional & Migration PP Exit Report |  | 2025-05-16 → 2025-05-23 (+7d) | 15d → 20d | 47% → 90% | 656d → 674d |  | was named Programme drafts Functional & Migration Completion Report Proformas; baseline start none → 2025-04-28; baseline finish none → 2025-05-23 |
| 1702 | Functional & Migration PP Exit Reports shared with PPs | 2025-05-16 → 2025-05-23 (+7d) | 2025-05-16 → 2025-05-23 (+7d) |  |  | 656d → 658d | 1700 → 1701 | was named Functional & Migration Completion Proformas shared with PPs; baseline start none → 2025-05-23; baseline finish none → 2025-05-23 |
| 1703 | PPs complete and return Exit Reports | 2025-05-19 → 2025-05-26 (+7d) | 2025-05-30 → 2025-06-06 (+7d) |  |  | 666d → 661d |  | was named PPs complete and return Completion Report Proformas; baseline start none → 2025-05-26; baseline finish none → 2025-06-06 |
| 1704 | PPs Exit Report submission deadline | 2025-05-30 → 2025-06-06 (+7d) | 2025-05-30 → 2025-06-06 (+7d) |  |  | 669d → 664d |  | was named PPs Completion Report Proforma deadline; baseline start none → 2025-06-06; baseline finish none → 2025-06-06 |
| 1705 | Programme drafts SI SIT Functional & Migration Overarching Exit Report | 2025-05-19 → 2025-05-26 (+7d) | 2025-06-13 → 2025-06-11 (-2d) | 20d → 13d |  | 656d → 658d |  | was named Programme drafts Functional & Migration Overarching Completion Report; constraint finish no earlier than 2025-06-13 → start no earlier than 2025-05-26; baseline start none → 2025-05-26; baseline finish none → 2025-06-11 |
| 1706 | SITWG Review status of Functional & Migration Overarching Completion Report |  |  |  |  |  |  | baseline start none → 2025-06-05; baseline finish none → 2025-06-05 |
| 1707 | SRO Review SI SIT Functional & Migration Overarching Exit Report |  |  |  |  |  |  | was named SRO Review Functional & Migration Overarching Completion Report; baseline start none → 2025-06-02; baseline finish none → 2025-06-06 |
| 1708 | SITAG endorses the SI SIT Functional & Migration Overarching Test Exit Report |  |  |  |  |  |  | was named SITAG endorses the Functional & Migration Overarching Test Completion Report; constraint none → finish no earlier than 2025-06-18; baseline start none → 2025-06-18; baseline finish none → 2025-06-18 |
| 1709 | **SIT Settlement and Regression Test Exit Report** |  | 2025-08-15 → 2025-08-27 (+12d) | 35d → 43d |  | 614d → 20d |  | was named SIT Settlement and Regression Test Completion Report |
| 1710 | Programme drafts Settlement and Regression PP Exit Report (when Participant completes Regression testing) |  |  |  |  |  |  | was named Programme drafts Settlement and Regression Completion Report Proformas (when Participant completes Regression testing); baseline start none → 2025-06-30; baseline finish none → 2025-08-08 |
| 1711 | All Settlement and Regression PP Exit Reports shared with PPs |  |  |  |  |  |  | was named Settlement and Regression Completion Proformas shared with PPs; baseline start none → 2025-08-08; baseline finish none → 2025-08-08 |
| 1712 | PPs complete and return PP Exit Reports |  | 2025-08-15 → 2025-08-08 (-7d) | 30d → 25d |  | 614d → 15d |  | was named PPs complete and return Completion Report Proformas; constraint finish no earlier than 2025-08-15 → start no earlier than 2025-07-07; baseline start none → 2025-07-07; baseline finish none → 2025-08-08 |
| 1713 | PPs Exit Report and Regression Exit Deceleration submission deadline | 2025-08-15 → 2025-08-08 (-7d) | 2025-08-15 → 2025-08-08 (-7d) |  |  | 614d → 619d |  | was named PPs Completion Report Proforma deadline; constraint start no earlier than 2025-08-15 → finish no earlier than 2025-08-08; baseline start none → 2025-08-08; baseline finish none → 2025-08-08 |
| 1714 | Programme drafts SI SIT Settlement and Regression Overarching Exit Report |  | 2025-08-15 → 2025-08-08 (-7d) | 30d → 25d |  | 609d → 614d |  | was named Programme drafts Settlement and Regression Overarching Completion Report; constraint finish no earlier than 2025-08-15 → start no earlier than 2025-07-07; baseline start none → 2025-07-07; baseline finish none → 2025-08-08 |
| 1715 | SRO Review SI SIT Settlement and Regression Overarching Exit Report |  |  |  |  |  |  | was named SRO Review Settlement and Regression Overarching Completion Report; baseline start none → 2025-08-04; baseline finish none → 2025-08-08 |
| 1719 | SIT Migration Testing Test Exit Report Approved | 2025-08-15 → 2025-08-20 (+5d) | 2025-08-15 → 2025-08-20 (+5d) |  |  | 609d → 7d |  | was named SIT Migration Testing Test Completion Report Approved; constraint none → finish no earlier than 2025-08-20; baseline start 2025-08-15 → 2025-08-20; baseline finish 2025-08-15 → 2025-08-20 |
| 1720 | SIT Migration Testing End (incl. confirmation that PPs have submitted their Test Exit Reports to Programme for assurance) |  |  |  |  |  | 1717FF, 1719, 1714 → 1717FF, 1714 | was named SIT Migration Testing End (incl. confirmation that PPs have submitted their Test Completion Reports to Programme for assurance); constraint start no earlier than 2025-03-14 → finish no earlier than 2025-08-15 |
| 1721 | SITAG Approves SI SIT Functional & Migration (Post-Regression) Overarching Test Exit Report | 2025-08-15 → 2025-08-20 (+5d) | 2025-08-15 → 2025-08-20 (+5d) |  |  | 614d → 606d | 1714, 1720, 1697, 1708 → 1717FF, 1714 | was named SITAG Approves Functional & Migration (Post-Regression) Overarching Test Completion Report; constraint none → finish no earlier than 2025-08-20; baseline start none → 2025-08-20; baseline finish none → 2025-08-20 |
| 1722 | Assurance of PPs Test Completion Reports | 2025-07-14 → 2025-07-17 (+3d) | 2025-08-22 → 2025-08-27 (+5d) |  |  | 609d → 606d | 1720FF+5d → 1720FF+5d, 1721FF+5d |  |
| 1723 | **SIT Non-Functional Testing (all SIT PPs)** |  | 2025-07-09 → 2025-07-16 (+7d) | 93d? → 98d? | 27% → 29% | 641d → 636d |  |  |
| 1727 | Theme 2 & 3 SIT Non-Functional Testing Execution |  |  |  | 60% → 65% |  |  |  |
| 1730 | **SIT Non-Functional Testing Test Exit Report (all SIT PPs)** |  | 2025-07-04 → 2025-07-16 (+12d) | 45d → 53d |  |  |  | was named SIT Non-Functional Testing Test Completion Report (all SIT PPs) |
| 1731 | Programme drafts Non-Functional PP Exit Report |  |  |  |  |  |  | was named Programme drafts Non-Functional Completion Report Proformas; baseline start none → 2025-05-26; baseline finish none → 2025-06-13 |
| 1732 | Non-Functional PP Exit Reports shared with PPs |  |  |  |  |  |  | was named Non-Functional Completion Proformas shared with PPs; baseline start none → 2025-06-13; baseline finish none → 2025-06-13 |
| 1733 | PPs complete and return PP Exit Reports | 2025-06-09 → 2025-06-16 (+7d) |  | 15d → 10d |  |  |  | was named PPs complete and return Completion Report Proformas; baseline start none → 2025-06-16; baseline finish none → 2025-06-27 |
| 1734 | PPs Exit Report submission deadline |  |  |  |  |  |  | was named PPs Completion Report Proforma deadline; baseline start none → 2025-06-27; baseline finish none → 2025-06-27 |
| 1735 | Programme drafts SI SIT Non-Functional Overarching Exit Report |  |  |  |  |  |  | was named Programme drafts Non-Functional Overarching Completion Report; baseline start none → 2025-06-16; baseline finish none → 2025-07-04 |
| 1736 | SRO Review SI SIT Non-Functional Overarching Exit Report |  |  |  |  |  |  | was named SRO Review Non-Functional Overarching Completion Report; baseline start none → 2025-06-23; baseline finish none → 2025-06-27 |
| 1740 | SIT Non-Functional Testing Test Exit Report (all SIT PPs) Approved | 2025-07-09 → 2025-07-16 (+7d) | 2025-07-09 → 2025-07-16 (+7d) |  |  | 37d → 32d |  | was named SIT Non-Functional Testing Test Completion Report (all SIT PPs) Approved; constraint none → finish no earlier than 2025-07-16; baseline start 2025-06-06 → 2025-07-16; baseline finish 2025-06-06 → 2025-07-16 |
| 1742 | **SIT Operational Testing (all SIT PPs)** |  |  |  | 19% → 30% |  |  |  |
| 1746 | **SIT B Testing** |  |  |  | 24% → 47% |  |  |  |

| ID | Task | Start | Finish | Duration | Complete | Total float | Predecessors | Other |
| --- | --- | --- | --- | --- | --- | --- | --- | --- |
| 1748 | SIT Operational Testing Execution Theme 1 |  |  |  | 45% → 50% |  |  |  |
| 1749 | SIT Operational Testing Execution Theme 2 |  |  |  | 2% → 60% |  |  |  |
| 1755 | SIT Operational Testing End (all SIT PPs) (incl. confirmation that PPs have submitted their Test Completion Reports to Programme for assurance) |  |  |  |  |  | 1745, 1748, 1749, 1750 → 1745, 1748, 1749, 1750, 1754 |  |
| 1757 | **SIT Operational Testing Test Exit Report (all SIT PPs)** |  | 2025-08-01 → 2025-08-06 (+5d) | 45d → 48d |  |  |  | was named SIT Operational Testing Test Completion Report (all SIT PPs) |
| 1758 | Programme drafts PP Exit Report (when Participant completes Operational testing) |  |  |  |  |  |  | was named Programme drafts Operational Completion Report Proformas (when Participant completes Operational testing); baseline start none → 2025-06-02; baseline finish none → 2025-07-11 |
| 1759 | All Operational Completion PP Exit Reports have been shared with PPs |  |  |  |  |  |  | was named All Operational Completion Proformas have been shared with PPs; baseline start none → 2025-07-11; baseline finish none → 2025-07-11 |
| 1760 | PPs complete and return PP Exit Reports | 2025-06-16 → 2025-06-13 (-3d) |  | 30d → 31d |  | 22d → 23d |  | was named PPs complete and return Completion Report Proformas; constraint start no earlier than 2025-06-16 → start no earlier than 2025-06-13; baseline start none → 2025-06-13; baseline finish none → 2025-07-25 |
| 1761 | PPs Exit Report submission deadline |  |  |  |  |  |  | was named PPs Completion Report Proforma deadline; baseline start none → 2025-07-25; baseline finish none → 2025-07-25 |
| 1762 | Programme drafts SI SIT Operational Overarching Exit Report |  |  |  |  |  |  | was named Programme drafts Operational Overarching Completion Report; baseline start none → 2025-06-23; baseline finish none → 2025-08-01 |
| 1763 | SITWG Review status of SI SIT Operational Overarching Exit Report |  |  |  |  |  |  | was named SITWG Review status of Operational Overarching Completion Report; baseline start none → 2025-07-03; baseline finish none → 2025-07-03 |
| 1764 | SRO Review SI SIT Operational Overarching Exit Report |  |  |  |  |  |  | was named SRO Review Operational Overarching Completion Report; baseline start none → 2025-07-21; baseline finish none → 2025-07-25 |
| 1765 | Develop document |  |  |  |  |  |  | baseline start 2025-06-23 → 2025-06-16; baseline finish 2025-07-11 → 2025-07-04 |
| 1766 | Review & agree document |  |  |  |  |  |  | baseline start 2025-07-14 → 2025-07-07; baseline finish 2025-07-18 → 2025-07-11 |
| 1767 | SIT Operational Testing Test Exit Report (all SIT PPs) Approved |  |  |  |  |  |  | was named SIT Operational Testing Test Completion Report (all SIT PPs) Approved; baseline start 2025-07-25 → 2025-08-06; baseline finish 2025-07-25 → 2025-08-06 |
| 1772 | SIT Complete (SIT Test Exit Report Approved) |  |  |  |  |  | 1536, 1630FS+5d, 1740, 1767 → 1536, 1630, 1740, 1767, 1719, 1768, 1741, 1631 | constraint none → finish no earlier than 2025-08-22 |
| 1777 | SIT Functional Testing End (Contingency) (incl. confirmation that PPs have submitted their Test Exit Reports to Programme for assurance) |  |  |  |  |  |  | was named SIT Functional Testing End (Contingency) (incl. confirmation that PPs have submitted their Test Completion Reports to Programme for assurance) |
| 1778 | Assurance of PPs Test Exit Reports |  |  |  |  |  |  | was named Assurance of PPs Test Completion Reports |
| 1782 | SIT Functional Testing Test Exit Report (Contingency) Approved |  |  |  |  |  |  | was named SIT Functional Testing Test Completion Report (Contingency) Approved |
| 1785 | SIT Migration Testing End (Contingency) (incl. confirmation that PPs have submitted their Test Exit Reports to Programme for assurance) |  |  |  |  |  |  | was named SIT Migration Testing End (Contingency) (incl. confirmation that PPs have submitted their Test Completion Reports to Programme for assurance) |
| 1786 | Assurance of PPs Test Exit Reports |  |  |  |  |  |  | was named Assurance of PPs Test Completion Reports |
| 1790 | SIT Migration Testing Test Exit Report (Contingency) Approved |  |  |  |  |  |  | was named SIT Migration Testing Test Completion Report (Contingency) Approved |
| 1795 | **UIT Environment Preparation** |  | 2025-06-06 → 2025-06-19 (+13d) | 680d? → 689d | 52% → 53% | 664d → 655d |  |  |
| 1796 | **Test Artefact Development** |  | 2025-04-17 → 2025-06-19 (+63d) | 557d? → 602d | 74% → 89% | 700d → 655d |  |  |
| 1797 | **E2E Sandbox Guidance** |  | 2025-04-17 → 2025-06-19 (+63d) | 557d? → 602d |  | 700d → 655d |  |  |
| 1801 | Update E2E Sandbox guidance to reflect CR055 | 2025-01-13 A → 2025-03-17 A (+63d) | 2025-03-14 A → 2025-05-16 A (+63d) |  |  |  |  | constraint finish no earlier than 2025-03-14 → finish no earlier than 2025-05-16; baseline start 2025-01-13 → 2025-03-17; baseline finish 2025-03-14 → 2025-05-16 |
| 1802 | Internal SI review | 2025-03-17 A → 2025-05-19 A (+63d) | 2025-03-21 A → 2025-05-23 (+63d) |  | 100% → 60% | none → 674d |  | baseline start 2025-03-17 → 2025-05-19; baseline finish 2025-03-21 → 2025-05-23 |
| 1803 | SRO / Code Bodies review | 2025-03-24 A → 2025-05-19 (+56d) | 2025-03-28 → 2025-05-23 (+56d) |  | 40% → 0% | 713d → 674d | 1802 → none | constraint finish no earlier than 2025-03-28 → finish no earlier than 2025-05-23; baseline start 2025-03-24 → 2025-05-19; baseline finish 2025-03-28 → 2025-05-23 |
| 1804 | Submit version to QWG | 2025-04-01 → 2025-06-03 (+63d) | 2025-04-01 → 2025-06-03 (+63d) |  |  | 711d → 667d | 1803 → none | constraint finish no earlier than 2025-04-01 → finish no earlier than 2025-06-03; baseline start 2025-04-01 → 2025-06-03; baseline finish 2025-04-01 → 2025-06-03 |
| 1805 | Artefact Recommendation for Approval (via QWG) | 2025-04-08 → 2025-06-10 (+63d) | 2025-04-08 → 2025-06-10 (+63d) |  |  | 706d → 662d |  | constraint finish no earlier than 2025-04-08 → finish no earlier than 2025-06-10; baseline start 2025-04-08 → 2025-06-10; baseline finish 2025-04-08 → 2025-06-10 |
| 1806 | Final Document updates post QWG review | 2025-04-09 → 2025-06-11 (+63d) | 2025-04-09 → 2025-06-11 (+63d) | 1d → 0d |  | 706d → 661d |  | constraint start no earlier than 2025-04-09 → finish no earlier than 2025-06-11; baseline start 2025-04-09 → 2025-06-11; baseline finish 2025-04-09 → 2025-06-11 |
| 1807 | Submit final version to QAG | 2025-04-10 → 2025-06-12 (+63d) | 2025-04-10 → 2025-06-12 (+63d) | 1d? → 0d |  | 701d → 657d |  | constraint finish no earlier than 2025-04-10 → finish no earlier than 2025-06-12; baseline start 2025-04-10 → 2025-06-12; baseline finish 2025-04-10 → 2025-06-12 |
| 1808 | E2E Sandbox guidance update approved at QAG | 2025-04-17 → 2025-06-19 (+63d) | 2025-04-17 → 2025-06-19 (+63d) | 1d? → 0d |  | 700d → 655d |  | constraint finish no earlier than 2025-04-17 → finish no earlier than 2025-06-19; baseline start 2025-04-17 → 2025-06-19; baseline finish 2025-04-17 → 2025-06-19 |
| 1809 | **E2E Sandbox Test Data Approach & Plan** | 2025-01-13 A → 2025-03-10 A (+56d) | 2025-04-16 → 2025-06-17 (+62d) | 68d → 72d | 23% → 74% | 701d → 657d |  |  |
| 1815 | Develop document | 2025-01-13 → 2025-04-10 A (+87d) | 2025-02-18 → 2025-05-16 A (+87d) |  | 0% → 100% | 701d → none |  | constraint start no earlier than 2025-01-13 → finish no earlier than 2025-05-16; baseline start 2025-01-13 → 2025-04-10; baseline finish 2025-02-18 → 2025-05-16 |
| 1816 | Internal SI review and updates | 2025-02-19 → 2025-05-19 A (+89d) | 2025-02-25 → 2025-05-23 (+87d) |  | 0% → 60% | 701d → 674d |  | baseline start 2025-02-19 → 2025-05-19; baseline finish 2025-02-25 → 2025-05-23 |
| 1817 | SRO / Code Bodies review | 2025-02-26 → 2025-05-19 A (+82d) | 2025-03-04 → 2025-05-23 (+80d) |  | 0% → 60% | 701d → 664d | 1816 → 1816SS | baseline start 2025-02-26 → 2025-05-19; baseline finish 2025-03-04 → 2025-05-23 |
| 1818 | Final updates prior to consultation | 2025-03-12 → 2025-05-26 (+75d) | 2025-03-17 → 2025-05-26 (+70d) | 4d → 1d |  | 701d → 664d | Discuss document at QWG → 1817 | baseline start 2025-03-12 → 2025-05-26; baseline finish 2025-03-17 → 2025-05-26 |
| 1819 | Industry Consultation for E2E Sandbox Test Data Approach and Plan document | 2025-03-18 → 2025-05-26 (+69d) | 2025-03-31 → 2025-06-06 (+67d) |  |  | 701d → 664d | 1818 → 1818SS | baseline start 2025-03-18 → 2025-05-26; baseline finish 2025-03-31 → 2025-06-06 |
| 1820 | Document updates post Industry Consultation | 2025-04-01 → 2025-06-05 (+65d) | 2025-04-03 → 2025-06-09 (+67d) |  |  | 701d → 663d | 1819 → 1819SS | constraint finish no earlier than 2024-04-22 → finish no earlier than 2025-06-09; baseline start 2025-04-01 → 2025-06-07; baseline finish 2025-04-03 → 2025-06-09 |
| 1821 | Submit Proposed Version to QWG | 2025-04-04 → 2025-06-10 (+67d) | 2025-04-08 → 2025-06-10 (+63d) | 3d → 0d |  | 701d → 660d | 1820 → none | constraint none → finish no earlier than 2025-06-10; baseline start 2025-04-04 → 2025-06-10; baseline finish 2025-04-08 → 2025-06-10 |
| 1822 | Artefact Approval (via QWG) | 2025-04-08 → 2025-06-10 (+63d) | 2025-04-08 → 2025-06-10 (+63d) |  |  | 701d → 660d |  | constraint none → finish no earlier than 2025-06-10; baseline start 2025-04-08 → 2025-06-10; baseline finish 2025-04-08 → 2025-06-10 |
| 1823 | Final Document updates post QWG review | 2025-04-09 → 2025-06-11 (+63d) | 2025-04-09 → 2025-06-11 (+63d) |  |  | 701d → 660d |  | baseline start 2025-04-09 → 2025-06-11; baseline finish 2025-04-09 → 2025-06-11 |
| 1824 | Submit final version to QAG | 2025-04-10 → 2025-06-12 (+63d) | 2025-04-10 → 2025-06-12 (+63d) |  |  | 701d → 660d | 1823FS+1d → 1823FS+1d, 1820 | baseline start 2025-04-10 → 2025-06-12; baseline finish 2025-04-10 → 2025-06-12 |
| 1825 | E2E Sandbox Test Data Approach and Plan Approved at QAG | 2025-04-16 → 2025-06-17 (+62d) | 2025-04-16 → 2025-06-17 (+62d) |  |  | 701d → 657d | 1824FS+4d → 1824 | was named E2E Sandbox Test Data Approach and Plan; constraint start no earlier than 2024-05-09 → finish no earlier than 2025-06-17 |
| 1877 | **Sandbox Testing Execution (UIT) - Supplier & Agent Participants** |  |  |  |  |  |  | was named Sandbox Testing Execution (UIT) |
| 1878 | Sandbox Testing Start (UIT) - Supplier & Agent Participants |  |  |  |  |  |  | was named Sandbox Testing Start (UIT) |
| 1879 | Sandbox Testing Execution (UIT) - Supplier & Agent Participants |  |  |  |  |  |  | was named Sandbox Testing Execution (UIT) |
| 1880 | Sandbox Testing End (UIT) - Supplier & Agent Participants |  |  |  |  |  |  | was named Sandbox Testing End (UIT) |
| 1885 | **SIT PPs Early Sandbox Testing Execution (SIT-A)** |  |  |  |  |  |  | baseline start 2025-02-07 → 2025-07-21; baseline finish 2026-04-24 → 2025-10-24 |
| 1886 | SIT PPs E2E Sandbox Testing Start |  |  |  |  |  |  | baseline start 2025-08-11 → 2025-07-21; baseline finish 2025-08-11 → 2025-07-21 |
| 1887 | SIT PPs E2E Sandbox Testing Execution |  |  |  |  |  |  | baseline start 2025-08-11 → 2025-07-21 |
| 1926 | Migration Schedule approved |  |  |  |  |  | none → 2778 |  |
| 1930 | MCC tested and ready to operate |  |  |  |  |  | none → 2811 |  |
| 1961 | **NON SIT LDSO QUALIFICATION** |  |  |  | 92% → 93% |  |  |  |
| 2056 | **Test Window** |  |  |  | 88% → 91% |  |  |  |
| 2057 | **All Non-SIT LDSOs Qualification Testing** |  | 2025-05-16 A |  | 96% → 100% | 0d → none |  |  |
| 2061 | LDSO Charlie |  | 2025-05-07 A |  | 96% → 100% | 6d → none |  |  |
| 2064 | LDSO Foxtrot |  | 2025-05-15 A |  | 72% → 100% | 0d → none |  |  |
| 2068 | Qualification Testing for Non-SIT LDSOs (Functional, Migration, NFT, Operational) 1 End | 2025-05-16 A | 2025-05-16 A |  | 0% → 100% | 0d → none |  |  |
| 2070 | **Test Result Assurance** |  |  |  | 43% → 90% | 649d → 680d |  |  |
| 2071 | Test Reports Reviewed By MHHS & Code Bodies & Finalised |  |  |  | 43% → 90% | 649d → 680d |  |  |
| 2072 | Non-SIT LDSOs submission deadline for their QT Test Completion Report to MHHS Programme | 2025-05-16 A | 2025-05-16 A |  | 0% → 100% | 649d → none |  |  |
| 2077 | **SERVICE MANAGEMENT** |  |  |  | 50% → 60% |  |  |  |
| 2078 | **Stage 2 - M10 Readiness** |  |  |  | 50% → 60% |  |  |  |
| 2079 | **Service Model Design (Cross Party Service Desk)** |  |  |  | 59% → 69% |  |  |  |
| 2080 | **Cross Party Service Desk** |  | 2025-05-20 → 2025-05-19 (-1d) | 56d → 55d | 85% → 99% | 678d → 679d |  |  |
| 2085 | **Cross Party Service Desk Consultation** |  | 2025-05-20 → 2025-05-19 (-1d) | 31d → 30d | 71% → 99% | 678d → 679d |  |  |
| 2088 | Cross Party Service Desk Model Updates (Feedback Review) |  | 2025-05-08 A |  | 13% → 100% | 682d → none |  |  |
| 2089 | Cross Party Service Desk Model Spotlight at Elexon Service Management Steering Group | 2025-05-07 A | 2025-05-07 A |  | 0% → 100% | 686d → none |  |  |
| 2090 | Updated Consultation Documents Shared with MHHS and Industry | 2025-05-08 A | 2025-05-08 A |  | 0% → 100% | 685d → none |  |  |

| ID | Task | Start | Finish | Duration | Complete | Total float | Predecessors | Other |
| --- | --- | --- | --- | --- | --- | --- | --- | --- |
| 2092 | Updated Consultation Documents Released to Industry for eTORWG |  |  |  |  |  | 2091FS+3d, 2135 → 2091FS+3d | baseline start 2025-07-01 → 2025-05-16; baseline finish 2025-07-01 → 2025-05-16 |
| 2093 | CPSD, Operating Hours & Triage Updates Endorsement (eTORWG) | 2025-05-20 → 2025-05-19 (-1d) | 2025-05-20 → 2025-05-19 (-1d) |  |  | 678d → 679d |  | constraint start no earlier than 2025-05-20 → start no earlier than 2025-05-19; baseline start 2025-07-01 → 2025-05-20; baseline finish 2025-07-01 → 2025-05-20 |
| 2094 | Cross Party Service Desk Model Completed | 2025-05-20 → 2025-05-19 (-1d) | 2025-05-20 → 2025-05-19 (-1d) |  |  | 678d → 679d |  | baseline start 2025-07-01 → 2025-05-20; baseline finish 2025-07-01 → 2025-05-20 |
| 2098 | Operations Manual Version 1.3 | 2025-05-15 A | 2025-05-15 A |  | 0% → 100% | 670d → none |  | was named Operations Manual Version 1.2 |
| 2101 | **Operational Readiness Testing** |  |  |  | 45% → 56% |  |  |  |
| 2102 | **ORT Design** |  |  |  | 69% → 88% |  |  |  |
| 2107 | **ORT Test Scope and Approach Consultation (Test Scope and Approach & Test Scripts)** |  | 2025-05-20 → 2025-05-19 (-1d) | 30d → 29d | 70% → 99% | 644d → 645d |  |  |
| 2110 | ORT Test Scope and Approach Updates (Feedback Review) |  | 2025-05-08 A |  | 13% → 100% | 633d → none |  |  |
| 2111 | Updated ORT Test Scope and Approach Documents Shared with MHHS and Industry | 2025-05-08 A | 2025-05-08 A |  | 0% → 100% | 651d → none |  |  |
| 2114 | ORT Test Scope and Approach Endorsement (eSITWG) | 2025-05-20 → 2025-05-19 (-1d) | 2025-05-20 → 2025-05-19 (-1d) |  |  | 644d → 645d |  | constraint start no earlier than 2025-05-20 → start no earlier than 2025-05-19 |
| 2115 | ORT Test Script Production and Updates |  | 2025-05-08 A |  | 65% → 100% | 633d → none |  |  |
| 2116 | ORT Test Scripts Shared | 2025-05-08 A | 2025-05-08 A |  | 0% → 100% | 633d → none |  |  |
| 2117 | **ORT Test Scripts Consultation** | 2025-05-07 A |  |  |  | 635d → 662d |  |  |
| 2118 | ORT Spotlight (Test Approach) at Elexon Service Management Helix Steering Group | 2025-05-07 A | 2025-05-07 A |  | 0% → 100% | 645d → none |  |  |
| 2119 | ORT Test Scripts Consultation |  | 2025-05-15 → 2025-05-16 (+1d) | 5d → 6d |  |  |  |  |
| 2120 | ORT Test Scripts Consultation Completed | 2025-05-15 → 2025-05-16 (+1d) | 2025-05-15 → 2025-05-16 (+1d) |  |  |  |  |  |
| 2121 | ORT Test Scripts Updates (Feedback Review) | 2025-05-16 → 2025-05-19 (+3d) |  | 5d → 4d |  |  |  |  |
| 2144 | **S & A QUALIFICATION** |  |  |  | 61% → 63% |  |  |  |
| 2206 | **MHHS Qualification - SIT Participants** |  |  |  | 25% → 44% |  |  |  |
| 2211 | **MHHS Qualification - M10-Ready** |  |  |  | 13% → 66% |  |  |  |
| 2213 | SIT M10-ready Participants submit Final QAD (exc Test Reports) |  | 2025-05-09 A |  | 25% → 100% | 60d → none |  | was named SIT MVC Participants submit Final QAD (exc Test Reports) |
| 2214 | Completion of Code Bodies review of Final QAD (M10-Ready) | 2025-05-12 A |  |  | 0% → 30% |  |  |  |
| 2215 | **SIT / LDSO Pathway 1** |  |  |  |  | 616d → 610d |  | baseline start none → 2025-07-23; baseline finish none → 2025-08-13 |
| 2216 | QAD Sign Off Deadline + Test Reports |  |  |  |  | 616d → 610d |  | baseline start none → 2025-07-23; baseline finish none → 2025-07-23 |
| 2217 | REC Code Manager / BSC PAB Approval of Qualification |  |  |  |  | 616d → 610d |  | baseline start none → 2025-08-13; baseline finish none → 2025-08-13 |
| 2218 | **SIT / LDSO Pathway 2** |  |  |  |  |  |  | baseline start none → 2025-08-07; baseline finish none → 2025-08-28 |
| 2219 | QAD Sign Off Deadline + Test Reports |  |  |  |  |  |  | baseline start none → 2025-08-07; baseline finish none → 2025-08-07 |
| 2220 | REC Code Manager / BSC PAB Approval of Qualification (M10-Ready) |  |  |  |  |  |  | baseline start none → 2025-08-28; baseline finish none → 2025-08-28 |
| 2221 | **SIT / LDSO Pathway 3** |  |  |  |  |  |  | baseline start none → 2025-08-22; baseline finish none → 2025-09-10 |
| 2222 | QAD Sign Off Deadline + Test Reports |  |  |  |  |  |  | baseline start none → 2025-08-22; baseline finish none → 2025-08-22 |
| 2223 | REC Code Manager / BSC PAB Approval of Qualification (M10-Ready) |  |  |  |  |  |  | baseline start none → 2025-09-09; baseline finish none → 2025-09-10 |
| 2224 | M10-Ready SIT Participants are qualified |  |  |  |  |  |  | was named 'M10-Ready SIT Participants are qualified'; baseline start none → 2025-09-10; baseline finish none → 2025-09-10 |
| 2225 | **MHHS Qualification - M11-Ready** |  |  |  | 0% → 47% |  |  | baseline start none → 2025-04-07; baseline finish none → 2025-10-15 |
| 2226 | Final QAD Submission Window opens |  |  |  |  |  |  | baseline start none → 2025-04-07; baseline finish none → 2025-04-07 |
| 2227 | SIT M11-ready Participants submit Final QAD (exc Test Reports) | 2025-04-08 A |  |  | 0% → 68% |  |  | was named SIT MVC Participants submit Final QAD (exc Test Reports); baseline start none → 2025-04-08; baseline finish none → 2025-06-06 |
| 2228 | Completion of Code Bodies review of Final QAD (M11-Ready) |  |  |  |  |  |  | baseline start none → 2025-06-09; baseline finish none → 2025-07-04 |
| 2229 | **SIT Pathway 4** |  |  |  |  |  |  | baseline start none → 2025-09-04; baseline finish none → 2025-09-25 |
| 2230 | QAD Sign Off Deadline + Test Reports |  |  |  |  |  |  | baseline start none → 2025-09-04; baseline finish none → 2025-09-04 |
| 2231 | REC Code Manager / BSC PAB Approval of Qualification (M11-Ready) |  |  |  |  |  |  | baseline start none → 2025-09-25; baseline finish none → 2025-09-25 |
| 2232 | **SIT Pathway 5** |  |  |  |  |  |  | baseline start none → 2025-09-24; baseline finish none → 2025-10-15 |
| 2233 | QAD Sign Off Deadline + Test Reports |  |  |  |  |  |  | baseline start none → 2025-09-24; baseline finish none → 2025-09-24 |
| 2234 | REC Code Manager / BSC PAB Approval of Qualification |  |  |  |  |  |  | baseline start none → 2025-10-15; baseline finish none → 2025-10-15 |
| 2235 | 'M11-Ready SIT Participants are qualified' |  |  |  |  |  |  | baseline start none → 2025-10-15; baseline finish none → 2025-10-15 |
| 2236 | **MHHS Qualification - Not M11-Ready** | 2025-05-19 A |  |  | 0% → 1% |  |  | baseline finish 2025-12-22 → 2025-12-17 |
| 2237 | Final QAD Submission Window opens | 2025-05-19 A | 2025-05-19 A |  | 0% → 100% | 613d → none |  |  |
| 2238 | SIT Not M11-Ready Participants submit Final QAD | 2025-05-19 A |  |  | 0% → 1% |  |  |  |
| 2240 | **SIT Pathway 6** |  |  |  |  |  |  | baseline start none → 2025-11-27; baseline finish none → 2025-12-17 |
| 2241 | QAD Sign Off Deadline (Not M11-Ready) |  |  |  |  |  |  | baseline start 2025-11-28 → 2025-11-27; baseline finish 2025-11-28 → 2025-11-27 |
| 2242 | SIT Participants are Qualified |  |  |  |  |  |  | was named REC Code Manager / BSC PAB Approval of Qualification (Not M11-Ready) |
| 2243 | **MHHS Qualification - Non-SIT LDSO (M10-Ready)** |  |  |  | 60% → 58% |  |  | baseline finish 2025-09-11 → 2025-09-10 |
| 2250 | Non-SIT LDSO Participants submit Final QAD |  |  |  | 20% → 89% | 49d → 9d |  |  |
| 2254 | QAD Sign Off Deadline (Non-SIT LDSOs) |  |  |  |  |  | 2252FS+5d, 1772, 2068 → 2252FS+5d, 1772, 2068, 2253 |  |
| 2256 | **MHHS Qualification - Qualification Waves** |  |  |  | 57% → 58% |  |  |  |
| 2257 | **Qualification Wave Prep** |  | 2026-02-06 → 2026-02-19 (+13d) | 560d? → 569d? | 94% → 96% | 489d → 480d |  |  |
| 2295 | **Qualification Testing Framework (Test Stubs and Supporting UI)** |  | 2026-02-06 → 2026-02-19 (+13d) | 530d? → 539d? | 93% → 96% | 489d → 480d |  |  |
| 2361 | **MPANs, DIP Messages, Settlement, Consumption, Reference** |  |  |  | 81% → 88% |  |  |  |
| 2402 | Test Data Request + Templates Completed | 2025-06-02 → 2025-07-14 (+42d) | 2025-06-06 → 2025-07-15 (+39d) | 5d → 2d |  | 440d → 426d |  | constraint start no earlier than 2025-06-02 → start no earlier than 2025-07-14; baseline start 2025-06-02 → 2025-07-14; baseline finish 2025-06-06 → 2025-07-15 |
| 2403 | Test Data Generated | 2025-06-09 → 2025-07-16 (+37d) | 2025-06-13 → 2025-07-17 (+34d) | 5d → 2d |  | 440d → 426d |  | baseline start 2025-06-09 → 2025-07-16; baseline finish 2025-06-13 → 2025-07-17 |
| 2404 | Test Data Loaded into QP Systems | 2025-06-16 → 2025-07-18 (+32d) | 2025-07-04 → 2025-08-07 (+34d) |  |  | 440d → 426d |  | baseline start 2025-06-16 → 2025-07-18; baseline finish 2025-07-04 → 2025-08-07 |
| 2405 | Test Data Loaded into QTF + ADO | 2025-07-07 → 2025-08-11 (+35d) | 2025-07-25 → 2025-08-15 (+21d) | 15d → 5d |  | 440d → 425d |  | constraint finish no earlier than 2025-06-17 → finish no earlier than 2025-08-15; baseline start 2025-07-07 → 2025-08-11; baseline finish 2025-07-25 → 2025-08-15 |
| 2407 | Test Data Request + Templates Completed | 2025-07-28 → 2025-09-17 (+51d) | 2025-08-01 → 2025-09-18 (+48d) | 5d → 2d |  | 407d → 387d |  | constraint start no earlier than 2025-07-28 → start no earlier than 2025-09-17; baseline start 2025-07-28 → 2025-09-17; baseline finish 2025-08-01 → 2025-09-18 |
| 2408 | Test Data Generated | 2025-08-04 → 2025-09-19 (+46d) | 2025-08-08 → 2025-09-22 (+45d) | 5d → 2d |  | 407d → 387d |  | baseline start 2025-08-04 → 2025-09-19; baseline finish 2025-08-08 → 2025-09-22 |
| 2409 | Test Data Loaded into QP Systems | 2025-08-11 → 2025-09-23 (+43d) | 2025-08-29 → 2025-10-13 (+45d) |  |  | 407d → 387d |  | baseline start 2025-08-11 → 2025-09-23; baseline finish 2025-08-29 → 2025-10-13 |
| 2410 | Test Data Loaded into QTF + ADO | 2025-09-01 → 2025-10-14 (+43d) | 2025-09-19 → 2025-10-17 (+28d) | 15d → 4d |  | 407d → 387d |  | baseline start 2025-09-01 → 2025-10-14; baseline finish 2025-09-19 → 2025-10-17 |
| 2412 | Test Data Request + Templates Completed | 2025-10-20 → 2025-11-10 (+21d) | 2025-10-24 → 2025-11-11 (+18d) | 5d → 2d |  | 376d → 377d |  | constraint start no earlier than 2025-10-20 → start no earlier than 2025-11-10; baseline start 2025-10-20 → 2025-11-10; baseline finish 2025-10-24 → 2025-11-11 |
| 2413 | Test Data Generated | 2025-10-27 → 2025-11-12 (+16d) | 2025-10-31 → 2025-11-13 (+13d) | 5d → 2d |  | 376d → 377d |  | baseline start 2025-10-27 → 2025-11-12; baseline finish 2025-10-31 → 2025-11-13 |
| 2414 | Test Data Loaded into QP Systems | 2025-11-03 → 2025-11-14 (+11d) | 2025-11-21 → 2025-12-04 (+13d) |  |  | 376d → 377d |  | baseline start 2025-11-03 → 2025-11-14; baseline finish 2025-11-21 → 2025-12-04 |
| 2415 | Test Data Loaded into QTF + ADO | 2025-11-24 → 2025-12-05 (+11d) | 2025-12-12 → 2025-12-11 (-1d) | 15d → 5d |  | 376d → 377d |  | baseline start 2025-11-24 → 2025-12-05; baseline finish 2025-12-12 → 2025-12-11 |
| 2417 | Test Data Request + Templates Completed | 2025-12-15 → 2026-01-19 (+35d) | 2025-12-19 → 2026-01-20 (+32d) | 5d → 2d |  | 256d → 247d |  | constraint start no earlier than 2025-12-15 → start no earlier than 2026-01-19; baseline start 2025-12-15 → 2026-01-19; baseline finish 2025-12-19 → 2026-01-20 |
| 2418 | Test Data Generated | 2025-12-22 → 2026-01-21 (+30d) | 2025-12-26 → 2026-01-22 (+27d) | 5d → 2d |  | 256d → 247d |  | baseline start 2025-12-22 → 2026-01-21; baseline finish 2025-12-26 → 2026-01-22 |

| ID | Task | Start | Finish | Duration | Complete | Total float | Predecessors | Other |
| --- | --- | --- | --- | --- | --- | --- | --- | --- |
| 2419 | Test Data Loaded into QP Systems | 2025-12-29 → 2026-01-23 (+25d) | 2026-01-16 → 2026-02-12 (+27d) |  |  | 256d → 247d |  | baseline start 2025-12-29 → 2026-01-23; baseline finish 2026-01-16 → 2026-02-12 |
| 2420 | Test Data Loaded into QTF + ADO | 2026-01-19 → 2026-02-13 (+25d) | 2026-02-06 → 2026-02-19 (+13d) | 15d → 5d |  | 256d → 247d |  | baseline start 2026-01-19 → 2026-02-13; baseline finish 2026-02-06 → 2026-02-19 |
| 2437 | **Qualification Wave 1** | 2025-05-05 A |  |  |  |  |  |  |
| 2438 | **Qualification Wave 1 QAD Prep** | 2025-05-05 A |  |  |  | 420d → 419d |  |  |
| 2439 | Initial QAD Submission window opens | 2025-05-05 A | 2025-05-05 A |  | 0% → 100% | 420d → none |  |  |
| 2457 | Qualification Wave 1 QT Execution Start |  |  |  |  |  | 2456, 2453, 1630FS+6d, 2405 → 2456FS+1d, 2453, 2405 |  |
| 2567 | PAB294 | 2025-05-14 A | 2025-05-14 A |  | 0% → 100% | 682d → none |  |  |
| 2733 | **MIGRATION** |  |  |  | 60% → 62% |  |  |  |
| 2734 | **Regulatory Governance** |  |  |  | 73% → 83% |  |  |  |
| 2736 | Incentives Implemented |  |  |  | 26% → 55% |  |  |  |
| 2781 | Supplier submission issued | 2025-04-25 A | 2025-04-25 A |  | 0% → 100% | 632d → none |  |  |
| 2785 | **Supplier Submission Support** | 2025-04-25 A |  |  | 0% → 99% |  |  |  |
| 2786 | Support guides issued | 2025-04-25 A | 2025-04-25 A |  | 0% → 100% | 666d → none |  |  |
| 2787 | Envelope webinar | 2025-05-02 A | 2025-05-02 A |  | 0% → 100% | 666d → none |  |  |
| 2788 | De-minimus webinar | 2025-05-02 A | 2025-05-02 A |  | 0% → 100% | 666d → none |  |  |
| 2789 | Drop-in session 1 | 2025-05-14 A | 2025-05-14 A |  | 0% → 100% | 666d → none |  |  |
| 2793 | **MCC Stood up** |  |  |  | 40% → 49% |  |  |  |
| 2794 | Migration Planning Management Tool Delivery |  |  |  | 40% → 49% |  |  |  |
| 2795 | **MCC Operational** | 2025-04-23 A |  |  |  |  |  |  |
| 2796 | **MCC Dress Rehersal 1 - Initialise Schedule (Weekly) Drop 1, 2** | 2025-04-23 A |  |  |  |  |  |  |
| 2797 | Issue Dress Rehearsal support information to Participants | 2025-04-23 A | 2025-04-23 A |  | 0% → 100% | 637d → none |  |  |
| 2798 | Kestrel Webinar 1 | 2025-04-23 A | 2025-04-23 A |  | 0% → 100% | 637d → none |  |  |
| 2799 | Onboard and connectivity testing - Dress Rehearsal with Suppliers (All SIT and Wave 1 mandatory) | 2025-04-25 A | 2025-04-25 A |  | 0% → 100% | 637d → none |  |  |
| 2800 | Dress rehearsal start | 2025-04-28 A | 2025-04-28 A |  | 0% → 100% | 637d → none |  |  |
| 2819 | **Migration Artefact Development and Publication** |  |  |  | 65% → 67% |  |  |  |
| 2862 | **Data Cleanse Plan** |  |  |  | 92% → 93% |  |  |  |
| 2867 | **MTDs** |  | 2025-07-18 → 2025-07-21 (+3d) | 240d → 241d | 77% → 79% | 634d → 633d |  |  |
| 2874 | **Meter Location and Number of Displayed Register Digits** |  | 2025-07-18 → 2025-07-21 (+3d) | 221d → 222d | 64% → 67% | 634d → 633d |  |  |
| 2878 | Suppliers complete Work Off plans |  | 2025-07-18 → 2025-07-21 (+3d) | 123d → 124d | 57% → 60% | 634d → 633d |  |  |
| 2879 | Meter Location and Number of Displayed Register Digits Complete | 2025-07-18 → 2025-07-21 (+3d) | 2025-07-18 → 2025-07-21 (+3d) |  |  | 634d → 633d |  |  |
| 2893 | **Connection Type and Meter Type Misalignments** |  |  |  | 32% → 35% |  |  |  |
| 2894 | **Traditional Meters installed on Current Transformers** |  |  |  | 10% → 11% |  |  |  |
| 2895 | Suppliers investigate all MPANs with Traditional Meters installed on a Current Transformer Connection Type |  |  |  | 72% → 80% |  |  |  |
| 2901 | **CHECK Meters** |  |  |  | 72% → 80% |  |  |  |
| 2902 | Suppliers and their appointed Meter Operator investigate MPANs within their portfolio that have incorrectly populated meters with the Meter Type CHECK within MPRS. Meter Operators are required to send a D0312 to remove the CHECK meter from MPRS. |  |  |  | 72% → 80% |  |  |  |
| 2903 | Once CHECK meters are either removed from MPRS or the Meter Type is changed to a valid Meter Type, the LDSO should check that the Connection Type assigned to the MPAN is still valid. |  |  |  | 72% → 80% |  |  |  |
| 2906 | **Smart Meter Types installed on CT Connection Types** |  |  |  | 36% → 41% |  |  |  |
| 2908 | LDSOs investigate Connection Type misalignments and correct where appropriate |  |  |  | 64% → 74% |  |  |  |
| 2912 | **Linked Import / Export MPANs** |  | 2025-07-25 → 2025-07-28 (+3d) | 105d → 106d | 45% → 49% | 629d → 628d |  |  |
| 2913 | LDSOs review and correct linked Import / Export MPANs with Different Connection Types |  | 2025-07-25 → 2025-07-28 (+3d) | 105d → 106d | 45% → 49% | 629d → 628d |  |  |
| 2914 | LDSOs, Import and Export Suppliers review and correct linked Import / Export MPANs with meters in the Advanced and Traditional or Smart Meter Groups |  | 2025-07-25 → 2025-07-28 (+3d) | 105d → 106d | 45% → 49% | 629d → 628d |  |  |
| 2915 | Linked Import / Export MPANs complete | 2025-07-25 → 2025-07-28 (+3d) | 2025-07-25 → 2025-07-28 (+3d) |  |  | 629d → 628d |  |  |
| 2916 | **Related MPANs** |  |  |  | 45% → 50% |  |  |  |
| 2917 | LDSOs review and correct related MPANs with different Connection Types |  |  |  | 59% → 65% |  |  |  |
| 2919 | Suppliers should investigate Related MPANs within different meter groups and verify that they are correct or request that their Meter Operators update the Meter Types where they are incorrect |  |  |  | 45% → 50% |  |  |  |
| 2951 | **Preparation for Cutover to Live** |  |  |  | 8% → 11% |  |  |  |
| 2952 | **Central Systems Prepare for Cutover to Live** |  |  |  | 19% → 31% |  |  |  |
| 2954 | **Development of Comms Approach and Declaration Guidance** |  |  |  | 6% → 20% |  |  |  |
| 2955 | Draft Cutover Comms Approach |  |  |  | 12% → 20% |  |  |  |
| 2957 | Finalised Cutover Comms Approach shared |  |  |  |  |  | 2956FS+20d, Implementation Group EstablishedFS+20d → 2956FS+20d |  |
| 2958 | **Development of Cutover Plan requirements with Participants** |  |  |  | 26% → 33% |  |  |  |
| 2959 | Development of Central Parties Cutover Plans |  |  |  | 69% → 88% |  |  |  |
| 2960 | Development of Programme Participant Cutover Plans |  | 2025-06-27 → 2025-06-30 (+3d) | 56d → 57d | 32% → 40% | 68d → 67d |  |  |
| 2961 | Central Party Cutover Plan Assurance |  |  |  | 38% → 49% |  |  |  |
| 3115 | **BUSINESS & OPERATIONAL READINESS** |  |  |  | 11% → 18% |  |  |  |
| 3130 | **Service Activation** | 2022-10-31 A |  |  | 0% → 20% |  |  |  |

## Version 10 (data date 2025-06-04, saved 2025-06-04, file MHHS-DEL1139 - MHHS Plan v6.26.mpp)

Last finish stays 2027-12-23. Complete tasks 1840 → 1930.

Added:

| ID | Task | Duration | Start | Finish | Predecessors | Constraint |
| --- | --- | --- | --- | --- | --- | --- |
| 1599 | eSITAG decision point on end of SIT A testing | 0d | 2025-06-11 | 2025-06-11 |  | finish no earlier than 2025-06-11 |
| 1936 | M10 Acceptance Criteria Ratification | 0d | 2025-09-24 | 2025-09-24 | 1935FS+2d |  |
| 2086 | ORT version of LLSD SOM CPSD | 0d | 2025-06-04 A | 2025-06-04 A |  | start no earlier than 2025-06-04 |
| 2087 | ORT version brought to TORWG | 0d | 2025-06-11 | 2025-06-11 | 2086FS+5d | start no earlier than 2025-06-11 |
| 2130 | **Codification of Service** | 81d | 2025-05-09 A | 2025-08-29 |  |  |
| 2131 | OFGEM Review Meeting | 0d | 2025-05-09 A | 2025-05-09 A |  | start no earlier than 2025-04-04 |
| 2132 | Codification Update at TORWG | 0d | 2025-05-14 A | 2025-05-14 A | 2131 | start no earlier than 2025-05-14 |
| 2133 | "Codify Service Management" Item Preparation | 36d | 2025-05-14 A | 2025-07-02 | 2132 |  |
| 2134 | "Codify Service Management" - Item raised | 0d | 2025-07-02 | 2025-07-02 | 2133 | start no earlier than 2025-07-02 |
| 2135 | Committee Views Ahead of Panel | 6d | 2025-07-03 | 2025-07-10 | 2134 |  |
| 2136 | Initial Panel Committee Views | 0d | 2025-07-10 | 2025-07-10 | 2135 | start no earlier than 2025-07-10 |
| 2137 | Consultation on Codify Service Management | 10d | 2025-07-14 | 2025-07-25 | 2136FS+1d | finish no earlier than 2025-07-25 |
| 2138 | Committee Views Ahead of Final Panel | 14d | 2025-07-28 | 2025-08-14 | 2137 |  |
| 2139 | Final Panel Committee Views | 0d | 2025-08-14 | 2025-08-14 | 2138 | start no earlier than 2025-08-14 |
| 2140 | Submission for Decision to Ofgem ("Codify Service Management") | 0d | 2025-08-18 | 2025-08-18 | 2139FS+1d | start no earlier than 2025-08-18 |
| 2141 | "Codify Service Management" Final Decision Process | 10d | 2025-08-18 | 2025-08-29 | 2140 |  |
| 2142 | "Codify Service Management" Decision Due (TBC and Indicitavely by End of Aug) | 0d | 2025-08-29 | 2025-08-29 | 2141 | start no earlier than 2025-08-29 |
| 2146 | Registration of LDSOs into ServiceNow | 3d | 2025-07-31 | 2025-08-04 | 2145 |  |
| 2147 | Helix Service Management Live for LDSO DIP Onboarding | 0d | 2025-08-04 | 2025-08-04 | 2146 | start no earlier than 2025-08-04 |
| 2148 | Helix Service Management Live for MHHS Enduring Arrangements | 500d | 2025-09-01 | 2027-07-30 | 2151 | start no earlier than 2025-09-01 |
| 2149 | **Business Readiness (inc DIP)** | 436d? | 2024-04-02 A | 2025-12-02 |  |  |
| 2150 | Knowledge Transfer triage | 35d? | 2025-04-28 A | 2025-06-13 |  | start no earlier than 2025-04-28 |
| 2151 | Elexon Leading Triage | 55d | 2025-06-16 | 2025-08-29 | 2150 | start no earlier than 2025-06-16 |
| 2152 | MHHS Transition (Knowledge Transfer) | 64d | 2025-05-06 A | 2025-08-01 |  | start no earlier than 2025-05-06 |
| 2153 | Artefact Handshake with MHHS | 0d | 2025-08-01 | 2025-08-01 | 2152 |  |
| 2154 | Operational Control Centre (OCC) Development | 85d | 2025-04-07 A | 2025-08-01 |  | start no earlier than 2025-04-07 |
| 2155 | Operational Control Centre (OCC) Live | 0d | 2025-08-04 | 2025-08-04 | 2154FS+1d |  |
| 2156 | **Service Activation Readiness** | 436d? | 2024-04-02 A | 2025-12-02 |  |  |
| 2158 | **Business Service Activation Governance, Planning & Scope** | 128d | 2024-04-04 A | 2024-09-30 A |  |  |
| 2159 | Create and Confirm SA Scope | 9d | 2024-06-03 A | 2024-06-13 A |  | finish no earlier than 2024-06-13 |
| 2160 | POAP Service Activation | 13d | 2024-06-03 A | 2024-06-19 A |  | finish no earlier than 2024-06-19 |
| 2161 | Service Activation Working Group | 62d | 2024-04-04 A | 2024-06-28 A |  | finish no earlier than 2024-06-28 |
| 2162 | Business Readiness Governance Framework | 42d | 2024-08-02 A | 2024-09-30 A |  | finish no earlier than 2024-09-30 |
| 2163 | Service Activation Governance Framework Completed | 0d | 2024-09-30 A | 2024-09-30 A | 2159, 2160, 2161, 2162 | finish no earlier than 2024-06-28 |
| 2164 | **Service Activation High Level Process Models** | 109d | 2024-04-02 A | 2024-08-31 A |  |  |
| 2165 | Transition Process Model | 70d | 2024-04-02 A | 2024-07-08 A |  | finish no earlier than 2024-07-08 |
| 2166 | Migration Process Model | 14d | 2024-08-13 A | 2024-08-30 A |  | finish no earlier than 2024-08-31 |
| 2167 | Enduring Process Model | 44d | 2024-06-03 A | 2024-08-01 A |  | start no earlier than 2024-06-01 |
| 2168 | Service Activation High Level Process Models Completed | 0d | 2024-08-31 A | 2024-08-31 A | 2165, 2166, 2167 | start no earlier than 2024-08-31 |
| 2169 | **Target Operating Model for Service Activation** | 83d | 2024-06-21 A | 2024-10-15 A |  |  |
| 2170 | MHHSP Engagement Team understanding | 25d | 2024-06-21 A | 2024-07-25 A |  | finish no earlier than 2024-07-25 |
| 2171 | Define and produce organisation model for Service Activation in Elexon | 83d | 2024-06-21 A | 2024-10-15 A |  | finish no earlier than 2024-10-15 |
| 2172 | Implement Target Operating model | 1d | 2024-10-15 A | 2024-10-15 A |  | start no earlier than 2024-10-15 |
| 2173 | Target Operating Model for Service Activation Completed | 0d | 2024-10-15 A | 2024-10-15 A | 2170, 2171, 2172 | start no earlier than 2024-10-15 |
| 2174 | **SIT Operational Testing for Service Activation** | 5d? | 2024-08-12 A | 2024-08-16 A |  |  |
| 2175 | Review and validate test cases | 5d | 2024-08-12 A | 2024-08-16 A |  | finish no earlier than 2024-08-16 |
| 2176 | SIT Operational Testing for Service Activation Completed | 1d? | 2024-08-16 A | 2024-08-16 A |  | start no earlier than 2024-08-16 |
| 2177 | **Operational Training for Service Activation** | 182d | 2024-11-13 A | 2025-07-25 |  |  |
| 2178 | Training Execution [Placeholder] | 153d | 2024-11-13 A | 2025-06-13 |  | start no earlier than 2024-11-13 |
| 2179 | Service Activation Training Completed | 0d | 2025-07-25 | 2025-07-25 |  | start no earlier than 2025-07-25 |
| 2180 | **Service Activation Readiness** | 7d | 2025-08-04 | 2025-08-12 |  |  |
| 2181 | Dress Rehearsal 1 | 2d | 2025-08-04 | 2025-08-05 | 2163, 2168, 2173, 2179 | start no earlier than 2025-08-04 |
| 2182 | Dress Rehearsal 1 Complete | 0d | 2025-08-05 | 2025-08-05 | 2181 | start no earlier than 2025-01-22 |
| 2183 | Dress Rehearsal 2 | 2d | 2025-08-11 | 2025-08-12 | 2182FS+3d | start no earlier than 2025-08-04 |
| 2184 | Dress Rehearsal 2 Complete | 0d | 2025-08-12 | 2025-08-12 | 2183 | start no earlier than 2025-01-22 |
| 2185 | **Service Activation Go / No Go** | 8d | 2025-08-13 | 2025-08-22 |  |  |
| 2186 | **Final Service Activation Go/No Go Decision** | 7d | 2025-08-13 | 2025-08-22 |  |  |
| 2187 | DIP Team Ready | 1d | 2025-08-13 | 2025-08-13 | 2184, 2182 |  |
| 2188 | DIP Technical Onboarding Processes Completed | 0d | 2025-08-22 | 2025-08-22 |  | start no earlier than 2025-08-22 |
| 2189 | PM Team Ready | 0d | 2025-08-22 | 2025-08-22 | 2182, 2184 | start no earlier than 2025-08-22 |
| 2190 | Operational Support Ready (Ops Control Centre, Account Managers) | 0d | 2025-08-22 | 2025-08-22 |  | start no earlier than 2025-08-22 |
| 2191 | Service Management Activity Completed (Resolver Groups) | 0d | 2025-08-22 | 2025-08-22 |  | start no earlier than 2025-08-22 |
| 2192 | Process 1.1.1 ISD and Related LWIs Completed | 0d | 2025-08-22 | 2025-08-22 | 2191 |  |
| 2193 | Service Activation Go / No Go | 0d | 2025-08-22 | 2025-08-22 | 2188FF, 2189FF, 2190FF, 2191FF, 2155FF, 2192FF | finish no earlier than 2025-08-22 |
| 2194 | **SOLR Consultation** | 122d | 2025-04-10 A | 2025-09-26 | 2193 |  |
| 2195 | SOLR workshop 1 | 1d | 2025-04-10 A | 2025-04-10 A | 2193SF | start no earlier than 2025-04-10 |
| 2196 | SOLR workshop 2 | 1d | 2025-04-29 A | 2025-04-29 A | 2193SF | start no earlier than 2025-04-29 |
| 2197 | SOLR consultation | 23d | 2025-08-27 | 2025-09-26 | 2193SF | finish no earlier than 2025-09-26 |
| 2198 | SOLR comms to MHHS for review | 1d | 2025-08-26 | 2025-08-26 |  | finish no earlier than 2025-08-26 |
| 2199 | **MDR Process** | 77d | 2025-04-16 A | 2025-07-31 |  |  |
| 2200 | MDR workshop 1 | 1d | 2025-04-16 A | 2025-04-16 A |  | start no earlier than 2025-04-16 |
| 2201 | MDR workshop 2 | 1d | 2025-04-30 A | 2025-04-30 A |  | start no earlier than 2025-04-30 |
| 2202 | MDR workshop | 1d | 2025-05-27 A | 2025-05-27 A |  | start no earlier than 2025-05-27 |
| 2203 | MDR consultation | 12d | 2025-05-06 A | 2025-05-21 A |  | start no earlier than 2025-05-06 |
| 2204 | MDR consultation ongoing actions | 62d | 2025-05-07 A | 2025-07-31 |  | start no earlier than 2025-05-07 |
| 2205 | **Phase 2 - Implementation** | 388d? | 2024-06-07 A | 2025-12-02 |  |  |
| 2206 | **Non-SIT LDSO & SIT MVC Data Loading (M10 Ready)** | 6d | 2024-06-07 A | 2024-06-14 A |  |  |
| 2207 | Define Non-SIT LDSO Upfront Activities | 6d | 2024-06-07 A | 2024-06-14 A |  | finish no earlier than 2024-06-15 |
| 2208 | **M10-Ready Activation Preparation Tasks** | 11d? | 2025-08-25 | 2025-09-08 | 2207 |  |
| 2209 | Identify Resources | 1d | 2025-08-25 | 2025-08-25 |  | start no earlier than 2025-08-25 |
| 2210 | Confirmation from Qualification of Wave Participants Complete | 0d | 2025-08-25 | 2025-08-25 |  | start no earlier than 2025-08-25 |
| 2211 | Agree & Understand Support Model | 1d | 2025-08-26 | 2025-08-26 |  | start no earlier than 2025-08-26 |
| 2212 | Confirm Training complete | 0d | 2025-08-27 | 2025-08-27 |  | start no earlier than 2025-08-27 |
| 2213 | Confirm IDNOs gobal sigin comleted prior to M10 | 1d | 2025-08-28 | 2025-08-28 |  | start no earlier than 2025-08-28 |
| 2214 | Engagement / Communications with Participants | 1d | 2025-08-29 | 2025-08-29 |  | start no earlier than 2025-08-29 |
| 2215 | **Internal Communications** | 1d | 2025-09-01 | 2025-09-01 |  |  |
| 2216 | Agree Content for Livewire | 1d | 2025-09-01 | 2025-09-01 |  | start no earlier than 2025-09-01 |
| 2217 | Publish Content for Livewire | 0d | 2025-09-01 | 2025-09-01 |  | start no earlier than 2025-09-01 |
| 2220 | Publish the guidence with Parties | 1d | 2025-09-04 | 2025-09-04 |  | start no earlier than 2025-09-04 |
| 2221 | Provide LWIs | 1d? | 2025-09-05 | 2025-09-05 | 2220 |  |
| 2223 | M10-Ready Participants Service Activation Preparation Completed | 0d | 2025-09-08 | 2025-09-08 | 2209, 2211, 2212, 2213, 2214, 2215, 2218, 2219, 2220, 2222 | start no earlier than 2025-09-05 |
| 2224 | **M10-Ready (Inlcuding Non-SIT LDSOs) Service Activation Implementation** | 31d? | 2025-08-06 | 2025-09-19 |  |  |
| 2225 | MHHSP Enabled Confirmation | 0d | 2025-09-10 | 2025-09-10 | 2418, 2421, 2424 | start no earlier than 2025-09-08 |
| 2226 | PAB Approval Completed | 0d | 2025-09-10 | 2025-09-10 |  | start no earlier than 2025-09-10 |
| 2227 | Add EFD (ISD Calendar Date) to DIP | 1d | 2025-09-11 | 2025-09-11 | 2218, 2219, 2222, 2225, 2226 | start no earlier than 2025-09-11 |
| 2229 | Create M16 in Customer Solution Started | 0d | 2025-09-11 | 2025-09-11 |  | start no earlier than 2025-09-11 |
| 2231 | DIP Production Success Checks | 1d? | 2025-09-12 | 2025-09-12 | 2227, 2230 |  |
| 2232 | 1st ISD Publish Started | 0d | 2025-09-11 | 2025-09-11 |  | start no earlier than 2025-09-11 |
| 2233 | 1st ISD Publish | 6d | 2025-09-11 | 2025-09-18 | 2227SS, 2232SS | start no earlier than 2025-09-11 |
| 2234 | Go Live ISD | 1d? | 2025-09-18 | 2025-09-18 |  | start no earlier than 2025-09-18 |
| 2235 | M10-Ready Service Activation Implementation Completed | 0d | 2025-09-19 | 2025-09-19 | 2225, 2226, 2227, 2228, 2230, 2233, 2234 | start no earlier than 2025-09-19 |
| 2236 | Non-SIT LDSO Service Activation Data Loading Completed | 0d | 2025-08-06 | 2025-08-06 |  | finish no earlier than 2025-08-06 |
| 2237 | **M10-Ready Service Activation Implementation MDD** | 7d | 2025-09-10 | 2025-09-19 |  |  |
| 2238 | MDD Final Circular Completed | 0d | 2025-09-10 | 2025-09-10 | 2222 | finish no earlier than 2025-09-10 |
| 2239 | MDD Manual Update | 3d | 2025-09-11 | 2025-09-15 | 2238FF | finish no earlier than 2025-09-15 |
| 2240 | MDD Publish | 6d | 2025-09-11 | 2025-09-18 | 2239SF | finish no earlier than 2025-09-18 |
| 2241 | MDD Go Live | 0d | 2025-09-18 | 2025-09-18 | 2240 | finish no earlier than 2025-09-18 |
| 2242 | Non-SIT LDSO & SIT MVC Service Activation Implementation MDD Completed | 0d | 2025-09-18 | 2025-09-18 | 2238, 2239, 2240, 2241 | finish no earlier than 2025-09-18 |
| 2243 | Non-SIT LDSO & SIT MVC Service Activation Implementation MDD Completed | 0d | 2025-09-19 | 2025-09-19 | 2242 | finish no earlier than 2025-09-19 |
| 2244 | **Non-SIT LDSO & SIT MVC Service Activation Hypercare (M10 Ready)** | 54d | 2025-09-18 | 2025-12-02 |  |  |
| 2245 | Monitoring | 54d | 2025-09-18 | 2025-12-02 |  | finish no earlier than 2025-12-02 |
| 2246 | Reporting | 54d | 2025-09-18 | 2025-12-02 |  | start no earlier than 2025-09-18 |
| 2248 | Closed Down Activities | 1d | 2025-09-19 | 2025-09-19 | 2245SS, 2246SS, 2247SS | finish no earlier than 2025-09-19 |
| 2249 | Inform MHHSP | 1d | 2025-09-19 | 2025-09-19 | 2248SS | finish no earlier than 2025-09-19 |
| 2250 | **DIP Guidance Notes** | 55d | 2025-05-05 A | 2025-07-18 |  |  |
| 2251 | GN/LWI creation & publication | 55d | 2025-05-05 A | 2025-07-18 |  | start no earlier than 2025-05-05 |
| 2252 | Tranche 1 GN/LWI created & published (critical for M10) | 0d | 2025-06-20 | 2025-06-20 |  | start no earlier than 2025-06-20 |
| 2253 | Tranche 2 GN/LWI created & published | 0d | 2025-07-04 | 2025-07-04 |  | start no earlier than 2025-07-04 |
| 2254 | Tranche 3 GN/LWI created & published | 0d | 2025-07-18 | 2025-07-18 |  | start no earlier than 2025-07-18 |
| 2255 | DIP Reporting (M11) | 65d | 2025-05-12 A | 2025-08-08 |  | start no earlier than 2025-05-12 |
| 2256 | Functional Training Execution | 85d | 2025-05-05 A | 2025-08-29 |  | start no earlier than 2025-05-05 |
| 2257 | **Operational Readiness E2E Testing** | 64d | 2025-05-13 A | 2025-08-08 |  |  |
| 2258 | Phase 1 Test Execution (Service Activation and Participant Management) | 34d | 2025-05-13 A | 2025-06-27 |  | start no earlier than 2025-05-13 |
| 2259 | Phase 2 Test Execution (S&I) | 25d | 2025-06-03 A | 2025-07-07 |  | start no earlier than 2025-06-03 |
| 2260 | Phase 3 Test Execution (Assurance & mop-up) | 23d | 2025-06-30 | 2025-07-30 |  | start no earlier than 2025-06-30 |
| 2261 | E2E Operational Testing Completed | 0d | 2025-08-08 | 2025-08-08 | 2258, 2259, 2260 | finish no earlier than 2025-08-08 |
| 2262 | **Helix Solution Build** | 254d? | 2024-08-19 A | 2025-08-07 |  |  |
| 2263 | M10 Build | 32d | 2025-04-28 A | 2025-06-10 |  | start no earlier than 2025-04-28 |
| 2264 | Helix Code Uplifts (TBC) | 40d? | 2025-06-11 | 2025-08-05 | 2263 |  |
| 2265 | **Helix E2E Settlement Assurance Testing (SAT)** | 254d? | 2024-08-19 A | 2025-08-07 |  |  |
| 2266 | **Test design** | 125d | 2024-09-02 A | 2025-02-21 A |  |  |
| 2267 | SAT tests (Review and finalise) | 95d | 2024-09-02 A | 2025-01-10 A |  | start no earlier than 2024-09-02 |
| 2268 | Test Automation and Supporting Tools | 80d | 2024-11-04 A | 2025-02-21 A |  | start no earlier than 2024-11-04 |
| 2269 | SAT tests batch 3 | 50d | 2024-12-16 A | 2025-02-21 A |  | start no earlier than 2024-12-16 |
| 2270 | **Data and environment** | 120d? | 2024-08-19 A | 2025-01-31 A |  |  |
| 2271 | Data and environment requirements | 55d | 2024-08-19 A | 2024-11-01 A |  | start no earlier than 2024-08-19 |
| 2272 | Data sourcing | 95d | 2024-09-02 A | 2025-01-10 A |  | start no earlier than 2024-09-02 |
| 2273 | Environment data check | 15d? | 2025-01-13 A | 2025-01-31 A | 2272 |  |
| 2274 | **Execution** | 194d? | 2024-11-11 A | 2025-08-07 |  |  |
| 2275 | Trial test runs | 50d | 2024-11-11 A | 2025-01-17 A |  | start no earlier than 2024-11-11 |
| 2276 | Test planning prioritisation | 14d | 2025-01-20 A | 2025-02-06 A | 2275 |  |
| 2277 | Programme agreement to start SAT testing | 0d | 2025-02-06 A | 2025-02-06 A | 2276 |  |
| 2278 | SAT Testing Start | 0d | 2025-02-06 A | 2025-02-06 A | 2277 |  |
| 2279 | **SAT Cycle 1** | 114d? | 2025-02-07 A | 2025-07-16 | 2278 |  |
| 2280 | **Legacy** | 99d | 2025-02-07 A | 2025-06-25 |  |  |
| 2281 | GMT | 89d | 2025-02-07 A | 2025-06-11 |  |  |
| 2282 | P0210 file shared for NESO Validation | 0d | 2025-05-23 A | 2025-05-23 A |  | start no earlier than 2025-05-23 |
| 2283 | NESO Validation Period (GMT) | 5d | 2025-05-28 A | 2025-06-03 A | 2282 | start no earlier than 2025-05-28 |
| 2284 | Long | 13d | 2025-05-28 | 2025-06-13 |  | start no earlier than 2025-05-28 |
| 2285 | Helix SAT Confidence Check 1 | 0d | 2025-06-10 | 2025-06-10 |  | finish no earlier than 2025-06-10 |
| 2286 | P0210 file shared for NESO Validation | 0d | 2025-06-13 | 2025-06-13 | 2284 | start no earlier than 2025-06-13 |
| 2287 | Helix SAT Confidence Check 2 | 0d | 2025-06-13 | 2025-06-13 |  | finish no earlier than 2025-06-13 |
| 2288 | NESO Validation Period (Long) | 5d | 2025-06-16 | 2025-06-20 | 2286 | start no earlier than 2025-06-16 |
| 2289 | SAT Confidence Assessment | 0d | 2025-06-13 A | 2025-06-13 |  | start no earlier than 2025-06-13 |
| 2290 | BST | 13d | 2025-06-02 | 2025-06-18 |  | start no earlier than 2025-06-02 |
| 2291 | P0210 file shared for NESO Validation | 0d | 2025-06-18 | 2025-06-18 | 2290 |  |
| 2292 | NESO Validation Period (BST) | 5d | 2025-06-19 | 2025-06-25 |  | start no earlier than 2025-06-19 |
| 2293 | Trading Dispute | 3d | 2025-06-18 | 2025-06-20 |  | start no earlier than 2025-06-18 |
| 2294 | **Transition** | 36d? | 2025-05-28 A | 2025-07-16 |  |  |
| 2295 | GMT | 19d | 2025-05-28 A | 2025-06-23 |  | start no earlier than 2025-05-28 |
| 2296 | P0210 file shared for NESO Validation | 1d? | 2025-06-13 | 2025-06-13 |  | finish no earlier than 2025-06-13 |
| 2297 | NESO Validation Period (GMT) | 5d | 2025-06-17 | 2025-06-23 | 2296 | finish no earlier than 2025-06-23 |
| 2298 | Long | 4d | 2025-06-24 | 2025-06-27 |  | start no earlier than 2025-06-24 |
| 2299 | P0210 file shared for NESO Validation | 0d | 2025-06-27 | 2025-06-27 | 2298 |  |
| 2300 | NESO Validation Period (Long) | 5d | 2025-06-30 | 2025-07-04 | 2299 | start no earlier than 2025-06-30 |
| 2301 | BST | 4d | 2025-06-26 | 2025-07-01 |  | start no earlier than 2025-06-26 |
| 2302 | P0210 file shared for NESO Validation | 0d | 2025-07-01 | 2025-07-01 | 2301 |  |
| 2303 | NESO Validation Period (BST) | 5d | 2025-07-03 | 2025-07-09 | 2302 | finish no earlier than 2025-07-09 |
| 2304 | Short | 3d | 2025-07-01 | 2025-07-03 |  | start no earlier than 2025-07-01 |
| 2305 | P0210 file shared for NESO Validation | 0d | 2025-07-03 | 2025-07-03 | 2304 |  |
| 2306 | NESO Validation Period (Short) | 5d | 2025-07-04 | 2025-07-10 | 2305 | start no earlier than 2025-07-04 |
| 2307 | DCP MPAN Mig | 3d | 2025-07-01 A | 2025-07-03 A |  | start no earlier than 2025-07-01 |
| 2308 | ISD | 3d | 2025-07-01 | 2025-07-03 |  | start no earlier than 2025-07-01 |
| 2309 | Data Agg | 6d | 2025-07-04 | 2025-07-11 |  | start no earlier than 2025-07-04 |
| 2310 | M16 | 3d | 2025-07-14 | 2025-07-16 |  | start no earlier than 2025-07-14 |
| 2311 | End of Cycle 1 | 0d | 2025-07-16 | 2025-07-16 |  | start no earlier than 2025-07-16 |
| 2312 | **SAT Cycle 2** | 12d | 2025-07-17 | 2025-08-01 |  |  |
| 2313 | **Legacy** | 12d | 2025-07-17 | 2025-08-01 |  |  |
| 2314 | Pre-M10 | 1d | 2025-07-17 | 2025-07-17 |  | start no earlier than 2025-07-17 |
| 2315 | GMT & BST & Long | 6d | 2025-07-18 | 2025-07-25 |  | start no earlier than 2025-07-18 |
| 2316 | NESO Validation Period (GMT & BST & Long) | 5d | 2025-07-28 | 2025-08-01 | 2315 |  |
| 2317 | Trading Dispute | 2d | 2025-07-28 | 2025-07-29 |  | start no earlier than 2025-07-28 |
| 2318 | **Transition** | 4d | 2025-07-24 | 2025-07-29 |  |  |
| 2319 | ISD | 4d | 2025-07-24 | 2025-07-29 |  | start no earlier than 2025-07-24 |
| 2320 | Data Agg | 3d | 2025-07-24 | 2025-07-28 |  | start no earlier than 2025-07-24 |
| 2321 | End of Cycle 2 | 0d | 2025-08-01 | 2025-08-01 |  | start no earlier than 2025-08-01 |
| 2322 | SAT Exit Report | 5d | 2025-08-01 | 2025-08-07 | 2321 |  |
| 2323 | SAT Complete | 0d | 2025-08-01 | 2025-08-01 |  | start no earlier than 2025-08-01 |
| 2324 | DR Testing | 30d | 2025-04-28 | 2025-06-06 |  | start no earlier than 2025-04-28 |
| 2325 | Pen Testing | 40d? | 2025-04-28 | 2025-06-20 |  | start no earlier than 2025-04-28 |
| 2326 | Post Environment Build | 24d | 2025-06-30 | 2025-07-31 |  | finish no earlier than 2025-07-31 |
| 2327 | Production Environment Base Platform Sign-off | 0d | 2025-07-31 | 2025-07-31 | 2326FF | start no earlier than 2025-07-31 |
| 2328 | **Implementation (Helix & DIP)** | 116d | 2025-04-28 | 2025-10-06 |  |  |
| 2329 | Go / No-Go (DIP & SM) | 0d | 2025-07-31 | 2025-07-31 |  | start no earlier than 2025-07-31 |
| 2330 | Implementation Readiness (inc Technical Readiness, Approach and Runbook, Walkthrough / Rehearsals | 69d | 2025-04-28 | 2025-07-31 |  | start no earlier than 2025-04-28 |
| 2331 | M10 Implementation Approach & Go-Live Runbook | 30d | 2025-04-28 | 2025-06-06 |  | start no earlier than 2025-04-28 |
| 2332 | DIP Production Build | 15d | 2025-06-09 | 2025-06-27 |  | start no earlier than 2025-06-09 |
| 2333 | Final Production Deployment | 15d | 2025-07-07 | 2025-07-25 |  | start no earlier than 2025-07-07 |
| 2334 | DIP Portal Available | 0d | 2025-08-04 | 2025-08-04 | 2333FS+6d |  |
| 2335 | DIP Technical Onboarding for LDSOs | 36d | 2025-08-05 | 2025-09-23 | 2333, 2334, 2147, 2329 |  |
| 2336 | ISD Dress Rehearsals | 25d | 2025-07-07 | 2025-08-08 |  | start no earlier than 2025-07-07 |
| 2337 | Go / No-Go (Helix Central Systems) | 0d | 2025-08-11 | 2025-08-11 | 2323, 1608, 2327 | start no earlier than 2025-08-11 |
| 2338 | Service Activation Implementation | 8d | 2025-08-15 | 2025-08-26 | 2337FS+4d |  |
| 2339 | ISD Data Migration | 8d | 2025-08-15 | 2025-08-26 | 2337FS+4d, 2322 |  |
| 2340 | DAH & ISD Dark Mode | 0d | 2025-08-26 | 2025-08-26 | 2339 |  |
| 2341 | Dual Run (Pre-Prod) | 15d | 2025-08-27 | 2025-09-16 | 2340 |  |
| 2342 | DIP Technical Onboarding for LDSOs | 26d | 2025-08-04 | 2025-09-08 | 2147FS-1d | start no earlier than 2025-08-04 |
| 2343 | M10 Cutover Weekend | 1d | 2025-09-22 | 2025-09-22 | 2341FS+3d |  |
| 2344 | Post Implementation Review | 1d | 2025-10-06 | 2025-10-06 | 2343FS+9d |  |
| 2993 | Drop-in session 4 | 0d | 2025-06-18 | 2025-06-18 | 2992FS+5d | start no earlier than 2025-06-18 |
| 3003 | Test Scripts shared with Participants | 0d | 2025-06-02 A | 2025-06-02 A |  | start no earlier than 2025-06-02 |
| 3004 | Dress rehearsal 1 start | 0d | 2025-06-09 | 2025-06-09 |  | start no earlier than 2025-06-09 |
| 3005 | Supplier Schedule Submission #2 complete | 1d | 2025-06-20 | 2025-06-20 |  | start no earlier than 2025-06-20 |
| 3006 | Consolidate baseline schedule | 15d | 2025-06-23 | 2025-07-11 | 3005 |  |
| 3007 | Consolidated baseline schedule published to industry | 0d | 2025-07-11 | 2025-07-11 | 3006 |  |
| 3008 | Baselined Schedule available for download | 1d | 2025-07-14 | 2025-07-14 | 3007 |  |
| 3012 | MCAG approval of Baseline Migration schedule | 0d | 2025-07-22 | 2025-07-22 | 3011 | finish no earlier than 2025-07-22 |

Removed: 1609 Assurance of PPs Test Completion Reports; 1628 Develop document; 1629 Review & agree document; 1717 Develop document; 1718 Review & agree document; 1722 Assurance of PPs Test Completion Reports; 1729 Assurance of PPs Test Completion Reports; 1738 Develop document; 1739 Review & agree document; 1756 Assurance of PPs Test Completion Reports; 1765 Develop document; 1766 Review & agree document; 1769 SIT Test Exit Report; 1770 Develop document; 1771 Review & agree document; 2814 SIT Participant's Prepared for Migration; 2815 Prep for Envelope Webinar; 2816 Envelope/Submission Webinar; 2817 Guides Creation; 2818 Support Channels; 3282 SIT MVC; 3283 SIT MVC Service Activation Preparation Tasks; 3284 Identify operational resources; 3285 Define and approve operational support model; 3286 Confirm SA Training completed; 3287 Participant Engagement / Communications; 3288 Internal Communications; 3291 Provide opeartional resources with LWIs; 3293 SIT MVC Service Activation Preparation Tasks Complete; 3294 MHHSP Confirms SIT MVC PPs MHHS Enabled; 3295 SIT MVC Service Activation Implementation; 3296 Add EFD to DIP; 3298 SIT LDSOs Create Certificates and Test Connectivity; 3299 SIT MVC S&As Create Certificates and Test Connectivity; 3301 Publish ISD; 3302 SIT LDSOs to update systems with ISD; 3303 SIT MVC S&As to update systems with ISD; 3304 SIT MVC Service Activation Implementation Complete; 3305 SIT MVC Service Activation Implementation MDD; 3306 MDD Manual Load; 3307 MDD Update; 3308 SIT MVC Service Activation Implementation MDD Complete; 3309 SIT MVC Service Activation Hypercare; 3310 Service & Process Monitoring; 3311 Daily Reporting; 3313 SA Hypercare Close Down Activities; 3314 Handover to MHHSP; 3315 SIT MVC Service Activation Hypercare Complete; 3316 SIT Non-MVC; 3317 SIT Non-MVC Service Activation Preparation Tasks; 3318 Helix Preparatory Activities Complete; 3319 MHHSP Confirms SIT Non-MVC PPs MHHS Enabled; 3320 SIT Non-MVC Service Activation Implementation; 3321 Add EDF to DIP; 3322 DIP Promoted to Production; 3323 SIT non-MVC S&As Create Certificates and Test Connectivity; 3324 Create M16 in Customer Solution; 3325 Publish ISD; 3326 SIT non-MVC S&As to update systems with ISD; 3327 SIT Non-MVC Service Activation Implementation Complete; 3328 SIT Non-MVC Service Activation Implementation MDD; 3329 MDD Manual Load; 3330 MDD Update; 3331 SIT Non-MVC Service Activation Implementation MDD Complete; 3332 Non-SIT MVC Service Activation Hypercare; 3333 Service& Process Monitoring; 3334 Daily Reporting; 3335 Issue Management; 3336 SA Hypercare Close Down Activities; 3337 Handover to MHHSP; 3338 Non-SIT MVC Service Activation Hypercare Complete (M)

Changed:

| ID | Task | Start | Finish | Duration | Complete | Total float | Predecessors | Other |
| --- | --- | --- | --- | --- | --- | --- | --- | --- |
| 1 | **PROGRAMME PLAN.** |  |  |  | 66% → 67% |  |  |  |
| 545 | **SYSTEMS INTEGRATION TESTING (SIT)** |  |  |  | 76% → 77% |  |  |  |
| 1520 | **SIT Execution** |  |  |  | 52% → 57% |  |  |  |
| 1537 | **SIT** |  | 2025-08-27 → 2025-08-22 (-5d) | 383d? → 380d? | 54% → 61% | 606d → 609d |  |  |
| 1538 | **SIT Functional Testing (MVC)** |  |  |  | 61% → 66% |  |  |  |
| 1577 | **SIT Functional Settlement Testing** |  |  |  | 29% → 35% |  |  |  |
| 1596 | **SIT-A Settlement Testing** |  | 2025-06-16 → 2025-06-13 (-3d) |  | 10% → 40% | 10d → 659d |  |  |
| 1598 | SIT-A Settlement Testing | 2025-05-20 A → 2025-05-19 A (-1d) | 2025-06-16 → 2025-06-13 (-3d) |  | 10% → 40% | 10d → 19d |  |  |
| 1600 | SIT-A Settlement Decision Point Exit Criteria |  |  |  |  | 10d → 4d | 1598FS-2d → 1598FS-1d |  |
| 1628 | SI SIT Functional Testing Test Exit Report Approved |  |  |  |  | 8d → 12d | Review & agree documentFF, 1625, 1627, 1608 → 1625, 1627, 1608 |  |
| 1629 | SITAG Approves SI SIT Functional & Migration (Post-Regression) Overarching Test Exit Report |  |  |  |  | 7d → 11d | Review & agree documentFF, 1625, 1627, 1608 → 1625, 1627, 1608 |  |
| 1662 | **SIT Migration Testing** |  | 2025-08-27 → 2025-08-20 (-7d) | 383d? → 378d? | 61% → 67% | 606d → 611d |  |  |
| 1664 | **SIT Migration Testing Execution** |  | 2025-08-27 → 2025-08-20 (-7d) | 383d? → 378d? | 61% → 67% | 606d → 611d |  |  |
| 1690 | Regression Test Execution Start |  |  |  |  | 15d → 26d | 1601FS+2d → 1601FS+2d, 2263 |  |
| 1707 | **SIT Settlement and Regression Test Exit Report** |  | 2025-08-27 → 2025-08-20 (-7d) | 43d → 38d |  | 20d → 24d |  |  |
| 1715 | SIT Migration Testing Test Exit Report Approved |  |  |  |  | 7d → 11d | Review & agree documentFS+5d → none |  |
| 1716 | SIT Migration Testing End (incl. confirmation that PPs have submitted their Test Exit Reports to Programme for assurance) |  |  |  |  | 609d → 614d | Develop documentFF, 1712 → 1712 |  |
| 1717 | SITAG Approves SI SIT Functional & Migration (Post-Regression) Overarching Test Exit Report |  |  |  |  | 606d → 611d | Develop documentFF, 1712 → 1712 |  |
| 1718 | **SIT Non-Functional Testing (all SIT PPs)** |  |  |  | 29% → 55% |  |  |  |
| 1722 | Theme 2 & 3 SIT Non-Functional Testing Execution |  | 2025-05-23 A |  | 65% → 100% | 60d → none |  |  |
| 1723 | SIT Non-Functional Testing Execution End (all SIT PPs) | 2025-05-23 A | 2025-05-23 A |  | 0% → 100% | 60d → none |  | was named SIT Non-Functional Testing End (all SIT PPs) (incl. confirmation that PPs have submitted their Test Completion Reports to Programme for assurance) |
| 1724 | **SIT Non-Functional Testing Test Exit Report (all SIT PPs)** | 2025-05-05 → 2025-05-26 (+21d) |  | 53d → 38d |  | 60d → 56d |  |  |
| 1732 | SIT Non-Functional Testing Test Exit Report (all SIT PPs) Approved |  |  |  |  | 32d → 36d | Review & agree documentFF+5d, 1729FS+3d → 1729FS+3d |  |
| 1733 | SITAG Approves SI SIT Non-Functional Overarching Test Exit Report |  |  |  |  | 33d → 22d | Review & agree documentFF+5d, 1729FS+3d → 1729FS+3d |  |
| 1734 | **SIT Operational Testing (all SIT PPs)** |  |  |  | 30% → 47% |  |  |  |
| 1738 | **SIT B Testing** |  |  |  | 47% → 67% | 30d → 644d |  |  |
| 1740 | SIT Operational Testing Execution Theme 1 |  |  |  | 50% → 75% | 30d → 644d |  |  |
| 1741 | SIT Operational Testing Execution Theme 2 |  |  |  | 60% → 80% | 30d → 644d |  |  |
| 1743 | **SIT Operational Testing Re-test Theme 3 (Batch 1)** |  |  |  | 55% → 75% | 45d → 659d |  |  |
| 1745 | Scripts uploaded to ADO / Project Created |  | 2025-05-23 A |  | 20% → 100% | 55d → none |  |  |
| 1756 | SIT Operational Testing Test Exit Report (all SIT PPs) Approved |  |  |  |  | 17d → 6d | Review & agree documentFF+5d, 1753FS+3d → 1753FS+3d |  |
| 1757 | SITAG Approves SI SIT Operational Testing Test Exit Report |  |  |  |  | 17d → 6d | Review & agree documentFF+5d, 1753FS+3d → 1753FS+3d |  |
| 1782 | **Test Artefact Development** |  |  |  | 89% → 96% |  |  |  |
| 1783 | **E2E Sandbox Guidance** |  |  |  | 96% → 99% |  |  |  |
| 1788 | Internal SI review |  | 2025-05-23 A |  | 60% → 100% | 674d → none |  |  |
| 1789 | SRO / Code Bodies review | 2025-05-19 A | 2025-05-23 A |  | 0% → 100% | 674d → none |  |  |
| 1795 | **E2E Sandbox Test Data Approach & Plan** |  |  |  | 74% → 86% |  |  |  |
| 1802 | Internal SI review and updates |  | 2025-05-23 A |  | 60% → 100% | 674d → none |  |  |
| 1803 | SRO / Code Bodies review |  | 2025-05-23 A |  | 60% → 100% | 664d → none |  |  |
| 1804 | Final updates prior to consultation | 2025-05-26 A | 2025-05-26 A |  | 0% → 100% | 664d → none |  |  |
| 1805 | Industry Consultation for E2E Sandbox Test Data Approach and Plan document | 2025-05-26 → 2025-05-27 A (+1d) |  | 10d → 9d | 0% → 22% |  |  |  |
| 1806 | Document updates post Industry Consultation | 2025-06-05 → 2025-06-06 (+1d) |  | 3d → 2d |  |  |  |  |
| 1900 | M10 Checkpoint 1 complete |  |  |  |  |  | 1935FS-126d, 1899 → 1899 |  |
| 1905 | Non-SIT LDSO Qualification Testing complete | 2025-05-16 A | 2025-05-16 A |  | 0% → 100% | 679d → none |  |  |
| 1935 | Central systems ready for migrating MPANs (M10) | 2025-09-24 → 2025-09-22 (-2d) | 2025-09-24 → 2025-09-22 (-2d) |  |  | 5d → 7d | 1758FS+20d, 3595, 3185FS+2d, 3182, 3200, 3161, 3168 → 1758FS+18d, 3595, 3185, 3182, 3200, 3161, 3168 | constraint none → start no earlier than 2025-09-22; baseline start 2025-09-24 → 2025-09-22; baseline finish 2025-09-24 → 2025-09-22 |
| 1937 | Central systems ready for migrating MPANs (M10*) - Late Exit |  |  |  |  |  | 1935FS+65d → 1935FS+67d |  |
| 1948 | **NON SIT LDSO QUALIFICATION** |  |  |  | 93% → 96% |  |  |  |
| 1994 | **Test Data** |  | 2025-05-16 A |  | 84% → 100% | 679d → none |  |  |
| 2003 | Test Execution Data Support |  | 2025-05-16 A |  | 50% → 100% | 679d → none |  |  |
| 2043 | **Test Window** |  |  |  | 91% → 92% |  |  |  |
| 2056 | Potential for non-SIT LDSO QT Regression for Qualification | 2025-05-19 A |  |  | 0% → 10% |  |  |  |
| 2057 | **Test Result Assurance** |  | 2025-05-16 A |  | 90% → 100% | 680d → none |  |  |
| 2058 | Test Reports Reviewed By MHHS & Code Bodies & Finalised |  | 2025-05-16 A |  | 90% → 100% | 680d → none |  |  |
| 2060 | **Non-SIT LDSO Qualification Closure** | 2025-05-16 A |  |  | 0% → 46% |  |  |  |
| 2061 | Non-SIT LDSO Qualification Learned Captured | 2025-05-16 A | 2025-05-29 A |  | 0% → 100% | 670d → none |  |  |
| 2062 | Non-SIT LDSO Regression Testing | 2025-05-16 A |  |  | 0% → 35% |  |  |  |
| 2064 | **HELIX / ELEXON M10 READINESS** | 2025-03-03 A → 2024-04-02 A (-335d) | 2025-09-01 → 2027-07-30 (+697d) | 130d → 869d? | 60% → 43% | 604d → 104d |  | was named SERVICE MANAGEMENT |
| 2065 | **Service Management - M10 Readiness** |  | 2025-09-01 → 2027-07-30 (+697d) | 130d → 630d | 60% → 23% | 604d → 104d |  | was named Stage 2 - M10 Readiness |
| 2066 | **Service Model Design (Cross Party Service Desk)** |  |  |  | 69% → 86% |  |  |  |
| 2067 | **Cross Party Service Desk** |  | 2025-05-19 A |  | 99% → 100% | 679d → none |  |  |
| 2072 | **Cross Party Service Desk Consultation** |  | 2025-05-19 A |  | 99% → 100% | 679d → none |  |  |
| 2078 | TORWG Post-Consultation Update (CPSD) | 2025-05-14 A | 2025-05-14 A |  | 0% → 100% | 679d → none |  |  |
| 2079 | Updated Consultation Documents Released to Industry for eTORWG | 2025-05-16 A | 2025-05-16 A |  | 0% → 100% | 679d → none |  |  |
| 2080 | CPSD, Operating Hours & Triage Updates Endorsement (eTORWG) | 2025-05-19 A | 2025-05-19 A |  | 0% → 100% | 679d → none |  |  |
| 2081 | Cross Party Service Desk Model Completed | 2025-05-19 A | 2025-05-19 A |  | 0% → 100% | 679d → none |  |  |
| 2082 | **Service Documentation** |  |  |  | 4% → 57% |  |  |  |
| 2083 | Operations Manual and LLSD Updates Post-Consultation |  | 2025-05-15 A |  | 8% → 100% | 670d → none |  |  |
| 2084 | Service User LLSD Version 1.2 | 2025-05-15 A | 2025-05-15 A |  | 0% → 100% | 670d → none |  |  |
| 2090 | **Operational Readiness Testing** |  | 2025-07-31 → 2025-08-29 (+29d) | 109d → 130d | 56% → 55% | 625d → 604d |  |  |
| 2091 | **ORT Design** |  |  |  | 88% → 99% | 662d → 623d |  |  |

| ID | Task | Start | Finish | Duration | Complete | Total float | Predecessors | Other |
| --- | --- | --- | --- | --- | --- | --- | --- | --- |
| 2096 | **ORT Test Scope and Approach Consultation (Test Scope and Approach & Test Scripts)** |  | 2025-05-19 A |  | 99% → 100% | 645d → none |  |  |
| 2101 | TORWG Post-Consultation Update (ORT Approach) | 2025-05-14 A | 2025-05-14 A |  | 0% → 100% | 648d → none |  |  |
| 2102 | Updated ORT Test Scope and Approach Documents Released to Industry for eSITWG | 2025-05-16 A | 2025-05-16 A |  | 0% → 100% | 646d → none |  |  |
| 2103 | ORT Test Scope and Approach Endorsement (eSITWG) | 2025-05-19 A | 2025-05-19 A |  | 0% → 100% | 645d → none |  |  |
| 2106 | **ORT Test Scripts Consultation** |  |  |  | 0% → 99% | 662d → 623d |  |  |
| 2108 | ORT Test Scripts Consultation | 2025-05-09 A | 2025-05-16 A |  | 0% → 100% | 633d → none |  |  |
| 2109 | ORT Test Scripts Consultation Completed | 2025-05-16 A | 2025-05-16 A |  | 0% → 100% | 633d → none |  |  |
| 2110 | ORT Test Scripts Updates (Feedback Review) | 2025-05-19 A | 2025-05-22 A |  | 0% → 100% | 633d → none |  |  |
| 2111 | ORT Test Scipts Updates Shared with MHHS and Industry | 2025-05-22 A | 2025-05-22 A |  | 0% → 100% | 633d → none |  |  |
| 2112 | Industry Assurance Review Session Post-Consultation Update (ORT Test Scripts) | 2025-05-30 A | 2025-05-30 A |  | 0% → 100% | 653d → none |  |  |
| 2113 | Updated ORT Test Script Consultation Documents Released to industry for eSITWG | 2025-06-03 A | 2025-06-03 A |  | 0% → 100% | 653d → none |  |  |
| 2114 | ORT Test Scripts and Readiness Spotlight at Elexon Service Management Steering Group | 2025-06-04 A | 2025-06-04 A |  | 0% → 100% | 666d → none |  |  |
| 2116 | **ORT Preparation** |  |  |  | 22% → 83% | 659d → 620d |  |  |
| 2117 | ORT Participant/User Scheduling |  | 2025-05-16 → 2025-06-03 A (+18d) | 12d → 24d | 33% → 100% | 665d → none |  |  |
| 2118 | ORT Participant/User Scheduling Completed | 2025-05-16 → 2025-06-03 A (+18d) | 2025-05-16 → 2025-06-03 A (+18d) |  | 0% → 100% | 679d → none |  |  |
| 2119 | ORT Training and Preparation | 2025-06-04 A |  |  | 0% → 17% | 625d → 595d |  |  |
| 2143 | **Service Go-Live** |  | 2025-09-01 → 2027-07-30 (+697d) | 22d → 522d |  | 604d → 104d |  | was named Service Go-Live Governance |
| 2145 | Helix Service Management Live | 2025-09-01 → 2025-07-31 (-32d) | 2025-09-01 → 2025-07-31 (-32d) |  |  | 604d → 587d |  | constraint start no earlier than 2025-09-01 → none |
| 2157 | **Phase 1 - Preparation** | 2022-10-31 → 2024-04-02 A (+519d) | 2026-01-16 → 2025-09-26 (-112d) | 840d? → 389d? | 0% → 70% | 504d → 584d |  |  |
| 2218 | Validate User Access | 2025-02-17 → 2025-09-02 (+197d) | 2025-02-21 → 2025-09-02 (+193d) | 5d → 1d |  | 739d → 596d |  | constraint finish no earlier than 2025-02-21 → start no earlier than 2025-09-02; baseline start 2025-02-17 → none; baseline finish 2025-02-21 → none |
| 2219 | Target Systems and Environments Ready | 2025-02-20 → 2025-09-03 (+195d) | 2025-02-24 → 2025-09-03 (+191d) | 3d → 1d |  | 738d → 595d |  | constraint finish no earlier than 2025-02-24 → start no earlier than 2025-09-03; baseline start 2025-02-20 → none; baseline finish 2025-02-24 → none |
| 2222 | Business Readiness Governance Approval | 2025-02-17 → 2025-09-08 (+203d) | 2025-02-19 → 2025-09-08 (+201d) | 3d → 1d |  | 741d → 592d | none → 2221 | constraint finish no earlier than 2025-02-19 → start no earlier than 2025-09-05; baseline start 2025-02-17 → none; baseline finish 2025-02-19 → none |
| 2228 | DIP Promoted to Production | 2025-09-15 → 2025-09-12 (-3d) | 2025-09-15 → 2025-09-12 (-3d) | 1d? → 1d |  | 5d → 594d | Add EFD to DIP → 2227 | constraint none → start no earlier than 2025-09-12; baseline start 2025-09-15 → none; baseline finish 2025-09-15 → none |
| 2230 | Create M16 in Customer Solution | 2025-09-16 → 2025-09-11 (-5d) | 2025-09-17 → 2025-09-11 (-6d) | 2d → 1d |  | 5d → 594d | 2228 → 2229SS, 2233SS | constraint finish no earlier than 2025-03-07 → start no earlier than 2025-09-11; baseline start 2025-09-16 → none; baseline finish 2025-09-17 → none |
| 2247 | Issue Management | 2025-09-12 → 2025-09-18 (+6d) | 2025-10-07 → 2025-12-02 (+56d) | 18d → 54d |  | 577d → 537d | Add EFD to DIPSS → none | constraint finish no earlier than 2025-03-26 → finish no earlier than 2025-12-02; baseline start 2025-03-03 → none; baseline finish 2025-03-26 → none |
| 2345 | **S & A QUALIFICATION** |  |  |  | 63% → 64% |  |  |  |
| 2374 | **Qualification Assessment Document** |  |  |  | 90% → 91% |  |  |  |
| 2393 | **Qualification Assessment Document Portal** |  |  |  | 82% → 84% |  |  |  |
| 2402 | QT Wave 2 Participant QAD Application Creation in Portal | 2025-05-26 A |  |  | 0% → 20% |  |  |  |
| 2407 | **MHHS Qualification - SIT Participants** |  |  |  | 44% → 46% |  |  |  |
| 2412 | **MHHS Qualification - M10-Ready** |  |  |  | 66% → 79% |  |  |  |
| 2415 | Completion of Code Bodies review of Final QAD (M10-Ready) |  |  |  | 30% → 60% | 60d → 642d |  |  |
| 2444 | **MHHS Qualification - Non-SIT LDSO (M10-Ready)** |  |  |  | 58% → 60% |  |  |  |
| 2451 | Non-SIT LDSO Participants submit Final QAD |  |  |  | 89% → 95% |  |  |  |
| 2457 | **MHHS Qualification - Qualification Waves** |  |  |  | 58% → 59% |  |  |  |
| 2638 | **Qualification Wave 1** |  |  |  | 0% → 7% |  |  |  |
| 2639 | **Qualification Wave 1 QAD Prep** |  |  |  | 0% → 29% |  |  |  |
| 2641 | Qualification Wave 1 Participants Submit Initial QAD | 2025-05-05 A |  |  | 0% → 46% |  |  |  |
| 2645 | **Qualification Wave 1 Test Prep** | 2025-05-26 A |  |  | 0% → 8% |  |  |  |
| 2646 | Confirmation from Qualification Wave 1 Participants that DIP onboarding has commenced | 2025-05-26 A | 2025-05-26 A |  | 0% → 100% | 444d → none |  |  |
| 2647 | Qualification Wave 1 Participants DIP Onboarding Window | 2025-05-26 A |  |  | 0% → 23% |  |  |  |
| 2769 | PAB295 | 2025-05-29 A | 2025-05-29 A |  | 0% → 100% | 671d → none |  |  |
| 2928 | Code changes delivered (M8) |  |  |  |  |  | 2908, 2887, 1935SS-3d, 2924 → 2908, 2887, 1935SS-3d, 2924, 2142 |  |
| 2934 | **MIGRATION** |  |  |  | 62% → 66% |  |  |  |
| 2935 | **Regulatory Governance** |  |  |  | 83% → 90% |  |  |  |
| 2937 | Incentives Implemented |  |  |  | 55% → 72% |  |  |  |
| 2986 | **Supplier Submission Support** |  | 2025-06-04 → 2025-06-18 (+14d) | 29d? → 38d? |  | 666d → 657d |  |  |
| 2991 | Drop-in session 2 | 2025-05-28 A | 2025-05-28 A |  | 0% → 100% | 666d → none |  |  |
| 2992 | Drop-in session 3 | 2025-06-04 → 2025-06-11 (+7d) | 2025-06-04 → 2025-06-11 (+7d) |  |  | 666d → 657d |  | constraint none → start no earlier than 2025-06-11; baseline start 2025-06-04 → 2025-06-11; baseline finish 2025-06-04 → 2025-06-11 |
| 2994 | Q+A documents from sessions published | 2025-06-04 → 2025-06-18 (+14d) | 2025-06-04 → 2025-06-18 (+14d) |  |  | 666d → 657d | 2992 → 2993 | baseline start 2025-06-04 → 2025-06-18; baseline finish 2025-06-04 → 2025-06-18 |
| 2995 | **MCC Stood up** |  |  |  | 49% → 50% |  |  |  |
| 2996 | Migration Planning Management Tool Delivery |  |  |  | 49% → 54% |  |  |  |
| 2998 | **MCC Dress Rehersal 1 - Initialise Schedule (Weekly) Drop 1, 2** |  | 2025-07-15 → 2025-07-22 (+7d) | 60d → 65d |  | 637d → 632d |  |  |
| 2999 | Issue Dress Rehearsal support information to all Suppliers (SIT & Non-SIT) |  |  |  |  |  |  | was named Issue Dress Rehearsal support information to Participants |
| 3010 | Dress rehearsal completion report |  |  |  |  |  | 3009 → 3009, 3006 |  |
| 3023 | **Migration Artefact Development and Publication** |  |  |  | 67% → 73% |  |  |  |
| 3066 | **Data Cleanse Plan** |  |  |  | 93% → 95% |  |  |  |
| 3071 | **MTDs** |  | 2025-07-21 → 2025-07-18 (-3d) | 241d → 240d | 79% → 86% | 633d → 634d |  |  |
| 3072 | **ESME ID** |  | 2025-05-16 A |  | 93% → 100% | 679d → none |  |  |
| 3076 | Suppliers complete Work Off plans |  | 2025-05-16 A |  | 92% → 100% | 679d → none |  |  |
| 3077 | ESME ID Complete | 2025-05-16 A | 2025-05-16 A |  | 0% → 100% | 679d → none |  |  |
| 3078 | **Meter Location and Number of Displayed Register Digits** |  | 2025-07-21 → 2025-07-18 (-3d) | 222d → 221d | 67% → 75% | 633d → 634d |  |  |
| 3082 | Suppliers complete Work Off plans |  | 2025-07-21 → 2025-07-18 (-3d) | 124d → 123d | 60% → 70% | 633d → 634d |  |  |
| 3083 | Meter Location and Number of Displayed Register Digits Complete | 2025-07-21 → 2025-07-18 (-3d) | 2025-07-21 → 2025-07-18 (-3d) |  |  | 633d → 634d |  |  |
| 3094 | The DCC to extract Domestic Premises Indicator from the CSS and provide a file to each LDSO and EES. |  |  |  |  |  | 1935FS-14d → none |  |
| 3097 | **Connection Type and Meter Type Misalignments** |  |  |  | 35% → 47% |  |  |  |
| 3098 | **Traditional Meters installed on Current Transformers** |  |  |  | 11% → 15% |  |  |  |
| 3099 | Suppliers investigate all MPANs with Traditional Meters installed on a Current Transformer Connection Type |  | 2025-05-30 A |  | 80% → 100% | 301d → none |  |  |
| 3100 | Suppliers to raise the relevant SDEP cases with LDSOs in pot 3 | 2025-05-30 A | 2025-05-30 A |  | 0% → 100% | 629d → none |  |  |
| 3101 | Suppliers to have ensured that Meter Operators have sent the necessary D0312s for MPANs in pot 2 | 2025-06-02 A |  |  | 0% → 14% |  |  |  |

| ID | Task | Start | Finish | Duration | Complete | Total float | Predecessors | Other |
| --- | --- | --- | --- | --- | --- | --- | --- | --- |
| 3102 | LDSOs will be required to have corrected all of these Connection Types in pot 3 | 2025-06-02 A |  |  | 0% → 8% |  |  |  |
| 3103 | Suppliers to have completed meter exchanges for those MPANs in pot 1 | 2025-06-02 A |  |  | 0% → 1% |  |  |  |
| 3105 | **CHECK Meters** |  | 2025-06-02 A |  | 80% → 100% | 668d → none |  |  |
| 3106 | Suppliers and their appointed Meter Operator investigate MPANs within their portfolio that have incorrectly populated meters with the Meter Type CHECK within MPRS. Meter Operators are required to send a D0312 to remove the CHECK meter from MPRS. |  | 2025-05-30 A |  | 80% → 100% | 669d → none |  |  |
| 3107 | Once CHECK meters are either removed from MPRS or the Meter Type is changed to a valid Meter Type, the LDSO should check that the Connection Type assigned to the MPAN is still valid. |  | 2025-05-30 A |  | 80% → 100% | 669d → none |  |  |
| 3108 | Suppliers confirm to the Programme that they have completed this activity | 2025-06-02 A | 2025-06-02 A |  | 0% → 100% | 668d → none |  |  |
| 3109 | CHECK Meters complete | 2025-06-02 A | 2025-06-02 A |  | 0% → 100% | 668d → none |  |  |
| 3110 | **Smart Meter Types installed on CT Connection Types** |  |  |  | 41% → 59% |  |  |  |
| 3112 | LDSOs investigate Connection Type misalignments and correct where appropriate |  | 2025-05-30 A |  | 74% → 100% | 629d → none |  |  |
| 3113 | LDSOs raise SDEP queries with Suppliers where they believe there is an issue | 2025-05-30 A | 2025-05-30 A |  | 0% → 100% | 629d → none |  |  |
| 3114 | Suppliers resolve all issues | 2025-06-02 A |  |  | 0% → 8% |  |  |  |
| 3116 | **Linked Import / Export MPANs** |  | 2025-07-28 → 2025-07-25 (-3d) | 106d → 105d | 49% → 65% | 628d → 629d |  |  |
| 3117 | LDSOs review and correct linked Import / Export MPANs with Different Connection Types |  | 2025-07-28 → 2025-07-25 (-3d) | 106d → 105d | 49% → 65% | 628d → 629d |  |  |
| 3118 | LDSOs, Import and Export Suppliers review and correct linked Import / Export MPANs with meters in the Advanced and Traditional or Smart Meter Groups |  | 2025-07-28 → 2025-07-25 (-3d) | 106d → 105d | 49% → 65% | 628d → 629d |  |  |
| 3119 | Linked Import / Export MPANs complete | 2025-07-28 → 2025-07-25 (-3d) | 2025-07-28 → 2025-07-25 (-3d) |  |  | 628d → 629d |  |  |
| 3120 | **Related MPANs** |  |  |  | 50% → 65% |  |  |  |
| 3121 | LDSOs review and correct related MPANs with different Connection Types |  |  |  | 65% → 85% |  |  |  |
| 3123 | Suppliers should investigate Related MPANs within different meter groups and verify that they are correct or request that their Meter Operators update the Meter Types where they are incorrect |  |  |  | 50% → 65% |  |  |  |
| 3155 | **Preparation for Cutover to Live** | 2024-06-28 A → 2022-10-31 A (-606d) |  | 744d → 1178d | 11% → 18% |  |  |  |
| 3156 | **Central Systems Prepare for Cutover to Live** | 2024-06-28 A → 2022-10-31 A (-606d) |  | 326d → 760d | 31% → 51% |  |  |  |
| 3158 | **Development of Comms Approach and Declaration Guidance** |  |  |  | 20% → 39% |  |  | baseline start 2025-03-03 → 2025-04-28; baseline finish 2025-06-19 → 2025-08-14 |
| 3159 | Draft Cutover Comms Approach |  |  |  | 20% → 39% |  |  |  |
| 3162 | **Development of Cutover Plan requirements with Participants** |  |  |  | 33% → 55% |  |  |  |
| 3163 | Development of Central Parties Cutover Plans |  | 2025-05-16 A |  | 88% → 100% | 659d → none |  | baseline start 2025-04-28 → 2025-04-11; baseline finish 2025-07-17 → 2025-05-16 |
| 3164 | Development of Programme Participant Cutover Plans |  |  |  | 40% → 68% |  |  | baseline start 2025-07-17 → 2025-04-11; baseline finish 2025-07-17 → 2025-06-30 |
| 3165 | Central Party Cutover Plan Assurance |  |  |  | 49% → 73% |  |  |  |
| 3166 | Consolidated MHHS Cutover Plan Developed | 2025-05-19 A |  |  | 0% → 65% |  |  |  |
| 3169 | **M10/M11 Cutover Activities** | 2025-09-05 → 2022-10-31 A (-1040d) |  | 15d → 760d |  | 12d → 584d |  |  |
| 3172 | Completion of the pre-M10 MHHS Data Cleanse | 2025-09-24 → 2025-09-22 (-2d) | 2025-09-24 → 2025-09-22 (-2d) |  |  | 586d → 588d |  |  |
| 3173 | Market-wide Participant MHHS Supporting Functionality Ready - Confirmation from Code Bodies | 2025-09-15 → 2022-10-31 A (-1050d) | 2025-09-15 → 2022-10-31 A (-1050d) |  | 0% → 100% | 594d → none | 1935FS-8d → none |  |
| 3174 | Market-wide Participant MHHS Supporting Functionality Ready |  |  |  |  | 589d → 588d | 1935FS-3d → 1935 |  |
| 3191 | Confirmation that Market Segment has been populated for 95% of LDSO portfolios |  |  |  |  | 5d → 7d |  | baseline start none → 2025-09-12; baseline finish none → 2025-09-12 |
| 3199 | TORWG (Recommendation from TORWG that the Programme should enter M10) |  |  |  |  | 5d → 7d | 3190FS+1d, 3194FS+1d, 3196FS+3d, 3170FS+1d, 3171FS+1d, SIT LDSOs Create Certificates and Test ConnectivityFS+1d, 3192FS+3d, 3193FS+3d, 3195FS+3d, 3197, 3198 → 3190FS+1d, 3194FS+1d, 3196FS+3d, 3170FS+1d, 3171FS+1d, 3192FS+3d, 3193FS+3d, 3195FS+3d, 3197, 3198 |  |
| 3200 | MCAG (Confirm that the Programme can Enter M10) |  |  |  |  | 5d → 7d | 3199FS+2d, SIT MVC Service Activation Implementation Complete → 3199FS+2d |  |
| 3205 | Recommendation from TORWG that PSG should approve M10 |  |  |  |  |  | 3201FS+1d, 3202FS+1d, 3203FS+1d, 3204FS+1d, SIT LDSOs to update systems with ISD → 3201FS+1d, 3202FS+1d, 3203FS+1d, 3204FS+1d |  |
| 3211 | TORWG (Confirmation of Qualified Parties from TORWG) |  |  |  |  |  | 3208FS+1d, 3209FS+1d, 3210FS+1d, 3186, SIT MVC S&As Create Certificates and Test Connectivity, SIT MVC S&As to update systems with ISD → 3208FS+1d, 3209FS+1d, 3210FS+1d, 3186 |  |
| 3221 | Sprint Execution Start |  |  |  |  |  | 3220FS+5d, SIT MVC Service Activation Implementation Complete, 3313 → 3220FS+5d, 3313 |  |
| 3308 | Assurance of DCC capacity upgrade to ensure suitability to support migration |  |  |  |  |  | 1935FF-23d → 1935FF-21d |  |
| 3310 | **Migration - Tier 1 Milestones** | 2025-09-24 → 2025-09-22 (-2d) |  | 488d → 490d |  | 25d → 27d |  |  |
| 3311 | Load Shaping Service switched on (M13) | 2025-09-24 → 2025-09-22 (-2d) | 2025-09-24 → 2025-09-22 (-2d) |  |  | 25d → 27d |  |  |
| 3312 | Load Shaping Service switched on (M13*) - Late Exit |  |  |  |  |  | 3311FS+65d → 3311FS+67d |  |
| 3313 | Start of 18-month migration for UMS / Advanced (M11) |  |  |  |  |  | 3311, 3212, 3213, SIT MVC Service Activation Implementation Complete, 1935FS+20d → 3311, 3212, 3213, 1935FS+20d |  |
| 3315 | Start of 18-month migration for Smart / Non-smart (M12) |  |  |  |  |  | 3311, 1935FS+20d → 3311, 1935FS+22d |  |
| 3319 | **BUSINESS & OPERATIONAL READINESS** |  |  |  | 18% → 38% |  |  |  |
| 3332 | Hypercare post M10 | 2025-09-25 → 2025-09-23 (-2d) |  | 80d → 82d |  |  |  |  |
| 3334 | **Service Activation** |  |  |  | 20% → 23% |  |  |  |
| 3491 | MHHSP Enabled Confirmation |  |  |  |  |  | MHHSP Confirms SIT Non-MVC PPs MHHS Enabled → none |  |
| 3625 | **PP Business Change** | 2025-02-03 A | 2025-07-31 A |  | 0% → 100% | 625d → none |  |  |
| 3626 | Plan stakeholder management | 2025-02-03 A | 2025-07-31 A |  | 0% → 100% | 625d → none |  |  |
| 3627 | Manage stakeholders | 2025-02-03 A | 2025-07-31 A |  | 0% → 100% | 625d → none |  |  |
| 3628 | Develop & implement changes to KPIs, organisation & people management | 2025-02-03 A | 2025-07-31 A |  | 0% → 100% | 625d → none |  |  |
| 3629 | Develop & test changes to business processes | 2025-02-03 A | 2025-07-31 A |  | 0% → 100% | 625d → none |  |  |
| 3630 | Develop and deliver training | 2025-02-03 A | 2025-07-31 A |  | 0% → 100% | 625d → none |  |  |
| 3631 | Programme support for PP Business Change activities | 2025-02-03 A | 2025-07-31 A |  | 0% → 100% | 625d → none |  |  |
| 3688 | **READINESS ASSESSMENTS** |  |  |  | 23% → 33% |  |  |  |
| 3696 | **Readiness Assessment 5 / 6 - Start of Qualification and Participant Readiness for M10 and M11 and CP3/CP4 check** | 2025-04-28 A |  |  | 0% → 46% |  |  |  |
| 3697 | Launch Readiness Assessment survey | 2025-04-28 A | 2025-04-28 A |  | 0% → 100% | 647d → none |  |  |
| 3698 | PPs submit survey responses | 2025-04-28 A | 2025-05-16 A |  | 0% → 100% | 647d → none |  |  |
| 3699 | Analyse survey responses | 2025-05-19 A | 2025-06-06 → 2025-06-27 (+21d) | 15d → 30d | 0% → 43% | 647d → 649d |  | baseline finish 2025-06-06 → 2025-06-27 |
| 3700 | Conduct deep-dive interviews (sample of PPs) | 2025-05-19 A | 2025-06-06 → 2025-06-27 (+21d) | 15d → 30d | 0% → 43% | 647d → 649d | 3698 → none | constraint none → start no earlier than 2025-05-19; baseline finish 2025-06-06 → 2025-06-27 |
| 3701 | Produce Readiness Assessment Reports (Overall Report & Individual Participant Reports) |  |  |  |  |  | 3699, 3700 → none | constraint none → start no earlier than 2025-06-09 |
| 3702 | Readiness Assessment 5 / 6 - Start of Qualification and Participant Readiness for M10 and M11 and CP3/CP4 check (incl. Readiness Assessment Report approval) Completed |  |  |  |  |  |  | constraint none → finish no earlier than 2025-07-01 |
| 3738 | Control Point 3/4 - Readiness for Migration (incl. Control Point Report approval) |  |  |  |  |  | 1935FS-5d → 1935FS-3d |  |

## Version 11 (data date 2025-06-17, saved 2025-06-18, file MHHS-DEL1139 - MHHS Plan v6.27.mpp)

Last finish stays 2027-12-23.

Added:

| ID | Task | Duration | Start | Finish | Predecessors | Constraint |
| --- | --- | --- | --- | --- | --- | --- |
| 2190 | **M11-Ready Activation Preparation Tasks** | 9d? | 2025-10-06 | 2025-10-16 | 2135 |  |
| 2199 | M11-Ready Participants Service Activation Preparation Completed | 0d | 2025-10-16 | 2025-10-16 | 2191, 2192, 2193, 2194, 2195, 2196, 2198 | start no earlier than 2025-09-05 |
| 2200 | **M11-Ready Service Activation Implementation** | 6d? | 2025-10-15 | 2025-10-22 |  |  |
| 2209 | M11-Ready Service Activation Implementation Completed | 0d | 2025-10-22 | 2025-10-22 | 2201, 2202, 2203, 2204, 2205, 2208 | start no earlier than 2025-09-19 |
| 2210 | **M11-Ready Service Activation Implementation MDD** | 5d | 2025-10-13 | 2025-10-17 |  |  |
| 2215 | M11-Ready Service Activation Implementation MDD Completed | 0d | 2025-10-17 | 2025-10-17 | 2211, 2212, 2213, 2214 | finish no earlier than 2025-09-18 |
| 2216 | **M11-Ready Service Activation Hypercare** | 16d | 2025-10-15 | 2025-11-05 |  |  |
| 2222 | M11-Ready Service Activation Hypercare Completed | 0d | 2025-11-05 | 2025-11-05 | 2221 |  |
| 2223 | **Not M11-Ready Service Activation Preparation Tasks** | 9d? | 2025-12-01 | 2025-12-11 | 2135 |  |
| 2224 | Review Entry / Exit Criteria & Lessons Learned | 1d? | 2025-12-01 | 2025-12-01 |  | start no earlier than 2025-12-01 |
| 2233 | Not M11-Ready Participants Service Activation Preparation Completed | 0d | 2025-12-11 | 2025-12-11 | 2225, 2226, 2227, 2228, 2229, 2230, 2232 | start no earlier than 2025-09-05 |
| 2234 | **Not M11-Ready (Inlcuding Non-SIT LDSOs) Service Activation Implementation** | 10d | 2025-12-17 | 2025-12-31 |  |  |
| 2236 | PAB Approval Completed | 0d | 2025-12-17 | 2025-12-17 | 2438 | start no earlier than 2025-09-10 |
| 2237 | Add EFD (ISD Calendar Date) to DIP | 2d | 2025-12-18 | 2025-12-19 | 2229, 2230, 2232, 2235, 2236 | start no earlier than 2025-09-11 |
| 2242 | Go Live ISD | 0d | 2025-12-26 | 2025-12-26 | 2241 | start no earlier than 2025-09-18 |
| 2243 | Not M11-Ready Service Activation Implementation Completed | 0d | 2025-12-31 | 2025-12-31 | 2235, 2236, 2237, 2238, 2239, 2241, 2242 | start no earlier than 2025-12-31 |
| 2244 | **Not M11-Ready Service Activation Implementation MDD** | 9d | 2025-12-17 | 2025-12-30 |  |  |
| 2250 | **Not M11-Ready Service Activation Hypercare** | 11d | 2025-12-17 | 2025-12-31 |  |  |
| 2256 | Not M11-Ready Service Activation Hypercare Completed | 0d | 2025-12-31 | 2025-12-31 | 2255 |  |
| 2435 | QAD Sign Off Deadline + Test Reports | 0d | 2025-10-09 | 2025-10-09 |  | start no earlier than 2025-10-09 |
| 2436 | REC Code Manager / BSC PAB Approval of Qualification | 0d | 2025-10-30 | 2025-10-30 | 2435FS+16d |  |
| 2437 | QAD Sign Off Deadline + Test Reports | 0d | 2025-11-26 | 2025-11-26 |  | start no earlier than 2025-11-26 |
| 2438 | REC Code Manager / BSC PAB Approval of Qualification | 0d | 2025-12-17 | 2025-12-17 | 2437FS+16d |  |
| 2934 | Ofgem Incentives Approval | 0d | 2025-09-22 | 2025-09-22 |  | start no earlier than 2025-09-22 |
| 2935 | Incnentives Implementation | 5d | 2025-09-22 | 2025-09-26 | 2934 |  |
| 3015 | Supplier Readiness Assessments for Sprint 0 | 20d | 2025-08-29 | 2025-09-25 | 3014 |  |
| 3016 | Legacy Settlement run stability assessment | 16d | 2025-09-25 | 2025-10-16 | 3015FS-1d | start no earlier than 2025-09-25 |
| 3328 | **M11-Ready Activation Preparation Tasks** | 1d | 2022-10-31 | 2022-10-31 |  |  |
| 3330 | Provide LWIs | 1d | 2022-10-31 | 2022-10-31 |  |  |
| 3332 | Identify Resources | 1d | 2022-11-01 | 2022-11-01 | 3330 |  |
| 3334 | Agree & Understand Support Model | 2d | 2022-10-31 | 2022-11-01 |  |  |
| 3335 | Confirm Training complete | 1d | 2022-10-31 | 2022-10-31 |  |  |
| 3336 | Engagement / Communications with Participants | 1d | 2022-11-01 | 2022-11-01 | 3330 |  |
| 3340 | Validate User Access | 1d | 2022-10-31 | 2022-10-31 |  |  |
| 3341 | Target Systems and Environments Ready | 1d | 2022-10-31 | 2022-10-31 |  |  |
| 3342 | Business Readiness Governance Approval | 1d | 2022-10-31 | 2022-10-31 |  |  |
| 3345 | DIP Production Success Checks | 7d | 2022-11-01 | 2022-11-09 | 3342 |  |
| 3352 | Go Live ISD | 0d | 2022-11-04 | 2022-11-04 | 3351 |  |
| 3355 | MDD Final Circular | 0d | 2022-10-31 | 2022-10-31 | 3346 |  |
| 3356 | MDD Manual Update | 3d | 2022-10-31 | 2022-11-02 | 3355SF |  |
| 3357 | MDD Publish | 5d | 2022-10-31 | 2022-11-04 | 3356SF |  |
| 3358 | MDD Go Live | 0d | 2022-11-04 | 2022-11-04 | 3357 |  |
| 3361 | Monitoring | 11d | 2022-10-31 | 2022-11-14 |  |  |
| 3362 | Reporting | 11d | 2022-10-31 | 2022-11-14 |  |  |
| 3364 | Closed Down Activities | 3d | 2022-10-31 | 2022-11-02 | 3361SS, 3362SS, 3363SS |  |
| 3365 | Inform MHHSP | 2d | 2022-10-31 | 2022-11-01 | 3364SS |  |
| 3454 | Publish ISD | 2d | 2026-03-11 | 2026-03-12 | 3453 | finish no earlier than 2026-03-06 |
| 3483 | MHHSP Enabled Confirmation | 2d | 2025-02-24 | 2025-02-25 |  | finish no earlier than 2025-02-25 |
| 3486 | DIP Promoted to Production | 2d | 2025-02-26 | 2025-02-27 |  | finish no earlier than 2025-02-27 |
| 3487 | Create M16 in Customer Solution | 2d | 2025-02-26 | 2025-02-27 |  | finish no earlier than 2025-02-27 |
| 3488 | Publish ISD | 2d | 2025-02-26 | 2025-02-27 |  | finish no earlier than 2025-02-27 |
| 3498 | Issue Management | 18d | 2025-02-24 | 2025-03-19 |  | finish no earlier than 2025-03-19 |

Removed: 199 Design Handover; 200 Creation of the Configuration Management Database; 201 Identify all baselined design artefacts; 202 Create CMBD; 203 Knowledge Transfer; 204 Elexon to document knowledge transfer requirements; 205 Review Requirements; 206 Agree Success Criteria; 207 Identify Key personel with Elexon; 208 Draft Agenda for initial meeting; 209 Define cadence for handover sessions; 210 Share Design Information; 211 Conduct Initial Handover Session; 212 Triage Sessions; 213 Design Triage Sessions; 214 Test Triage Sessions; 215 Knowledge Base; 216 Document Knowledge base update process; 217 Document Design updates to Collaboration Base; 218 FreshDesk; 219 Agree Indicative Handover of FreshDesk Calls to Service Now; 220 Prepare Comms to Industry; 221 Issue Comms to Industry; 222 Redirect Design Mailbox to Service Now; 223 Archive Freshdesk calls; 224 Decommission FreshDesk; 225 iServer; 226 Gather Licensing information; 227 Inform Orbus of iServer support termination; 228 Produce iServer decomissioning pack; 229 Publish iServer decommising pack on the Clock; 230 Clear down old information; 231 Clear down accounts; 232 Identify Collaboration Base Design Dependencies on iServer; 233 Remove Design dependencies; 234 Close down iServer; 1618 SRO Review SI SIT Functional & Migration Overarching Exit Report; 1619 SITAG endorses the SI SIT Functional & Migration Overarching Test Exit Report; 1630 Helix E2E Settlement Assurance Testing (SAT); 1631 Test design; 1632 SAT tests (Review and finalise); 1633 Test Automation and Supporting Tools; 1634 SAT tests batch 3; 1635 Data and environment; 1636 Data and environment requirements; 1637 Data sourcing; 1638 Environment data check; 1639 Execution; 1640 Trial test runs; 1641 Test planning prioritisation; 1642 Programme agreement to start SAT testing; 1643 SAT Testing Start; 1644 SAT first run; 1645 First run complete; 1646 SAT test second run; 1647 Second run complete; 1648 Contingency test time; 1649 Demand Disconnection Event (DDE); 1650 Trading Disputes; 1651 NESO; 1652 P210 Test files to NESO; 1653 NESO; 1654 Estimated all SAT tests completed; 1655 Test Completion Report Drafting; 1656 Test Completion Report/Recommendation; 1657 SAT is signed off by the SAA Value Stream Lead / Head of Product (SAT complete); 1658 MHHS Programme Assurance of Helix E2E SAT; 1659 MHHS Programme Assurance Start; 1660 Ongoing MHHS Programme Assurance; 1661 MHHS Programme Assurance End; 1705 SRO Review SI SIT Functional & Migration Overarching Exit Report; 1706 SITAG endorses the SI SIT Functional & Migration Overarching Test Exit Report; 2289 SAT Confidence Assessment; 2342 DIP Technical Onboarding for LDSOs; 2442 QAD Sign Off Deadline (Not M11-Ready); 2980 Supplier Commission 2; 2981 Confirm / validate contacts for all Suppliers; 2982 Supplier submission issued; 2983 Supplier submission deadline; 2984 Second Supplier Submission complete; 2985 Publish and baseline Migration Schedule; 3334 Service Activation; 3335 Phase 1 - Preparation; 3336 Business Service Activation Governance, Planning & Scope; 3337 Create and Confirm SA Scope; 3338 POAP Service Activation; 3339 Service Activation Working Group; 3340 Business Readiness Governance Framework; 3341 Service Activation Governance Framework Completed; 3342 Service Activation High Level Process Models; 3343 Transition Process Model; 3344 Migration Process Model; 3345 Enduring Process Model; 3346 Service Activation High Level Process Models Completed; 3347 Target Operating Model for Service Activation; 3348 MHHSP Engagement Team understanding; 3349 Define and produce organisation model for Service Activation in Elexon; 3350 Implement Target Operating model; 3351 Target Operating Model for Service Activation Completed; 3352 SIT Operational Testing for Service Activation; 3353 Review and validate test cases; 3354 SIT Operational Testing for Service Activation Completed; 3355 Operational Readiness E2E Testing; 3356 Define Service Activation Scenarios & Scripts; 3357 Define Service Activation Test plan; 3358 Test Execution [Placeholder]; 3359 Service Activation Test Scenarios Completed; 3360 Operational Training for Service Activation; 3361 Training Execution [Placeholder]; 3362 Service Activation Training Completed; 3363 Service Activation Readiness; 3364 Dress Rehearsal 1; 3365 Dress Rehearsal 1 Complete; 3366 Dress Rehearsal 2; 3367 Dress Rehearsal 2 Complete; 3368 Service Activation Go / No Go; 3369 Final Service Activation Go/No Go Decision; 3370 DIP Team Ready; 3371 DIP Technical Onboarding Processes Completed; 3372 PM Team Ready; 3373 Operational Support Ready (Ops Control Centre, Account Managers); 3374 Service Management Activity Completed (Resolver Groups); 3375 Process 1.1.1 ISD and Related LWIs Completed; 3376 Service Activation Go / No Go; 3377 SOLR Consultation; 3378 SOLR workshop 1; 3379 SOLR workshop 2; 3380 SOLR consultation; 3381 SOLR comms to MHHS for review; 3382 MDR Process; 3383 MDR workshop 1; 3384 MDR workshop 2; 3385 MDR consultation; 3386 Phase 2 - Implementation; 3387 Non-SIT LDSO & SIT MVC Data Loading (M10 Ready); 3388 Define Non-SIT LDSO Upfront Activities; 3389 Perform Non-SIT LDSO Activities (M10 Ready); 3392 DIP - Promote to production Environment; 3395 ISD - Replicate Entity Forms from CS Completed; 3397 Non-SIT LDSO Service Activation Data Loading Completed; 3398 Non-SIT LDSO & SIT MCV Activation Preparation Tasks (M10 Ready); 3403 Confirm IDNOs gobal sigin comleted prior to M10; 3410 Publish the guidence with Parties; 3413 Non-SIT LDSO & SIT MVC Service Activation Preparation Completed; 3414 Non-SIT LDSO & SIT MVC Service Activation Implementation (M10 Ready Pathway 1); 3419 Create M16 in Customer Solution Started; 3422 1st ISD Publish Started; 3423 1st ISD Publish; 3424 Go-Live ISD; 3425 Non-SIT LDSO SIT MVC Service Activation Implementation Completed; 3426 Non-SIT LDSO & SIT MVC Service Activation Implementation MDD (M10 Ready); 3432 Non-SIT LDSO & SIT MVC Service Activation Hypercare (M10 Ready); 3438 Non-SIT LDSO Service &SIT MVC Activation Hypercare Completed; 3439 Non-SIT LDSO & SIT MVC Service Activation Retro and Go/No-Go (M11 Ready); 3442 SIT Non-MVC Service Activation Readiness Review Against Entry/Exit Criteria; 3446 Confirmation from Qualification of Wave Participants Complete; 3450 Internal Communications; 3451 Agree Content for Livewire; 3452 Publish Content for Livewire; 3482 Review; 3483 Lessons Learned; 3585 Create Entity Forms in Customer Solution; 3587 DIP - Enable Technology capabilities for participants; 3588 DIP - Add EFD to DIP; 3589 ISD - Replicate Entity Forms from CS; 3590 MDD - Load MHHS roles

Changed:

| ID | Task | Start | Finish | Duration | Complete | Total float | Predecessors | Other |
| --- | --- | --- | --- | --- | --- | --- | --- | --- |
| 1 | **PROGRAMME PLAN.** |  |  |  | 67% → 69% |  |  |  |
| 45 | **DESIGN, BUILD & TEST (PIT)** |  | 2027-07-05 → 2027-01-18 (-168d) | 1221d? → 1101d? | 84% → 89% | 123d → 243d |  |  |
| 187 | **PP Design, Build & Test (DBT)** |  | 2027-07-05 → 2025-02-21 (-864d) | 1221d? → 605d | 77% → 96% | 123d → 739d |  |  |
| 326 | **All SIT Programme Participants PIT (SIT Functional)** |  |  |  | 78% → 79% |  |  |  |
| 360 | **All SIT Programme Participants PIT (SIT Non Functional)** |  | 2025-02-21 A |  | 98% → 100% | 739d → none |  |  |
| 364 | **Test Readiness Report** |  | 2024-10-22 A |  | 85% → 100% | 827d → none |  |  |
| 365 | Test readiness reporting |  | 2024-10-22 A |  | 85% → 100% | 827d → none |  |  |
| 509 | **SYSTEMS INTEGRATION TESTING (SIT)** |  |  |  | 77% → 79% |  |  |  |
| 1484 | **SIT Execution** |  |  |  | 57% → 63% |  |  |  |
| 1501 | **SIT** |  |  |  | 61% → 71% |  |  |  |
| 1502 | **SIT Functional Testing (MVC)** |  |  |  | 66% → 78% |  |  |  |
| 1541 | **SIT Functional Settlement Testing** |  |  |  | 35% → 59% |  |  |  |
| 1542 | SIT-B Settlement Testing Cycle 2 |  | 2025-06-13 A |  | 5% → 100% | 659d → none |  |  |
| 1563 | eSITAG decision point on end of SIT A testing |  |  |  |  |  |  | baseline start none → 2025-06-11; baseline finish none → 2025-06-11 |
| 1574 | **SIT Functional & Migration Overarching Exit Report** |  | 2025-06-18 → 2025-07-03 (+15d) | 38d → 49d | 36% → 72% | 656d → 645d |  |  |
| 1575 | Programme drafts Functional & Migration PP Exit Report |  | 2025-05-23 → 2025-06-10 A (+18d) | 20d → 32d | 90% → 100% | 674d → none |  |  |
| 1576 | SRO Review PP Exit Reports | 2025-05-22 A | 2025-05-23 → 2025-06-04 A (+12d) | 2d → 10d | 0% → 100% | 658d → none |  |  |
| 1577 | Functional & Migration PP Exit Reports shared with PPs | 2025-05-23 → 2025-06-10 A (+18d) | 2025-05-23 → 2025-06-10 A (+18d) |  | 0% → 100% | 658d → none | 1576 → 1575 |  |
| 1578 | PPs complete and return Exit Reports | 2025-05-26 → 2025-06-11 A (+16d) | 2025-06-06 → 2025-06-24 (+18d) |  | 0% → 50% | 661d → 648d |  |  |
| 1579 | PPs Exit Report submission deadline | 2025-06-06 → 2025-06-24 (+18d) | 2025-06-06 → 2025-06-24 (+18d) |  |  | 661d → 648d |  |  |
| 1580 | Programme drafts SI SIT Functional & Migration Overarching Exit Report | 2025-05-26 → 2025-06-11 (+16d) | 2025-06-11 → 2025-06-27 (+16d) |  |  | 658d → 645d |  |  |
| 1581 | SITWG Review status of SI SIT Functional & Migration Overarching Exit Report | 2025-06-05 → 2025-07-03 (+28d) | 2025-06-05 → 2025-07-03 (+28d) |  |  | 666d → 645d | 1580SS → 1580FS+4d |  |
| 1592 | **SIT Migration Testing** |  |  |  | 67% → 71% |  |  |  |
| 1594 | **SIT Migration Testing Execution** |  |  |  | 67% → 71% |  |  |  |
| 1620 | Regression Test Execution Start |  |  |  |  | 26d → 619d | 1565FS+2d, 2258 → 1565FS+2d |  |
| 1627 | **SIT Functional & Migration Test Exit Report** |  | 2025-06-18 → 2025-07-03 (+15d) | 38d → 49d | 36% → 72% | 656d → 645d |  |  |
| 1628 | Programme drafts Functional & Migration PP Exit Report |  | 2025-05-23 → 2025-06-10 A (+18d) | 20d → 32d | 90% → 100% | 674d → none |  |  |
| 1629 | SRO Review PP Exit Reports | 2025-05-22 A | 2025-05-23 → 2025-06-04 A (+12d) | 2d → 10d | 0% → 100% | 658d → none |  |  |
| 1630 | Functional & Migration PP Exit Reports shared with PPs | 2025-05-23 → 2025-06-10 A (+18d) | 2025-05-23 → 2025-06-10 A (+18d) |  | 0% → 100% | 658d → none | 1629 → 1628 |  |
| 1631 | PPs complete and return Exit Reports | 2025-05-26 → 2025-06-11 A (+16d) | 2025-06-06 → 2025-06-24 (+18d) |  | 0% → 50% | 661d → 652d |  |  |
| 1632 | PPs Exit Report submission deadline | 2025-06-06 → 2025-06-24 (+18d) | 2025-06-06 → 2025-06-24 (+18d) |  |  | 664d → 652d |  |  |
| 1633 | Programme drafts SI SIT Functional & Migration Overarching Exit Report | 2025-05-26 → 2025-06-11 (+16d) | 2025-06-11 → 2025-06-27 (+16d) |  |  | 658d → 645d | 1630, 1631FF → 1630 |  |
| 1634 | SITWG Review status of Functional & Migration Overarching Completion Report | 2025-06-05 → 2025-07-03 (+28d) | 2025-06-05 → 2025-07-03 (+28d) |  |  | 666d → 645d | 1633SS → 1633FS+4d |  |
| 1662 | **SIT Operational Testing (all SIT PPs)** |  |  |  | 47% → 58% |  |  |  |
| 1666 | **SIT B Testing** |  |  |  | 67% → 86% |  |  |  |
| 1668 | SIT Operational Testing Execution Theme 1 |  |  |  | 75% → 95% |  |  |  |
| 1669 | SIT Operational Testing Execution Theme 2 |  |  |  | 80% → 90% |  |  |  |
| 1670 | SIT Operational Testing Execution Theme 3 Batch 2 | 2025-06-09 A |  |  | 0% → 35% |  |  |  |
| 1671 | **SIT Operational Testing Re-test Theme 3 (Batch 1)** |  | 2025-06-13 A |  | 75% → 100% | 659d → none |  |  |
| 1674 | SIT Operational Testing Re-test Execution Theme 3 (Batch 1) | 2025-06-09 A | 2025-06-13 A |  | 0% → 100% | 659d → none |  |  |
| 1709 | **UIT Environment Preparation** |  |  |  | 53% → 54% |  |  |  |
| 1710 | **Test Artefact Development** |  |  |  | 96% → 99% |  |  |  |
| 1718 | Submit version to QWG | 2025-06-03 A | 2025-06-03 A |  | 0% → 100% | 667d → none |  |  |
| 1719 | Artefact Recommendation for Approval (via QWG) | 2025-06-10 A | 2025-06-10 A |  | 0% → 100% | 662d → none |  |  |
| 1720 | Final Document updates post QWG review | 2025-06-11 A | 2025-06-11 A |  | 0% → 100% | 661d → none |  |  |
| 1721 | Submit final version to QAG | 2025-06-12 A | 2025-06-12 A |  | 0% → 100% | 657d → none |  |  |
| 1723 | **E2E Sandbox Test Data Approach & Plan** |  | 2025-06-17 → 2025-06-19 (+2d) | 72d → 73d | 86% → 99% | 657d → 656d |  |  |
| 1733 | Industry Consultation for E2E Sandbox Test Data Approach and Plan document |  | 2025-06-06 A |  | 22% → 100% | 664d → none |  |  |
| 1734 | Document updates post Industry Consultation | 2025-06-06 A | 2025-06-09 A |  | 0% → 100% | 663d → none |  |  |
| 1735 | Submit Proposed Version to QWG | 2025-06-10 A | 2025-06-10 A |  | 0% → 100% | 660d → none |  |  |
| 1736 | Artefact Approval (via QWG) | 2025-06-10 A | 2025-06-10 A |  | 0% → 100% | 660d → none |  |  |
| 1737 | Final Document updates post QWG review | 2025-06-11 A | 2025-06-11 A |  | 0% → 100% | 660d → none |  |  |
| 1738 | Submit final version to QAG | 2025-06-12 A | 2025-06-12 A |  | 0% → 100% | 660d → none |  |  |
| 1739 | E2E Sandbox Test Data Approach and Plan Approved at QAG | 2025-06-17 → 2025-06-19 (+2d) | 2025-06-17 → 2025-06-19 (+2d) |  |  | 657d → 656d |  | constraint finish no earlier than 2025-06-17 → start no earlier than 2025-06-19 |
| 1795 | **Sandbox Testing Execution (UIT) - LDSO Participants** | 2025-06-02 A |  |  | 0% → 7% |  |  |  |
| 1796 | Sandbox Testing Start (UIT) - LDSO Participants | 2025-06-02 A | 2025-06-02 A |  | 0% → 100% | 668d → none |  |  |
| 1797 | Sandbox Testing Execution (UIT) - LDSO Participants | 2025-06-02 A |  |  | 0% → 7% |  |  |  |
| 1863 | Central systems ready for migrating MPANs (M10) |  |  |  |  |  | 1686FS+18d, 3481, 3179, 3176, 3194, 3155, 3162 → 1686FS+18d, 3179, 3176, 3194, 3155, 3162, 2336 |  |
| 1876 | **NON SIT LDSO QUALIFICATION** |  |  |  | 96% → 98% |  |  |  |
| 1971 | **Test Window** |  |  |  | 92% → 94% |  |  |  |
| 1984 | Potential for non-SIT LDSO QT Regression for Qualification |  |  |  | 10% → 31% |  |  |  |
| 1988 | **Non-SIT LDSO Qualification Closure** |  |  |  | 46% → 94% |  |  |  |
| 1990 | Non-SIT LDSO Regression Testing |  | 2025-06-20 A |  | 35% → 100% | 649d → none |  |  |
| 1991 | Non-SIT LDSO Qualification Closure Down | 2025-06-23 A |  |  | 0% → 50% |  |  |  |
| 1992 | **HELIX / ELEXON M10 READINESS** |  |  |  | 43% → 47% |  |  |  |
| 1993 | **Service Management - M10 Readiness** |  |  |  | 23% → 25% |  |  |  |
| 1994 | **Service Model Design (Cross Party Service Desk)** |  | 2025-07-25 → 2025-07-18 (-7d) | 105d → 100d | 86% → 92% | 629d → 634d |  |  |
| 2010 | **Service Documentation** |  | 2025-07-25 → 2025-07-18 (-7d) | 64d → 59d | 57% → 72% | 629d → 634d |  |  |
| 2014 | ORT version of LLSD SOM CPSD |  |  |  |  |  |  | baseline start none → 2025-06-04; baseline finish none → 2025-06-04 |
| 2015 | Operations Manual version 1.4 (ORT) brought to TORWG | 2025-06-11 A | 2025-06-11 A |  | 0% → 100% | 662d → none |  | was named ORT version brought to TORWG; baseline start none → 2025-06-11; baseline finish none → 2025-06-11 |

| ID | Task | Start | Finish | Duration | Complete | Total float | Predecessors | Other |
| --- | --- | --- | --- | --- | --- | --- | --- | --- |
| 2016 | Post-ORT Operations Manual and LLSD Updates |  | 2025-07-25 → 2025-07-18 (-7d) | 10d → 5d |  | 629d → 634d |  |  |
| 2017 | M10 Operations Manual Version 2.0 & LLSD ORT Learning | 2025-07-25 → 2025-07-18 (-7d) | 2025-07-25 → 2025-07-18 (-7d) |  |  | 629d → 634d |  |  |
| 2018 | **Operational Readiness Testing** |  |  |  | 55% → 62% | 604d → 569d |  |  |
| 2019 | **ORT Design** |  | 2025-06-10 A |  | 99% → 100% | 623d → none |  |  |
| 2034 | **ORT Test Scripts Consultation** |  | 2025-06-10 A |  | 99% → 100% | 623d → none |  |  |
| 2043 | ORT Test Scipt Updates Endorsement (eSITWG) | 2025-06-10 A | 2025-06-10 A |  | 0% → 100% | 623d → none |  |  |
| 2044 | **ORT Preparation** |  | 2025-06-13 A |  | 83% → 100% | 620d → none |  |  |
| 2047 | ORT Training and Preparation |  | 2025-06-11 A |  | 17% → 100% | 595d → none |  |  |
| 2048 | ORT DITL Session | 2025-06-12 A | 2025-06-12 A |  | 0% → 100% | 622d → none |  |  |
| 2049 | ORT Orientation (JiT) | 2025-06-13 A | 2025-06-13 A |  | 0% → 100% | 595d → none |  |  |
| 2050 | **ORT Execution** | 2025-06-16 A |  |  | 0% → 10% | 595d → 590d |  |  |
| 2051 | ORT Execution | 2025-06-16 A |  |  | 0% → 10% | 595d → 590d |  |  |
| 2058 | **Codification of Service** |  |  |  | 20% → 33% |  |  |  |
| 2061 | "Codify Service Management" Item Preparation |  |  |  | 42% → 69% |  |  |  |
| 2074 | Registration of LDSOs into ServiceNow |  |  |  |  | 587d → 588d | 2073 → 2073, 2057FF | baseline start none → 2025-07-31; baseline finish none → 2025-08-04 |
| 2075 | Helix Service Management Live for LDSO DIP Onboarding |  |  |  |  | 587d → 588d |  | baseline start none → 2025-08-04; baseline finish none → 2025-08-04 |
| 2076 | Helix Service Management Live for MHHS Enduring Arrangements |  |  |  |  |  |  | baseline start none → 2025-09-01; baseline finish none → 2027-07-30 |
| 2077 | **Business Readiness (inc DIP)** |  | 2025-12-02 → 2025-12-31 (+29d) | 436d? → 457d? |  | 537d → 516d |  | baseline start none → 2024-04-02; baseline finish none → 2025-12-02 |
| 2078 | Knowledge Transfer triage |  | 2025-06-13 A |  | 80% → 100% | 104d → none |  | baseline start none → 2025-04-28; baseline finish none → 2025-06-13 |
| 2079 | Elexon Leading Triage | 2025-06-16 A |  |  | 0% → 4% |  |  | baseline start none → 2025-06-16; baseline finish none → 2025-08-29 |
| 2080 | MHHS Transition (Knowledge Transfer) |  |  |  | 34% → 48% |  |  | baseline start none → 2025-05-06; baseline finish none → 2025-08-01 |
| 2081 | Artefact Handshake with MHHS |  |  |  |  |  |  | baseline start none → 2025-08-01; baseline finish none → 2025-08-01 |
| 2082 | Operational Control Centre (OCC) Development |  |  |  | 51% → 61% |  |  | baseline start none → 2025-04-07; baseline finish none → 2025-08-01 |
| 2083 | Operational Control Centre (OCC) Live |  |  |  |  |  |  | baseline start none → 2025-08-04; baseline finish none → 2025-08-04 |
| 2084 | **Service Activation Readiness** |  | 2025-12-02 → 2025-12-31 (+29d) | 436d? → 457d? | 54% → 45% | 537d → 516d |  | baseline start none → 2024-04-02; baseline finish none → 2025-12-02 |
| 2085 | **Phase 1 - Preparation** |  |  |  | 70% → 79% |  |  | baseline start none → 2024-04-02; baseline finish none → 2025-09-26 |
| 2086 | **Business Service Activation Governance, Planning & Scope** |  |  |  |  |  |  | baseline start none → 2024-04-04; baseline finish none → 2024-09-30 |
| 2087 | Create and Confirm SA Scope |  |  |  |  |  |  | baseline start none → 2024-06-03; baseline finish none → 2024-06-13 |
| 2088 | POAP Service Activation |  |  |  |  |  |  | baseline start none → 2024-06-03; baseline finish none → 2024-06-19 |
| 2089 | Service Activation Working Group |  |  |  |  |  |  | baseline start none → 2024-04-04; baseline finish none → 2024-06-28 |
| 2090 | Business Readiness Governance Framework |  |  |  |  |  |  | baseline start none → 2024-08-02; baseline finish none → 2024-09-30 |
| 2091 | Service Activation Governance Framework Completed |  |  |  |  |  |  | baseline start none → 2024-09-30; baseline finish none → 2024-09-30 |
| 2092 | **Service Activation High Level Process Models** |  |  |  |  |  |  | baseline start none → 2024-04-02; baseline finish none → 2024-08-31 |
| 2093 | Transition Process Model |  |  |  |  |  |  | baseline start none → 2024-04-02; baseline finish none → 2024-07-08 |
| 2094 | Migration Process Model |  |  |  |  |  |  | baseline start none → 2024-08-13; baseline finish none → 2024-08-30 |
| 2095 | Enduring Process Model |  |  |  |  |  |  | baseline start none → 2024-06-03; baseline finish none → 2024-08-01 |
| 2096 | Service Activation High Level Process Models Completed |  |  |  |  |  |  | baseline start none → 2024-08-31; baseline finish none → 2024-08-31 |
| 2097 | **Target Operating Model for Service Activation** |  |  |  |  |  |  | baseline start none → 2024-06-21; baseline finish none → 2024-10-15 |
| 2098 | MHHSP Engagement Team understanding |  |  |  |  |  |  | baseline start none → 2024-06-21; baseline finish none → 2024-07-25 |
| 2099 | Define and produce organisation model for Service Activation in Elexon |  |  |  |  |  |  | baseline start none → 2024-06-21; baseline finish none → 2024-10-15 |
| 2100 | Implement Target Operating model |  |  |  |  |  |  | baseline start none → 2024-10-15; baseline finish none → 2024-10-15 |
| 2101 | Target Operating Model for Service Activation Completed |  |  |  |  |  |  | baseline start none → 2024-10-15; baseline finish none → 2024-10-15 |
| 2102 | **SIT Operational Testing for Service Activation** |  |  |  |  |  |  | baseline start none → 2024-08-12; baseline finish none → 2024-08-16 |
| 2103 | Review and validate test cases |  |  |  |  |  |  | baseline start none → 2024-08-12; baseline finish none → 2024-08-16 |
| 2104 | SIT Operational Testing for Service Activation Completed |  |  |  |  |  |  | baseline start none → 2024-08-16; baseline finish none → 2024-08-16 |
| 2105 | **Operational Training for Service Activation** | 2024-11-13 A → 2025-05-15 A (+183d) | 2025-07-25 → 2025-08-29 (+35d) | 182d → 77d | 16% → 31% | 630d → 604d |  | baseline start none → 2024-11-13; baseline finish none → 2025-07-25 |
| 2106 | Training Execution [Placeholder] | 2024-11-13 A → 2025-05-15 A (+183d) | 2025-06-13 → 2025-08-29 (+77d) | 153d → 77d | 16% → 31% | 659d → 604d |  | baseline start none → 2025-05-15; baseline finish none → 2025-08-29 |
| 2107 | Service Activation Training Completed | 2025-07-25 → 2025-08-29 (+35d) | 2025-07-25 → 2025-08-29 (+35d) |  |  | -83d → 604d | none → 2106 | baseline start none → 2025-08-29; baseline finish none → 2025-08-29 |
| 2108 | **Service Activation Readiness** |  |  |  |  |  |  | baseline start none → 2025-08-04; baseline finish none → 2025-08-12 |
| 2109 | Dress Rehearsal 1 |  |  |  |  |  | 2091, 2096, 2101, 2107 → 2091, 2096, 2101 | baseline start none → 2025-08-04; baseline finish none → 2025-08-05 |
| 2110 | Dress Rehearsal 1 Complete |  |  |  |  |  |  | baseline start none → 2025-08-05; baseline finish none → 2025-08-05 |
| 2111 | Dress Rehearsal 2 |  |  |  |  |  |  | baseline start none → 2025-08-11; baseline finish none → 2025-08-12 |
| 2112 | Dress Rehearsal 2 Complete |  |  |  |  |  |  | baseline start none → 2025-08-12; baseline finish none → 2025-08-12 |
| 2113 | **Service Activation Go / No Go** |  |  | 8d → 7d |  |  |  | baseline start none → 2025-08-13; baseline finish none → 2025-08-22 |
| 2114 | **Final Service Activation Go/No Go Decision** |  |  |  |  |  |  | baseline start none → 2025-08-13; baseline finish none → 2025-08-22 |
| 2115 | DIP Team Ready |  |  |  |  |  |  | baseline start none → 2025-08-13; baseline finish none → 2025-08-13 |
| 2116 | DIP Technical Onboarding Processes Completed |  |  |  |  |  |  | baseline start none → 2025-08-22; baseline finish none → 2025-08-22 |
| 2117 | PM Team Ready |  |  |  |  |  |  | baseline start none → 2025-08-22; baseline finish none → 2025-08-22 |
| 2118 | Operational Support Ready (Ops Control Centre, Account Managers) |  |  |  |  |  |  | baseline start none → 2025-08-22; baseline finish none → 2025-08-22 |
| 2119 | Service Management Activity Completed (Resolver Groups) |  |  |  |  |  |  | baseline start none → 2025-08-22; baseline finish none → 2025-08-22 |
| 2120 | Process 1.1.1 ISD and Related LWIs Completed |  |  |  |  |  |  | baseline start none → 2025-08-22; baseline finish none → 2025-08-22 |
| 2121 | **SOLR Consultation** |  |  |  |  |  |  | baseline start none → 2025-04-10; baseline finish none → 2025-09-26 |
| 2122 | SOLR workshop 1 |  |  |  |  |  |  | baseline start none → 2025-04-10; baseline finish none → 2025-04-10 |
| 2123 | SOLR workshop 2 |  |  |  |  |  |  | baseline start none → 2025-04-29; baseline finish none → 2025-04-29 |
| 2124 | SOLR consultation |  |  |  |  |  |  | baseline start none → 2025-08-27; baseline finish none → 2025-09-26 |
| 2125 | SOLR comms to MHHS for review |  |  |  |  |  |  | baseline start none → 2025-08-26; baseline finish none → 2025-08-26 |
| 2126 | **MDR Process** |  |  |  | 60% → 58% |  |  | baseline start none → 2025-04-16; baseline finish none → 2025-07-31 |
| 2127 | MDR workshop 1 |  |  |  |  |  |  | baseline start none → 2025-04-16; baseline finish none → 2025-04-16 |
| 2128 | MDR workshop 2 |  |  |  |  |  |  | baseline start none → 2025-04-30; baseline finish none → 2025-04-30 |
| 2129 | MDR workshop |  |  |  |  |  |  | baseline start none → 2025-05-27; baseline finish none → 2025-05-27 |

| ID | Task | Start | Finish | Duration | Complete | Total float | Predecessors | Other |
| --- | --- | --- | --- | --- | --- | --- | --- | --- |
| 2130 | MDR consultation |  |  |  |  |  |  | baseline start none → 2025-05-06; baseline finish none → 2025-05-21 |
| 2131 | MDR consultation ongoing actions |  |  |  | 50% → 48% |  |  | baseline start none → 2025-05-07; baseline finish none → 2025-07-31 |
| 2132 | Service Activation Go / No Go |  |  |  |  |  | 2116FF, 2117FF, 2118FF, 2119FF, 2083FF, 2120FF → 2116FF, 2117FF, 2118FF, 2119FF, 2083FF, 2120FF, 2332, 2333 | baseline start none → 2025-08-22; baseline finish none → 2025-08-22 |
| 2133 | **Phase 2 - Implementation** |  | 2025-12-02 → 2025-12-31 (+29d) | 388d? → 409d? | 3% → 14% | 537d → 516d |  | baseline start none → 2024-06-07; baseline finish none → 2025-12-02 |
| 2134 | **Non-SIT LDSO & SIT MVC Data Loading (M10 Ready)** |  |  |  |  |  |  | baseline start none → 2024-06-07; baseline finish none → 2024-06-14 |
| 2135 | Define Non-SIT LDSO Upfront Activities |  |  |  |  |  |  | baseline start none → 2024-06-07; baseline finish none → 2024-06-14 |
| 2136 | **M10-Ready Activation Preparation Tasks** |  |  |  |  |  |  | baseline start none → 2025-08-25; baseline finish none → 2025-09-08 |
| 2137 | Identify Resources |  |  |  |  |  | none → 2132 | baseline start none → 2025-08-25; baseline finish none → 2025-08-25 |
| 2138 | Confirmation from Qualification of Wave Participants Complete |  |  |  |  |  |  | baseline start none → 2025-08-25; baseline finish none → 2025-08-25 |
| 2139 | Agree & Understand Support Model |  |  |  |  |  |  | baseline start none → 2025-08-26; baseline finish none → 2025-08-26 |
| 2140 | Confirm Training complete |  |  |  |  |  |  | baseline start none → 2025-08-27; baseline finish none → 2025-08-27 |
| 2141 | Confirm IDNOs gobal sigin comleted prior to M10 |  |  |  |  |  |  | baseline start none → 2025-08-28; baseline finish none → 2025-08-28 |
| 2142 | Engagement / Communications with Participants |  |  |  |  |  |  | baseline start none → 2025-08-29; baseline finish none → 2025-08-29 |
| 2143 | **Internal Communications** |  |  |  |  |  |  | baseline start none → 2025-09-01; baseline finish none → 2025-09-01 |
| 2144 | Agree Content for Livewire |  |  |  |  |  |  | baseline start none → 2025-09-01; baseline finish none → 2025-09-01 |
| 2145 | Publish Content for Livewire |  |  |  |  |  |  | baseline start none → 2025-09-01; baseline finish none → 2025-09-01 |
| 2146 | Validate User Access |  |  |  |  |  |  | baseline start none → 2025-09-02; baseline finish none → 2025-09-02 |
| 2147 | Target Systems and Environments Ready |  |  |  |  |  |  | baseline start none → 2025-09-03; baseline finish none → 2025-09-03 |
| 2148 | Publish the guidence with Parties |  |  |  |  |  |  | baseline start none → 2025-09-04; baseline finish none → 2025-09-04 |
| 2149 | Provide LWIs |  |  |  |  |  |  | baseline start none → 2025-09-05; baseline finish none → 2025-09-05 |
| 2150 | Business Readiness Governance Approval |  |  |  |  |  |  | baseline start none → 2025-09-08; baseline finish none → 2025-09-08 |
| 2151 | M10-Ready Participants Service Activation Preparation Completed |  |  |  |  |  |  | baseline start none → 2025-09-08; baseline finish none → 2025-09-08 |
| 2152 | **M10-Ready (Inlcuding Non-SIT LDSOs) Service Activation Implementation** |  |  |  |  |  |  | baseline start none → 2025-08-06; baseline finish none → 2025-09-19 |
| 2153 | MHHSP Enabled Confirmation |  |  |  |  |  |  | baseline start none → 2025-09-10; baseline finish none → 2025-09-10 |
| 2154 | PAB Approval Completed |  |  |  |  |  |  | baseline start none → 2025-09-10; baseline finish none → 2025-09-10 |
| 2155 | Add EFD (ISD Calendar Date) to DIP |  |  |  |  |  |  | baseline start none → 2025-09-11; baseline finish none → 2025-09-11 |
| 2156 | DIP Promoted to Production |  |  |  |  |  |  | baseline start none → 2025-09-12; baseline finish none → 2025-09-12 |
| 2157 | Create M16 in Customer Solution Started |  |  |  |  |  |  | baseline start none → 2025-09-11; baseline finish none → 2025-09-11 |
| 2158 | Create M16 in Customer Solution |  |  |  |  |  |  | baseline start none → 2025-09-11; baseline finish none → 2025-09-11 |
| 2159 | DIP Production Success Checks |  |  |  |  |  |  | baseline start none → 2025-09-12; baseline finish none → 2025-09-12 |
| 2160 | 1st ISD Publish Started |  |  |  |  |  |  | baseline start none → 2025-09-11; baseline finish none → 2025-09-11 |
| 2161 | 1st ISD Publish |  |  |  |  |  |  | baseline start none → 2025-09-11; baseline finish none → 2025-09-18 |
| 2162 | Go Live ISD |  |  |  |  |  |  | baseline start none → 2025-09-18; baseline finish none → 2025-09-18 |
| 2163 | M10-Ready Service Activation Implementation Completed |  |  |  |  |  |  | baseline start none → 2025-09-19; baseline finish none → 2025-09-19 |
| 2164 | Non-SIT LDSO Service Activation Data Loading Completed |  |  |  |  |  |  | baseline start none → 2025-08-06; baseline finish none → 2025-08-06 |
| 2165 | **M10-Ready Service Activation Implementation MDD** |  |  |  |  |  |  | baseline start none → 2025-09-10; baseline finish none → 2025-09-19 |
| 2166 | MDD Final Circular Completed |  |  |  |  |  |  | baseline start none → 2025-09-10; baseline finish none → 2025-09-10 |
| 2167 | MDD Manual Update |  |  |  |  |  |  | baseline start none → 2025-09-11; baseline finish none → 2025-09-15 |
| 2168 | MDD Publish |  |  |  |  |  |  | baseline start none → 2025-09-11; baseline finish none → 2025-09-18 |
| 2169 | MDD Go Live |  |  |  |  |  |  | baseline start none → 2025-09-18; baseline finish none → 2025-09-18 |
| 2170 | Non-SIT LDSO & SIT MVC Service Activation Implementation MDD Completed |  |  |  |  |  |  | baseline start none → 2025-09-18; baseline finish none → 2025-09-18 |
| 2171 | Non-SIT LDSO & SIT MVC Service Activation Implementation MDD Completed |  |  |  |  |  |  | baseline start none → 2025-09-19; baseline finish none → 2025-09-19 |
| 2172 | **Non-SIT LDSO & SIT MVC Service Activation Hypercare (M10 Ready)** |  |  |  |  |  |  | baseline start none → 2025-09-18; baseline finish none → 2025-12-02 |
| 2173 | Monitoring |  |  |  |  |  |  | baseline start none → 2025-09-18; baseline finish none → 2025-12-02 |
| 2174 | Reporting |  |  |  |  |  |  | baseline start none → 2025-09-18; baseline finish none → 2025-12-02 |
| 2175 | Issue Management |  |  |  |  |  |  | baseline start none → 2025-09-18; baseline finish none → 2025-12-02 |
| 2176 | Closed Down Activities |  |  |  |  |  |  | baseline start none → 2025-09-19; baseline finish none → 2025-09-19 |
| 2177 | Inform MHHSP |  |  |  |  |  |  | baseline start none → 2025-09-19; baseline finish none → 2025-09-19 |
| 2178 | **DIP Guidance Notes** |  |  |  | 42% → 58% |  |  | baseline start none → 2025-05-05; baseline finish none → 2025-07-18 |
| 2179 | GN/LWI creation & publication |  |  |  | 42% → 58% |  |  | baseline start none → 2025-05-05; baseline finish none → 2025-07-18 |
| 2180 | Tranche 1 GN/LWI created & published (critical for M10) |  |  |  |  |  |  | baseline start none → 2025-06-20; baseline finish none → 2025-06-20 |
| 2181 | Tranche 2 GN/LWI created & published |  |  |  |  |  |  | baseline start none → 2025-07-04; baseline finish none → 2025-07-04 |
| 2182 | Tranche 3 GN/LWI created & published |  |  |  |  |  |  | baseline start none → 2025-07-18; baseline finish none → 2025-07-18 |
| 2183 | DIP Reporting (M11) |  |  |  |  |  |  | baseline start none → 2025-05-12; baseline finish none → 2025-08-08 |
| 2184 | Functional Training Execution |  |  |  |  |  |  | baseline start none → 2025-05-05; baseline finish none → 2025-08-29 |
| 2185 | **Operational Readiness E2E Testing** |  |  |  | 23% → 6% |  |  | baseline start none → 2025-05-13; baseline finish none → 2025-08-08 |
| 2186 | Phase 1 Test Execution (Service Activation and Participant Management) |  |  |  | 50% → 10% |  |  | baseline start none → 2025-05-13; baseline finish none → 2025-06-27 |
| 2187 | Phase 2 Test Execution (S&I) | 2025-06-03 A → 2025-06-10 A (+7d) | 2025-07-07 → 2025-07-11 (+4d) | 25d → 24d | 8% → 5% | 643d → 639d |  | baseline start none → 2025-06-10; baseline finish none → 2025-07-11 |
| 2188 | Phase 3 Test Execution (Assurance & mop-up) | 2025-06-30 → 2025-06-23 (-7d) | 2025-07-30 → 2025-07-18 (-12d) | 23d → 20d |  | 626d → 634d |  | constraint start no earlier than 2025-06-30 → start no earlier than 2025-06-23; baseline start none → 2025-06-30; baseline finish none → 2025-07-30 |
| 2189 | E2E Operational Testing Completed |  |  |  |  |  |  | baseline start none → 2025-08-08; baseline finish none → 2025-08-08 |
| 2191 | Identify Resources | 2025-08-25 → 2025-10-06 (+42d) | 2025-08-25 → 2025-10-06 (+42d) |  |  | 606d → 578d | Define Non-SIT LDSO Upfront Activities, Non-SIT LDSO Service Activation Data Loading CompletedFS-1d → none | constraint start no earlier than 2025-08-25 → start no earlier than 2025-10-06; baseline start none → 2025-10-06; baseline finish none → 2025-10-06 |
| 2192 | Agree & Understand Support Model | 2025-08-26 → 2025-10-07 (+42d) | 2025-08-26 → 2025-10-07 (+42d) |  |  | 605d → 577d |  | constraint start no earlier than 2025-08-26 → start no earlier than 2025-10-07; baseline start none → 2025-10-07; baseline finish none → 2025-10-07 |
| 2193 | Confirm Training complete | 2025-08-27 → 2025-10-08 (+42d) | 2025-08-27 → 2025-10-08 (+42d) |  |  | 605d → 577d |  | constraint start no earlier than 2025-08-27 → start no earlier than 2025-10-08; baseline start none → 2025-10-08; baseline finish none → 2025-10-08 |
| 2194 | Engagement / Communications with Participants | 2025-08-29 → 2025-10-09 (+41d) | 2025-08-29 → 2025-10-09 (+41d) |  |  | 602d → 575d |  | constraint start no earlier than 2025-08-29 → start no earlier than 2025-10-09; baseline start none → 2025-10-09; baseline finish none → 2025-10-09 |
| 2195 | Validate User Access | 2025-09-02 → 2025-10-13 (+41d) | 2025-09-02 → 2025-10-13 (+41d) |  |  | 596d → 571d |  | constraint start no earlier than 2025-09-02 → start no earlier than 2025-10-13; baseline start none → 2025-10-13; baseline finish none → 2025-10-13 |
| 2196 | Target Systems and Environments Ready | 2025-09-03 → 2025-10-14 (+41d) | 2025-09-03 → 2025-10-14 (+41d) |  |  | 595d → 570d |  | constraint start no earlier than 2025-09-03 → start no earlier than 2025-10-14; baseline start none → 2025-10-14; baseline finish none → 2025-10-14 |
| 2197 | Provide LWIs | 2025-09-05 → 2025-10-15 (+40d) | 2025-09-05 → 2025-10-15 (+40d) |  |  | 593d → 570d |  | constraint start no earlier than 2025-09-05 → start no earlier than 2025-10-15; baseline start none → 2025-10-15; baseline finish none → 2025-10-15 |
| 2198 | Business Readiness Governance Approval | 2025-09-05 → 2025-10-16 (+41d) | 2025-09-05 → 2025-10-16 (+41d) |  |  | 593d → 570d | none → 2197 | baseline start none → 2025-10-16; baseline finish none → 2025-10-16 |
| 2201 | MHHSP Enabled Confirmation | 2025-08-13 → 2025-10-15 (+63d) | 2025-08-13 → 2025-10-15 (+63d) |  |  | 610d → 569d | 2202 → 2425, 2428 | constraint none → start no earlier than 2025-09-08; baseline start none → 2025-10-15; baseline finish none → 2025-10-15 |
| 2202 | PAB Approval Completed | 2025-08-13 → 2025-10-15 (+63d) | 2025-08-13 → 2025-10-15 (+63d) |  |  | 610d → 569d | 2411 → 2425, 2428 | constraint none → start no earlier than 2025-09-10; baseline start none → 2025-10-15; baseline finish none → 2025-10-15 |

| ID | Task | Start | Finish | Duration | Complete | Total float | Predecessors | Other |
| --- | --- | --- | --- | --- | --- | --- | --- | --- |
| 2203 | Add EFD (ISD Calendar Date) to DIP | 2025-09-08 → 2025-10-16 (+38d) | 2025-09-08 → 2025-10-16 (+38d) |  |  | 593d → 569d | 2195, 2196, 2198, 2202, 2201, 2197 → 2195, 2196, 2201, 2202 | constraint none → start no earlier than 2025-10-15; baseline start none → 2025-10-16; baseline finish none → 2025-10-16 |
| 2204 | DIP Promoted to Production | 2025-09-09 → 2025-10-17 (+38d) | 2025-09-09 → 2025-10-17 (+38d) |  |  | 597d → 569d |  | constraint none → start no earlier than 2025-09-12; baseline start none → 2025-10-17; baseline finish none → 2025-10-17 |
| 2205 | Create M16 in Customer Solution | 2025-09-08 → 2025-10-16 (+38d) | 2025-09-08 → 2025-10-16 (+38d) |  |  | 598d → 569d | Create M16 in Customer Solution StartedSS, 1st ISD PublishSS → none | constraint none → start no earlier than 2025-10-16; baseline start none → 2025-10-16; baseline finish none → 2025-10-16 |
| 2206 | DIP Production Success Checks | 2022-10-31 → 2025-10-17 (+1082d) | 2022-10-31 → 2025-10-17 (+1082d) |  |  | 1343d → 569d | none → 2203, 2205 | baseline start none → 2025-10-17; baseline finish none → 2025-10-17 |
| 2207 | Publish ISD | 2022-11-01 → 2025-10-15 (+1079d) | 2022-11-07 → 2025-10-22 (+1080d) | 5d → 6d |  | 1338d → 566d | 3348SS → none | constraint none → start no earlier than 2025-10-15; baseline start none → 2025-10-15; baseline finish none → 2025-10-22 |
| 2208 | Go Live ISD | 2022-11-07 → 2025-10-22 (+1080d) | 2022-11-07 → 2025-10-22 (+1080d) |  |  | 1338d → 566d |  | constraint none → start no earlier than 2025-10-17; baseline start none → 2025-10-22; baseline finish none → 2025-10-22 |
| 2211 | MDD Final Circular Completed | 2022-10-31 → 2025-10-15 (+1080d) | 2022-10-31 → 2025-10-15 (+1080d) |  |  | 1280d → 571d | none → 2201 | constraint none → finish no earlier than 2025-09-10; baseline start none → 2025-10-15; baseline finish none → 2025-10-15 |
| 2212 | MDD Manual Update | 2022-10-31 → 2025-10-13 (+1078d) | 2022-11-02 → 2025-10-15 (+1078d) |  |  | 1277d → 571d | 2211SF → 2211FF | constraint none → finish no earlier than 2025-09-15; baseline start none → 2025-10-13; baseline finish none → 2025-10-15 |
| 2213 | MDD Publish | 2022-10-31 → 2025-10-13 (+1078d) | 2022-11-07 → 2025-10-17 (+1075d) | 6d → 5d |  | 1274d → 569d |  | constraint none → start no earlier than 2025-10-13; baseline start none → 2025-10-13; baseline finish none → 2025-10-17 |
| 2214 | MDD Go Live | 2022-11-07 → 2025-10-17 (+1075d) | 2022-11-07 → 2025-10-17 (+1075d) |  |  | 1274d → 569d |  | constraint none → finish no earlier than 2025-09-18; baseline start none → 2025-10-17; baseline finish none → 2025-10-17 |
| 2217 | Monitoring | 2022-11-08 → 2025-10-15 (+1072d) | 2023-01-20 → 2025-10-29 (+1013d) | 54d → 11d |  | 1274d → 561d | 2249 → none | constraint none → start no earlier than 2025-10-15; baseline start none → 2025-10-15; baseline finish none → 2025-10-29 |
| 2218 | Reporting | 2022-11-08 → 2025-10-15 (+1072d) | 2023-01-20 → 2025-10-29 (+1013d) | 54d → 11d |  | 1274d → 561d | 2249 → none | constraint none → start no earlier than 2025-10-15; baseline start none → 2025-11-18; baseline finish none → 2025-12-02 |
| 2219 | Issue Management | 2022-11-08 → 2025-10-15 (+1072d) | 2023-01-20 → 2025-10-29 (+1013d) | 54d → 11d |  | 1274d → 556d | 2249 → none | constraint none → start no earlier than 2025-10-15; baseline start none → 2025-10-15; baseline finish none → 2025-10-29 |
| 2220 | Closed Down Activities | 2022-11-08 → 2025-10-30 (+1087d) | 2022-11-08 → 2025-11-03 (+1091d) | 1d → 3d |  | 1327d → 556d | 2217SS, 2218SS, 2219SS → 2219 | constraint none → finish no earlier than 2025-09-19; baseline start none → 2025-11-18; baseline finish none → 2025-11-20 |
| 2221 | Inform MHHSP | 2022-11-08 → 2025-11-04 (+1092d) | 2022-11-08 → 2025-11-05 (+1093d) | 1d → 2d |  | 1327d → 556d | 2220SS → 2220 | constraint none → finish no earlier than 2025-09-19; baseline start none → 2025-11-18; baseline finish none → 2025-11-19 |
| 2225 | Identify Resources | 2022-10-31 → 2025-12-01 (+1127d) | 2022-10-31 → 2025-12-01 (+1127d) |  |  | 1343d → 538d | none → 2132 | constraint none → start no earlier than 2025-12-01; baseline start none → 2025-12-01; baseline finish none → 2025-12-01 |
| 2226 | Agree & Understand Support Model | 2022-10-31 → 2025-12-02 (+1128d) | 2022-11-01 → 2025-12-02 (+1127d) | 2d → 1d |  | 1342d → 535d |  | constraint none → start no earlier than 2025-12-02; baseline start none → 2025-12-02; baseline finish none → 2025-12-02 |
| 2227 | Confirm Training complete | 2022-10-31 → 2025-12-03 (+1129d) | 2022-10-31 → 2025-12-03 (+1129d) |  |  | 1343d → 535d | none → 2226 | constraint none → start no earlier than 2025-08-27; baseline start none → 2025-12-03; baseline finish none → 2025-12-03 |
| 2228 | Engagement / Communications with Participants | 2022-10-31 → 2025-12-04 (+1130d) | 2022-10-31 → 2025-12-04 (+1130d) |  |  | 1343d → 535d | none → 2227 | constraint none → start no earlier than 2025-08-29; baseline start none → 2025-12-04; baseline finish none → 2025-12-04 |
| 2229 | Validate User Access | 2022-10-31 → 2025-12-08 (+1134d) | 2022-10-31 → 2025-12-08 (+1134d) |  |  | 1334d → 524d |  | constraint none → start no earlier than 2025-12-08; baseline start none → 2025-12-08; baseline finish none → 2025-12-08 |
| 2230 | Target Systems and Environments Ready | 2022-10-31 → 2025-12-09 (+1135d) | 2022-10-31 → 2025-12-09 (+1135d) |  |  | 1334d → 523d |  | constraint none → start no earlier than 2025-12-09; baseline start none → 2025-12-09; baseline finish none → 2025-12-09 |
| 2231 | Provide LWIs | 2022-10-31 → 2025-12-10 (+1136d) | 2022-10-31 → 2025-12-10 (+1136d) | 1d → 1d? |  | 1334d → 521d |  | constraint none → start no earlier than 2025-12-10; baseline start none → 2025-12-10; baseline finish none → 2025-12-10 |
| 2232 | Business Readiness Governance Approval | 2022-10-31 → 2025-12-11 (+1137d) | 2022-10-31 → 2025-12-11 (+1137d) |  |  | 1334d → 521d | none → 2231 | constraint none → start no earlier than 2025-09-05; baseline start none → 2025-12-11; baseline finish none → 2025-12-11 |
| 2235 | MHHSP Enabled Confirmation | 2022-10-31 → 2025-12-17 (+1143d) | 2022-10-31 → 2025-12-17 (+1143d) | 1d → 0d |  | 1334d → 517d | none → 2438 | constraint none → start no earlier than 2025-09-08; baseline start none → 2025-12-17; baseline finish none → 2025-12-17 |
| 2238 | DIP Promoted to Production | 2022-11-01 → 2025-12-22 (+1147d) | 2022-11-01 → 2025-12-22 (+1147d) |  |  | 1342d → 523d | 3348SS → 2237 | constraint none → start no earlier than 2025-09-12; baseline start none → 2025-12-22; baseline finish none → 2025-12-22 |
| 2239 | Create M16 in Customer Solution | 2022-10-31 → 2025-12-22 (+1148d) | 2022-10-31 → 2025-12-22 (+1148d) |  |  | 1336d → 516d | none → 2241SS | constraint none → start no earlier than 2025-12-19; baseline start none → 2025-12-22; baseline finish none → 2025-12-22 |
| 2240 | DIP Production Success Checks | 2022-11-03 → 2025-12-23 (+1146d) | 2022-11-11 → 2025-12-31 (+1146d) |  |  | 1334d → 516d | 3348, 2239 → 2237, 2239 | constraint none → start no earlier than 2025-12-23; baseline start none → 2025-12-23; baseline finish none → 2025-12-31 |
| 2241 | Publish ISD | 2026-04-24 → 2025-12-22 (-123d) | 2026-04-27 → 2025-12-26 (-122d) | 2d → 5d |  | 422d → 516d | 3350 → 2237SS | constraint finish no earlier than 2025-09-05 → start no earlier than 2025-12-22; baseline start 2025-09-04 → 2025-12-22; baseline finish 2025-09-05 → 2025-12-26 |
| 2245 | MDD Final Circular | 2022-10-31 → 2025-12-17 (+1143d) | 2022-10-31 → 2025-12-17 (+1143d) |  |  | 1344d → 519d | 3347 → 2235 | constraint none → finish no earlier than 2025-09-10; baseline start none → 2025-12-17; baseline finish none → 2025-12-17 |
| 2246 | MDD Manual Update | 2022-10-31 → 2025-12-24 (+1150d) | 2022-11-02 → 2025-12-26 (+1150d) |  |  | 1341d → 519d | 2245SF → 2245FS+4d | constraint none → finish no earlier than 2025-09-15; baseline start none → 2025-12-24; baseline finish none → 2025-12-26 |
| 2247 | MDD Publish | 2022-10-31 → 2025-12-24 (+1150d) | 2022-11-04 → 2025-12-30 (+1152d) |  |  | 1339d → 517d | 2246SF → 2246SS | constraint none → start no earlier than 2025-12-22; baseline start none → 2025-12-24; baseline finish none → 2025-12-30 |
| 2248 | MDD Go Live | 2022-11-04 → 2025-12-30 (+1152d) | 2022-11-04 → 2025-12-30 (+1152d) |  |  | 1339d → 517d |  | constraint none → finish no earlier than 2025-09-18; baseline start none → 2025-12-30; baseline finish none → 2025-12-30 |
| 2249 | Non-SIT LDSO & SIT MVC Service Activation Implementation MDD Completed | 2022-11-07 → 2025-12-30 (+1149d) | 2022-11-07 → 2025-12-30 (+1149d) |  |  | 1274d → 517d | 2211, 2212, 2213, 2214 → 2245, 2246, 2247, 2248 | constraint none → finish no earlier than 2025-09-18; baseline start none → 2025-12-30; baseline finish none → 2025-12-30 |
| 2251 | Monitoring | 2022-10-31 → 2025-12-17 (+1143d) | 2022-11-14 → 2025-12-31 (+1143d) |  |  | 1333d → 516d |  | constraint none → start no earlier than 2025-12-17; baseline start none → 2025-12-17; baseline finish none → 2025-12-31 |
| 2252 | Reporting | 2022-10-31 → 2025-12-17 (+1143d) | 2022-11-14 → 2025-12-31 (+1143d) |  |  | 1333d → 516d |  | constraint none → start no earlier than 2025-12-17; baseline start none → 2025-12-17; baseline finish none → 2025-12-31 |
| 2253 | Issue Management | 2022-10-31 → 2025-12-17 (+1143d) | 2022-11-14 → 2025-12-31 (+1143d) |  |  | 1333d → 516d |  | constraint none → start no earlier than 2025-12-17; baseline start none → 2025-12-17; baseline finish none → 2025-12-31 |
| 2254 | Closed Down Activities | 2022-10-31 → 2025-12-29 (+1155d) | 2022-11-02 → 2025-12-31 (+1155d) |  |  | 1341d → 516d |  | constraint none → start no earlier than 2025-12-29; baseline start none → 2025-12-29; baseline finish none → 2025-12-31 |
| 2255 | Inform MHHSP | 2022-10-31 → 2025-12-30 (+1156d) | 2022-11-01 → 2025-12-31 (+1156d) |  |  | 1342d → 516d |  | constraint none → start no earlier than 2025-12-30; baseline start none → 2025-12-30; baseline finish none → 2025-12-31 |
| 2257 | **Helix Solution Build** |  |  |  | 69% → 75% |  |  | baseline start none → 2024-08-19; baseline finish none → 2025-08-07 |
| 2258 | M10 Build Candidate |  | 2025-06-10 → 2025-07-16 (+36d) | 32d → 58d | 88% → 64% | 622d → 634d |  | was named M10 Build; baseline start none → 2025-04-28; baseline finish none → 2025-07-16 |
| 2259 | Helix Code Uplifts (TBC) | 2025-06-11 → 2025-07-17 (+36d) | 2025-08-05 → 2025-07-18 (-18d) | 40d? → 2d |  | 622d → 634d |  | constraint none → finish no earlier than 2025-07-16; baseline start none → 2025-07-17; baseline finish none → 2025-07-18 |
| 2260 | **Helix E2E Settlement Assurance Testing (SAT)** |  |  |  | 81% → 87% |  |  |  |
| 2269 | **Execution** |  |  | 194d? → 194d | 56% → 69% |  |  |  |
| 2274 | **SAT Cycle 1** |  |  | 114d? → 114d | 49% → 68% |  |  |  |
| 2275 | **Legacy** |  |  |  | 67% → 87% |  |  | baseline start none → 2025-02-07; baseline finish none → 2025-06-25 |
| 2276 | GMT |  | 2025-06-11 A |  | 95% → 100% | 661d → none |  | baseline start none → 2025-02-07; baseline finish none → 2025-06-11 |
| 2277 | P0210 file shared for NESO Validation |  |  |  |  |  |  | baseline start none → 2025-05-23; baseline finish none → 2025-05-23 |
| 2278 | NESO Validation Period (GMT) |  |  |  |  |  |  | baseline start none → 2025-05-28; baseline finish none → 2025-06-03 |
| 2279 | Long | 2025-05-28 A |  |  | 0% → 88% | 654d → 659d |  | baseline start none → 2025-05-28; baseline finish none → 2025-06-13 |
| 2280 | Helix SAT Confidence Check 1 | 2025-06-10 A | 2025-06-10 A |  | 0% → 100% | 662d → none |  | baseline start none → 2025-06-10; baseline finish none → 2025-06-10 |
| 2281 | P0210 file shared for NESO Validation | 2025-06-13 A | 2025-06-13 A |  | 0% → 100% | 654d → none |  | baseline start none → 2025-06-13; baseline finish none → 2025-06-13 |
| 2282 | Helix SAT Confidence Check 2 | 2025-06-13 A | 2025-06-13 A |  | 0% → 100% | 659d → none |  | baseline start none → 2025-06-13; baseline finish none → 2025-06-13 |
| 2283 | NESO Validation Period (Long) | 2025-06-16 A |  |  | 0% → 40% |  |  | baseline start none → 2025-06-16; baseline finish none → 2025-06-20 |
| 2284 | BST | 2025-06-02 A |  |  | 0% → 61% |  |  | baseline start none → 2025-06-02; baseline finish none → 2025-06-18 |
| 2285 | P0210 file shared for NESO Validation |  |  |  |  |  |  | baseline start none → 2025-06-18; baseline finish none → 2025-06-18 |
| 2286 | NESO Validation Period (BST) |  |  |  |  |  |  | baseline start none → 2025-06-19; baseline finish none → 2025-06-25 |
| 2287 | Trading Dispute | 2025-06-18 A |  |  | 0% → 24% |  |  | baseline start none → 2025-06-18; baseline finish none → 2025-06-20 |
| 2288 | **Transition** |  |  | 36d? → 36d | 12% → 27% |  |  | baseline start none → 2025-05-28; baseline finish none → 2025-07-16 |
| 2289 | GMT |  |  |  | 26% → 74% |  |  | baseline start none → 2025-05-28; baseline finish none → 2025-06-23 |
| 2290 | P0210 file shared for NESO Validation | 2025-06-13 A | 2025-06-13 A | 1d? → 0d | 0% → 100% | 654d → none |  | baseline start none → 2025-06-13; baseline finish none → 2025-06-13 |
| 2291 | NESO Validation Period (GMT) |  |  |  |  |  |  | baseline start none → 2025-06-17; baseline finish none → 2025-06-23 |
| 2292 | Long | 2025-06-24 A |  |  | 0% → 18% |  |  | baseline start none → 2025-06-24; baseline finish none → 2025-06-27 |
| 2293 | P0210 file shared for NESO Validation |  |  |  |  |  |  | baseline start none → 2025-06-27; baseline finish none → 2025-06-27 |
| 2294 | NESO Validation Period (Long) |  |  |  |  |  |  | baseline start none → 2025-06-30; baseline finish none → 2025-07-04 |
| 2295 | BST |  |  |  |  |  |  | baseline start none → 2025-06-26; baseline finish none → 2025-07-01 |
| 2296 | P0210 file shared for NESO Validation |  |  |  |  |  |  | baseline start none → 2025-07-01; baseline finish none → 2025-07-01 |
| 2297 | NESO Validation Period (BST) |  |  |  |  |  |  | baseline start none → 2025-07-03; baseline finish none → 2025-07-09 |
| 2298 | Short |  |  |  |  |  |  | baseline start none → 2025-07-01; baseline finish none → 2025-07-03 |
| 2299 | P0210 file shared for NESO Validation |  |  |  |  |  |  | baseline start none → 2025-07-03; baseline finish none → 2025-07-03 |
| 2300 | NESO Validation Period (Short) |  |  |  |  |  |  | baseline start none → 2025-07-04; baseline finish none → 2025-07-10 |

| ID | Task | Start | Finish | Duration | Complete | Total float | Predecessors | Other |
| --- | --- | --- | --- | --- | --- | --- | --- | --- |
| 2301 | DCP MPAN Mig |  |  |  |  |  |  | baseline start none → 2025-07-01; baseline finish none → 2025-07-03 |
| 2302 | ISD |  |  |  |  |  |  | baseline start none → 2025-07-01; baseline finish none → 2025-07-03 |
| 2303 | Data Agg |  |  |  |  |  |  | baseline start none → 2025-07-04; baseline finish none → 2025-07-11 |
| 2304 | M16 |  |  |  |  |  |  | baseline start none → 2025-07-14; baseline finish none → 2025-07-16 |
| 2305 | End of Cycle 1 |  |  |  |  |  |  | baseline start none → 2025-07-16; baseline finish none → 2025-07-16 |
| 2306 | **SAT Cycle 2** |  |  |  |  | 594d → -81d |  | baseline start none → 2025-07-17; baseline finish none → 2025-08-01 |
| 2307 | **Legacy** |  |  |  |  |  |  | baseline start none → 2025-07-17; baseline finish none → 2025-08-01 |
| 2308 | Pre-M10 |  |  |  |  |  |  | baseline start none → 2025-07-17; baseline finish none → 2025-07-17 |
| 2309 | GMT & BST & Long |  |  |  |  |  |  | baseline start none → 2025-07-18; baseline finish none → 2025-07-25 |
| 2310 | NESO Validation Period (GMT & BST & Long) |  |  |  |  |  |  | baseline start none → 2025-07-28; baseline finish none → 2025-08-01 |
| 2311 | Trading Dispute |  |  |  |  |  |  | baseline start none → 2025-07-28; baseline finish none → 2025-07-29 |
| 2312 | **Transition** |  |  |  |  |  |  | baseline start none → 2025-07-24; baseline finish none → 2025-07-29 |
| 2313 | ISD |  |  |  |  |  |  | baseline start none → 2025-07-24; baseline finish none → 2025-07-29 |
| 2314 | Data Agg |  |  |  |  |  |  | baseline start none → 2025-07-24; baseline finish none → 2025-07-28 |
| 2315 | End of Cycle 2 |  |  |  |  | 583d → -92d |  | baseline start none → 2025-08-01; baseline finish none → 2025-08-01 |
| 2316 | SAT Exit Report |  |  |  |  | 583d → -92d |  | baseline start none → 2025-08-01; baseline finish none → 2025-08-07 |
| 2317 | SAT Complete |  |  |  |  | 584d → -91d |  | baseline start none → 2025-08-01; baseline finish none → 2025-08-01 |
| 2318 | DR Testing |  |  |  |  |  |  | baseline start none → 2025-04-28; baseline finish none → 2025-06-06 |
| 2319 | Pen Testing |  |  |  |  |  |  | baseline start none → 2025-04-28; baseline finish none → 2025-06-20 |
| 2320 | Post Environment Build |  |  |  |  | 584d → -91d |  | baseline start none → 2025-06-30; baseline finish none → 2025-07-31 |
| 2321 | Production Environment Base Platform Sign-off |  |  |  |  | 584d → -91d |  | baseline start none → 2025-07-31; baseline finish none → 2025-07-31 |
| 2322 | **Implementation (Helix & DIP)** | 2025-04-28 A |  |  | 0% → 28% |  |  | baseline start none → 2025-04-28; baseline finish none → 2025-10-06 |
| 2323 | Go / No-Go (DIP & SM) |  |  |  |  | 590d → 591d |  | baseline start none → 2025-07-31; baseline finish none → 2025-07-31 |
| 2324 | Implementation Readiness (inc Technical Readiness, Approach and Runbook, Walkthrough / Rehearsals | 2025-04-28 A |  |  | 0% → 46% |  |  | baseline start none → 2025-04-28; baseline finish none → 2025-07-31 |
| 2325 | M10 Implementation Approach & Go-Live Runbook | 2025-04-28 A | 2025-06-06 → 2025-06-13 (+7d) | 30d → 35d | 0% → 91% | 664d → 659d |  | baseline start none → 2025-04-28; baseline finish none → 2025-06-06 |
| 2326 | DIP Production Build |  |  |  |  |  |  | baseline start none → 2025-06-09; baseline finish none → 2025-06-27 |
| 2327 | Final Production Deployment |  | 2025-07-25 → 2025-08-01 (+7d) | 15d → 20d |  | 587d → 588d |  | baseline start none → 2025-07-07; baseline finish none → 2025-08-01 |
| 2328 | DIP Portal Available |  |  |  |  | 587d → 588d | 2327FS+6d → 2327FS+1d | baseline start none → 2025-08-04; baseline finish none → 2025-08-04 |
| 2329 | DIP Technical Onboarding for LDSOs |  | 2025-09-23 → 2025-09-22 (-1d) | 36d → 35d |  | 587d → 588d |  | baseline start none → 2025-08-05; baseline finish none → 2025-09-22 |
| 2330 | ISD Dress Rehearsals |  |  |  |  | 619d → -93d |  | baseline start none → 2025-07-07; baseline finish none → 2025-08-08 |
| 2331 | Go / No-Go (Helix Central Systems) |  |  |  |  | 578d → -97d |  | baseline start none → 2025-08-11; baseline finish none → 2025-08-11 |
| 2332 | Service Activation Implementation |  | 2025-08-26 → 2025-08-22 (-4d) | 8d → 6d |  | 607d → -97d |  | baseline start none → 2025-08-15; baseline finish none → 2025-08-26 |
| 2333 | ISD Data Migration |  | 2025-08-26 → 2025-08-22 (-4d) | 8d → 6d |  | 578d → -97d | 2331FS+4d, 2316 → 2331FS+4d, 2316, 2330 | baseline start none → 2025-08-15; baseline finish none → 2025-08-26 |
| 2334 | DAH & ISD Dark Mode |  |  |  |  | 578d → 22d | 2333 → 2333FS+2d | baseline start none → 2025-08-26; baseline finish none → 2025-08-26 |
| 2335 | Dual Run (Pre-Prod) | 2025-08-27 → 2025-08-26 (-1d) | 2025-09-16 → 2025-09-15 (-1d) |  |  | 578d → 8d | 2334 → 2334SS-1d | baseline start none → 2025-08-27; baseline finish none → 2025-09-16 |
| 2336 | M10 Cutover Weekend (20/09 and 21/09) | 2025-09-22 → 2025-09-19 (-3d) | 2025-09-22 → 2025-09-19 (-3d) |  |  | 578d → 8d |  | was named M10 Cutover Weekend; baseline start none → 2025-09-22; baseline finish none → 2025-09-22 |
| 2337 | Post Implementation Review |  |  |  |  |  | 2336FS+9d → 2336FS+10d | baseline start none → 2025-10-06; baseline finish none → 2025-10-06 |
| 2338 | **S & A QUALIFICATION** |  |  |  | 64% → 65% |  |  |  |
| 2339 | **MHHS Qualification - Qualification Deliverables** |  |  |  | 96% → 97% | 305d → 315d |  |  |
| 2367 | **Qualification Assessment Document** |  |  |  | 91% → 94% | 305d → 315d |  |  |
| 2386 | **Qualification Assessment Document Portal** |  |  |  | 84% → 88% | 305d → 315d |  |  |
| 2395 | QT Wave 2 Participant QAD Application Creation in Portal |  | 2025-06-06 A |  | 20% → 100% | 386d → none |  |  |
| 2400 | **MHHS Qualification - SIT Participants** |  |  |  | 46% → 63% |  |  |  |
| 2405 | **MHHS Qualification - M10-Ready** |  |  |  | 79% → 96% |  |  |  |
| 2408 | Completion of Code Bodies review of Final QAD (M10-Ready) |  | 2025-06-06 A |  | 60% → 100% | 642d → none |  |  |
| 2419 | **MHHS Qualification - M11-Ready** |  |  |  | 47% → 80% |  |  |  |
| 2421 | SIT M11-ready Participants submit Final QAD (exc Test Reports) |  | 2025-06-06 A |  | 68% → 100% | 628d → none |  |  |
| 2422 | Completion of Code Bodies review of Final QAD (M11-Ready) | 2025-06-09 A |  |  | 0% → 35% | 628d → 626d |  |  |
| 2430 | **MHHS Qualification - Not M11-Ready** |  |  |  | 1% → 19% |  |  |  |
| 2432 | SIT Not M11-Ready Participants submit Final QAD |  |  |  | 1% → 24% | 545d → 564d |  |  |
| 2434 | **SIT Pathway 6** | 2025-11-27 → 2025-10-09 (-49d) |  | 15d → 50d |  |  |  |  |
| 2439 | SIT Participants are Qualified |  |  |  |  |  | QAD Sign Off Deadline (Not M11-Ready)FS+14d → none | constraint none → finish no earlier than 2025-12-17 |
| 2440 | **MHHS Qualification - Non-SIT LDSO (M10-Ready)** |  |  |  | 60% → 71% | 9d → 596d |  |  |
| 2447 | Non-SIT LDSO Participants submit Final QAD |  | 2025-05-23 A |  | 95% → 100% | 9d → none |  |  |
| 2448 | Non-SIT LDSO QT Participants have submitted their final QAD | 2025-05-23 A | 2025-05-23 A |  | 0% → 100% | 9d → none |  |  |
| 2449 | Completion of Code Bodies review of the Final QAD | 2025-05-26 A |  |  | 0% → 85% | 9d → 596d |  |  |
| 2634 | **Qualification Wave 1** |  |  |  | 7% → 11% | 419d → 441d |  |  |
| 2635 | **Qualification Wave 1 QAD Prep** |  |  |  | 29% → 40% | 419d → 441d |  |  |
| 2637 | Qualification Wave 1 Participants Submit Initial QAD |  |  |  | 46% → 64% | 419d → 441d |  |  |
| 2641 | **Qualification Wave 1 Test Prep** |  |  |  | 8% → 15% | 425d → 614d |  |  |
| 2643 | Qualification Wave 1 Participants DIP Onboarding Window |  |  |  | 23% → 49% | 444d → 466d |  |  |
| 2645 | Qualification Wave 1 Participants' to provide status of PIT completion and submit QT Test Plan | 2025-06-13 → 2025-06-16 (+3d) | 2025-06-13 → 2025-06-16 (+3d) |  |  | 450d → 658d |  | constraint start no earlier than 2025-06-13 → finish no earlier than 2025-06-16 |
| 2646 | Review of Participants' PIT Status and QT Test Plan | 2025-06-13 → 2025-06-16 A (+3d) | 2025-07-03 → 2025-08-15 (+43d) | 15d → 45d | 0% → 4% | 450d → 441d | 2645 → none | constraint none → start no earlier than 2025-06-16 |
| 2647 | Qualification Test Plans for Wave 1 Participants approved | 2025-07-03 → 2025-08-15 (+43d) | 2025-07-03 → 2025-08-15 (+43d) |  |  | 450d → 441d |  |  |
| 2664 | **Qualification Wave 2** | 2025-06-09 A |  |  | 0% → 2% | 386d → 410d |  |  |
| 2665 | **Qualification Wave 2 QAD Prep** | 2025-06-09 A |  |  | 0% → 7% | 386d → 410d |  |  |
| 2666 | Initial QAD Submission window opens | 2025-06-09 A | 2025-06-09 A |  | 0% → 100% | 386d → none |  |  |
| 2667 | Qualification Wave 2 Participants Submit Initial QAD | 2025-06-09 A |  |  | 0% → 10% | 386d → 410d |  |  |
| 2766 | PAB296 | 2025-06-11 A | 2025-06-11 A |  | 0% → 100% | 662d → none |  |  |
| 2911 | CDWG Endorsement | 2025-06-10 A | 2025-06-10 A |  | 0% → 100% | 662d → none |  |  |

| ID | Task | Start | Finish | Duration | Complete | Total float | Predecessors | Other |
| --- | --- | --- | --- | --- | --- | --- | --- | --- |
| 2912 | CCAG Endorsement | 2025-06-25 A | 2025-06-25 A |  | 0% → 100% | 651d → none |  |  |
| 2930 | **MIGRATION** |  |  |  | 66% → 67% |  |  |  |
| 2931 | **Regulatory Governance** |  | 2025-06-27 → 2025-09-26 (+91d) | 325d → 390d | 90% → 96% | 649d → 584d |  |  |
| 2933 | BSC Panel Ruling | 2025-03-31 A → 2025-06-12 A (+73d) | 2025-06-27 → 2025-06-12 A (-15d) | 65d → 0d | 72% → 100% | 649d → none |  | was named Incentives Implemented; constraint start no earlier than 2025-03-31 → finish no earlier than 2025-06-12; baseline start 2025-03-31 → 2025-06-12; baseline finish 2025-06-27 → 2025-06-12 |
| 2984 | Drop-in session 3 | 2025-06-11 A | 2025-06-11 A |  | 0% → 100% | 657d → none |  |  |
| 2985 | Drop-in session 4 | 2025-06-18 A | 2025-06-18 A |  | 0% → 100% | 657d → none |  |  |
| 2987 | **MCC Stood up** |  |  |  | 50% → 54% |  |  |  |
| 2988 | Migration Planning Management Tool Delivery |  |  |  | 54% → 57% |  |  |  |
| 2996 | Dress rehearsal 1 start | 2025-06-09 A | 2025-06-09 A |  | 0% → 100% | 664d → none |  |  |
| 3014 | M11 Readiness Checkpoint |  | 2025-09-26 → 2025-08-28 (-29d) | 45d → 24d |  | 584d → 570d |  | constraint finish no earlier than 2025-09-26 → finish no earlier than 2025-08-28 |
| 3017 | **Migration Artefact Development and Publication** |  |  |  | 73% → 77% |  |  |  |
| 3060 | **Data Cleanse Plan** |  |  |  | 95% → 97% |  |  |  |
| 3065 | **MTDs** |  |  |  | 86% → 91% |  |  |  |
| 3072 | **Meter Location and Number of Displayed Register Digits** |  |  |  | 75% → 84% |  |  |  |
| 3076 | Suppliers complete Work Off plans |  |  |  | 70% → 81% |  |  |  |
| 3091 | **Connection Type and Meter Type Misalignments** |  |  |  | 47% → 53% |  |  |  |
| 3092 | **Traditional Meters installed on Current Transformers** |  |  |  | 15% → 20% |  |  |  |
| 3095 | Suppliers to have ensured that Meter Operators have sent the necessary D0312s for MPANs in pot 2 |  |  |  | 14% → 57% |  |  |  |
| 3096 | LDSOs will be required to have corrected all of these Connection Types in pot 3 |  |  |  | 8% → 30% |  |  |  |
| 3097 | Suppliers to have completed meter exchanges for those MPANs in pot 1 |  |  |  | 1% → 3% |  |  |  |
| 3104 | **Smart Meter Types installed on CT Connection Types** |  |  |  | 59% → 69% |  |  |  |
| 3108 | Suppliers resolve all issues |  |  |  | 8% → 30% |  |  |  |
| 3110 | **Linked Import / Export MPANs** |  |  |  | 65% → 73% |  |  |  |
| 3111 | LDSOs review and correct linked Import / Export MPANs with Different Connection Types |  |  |  | 65% → 73% |  |  |  |
| 3112 | LDSOs, Import and Export Suppliers review and correct linked Import / Export MPANs with meters in the Advanced and Traditional or Smart Meter Groups |  |  |  | 65% → 73% |  |  |  |
| 3114 | **Related MPANs** |  |  |  | 65% → 73% |  |  |  |
| 3115 | LDSOs review and correct related MPANs with different Connection Types |  |  |  | 85% → 96% |  |  |  |
| 3117 | Suppliers should investigate Related MPANs within different meter groups and verify that they are correct or request that their Meter Operators update the Meter Types where they are incorrect |  |  |  | 65% → 73% |  |  |  |
| 3149 | **Preparation for Cutover to Live** |  |  |  | 18% → 24% |  |  |  |
| 3150 | **Central Systems Prepare for Cutover to Live** | 2022-10-31 A → 2024-06-28 A (+606d) |  | 760d → 326d | 51% → 65% |  |  |  |
| 3152 | **Development of Comms Approach and Declaration Guidance** |  |  |  | 39% → 63% |  |  |  |
| 3153 | Draft Cutover Comms Approach |  |  |  | 39% → 63% |  |  |  |
| 3156 | **Development of Cutover Plan requirements with Participants** |  |  |  | 55% → 66% |  |  |  |
| 3158 | Development of Programme Participant Cutover Plans |  |  |  | 68% → 84% |  |  |  |
| 3159 | Central Party Cutover Plan Assurance |  | 2025-06-13 A |  | 73% → 100% | 659d → none |  |  |
| 3160 | Consolidated MHHS Cutover Plan Developed |  | 2025-06-13 → 2025-06-27 (+14d) | 20d → 30d | 65% → 73% | 659d → 649d |  | baseline finish 2025-06-13 → 2025-06-27 |
| 3163 | **M10/M11 Cutover Activities** | 2022-10-31 A → 2025-09-05 (+1040d) |  | 760d → 15d |  | 584d → 14d |  |  |
| 3167 | Market-wide Participant MHHS Supporting Functionality Ready - Confirmation from Code Bodies | 2022-10-31 A → 2025-09-15 (+1050d) | 2022-10-31 A → 2025-09-15 (+1050d) |  | 100% → 0% | none → 593d |  | constraint none → finish no earlier than 2025-09-15 |
| 3208 | **Migration Sprints** | 2025-09-25 → 2022-10-31 (-1060d) |  | 420d → 1178d |  |  |  |  |
| 3227 | **Migration Sprint 2** | 2026-03-04 → 2022-10-31 (-1220d) |  | 65d → 937d |  |  |  |  |
| 3235 | Non-SIT Participants Migration Start | 2026-05-15 → 2022-10-31 (-1292d) | 2026-05-15 → 2022-10-31 (-1292d) |  |  | 419d → 1344d | 3375FS+1d → none |  |
| 3313 | **BUSINESS & OPERATIONAL READINESS** |  |  | 1344d? → 1344d | 38% → 35% |  |  |  |
| 3314 | **Service Management** |  | 2026-01-14 → 2026-03-26 (+71d) | 838d → 889d | 42% → 21% | 506d → 455d |  |  |
| 3333 | Confirmation from Qualification of Wave Participants Complete | 2025-08-25 → 2022-10-31 (-1029d) | 2025-08-25 → 2022-10-31 (-1029d) |  |  | 609d → 1342d |  | constraint start no earlier than 2025-08-25 → none |
| 3338 | Agree Content for Livewire | 2025-09-01 → 2022-10-31 (-1036d) | 2025-09-01 → 2022-10-31 (-1036d) |  |  | 603d → 1343d |  | constraint start no earlier than 2025-09-01 → none |
| 3339 | Publish Content for Livewire | 2025-09-01 → 2022-10-31 (-1036d) | 2025-09-01 → 2022-10-31 (-1036d) |  |  | 604d → 1342d |  | constraint start no earlier than 2025-09-01 → none |
| 3343 | SIT Non-MVC Service Activation Preparation Tasks Completed |  |  |  |  | 1342d → 1340d | 2225, 2226, 2227, 2228, Internal Communications, 2229, 2230, 2231, 2232 → 3331, 3333, 3334, 3335, 3336, 3339, 3340, 3341, 3342 |  |
| 3344 | **SIT Non-MVC Service Activation Implementation (M11 Not Ready)** |  |  |  |  |  | none → 3332, 3334, 3335, 3336, 3337, 3340, 3341 |  |
| 3346 | MHHSP Enabled Confirmation | 2025-09-01 → 2022-10-31 (-1036d) | 2025-09-02 → 2022-10-31 (-1037d) | 2d → 0d |  | 602d → 1338d |  | constraint finish no earlier than 2025-09-02 → none; baseline start 2025-09-01 → none; baseline finish 2025-09-02 → none |
| 3348 | Add EFD(ISD Calendar Date) to DIP | 2022-11-01 → 2022-11-04 (+3d) | 2022-11-02 → 2022-11-07 (+5d) |  |  | 1334d → 1338d | 2229, 2230, 2231, 2232, 2235, 3347 → 3340, 3341, 3342, 3343, 3346FS+4d, 3347 |  |
| 3349 | DIP Promoted to Production | 2026-04-20 → 2022-11-04 (-1263d) | 2026-04-21 → 2022-11-04 (-1264d) | 2d → 1d |  | 422d → 1339d | 3379 → 3348SS | constraint finish no earlier than 2025-09-04 → none; baseline start 2025-09-03 → none; baseline finish 2025-09-04 → none |
| 3350 | Create M16 in Customer Solution | 2026-04-22 → 2022-10-31 (-1269d) | 2026-04-23 → 2022-10-31 (-1270d) | 2d → 1d |  | 422d → 1343d | 3349 → none | constraint finish no earlier than 2025-09-05 → none; baseline start 2025-09-04 → none; baseline finish 2025-09-05 → none |
| 3351 | Publish ISD | 2026-06-08 → 2022-10-31 (-1316d) | 2026-06-09 → 2022-11-04 (-1313d) | 2d → 5d |  | 402d → 1339d | 3381 → 3347SS | constraint finish no earlier than 2025-11-07 → none; baseline start 2025-11-06 → none; baseline finish 2025-11-07 → none |
| 3353 | SIT Non-MVC Service Activation Implementation Completed | 2022-11-11 → 2022-11-09 (-2d) | 2022-11-11 → 2022-11-09 (-2d) |  |  | 1334d → 1336d | 2235, 3347, 3348, 2238, 2239, 2240, 2207, 2208 → 3345, 3346, 3347, 3348, 3349, 3350, 3351, 3352 |  |
| 3354 | **SIT Non-MVC Service Activation Implementation MDD (M11 Not Ready)** |  |  |  |  |  | none → 3346, 3347, 3348, 3349, 3350 |  |
| 3359 | SIT Non-MVC Service Activation Implementation MDD Completed |  |  |  |  |  | 2245, 2248 → 3355, 3358 |  |
| 3363 | Issue Management | 2026-04-16 → 2022-10-31 (-1263d) | 2026-05-05 → 2022-11-14 (-1268d) | 14d → 11d |  | 427d → 1333d | 3379SS → none | constraint finish no earlier than 2025-09-18 → none; baseline start 2025-09-01 → none; baseline finish 2025-09-18 → none |
| 3366 | Non-SIT LDSO Service Activation Hypercare Completed |  |  |  |  |  | 2251, 2252, 2253, 2254, 2255 → 3361, 3362, 3363, 3364, 3365 |  |
| 3368 | Review | 2023-01-20 → 2022-10-31 (-81d) | 2023-01-20 → 2022-10-31 (-81d) |  |  | 1274d → 1334d | Non-SIT LDSO Service &SIT MVC Activation Hypercare Completed → none |  |
| 3369 | Lessons Learned | 2023-01-23 → 2022-10-31 (-84d) | 2023-01-27 → 2022-11-04 (-84d) |  |  | 1274d → 1334d | 3368 → 3368SS |  |
| 3370 | Wave 1 - Service Activation Readiness Review Against Entry/Exit Criteria |  |  |  |  |  | Lessons Learned → 3369 |  |
| 3371 | **Wave 1** |  | 2026-05-14 → 2025-09-26 (-230d) | 924d → 760d |  | 420d → 584d |  |  |
| 3372 | **SIT Non-MVC Service Activation Preparation Tasks** |  | 2026-05-14 → 2022-11-29 (-1262d) | 924d → 22d |  | 420d → 1322d |  |  |
| 3375 | Wave 1 Service Activation | 2026-04-16 → 2022-11-01 (-1262d) | 2026-05-14 → 2022-11-29 (-1262d) |  |  | 419d → 1322d | 2663, 3374 → 3374 |  |
| 3376 | **Wave 1 - Service Activation Implementation** |  | 2026-04-27 → 2025-09-11 (-228d) | 171d → 9d |  | 433d → 585d |  |  |
| 3377 | MHHSP Enabled Confirmation | 2025-11-03 → 2025-09-01 (-63d) | 2025-11-04 → 2025-09-02 (-63d) |  |  | 557d → 602d |  | constraint finish no earlier than 2025-11-04 → finish no earlier than 2025-09-02; baseline start 2025-11-03 → 2025-09-01; baseline finish 2025-11-04 → 2025-09-02 |
| 3378 | PAB Approval | 2026-04-16 → 2025-09-01 (-227d) | 2026-04-17 → 2025-09-02 (-227d) |  |  | 439d → 602d | 2663 → none |  |
| 3379 | Add EFD to DIP | 2026-04-16 → 2025-09-02 (-226d) | 2026-04-17 → 2025-09-03 (-226d) |  |  | 422d → 584d | 2663 → none |  |
| 3380 | DIP Promoted to Production | 2026-06-02 → 2025-09-04 (-271d) | 2026-06-03 → 2025-09-05 (-271d) |  |  | 402d → 584d | 3403 → 3379 | constraint finish no earlier than 2025-11-06 → finish no earlier than 2025-09-04; baseline start 2025-11-05 → 2025-09-03; baseline finish 2025-11-06 → 2025-09-04 |
| 3381 | Create M16 in Customer Solution | 2026-06-04 → 2025-09-08 (-269d) | 2026-06-05 → 2025-09-09 (-269d) |  |  | 402d → 584d |  | constraint finish no earlier than 2025-11-07 → finish no earlier than 2025-09-05; baseline start 2025-11-06 → 2025-09-04; baseline finish 2025-11-07 → 2025-09-05 |

| ID | Task | Start | Finish | Duration | Total float | Predecessors | Other |
| --- | --- | --- | --- | --- | --- | --- | --- |
| 3382 | Publish ISD | 2026-08-12 → 2025-09-10 (-336d) | 2026-08-13 → 2025-09-11 (-336d) |  | 355d → 584d | 3405 → 3381 | constraint finish no earlier than 2025-12-30 → finish no earlier than 2025-09-05; baseline start 2025-12-29 → 2025-09-04; baseline finish 2025-12-30 → 2025-09-05 |
| 3383 | Wave 1 - Service Activation Implementation Complete (M) | 2026-04-27 → 2025-09-11 (-228d) | 2026-04-27 → 2025-09-11 (-228d) |  | 433d → 595d | 2241 → 3382 |  |
| 3384 | **Wave 1 - Service Activation Implementation MDD** | 2026-04-28 → 2025-09-12 (-228d) | 2026-05-12 → 2025-09-26 (-228d) |  | 422d → 584d |  |  |
| 3385 | MDD Manual Load | 2026-04-28 → 2025-09-12 (-228d) | 2026-05-04 → 2025-09-18 (-228d) |  | 422d → 584d | 2241 → 3382 |  |
| 3386 | MDD Update | 2026-05-05 → 2025-09-19 (-228d) | 2026-05-12 → 2025-09-26 (-228d) |  | 422d → 584d |  |  |
| 3387 | Wave 1 - Service Activation Implementation MDD Complete (M) | 2026-05-12 → 2025-09-26 (-228d) | 2026-05-12 → 2025-09-26 (-228d) |  | 422d → 584d |  |  |
| 3388 | **Wave 1 - Service Activation Hypercare** |  | 2026-05-05 → 2025-09-24 (-223d) | 177d → 18d | 427d → 586d |  |  |
| 3389 | Service& Process Monitoring | 2026-04-16 → 2025-09-02 (-226d) | 2026-05-05 → 2025-09-19 (-228d) |  | 427d → 589d |  |  |
| 3390 | Daily Reporting | 2026-04-16 → 2025-09-02 (-226d) | 2026-05-05 → 2025-09-19 (-228d) |  | 427d → 589d |  |  |
| 3391 | Issue Management | 2025-11-03 → 2025-09-02 (-62d) | 2025-11-20 → 2025-09-19 (-62d) |  | 545d → 589d | none → 3379SS | constraint finish no earlier than 2025-11-20 → finish no earlier than 2025-09-18; baseline start 2025-11-03 → 2025-09-01; baseline finish 2025-11-20 → 2025-09-18 |
| 3395 | **Wave 2** |  | 2026-07-01 → 2025-11-20 (-223d) | 958d → 799d | 386d → 545d |  |  |
| 3396 | **SIT Non-MVC Service Activation Preparation Tasks** |  | 2026-07-01 → 2022-12-02 (-1307d) | 958d → 25d | 386d → 1319d |  |  |
| 3399 | Wave 2 Service Activation | 2026-05-29 → 2022-11-01 (-1305d) | 2026-07-01 → 2022-12-02 (-1307d) |  | 386d → 1319d | 2693, 3398 → 3398 |  |
| 3400 | **Wave 2 - Service Activation Implementation** |  | 2026-06-09 → 2025-11-13 (-208d) | 157d → 9d | 402d → 550d |  |  |
| 3401 | MHHSP Enabled Confirmation | 2025-12-22 → 2025-11-03 (-49d) | 2025-12-23 → 2025-11-04 (-49d) |  | 522d → 557d |  | constraint finish no earlier than 2025-12-23 → finish no earlier than 2025-11-04; baseline start 2025-12-22 → 2025-11-03; baseline finish 2025-12-23 → 2025-11-04 |
| 3402 | PAB Approval | 2026-05-29 → 2025-11-03 (-207d) | 2026-06-01 → 2025-11-04 (-209d) |  | 408d → 557d | 2693 → none |  |
| 3403 | Add EFD to DIP | 2026-05-29 → 2025-11-04 (-206d) | 2026-06-01 → 2025-11-05 (-208d) |  | 402d → 550d | 2693 → none |  |
| 3404 | DIP Promoted to Production | 2026-08-06 → 2025-11-06 (-273d) | 2026-08-07 → 2025-11-07 (-273d) |  | 355d → 550d | 3427 → 3403 | constraint finish no earlier than 2025-12-30 → finish no earlier than 2025-11-06; baseline start 2025-12-29 → 2025-11-05; baseline finish 2025-12-30 → 2025-11-06 |
| 3405 | Create M16 in Customer Solution | 2026-08-10 → 2025-11-10 (-273d) | 2026-08-11 → 2025-11-11 (-273d) |  | 355d → 550d |  | constraint finish no earlier than 2025-12-30 → finish no earlier than 2025-11-07; baseline start 2025-12-29 → 2025-11-06; baseline finish 2025-12-30 → 2025-11-07 |
| 3406 | Publish ISD | 2026-10-06 → 2025-11-12 (-328d) | 2026-10-07 → 2025-11-13 (-328d) |  | 316d → 550d | 3429 → 3405 | constraint finish no earlier than 2026-03-06 → finish no earlier than 2025-11-07; baseline start 2026-03-05 → 2025-11-06; baseline finish 2026-03-06 → 2025-11-07 |
| 3407 | Wave 2 - Service Activation Implementation Complete (M) | 2026-06-09 → 2025-11-13 (-208d) | 2026-06-09 → 2025-11-13 (-208d) |  | 402d → 550d | 3351 → 3406 |  |
| 3415 | Issue Management | 2025-12-22 → 2025-11-03 (-49d) | 2026-01-16 → 2025-11-20 (-57d) | 20d → 14d | 504d → 545d |  | constraint finish no earlier than 2026-01-16 → finish no earlier than 2025-11-20; baseline start 2025-12-22 → 2025-11-03; baseline finish 2026-01-16 → 2025-11-20 |
| 3419 | **Wave 3** |  | 2026-08-13 → 2026-01-16 (-209d) | 989d → 840d | 355d → 504d |  |  |
| 3420 | **SIT Non-MVC Service Activation Preparation Tasks** |  | 2026-08-13 → 2022-11-14 (-1368d) | 989d → 11d | 355d → 1333d |  |  |
| 3423 | Wave 3 Service Activation | 2026-07-31 → 2022-11-01 (-1368d) | 2026-08-13 → 2022-11-14 (-1368d) |  | 355d → 1333d | 2723, 3422 → 3422 |  |
| 3424 | **Wave 3 - Service Activation Implementation** |  | 2026-08-13 → 2026-01-05 (-220d) | 169d → 11d | 355d → 513d |  |  |
| 3425 | MHHSP Enabled Confirmation | 2026-03-02 → 2025-12-22 (-70d) | 2026-03-03 → 2025-12-23 (-70d) |  | 472d → 522d |  | constraint finish no earlier than 2026-03-03 → finish no earlier than 2025-12-23; baseline start 2026-03-02 → 2025-12-22; baseline finish 2026-03-03 → 2025-12-23 |
| 3426 | PAB Approval | 2026-07-31 → 2025-12-22 (-221d) | 2026-08-03 → 2025-12-23 (-223d) |  | 355d → 514d | 2723 → none |  |
| 3427 | Add EFD to DIP | 2026-08-04 → 2025-12-24 (-223d) | 2026-08-05 → 2025-12-25 (-223d) |  | 355d → 514d | 2723, 3426 → 3426 |  |
| 3428 | DIP Promoted to Production | 2026-09-30 → 2025-12-29 (-275d) | 2026-10-01 → 2025-12-30 (-275d) |  | 316d → 513d | 3451 → 3427 | constraint finish no earlier than 2026-03-05 → finish no earlier than 2025-12-30; baseline start 2026-03-04 → 2025-12-29; baseline finish 2026-03-05 → 2025-12-30 |
| 3429 | Create M16 in Customer Solution | 2026-10-02 → 2025-12-31 (-275d) | 2026-10-05 → 2026-01-01 (-277d) |  | 316d → 513d |  | constraint finish no earlier than 2026-03-06 → finish no earlier than 2025-12-30; baseline start 2026-03-05 → 2025-12-29; baseline finish 2026-03-06 → 2025-12-30 |
| 3430 | Publish ISD | 2025-02-26 → 2026-01-02 (+310d) | 2025-02-27 → 2026-01-05 (+312d) |  | 735d → 513d | none → 3429 | constraint finish no earlier than 2025-02-27 → finish no earlier than 2025-12-30; baseline start 2025-02-26 → 2025-12-29; baseline finish 2025-02-27 → 2025-12-30 |
| 3431 | Wave 3 - Service Activation Implementation Complete (M) | 2026-08-13 → 2026-01-05 (-220d) | 2026-08-13 → 2026-01-05 (-220d) |  | 355d → 513d | 3382 → 3430 |  |
| 3439 | Issue Management | 2026-03-02 → 2025-12-22 (-70d) | 2026-03-26 → 2026-01-16 (-69d) | 19d → 20d | 455d → 504d |  | constraint finish no earlier than 2026-03-26 → finish no earlier than 2026-01-16; baseline start 2026-03-02 → 2025-12-22; baseline finish 2026-03-26 → 2026-01-16 |
| 3443 | **Wave 4** |  | 2026-10-28 → 2026-03-26 (-216d) | 1043d → 889d | 301d → 455d |  |  |
| 3444 | **SIT Non-MVC Service Activation Preparation Tasks** |  | 2026-10-28 → 2022-12-02 (-1426d) | 1043d → 25d | 301d → 1319d |  |  |
| 3447 | Wave 4 Service Activation | 2026-09-25 → 2022-11-01 (-1424d) | 2026-10-28 → 2022-12-02 (-1426d) |  | 301d → 1319d | 2753, 3446 → 3446 |  |
| 3448 | **Wave 4 - Service Activation Implementation** | 2026-03-02 → 2025-03-03 (-364d) | 2026-10-07 → 2026-03-12 (-209d) | 158d → 269d | 316d → 465d |  |  |
| 3449 | MHHSP Enabled Confirmation | 2025-02-24 → 2026-03-02 (+371d) | 2025-02-25 → 2026-03-03 (+371d) |  | 737d → 472d |  | constraint finish no earlier than 2025-02-25 → finish no earlier than 2026-03-03; baseline start 2025-02-24 → 2026-03-02; baseline finish 2025-02-25 → 2026-03-03 |
| 3450 | PAB Approval | 2026-09-25 → 2025-03-03 (-571d) | 2026-09-25 → 2025-03-03 (-571d) |  | 316d → 725d | 2753 → none |  |
| 3451 | Add EFD to DIP | 2026-09-28 → 2026-03-03 (-209d) | 2026-09-29 → 2026-03-04 (-209d) |  | 316d → 465d |  |  |
| 3452 | DIP Promoted to Production | 2025-02-26 → 2026-03-05 (+372d) | 2025-02-27 → 2026-03-06 (+372d) |  | 735d → 465d | none → 3451 | constraint finish no earlier than 2025-02-27 → finish no earlier than 2026-03-05; baseline start 2025-02-26 → 2026-03-04; baseline finish 2025-02-27 → 2026-03-05 |
| 3453 | Create M16 in Customer Solution | 2025-02-26 → 2026-03-09 (+376d) | 2025-02-27 → 2026-03-10 (+376d) |  | 735d → 465d | none → 3452 | constraint finish no earlier than 2025-02-27 → finish no earlier than 2026-03-06; baseline start 2025-02-26 → 2026-03-05; baseline finish 2025-02-27 → 2026-03-06 |
| 3455 | Wave 4 - Service Activation Implementation Complete (M) | 2026-10-07 → 2026-03-12 (-209d) | 2026-10-07 → 2026-03-12 (-209d) |  | 316d → 465d | 3406 → 3454 |  |
| 3463 | Issue Management | 2025-02-24 → 2026-03-02 (+371d) | 2025-03-19 → 2026-03-26 (+372d) | 18d → 19d | 721d → 455d |  | constraint finish no earlier than 2025-03-19 → finish no earlier than 2026-03-26; baseline start 2025-02-24 → 2026-03-02; baseline finish 2025-03-19 → 2026-03-26 |
| 3467 | **Non-SIT LDSO** |  | 2025-09-18 → 2025-03-19 (-183d) | 754d → 623d | 590d → 721d |  |  |
| 3471 | Create Entity Forms in Customer Solution | 2025-08-22 → 2025-02-03 (-200d) | 2025-08-25 → 2025-02-05 (-201d) | 2d → 3d | 606d → 751d |  | constraint start no earlier than 2025-08-22 → finish no earlier than 2025-02-05; baseline start none → 2025-02-03; baseline finish none → 2025-02-05 |
| 3473 | DIP - Enable Technology capabilities for participants | 2025-08-15 → 2025-02-03 (-193d) | 2025-08-18 → 2025-02-05 (-194d) | 2d → 3d | 611d → 751d |  | constraint start no earlier than 2025-08-15 → finish no earlier than 2025-02-05; baseline start none → 2025-02-03; baseline finish none → 2025-02-05 |
| 3474 | DIP - Add EFD to DIP | 2025-08-15 → 2025-02-03 (-193d) | 2025-08-18 → 2025-02-05 (-194d) | 2d → 3d | 609d → 751d |  | constraint start no earlier than 2025-08-15 → finish no earlier than 2025-02-05; baseline start none → 2025-02-03; baseline finish none → 2025-02-05 |
| 3475 | ISD - Replicate Entity Forms from CS | 2025-08-15 → 2025-02-06 (-190d) | 2025-08-18 → 2025-02-07 (-192d) |  | 611d → 749d |  | constraint start no earlier than 2025-08-15 → finish no earlier than 2025-02-07; baseline start none → 2025-02-06; baseline finish none → 2025-02-07 |
| 3476 | MDD - Load MHHS roles | 2025-08-15 → 2025-02-03 (-193d) | 2025-08-18 → 2025-02-05 (-194d) | 2d → 3d | 611d → 751d |  | constraint start no earlier than 2025-08-15 → finish no earlier than 2025-02-05; baseline start none → 2025-02-03; baseline finish none → 2025-02-05 |
| 3478 | **SIT Non-MVC Service Activation Preparation Tasks** |  | 2025-09-18 → 2022-11-08 (-1045d) | 754d → 7d | 590d → 1337d |  |  |
| 3481 | Non-SIT LDSO Service Activation | 2025-09-11 → 2022-11-01 (-1045d) | 2025-09-18 → 2022-11-08 (-1045d) |  | 9d → 1337d | 3480, 2452 → 3480 |  |

## Version 12 (data date 2025-07-01, saved 2025-07-02, file MHHS-DEL1139 - MHHS Plan v6.28.mpp)

Last finish stays 2027-12-23. Complete tasks 1930 → 1978.

Added:

| ID | Task | Duration | Start | Finish | Predecessors | Constraint |
| --- | --- | --- | --- | --- | --- | --- |
| 1572 | Regression Sprint 4 | 15d | 2025-08-25 | 2025-09-12 | 1571 |  |
| 1581 | SRO/Code Bodies Review SI SIT Funcational & Migration Overarching Exit Report | 5d | 2025-06-26 A | 2025-07-02 | 1580SS | finish no earlier than 2025-07-02 |
| 1583 | SI SIT Functional & Migration Overarching Exit Report Industry Review | 10d | 2025-07-04 | 2025-07-17 | 1582 |  |
| 1586 | SRO Review Settlement and Regression Pathway 2 PP Exit Reports | 5d | 2025-07-17 | 2025-07-23 | 1585SS | finish no earlier than 2025-07-23 |
| 1589 | Programme drafts Settlement and Regression Pathway 3 PP Exit Reports | 13d | 2025-07-28 | 2025-08-13 | 1570SS | start no earlier than 2025-07-28 |
| 1590 | SRO Review Settlement and Regression Pathway 3 PP Exit Reports | 5d | 2025-08-07 | 2025-08-13 | 1589SS | finish no earlier than 2025-08-13 |
| 1591 | Pathway 3 PPs review and sign off Exit Reports | 5d | 2025-08-11 | 2025-08-15 | 1589SS | start no earlier than 2025-08-11 |
| 1592 | Programme drafts Settlement and Regression Pathway 4, 5 & 6 PP Exit Reports | 25d | 2025-08-18 | 2025-09-19 | 1571SS | start no earlier than 2025-08-18 |
| 1596 | SI SIT Migration Testing Test Exit Report Approved | 0d | 2025-08-15 | 2025-08-15 |  | start no earlier than 2025-08-15 |
| 1598 | SI SIT Migration Testing End (incl. confirmation that PPs have submitted their Test Exit Reports to Programme for assurance) | 0d | 2025-08-15 | 2025-08-15 | 1648 | finish no earlier than 2025-08-15 |
| 1667 | SRO / Code Bodies / DIP Manager formal review SI SIT Non-Functional Overarching Exit Report | 5d | 2025-07-14 | 2025-07-18 | 1666 |  |
| 1669 | SI SIT Non-Functional Overarching Exit Report published to PPs for industry review | 0d | 2025-07-18 | 2025-07-18 | 1668 |  |
| 1670 | SI SIT Non-Functional Overarching Exit Report industry review | 10d | 2025-07-21 | 2025-08-01 | 1669 |  |
| 1692 | Programme drafts Pathway 3 PP Exit Report (when Participant completes Operational testing) | 15d | 2025-07-21 | 2025-08-08 | 1688 | start no earlier than 2025-07-21 |
| 1693 | All Pathway 3 Operational Exit Reports and Exit Declarations shared with PPs | 0d | 2025-08-08 | 2025-08-08 | 1688, 1692 |  |
| 1694 | Pathway 3 PPs have reviewed Exit Report and signed Exit Declaration | 5d | 2025-08-11 | 2025-08-15 | 1693 |  |
| 1696 | Programme drafts Pathway 4, 5 & 6 PP Exit Report (when Participant completes Operational testing) | 15d | 2025-08-11 | 2025-08-29 | 1692 |  |
| 1698 | SRO/Code Bodies/DIP Manager Review SI SIT Operational Overarching Exit Report | 5d | 2025-07-28 | 2025-08-01 | 1697SS | finish no earlier than 2025-08-01 |
| 1700 | SI SIT Operational Overarching Exit Report industry review | 10d | 2025-08-04 | 2025-08-15 | 1699 |  |
| 1784 | LDSO Onboarding and Test Data Creation and Support | 169d | 2025-06-02 A | 2026-01-22 |  | start no earlier than 2025-06-02 |
| 1785 | Supplier & Agent Onboarding and Test Data Creation and Support | 260d | 2025-09-01 | 2026-08-28 |  | start no earlier than 2025-09-01 |
| 1810 | **Sandbox Execution** | 330d | 2025-05-26 A | 2026-08-28 |  |  |
| 1816 | UIT E2E Sandbox Preparation Complete | 0d | 2025-05-26 A | 2025-05-26 A |  | start no earlier than 2025-05-26 |
| 1821 | UIT E2E Sandbox Preparation Complete - Supplier and Agent | 0d | 2025-08-25 | 2025-08-25 |  | start no earlier than 2025-08-25 |
| 2037 | Service User LLSD Updates Post Consultation | 13d | 2025-05-19 A | 2025-06-04 A |  | start no earlier than 2025-05-19 |
| 2038 | Service User LLSD Version 1.2 (ORT) (TORWG Paper Day) | 0d | 2025-06-04 A | 2025-06-04 A | 2036 |  |
| 2039 | CPSD Scenarios and Runbook | 19d | 2025-04-29 A | 2025-05-23 A |  | start no earlier than 2025-04-29 |
| 2040 | CPSD Scenarios and Runbook Shared with MHHS Team for Review | 0d | 2025-05-23 A | 2025-05-23 A | 2039 |  |
| 2041 | CPSD Scenarios and Runbook Review Window | 8d | 2025-05-26 A | 2025-06-04 A | 2040 |  |
| 2042 | CPSD Scenarios and Runbook Released for TORWG (Paper Day) | 0d | 2025-06-04 A | 2025-06-04 A | 2041 |  |
| 2043 | Parent/Child Industry Engagement Session | 0d | 2025-06-06 A | 2025-06-06 A | 2042 | start no earlier than 2025-06-06 |
| 2044 | CPSD Runbook Completed | 0d | 2025-06-11 A | 2025-06-11 A | 2042FS+5d |  |
| 2045 | **Service Documentation V2** | 23d | 2025-07-14 | 2025-08-13 |  |  |
| 2048 | Operations Manual and LLSD v2 Consultation | 10d | 2025-07-17 | 2025-07-30 | 2047 |  |
| 2049 | Operations Manual and LLSD v2 Consultation Completed | 0d | 2025-07-30 | 2025-07-30 | 2048 |  |
| 2050 | Consultation Feedback Implemented Operations Manual and LLSD v2 | 5d | 2025-07-31 | 2025-08-06 | 2049 |  |
| 2051 | Operations Manual and LLSD v2 Feedback Implemented | 0d | 2025-08-06 | 2025-08-06 | 2050 |  |
| 2052 | TORWG Paper Day | 0d | 2025-08-06 | 2025-08-06 | 2051 |  |
| 2053 | TORWG Operations Manual and LLSD v2 Approval | 0d | 2025-08-13 | 2025-08-13 | 2052FS+5d |  |
| 2054 | Operations Manual and LLSD v2 Approved and Completed | 0d | 2025-08-13 | 2025-08-13 | 2053 |  |
| 2120 | Operational Control Centre (OCC) Live (Service and ULT Triage) | 0d | 2025-08-04 | 2025-08-04 | 2119FS+1d |  |
| 2122 | **DIP Guidance Notes** | 55d | 2025-05-05 A | 2025-07-18 |  |  |
| 2123 | GN/LWI creation & publication | 55d | 2025-05-05 A | 2025-07-18 |  | start no earlier than 2025-05-05 |
| 2124 | Tranche 1 GN/LWI created & published (critical for M10) | 0d | 2025-06-20 A | 2025-06-20 A |  | start no earlier than 2025-06-20 |
| 2125 | Tranche 2 GN/LWI created & published | 0d | 2025-07-04 | 2025-07-04 |  | start no earlier than 2025-07-04 |
| 2126 | Tranche 3 GN/LWI created & published | 0d | 2025-07-18 | 2025-07-18 |  | start no earlier than 2025-07-18 |
| 2127 | DIP Reporting (M11) | 65d | 2025-05-12 A | 2025-08-08 |  | start no earlier than 2025-05-12 |
| 2128 | Functional Training Execution | 85d | 2025-05-05 A | 2025-08-29 |  | start no earlier than 2025-05-05 |
| 2129 | **Operational Readiness E2E Testing** | 64d | 2025-05-13 | 2025-08-08 |  |  |
| 2130 | Phase 1 Test Execution (Service Activation and Participant Management) | 48d | 2025-05-14 A | 2025-07-18 |  | finish no earlier than 2025-07-18 |
| 2131 | Phase 2 Test Execution (S&I) | 17d | 2025-06-11 A | 2025-07-11 |  | finish no earlier than 2025-07-11 |
| 2132 | Phase 3 Test Execution (Assurance & mop-up) | 13d | 2025-07-02 | 2025-07-18 |  | start no earlier than 2025-07-02 |
| 2133 | E2E Operational Testing Completed | 1d | 2025-08-08 | 2025-08-08 | 2130, 2131, 2132 | finish no earlier than 2025-08-08 |
| 2175 | LDSO Workshop | 0d | 2025-06-30 | 2025-06-30 |  | start no earlier than 2025-06-30 |
| 2176 | GLIG | 0d | 2025-07-04 | 2025-07-04 |  | start no earlier than 2025-07-04 |
| 2177 | QWG | 0d | 2025-07-08 | 2025-07-08 |  | start no earlier than 2025-07-08 |
| 2178 | GLIG (Second presentation) | 0d | 2025-07-18 | 2025-07-18 |  | start no earlier than 2025-07-18 |
| 2210 | Non-LDSO SIT PP DIP User Promoted to Production | 1d | 2025-09-12 | 2025-09-12 | 2209 | start no earlier than 2025-09-12 |
| 2255 | **Pathway 4 PPs** | 6d? | 2025-09-25 | 2025-10-03 |  |  |
| 2264 | Publish MDD | 6d | 2025-09-26 | 2025-10-03 | 2257 |  |
| 2267 | **Pathway 5 PPs** | 5d? | 2025-10-15 | 2025-10-22 |  |  |
| 2268 | PAB Approval Completed | 0d | 2025-10-15 | 2025-10-15 | 2507, 2510 | start no earlier than 2025-09-10 |
| 2270 | Add EFD (ISD Calendar Date) to DIP | 0d | 2025-10-15 | 2025-10-15 | 2269 | start no earlier than 2025-10-15 |
| 2276 | Publish MDD | 5d | 2025-10-16 | 2025-10-22 | 2269 |  |
| 2277 | MDD Go Live | 0d | 2025-10-22 | 2025-10-22 | 2276 |  |
| 2278 | Pathway 5 Service Activation Implementation Completed | 0d | 2025-10-22 | 2025-10-22 | 2269, 2268, 2270, 2271, 2272, 2275 | start no earlier than 2025-09-19 |
| 2304 | **First Pathway 6 PAB** | 38d? | 2025-10-30 | 2025-12-23 |  |  |
| 2313 | Publish MDD | 6d | 2025-10-31 | 2025-11-07 | 2306 |  |
| 2314 | MDD Go Live | 0d | 2025-11-07 | 2025-11-07 | 2313 |  |
| 2316 | **Final Pathway 6 PAB** | 9d? | 2025-12-17 | 2025-12-30 |  |  |
| 2317 | MHHSP Enabled Confirmation | 0d | 2025-12-17 | 2025-12-17 | 2520 | start no earlier than 2025-09-08 |
| 2318 | Add EFD (ISD Calendar Date) to DIP | 0d | 2025-12-17 | 2025-12-17 | 2317 | start no earlier than 2025-09-11 |
| 2319 | Create M16 in Customer Solution | 0d | 2025-12-22 | 2025-12-22 | 2321SS | start no earlier than 2025-12-19 |
| 2320 | DIP Production Success Checks | 1d? | 2025-12-23 | 2025-12-23 | 2318, 2319 | start no earlier than 2025-12-23 |
| 2321 | Publish ISD | 7d | 2025-12-22 | 2025-12-30 | 2317FS+2d |  |
| 2322 | Go Live ISD | 0d | 2025-12-30 | 2025-12-30 | 2321 | start no earlier than 2025-09-18 |
| 2323 | Publish MDD | 7d | 2025-12-22 | 2025-12-30 | 2317FS+2d |  |
| 2324 | MDD Go Live | 0d | 2025-12-30 | 2025-12-30 | 2323 |  |
| 2325 | Service Activation Implementation Completed | 0d | 2025-12-30 | 2025-12-30 | 2322, 2324 |  |

Removed: 1589 SITWG Review status of SI SIT Settlement and Regression Overarching Exit Report; 1683 SRO Review SI SIT Operational Overarching Exit Report; 2012 Service User LLSD Version 1.2; 3328 M11-Ready Activation Preparation Tasks; 3329 SIT Non-MVC Service Activation Preparation Tasks (M11 Not Ready); 3330 Provide LWIs; 3331 Review Entry/Exit Criteria & Lessons Learned; 3332 Identify Resources; 3333 Confirmation from Qualification of Wave Participants Complete; 3334 Agree & Understand Support Model; 3335 Confirm Training complete; 3336 Engagement / Communications with Participants; 3337 Internal Communications; 3338 Agree Content for Livewire; 3339 Publish Content for Livewire; 3340 Validate User Access; 3341 Target Systems and Environments Ready; 3342 Business Readiness Governance Approval; 3343 SIT Non-MVC Service Activation Preparation Tasks Completed; 3344 SIT Non-MVC Service Activation Implementation (M11 Not Ready); 3347 PAB Approval; 3348 Add EFD(ISD Calendar Date) to DIP; 3349 DIP Promoted to Production; 3353 SIT Non-MVC Service Activation Implementation Completed; 3354 SIT Non-MVC Service Activation Implementation MDD (M11 Not Ready); 3355 MDD Final Circular; 3356 MDD Manual Update; 3357 MDD Publish; 3359 SIT Non-MVC Service Activation Implementation MDD Completed; 3360 SIT Non-MVC Service Activation Hypercare (M11 Not Ready); 3361 Monitoring; 3362 Reporting; 3363 Issue Management; 3364 Closed Down Activities; 3365 Inform MHHSP; 3366 Non-SIT LDSO Service Activation Hypercare Completed; 3367 SIT Non-MVC Service Activation Retro & Go/No Go (M11 Not Ready); 3368 Review; 3369 Lessons Learned; 3370 Wave 1 - Service Activation Readiness Review Against Entry/Exit Criteria

Changed:

| ID | Task | Start | Finish | Duration | Complete | Total float | Predecessors | Other |
| --- | --- | --- | --- | --- | --- | --- | --- | --- |
| 509 | **SYSTEMS INTEGRATION TESTING (SIT)** |  |  |  | 79% → 77% |  |  |  |
| 1484 | **SIT Execution** |  | 2025-11-26 → 2025-12-10 (+14d) | 543d? → 553d? | 63% → 65% | 541d → 531d |  |  |
| 1501 | **SIT** |  | 2025-08-22 → 2025-09-19 (+28d) | 380d? → 400d? | 71% → 72% | 609d → 589d |  |  |
| 1502 | **SIT Functional Testing (MVC)** |  | 2025-08-20 → 2025-09-19 (+30d) | 378d? → 400d? |  | 611d → 589d |  |  |
| 1541 | **SIT Functional Settlement Testing** |  |  |  | 59% → 62% |  |  |  |
| 1560 | **SIT-A Settlement Testing** |  | 2025-06-13 → 2025-06-27 A (+14d) | 20d → 30d | 40% → 100% | 659d → none |  |  |
| 1562 | SIT-A Settlement Testing |  | 2025-06-13 → 2025-06-27 A (+14d) | 20d → 30d | 40% → 100% | -97d → none |  | baseline start 2025-05-20 → 2025-05-19; baseline finish 2025-06-16 → 2025-06-27 |
| 1563 | eSITAG decision point on end of SIT A testing | 2025-06-11 → 2025-06-26 A (+15d) | 2025-06-11 → 2025-06-26 A (+15d) |  | 0% → 100% | 661d → none |  | constraint finish no earlier than 2025-06-11 → finish no earlier than 2025-06-26 |
| 1564 | SIT-A Settlement Decision Point Exit Criteria | 2025-06-13 → 2025-06-27 A (+14d) | 2025-06-13 → 2025-06-27 A (+14d) |  | 0% → 100% | -97d → none |  | baseline start 2025-06-13 → 2025-06-27; baseline finish 2025-06-13 → 2025-06-27 |
| 1565 | SIT-A Settlement Testing Completed | 2025-06-13 → 2025-06-27 A (+14d) | 2025-06-13 → 2025-06-27 A (+14d) |  | 0% → 100% | -97d → none |  | baseline start 2025-06-13 → 2025-06-27; baseline finish 2025-06-13 → 2025-06-27 |
| 1566 | **SIT Functional & Migration Regression Testing (code freeze)** | 2025-06-16 → 2025-06-30 A (+14d) | 2025-08-08 → 2025-09-19 (+42d) | 40d? → 60d? | 0% → 3% | -97d → 589d |  | was named SIT Functional Regression Testing (code freeze) |
| 1567 | Regression Test Execution Start | 2025-06-16 → 2025-06-30 A (+14d) | 2025-06-16 → 2025-06-30 A (+14d) |  | 0% → 100% | -97d → none |  | baseline start 2025-06-16 → 2025-06-30; baseline finish 2025-06-16 → 2025-06-30 |
| 1568 | Regression Execution | 2025-06-16 → 2025-06-30 A (+14d) | 2025-06-20 → 2025-07-04 (+14d) |  | 0% → 40% |  |  | baseline start 2025-06-16 → 2025-06-30; baseline finish 2025-06-20 → 2025-07-04 |
| 1569 | Regression Sprint 1 | 2025-06-23 → 2025-07-07 (+14d) | 2025-07-04 → 2025-07-18 (+14d) |  |  |  |  | baseline start 2025-06-23 → 2025-07-07; baseline finish 2025-07-04 → 2025-07-18 |
| 1570 | Regression Sprint 2 | 2025-07-07 → 2025-07-21 (+14d) | 2025-07-18 → 2025-08-08 (+21d) | 10d → 15d |  |  |  | baseline start 2025-07-07 → 2025-07-21; baseline finish 2025-07-18 → 2025-08-08 |
| 1571 | Regression Sprint 3 | 2025-07-21 → 2025-08-11 (+21d) | 2025-08-01 → 2025-08-22 (+21d) |  |  | -97d → 589d |  | baseline start 2025-07-21 → 2025-08-11; baseline finish 2025-08-01 → 2025-08-22 |
| 1573 | Regression Contingency Week | 2025-08-04 → 2025-09-15 (+42d) | 2025-08-08 → 2025-09-19 (+42d) |  |  | -97d → 589d | 1571, 1585FF → 1572, 1585FF, 1571 |  |
| 1574 | SIT Functional Testing End |  |  | 0d → 1d |  |  | 1573 → none | constraint start no earlier than 2025-03-14 → finish no earlier than 2025-08-08 |
| 1575 | **SIT Functional & Migration Overarching Exit Report** |  | 2025-07-03 → 2025-07-17 (+14d) | 49d → 59d | 72% → 84% | 645d → 635d |  |  |
| 1576 | Programme drafts Functional & Migration PP Exit Report |  |  |  |  |  |  | baseline finish 2025-05-23 → 2025-06-10 |
| 1577 | SRO Review PP Exit Reports |  |  |  |  |  |  | baseline finish 2025-05-23 → 2025-06-04 |
| 1578 | Functional & Migration PP Exit Reports shared with PPs |  |  |  |  |  |  | baseline start 2025-05-23 → 2025-06-10; baseline finish 2025-05-23 → 2025-06-10 |
| 1579 | PPs review Exit Report and sign Functional & Migration Exit Declaration |  | 2025-06-24 A |  | 50% → 100% | 648d → none |  | was named PPs complete and return Exit Reports; baseline start 2025-05-26 → 2025-06-11; baseline finish 2025-06-06 → 2025-06-24 |
| 1580 | Programme drafts SI SIT Functional & Migration Overarching Exit Report | 2025-06-11 A | 2025-06-27 A |  | 0% → 100% | 645d → none | 1578, 1695FF → 1578 | baseline start 2025-05-26 → 2025-06-11; baseline finish 2025-06-11 → 2025-06-27 |
| 1582 | SITWG Review status of SI SIT Functional & Migration Overarching Exit Report |  |  |  |  | 645d → 635d | 1580FS+4d → 1580FS+4d, 1581 | baseline start 2025-06-05 → 2025-07-03; baseline finish 2025-06-05 → 2025-07-03 |
| 1584 | **SIT Settlement and Regression Test Exit Report** | 2025-06-30 → 2025-07-07 (+7d) | 2025-08-20 → 2025-09-19 (+30d) | 38d → 55d |  | -97d → 30d |  |  |
| 1585 | Programme drafts Settlement and Regression Pathway 2 PP Exit Reports | 2025-06-30 → 2025-07-07 (+7d) | 2025-08-08 → 2025-07-23 (-16d) | 30d → 13d |  | -97d → 616d |  | was named Programme drafts Settlement and Regression PP Exit Reports (when Participant completes Regression testing); constraint start no earlier than 2025-06-30 → start no earlier than 2025-07-07 |
| 1587 | All Settlement and Regression Pathway 2 PP Exit Reports shared with PPs | 2025-08-08 → 2025-07-23 (-16d) | 2025-08-08 → 2025-07-23 (-16d) |  |  | 619d → 631d |  | was named All Settlement and Regression PP Exit Reports shared with PPs |
| 1588 | Pathway 2 PPs review and sign off Regression Exit Declaration | 2025-07-07 → 2025-07-21 (+14d) | 2025-08-08 → 2025-07-28 (-11d) | 25d → 6d |  | 20d → 606d | 1585SS, 1644SS → 1585SS | was named PPs complete and return Exit Reports; constraint start no earlier than 2025-07-07 → start no earlier than 2025-07-21 |
| 1593 | Pathway 3 PPs Exit Report and Regression Exit Decleration submission deadline |  |  |  |  |  |  | was named PPs Exit Report and Regression Exit Decleration submission deadline |
| 1594 | Programme drafts SI SIT Settlement and Regression Addendum | 2025-07-07 → 2025-07-21 (+14d) |  | 25d → 15d |  |  | 1588SS, 1646SS → none | was named Programme drafts SI SIT Settlement and Regression Overarching Exit Report; constraint none → start no earlier than 2025-07-21 |
| 1595 | SRO/Code Bodies Review SI SIT Settlement and Regression Addendum |  |  |  |  |  |  | was named SRO Review SI SIT Settlement and Regression Overarching Exit Report |
| 1597 | SI SIT Functional Testing Test Exit Report Approved | 2025-08-20 → 2025-08-15 (-5d) | 2025-08-20 → 2025-08-15 (-5d) |  |  | 13d → 15d | 1594, SITWG Review status of SI SIT Settlement and Regression Overarching Exit Report, 1573 → 1594, 1570 | constraint start no earlier than 2025-08-20 → finish no earlier than 2025-08-15 |
| 1599 | eSITAG Approves SI SIT Functional & Migration (Post-Regression) Overarching Test Exit Report | 2025-08-20 → 2025-08-15 (-5d) | 2025-08-20 → 2025-08-15 (-5d) |  |  | 12d → 615d | 1594, SITWG Review status of SI SIT Settlement and Regression Overarching Exit Report, 1573 → 1594, 1570, 1583 | was named SITAG Approves SI SIT Functional & Migration (Post-Regression) Overarching Test Exit Report; constraint finish no earlier than 2025-08-20 → start no earlier than 2025-08-15 |
| 1600 | **SIT Migration Testing** |  | 2025-08-20 → 2025-08-22 (+2d) | 378d? → 380d? |  | 611d → 609d |  |  |
| 1602 | **SIT Migration Testing Execution** |  | 2025-08-20 → 2025-08-22 (+2d) | 378d? → 380d? |  | 611d → 609d |  |  |
| 1627 | **SIT Migration Regression Testing (code freeze)** | 2025-06-16 → 2025-06-30 (+14d) | 2025-08-08 → 2025-08-22 (+14d) |  |  | 619d → 609d |  |  |
| 1628 | Regression Test Execution Start | 2025-06-16 → 2025-06-30 (+14d) | 2025-06-16 → 2025-06-30 (+14d) |  |  | 619d → 609d |  |  |
| 1629 | Regression Execution | 2025-06-16 → 2025-06-30 (+14d) | 2025-06-20 → 2025-07-04 (+14d) |  |  | 619d → 609d |  |  |
| 1630 | Regression Sprint 1 | 2025-06-23 → 2025-07-07 (+14d) | 2025-07-04 → 2025-07-18 (+14d) |  |  | 619d → 609d |  |  |
| 1631 | Regression Sprint 2 | 2025-07-07 → 2025-07-21 (+14d) | 2025-07-18 → 2025-08-01 (+14d) |  |  | 619d → 609d |  |  |
| 1632 | Regression Sprint 3 | 2025-07-21 → 2025-08-04 (+14d) | 2025-08-01 → 2025-08-15 (+14d) |  |  | 619d → 609d |  |  |
| 1633 | Regression Contingency Week | 2025-08-04 → 2025-08-18 (+14d) | 2025-08-08 → 2025-08-22 (+14d) |  |  | 619d → 609d |  |  |
| 1634 | SIT Migration Testing End (incl. confirmation that PPs have submitted their Test Completion Reports to Programme for assurance) | 2025-08-08 → 2025-08-22 (+14d) | 2025-08-08 → 2025-08-22 (+14d) |  |  | 619d → 609d |  |  |
| 1643 | **SIT Settlement and Regression Test Exit Report** | 2025-06-30 → 2025-07-07 (+7d) |  | 38d → 33d |  | 25d → 45d |  |  |
| 1644 | Programme drafts Settlement and Regression PP Exit Report (when Participant completes Regression testing) | 2025-06-30 → 2025-07-07 (+7d) | 2025-08-08 → 2025-08-15 (+7d) |  |  | 619d → 614d |  |  |
| 1645 | All Settlement and Regression PP Exit Reports shared with PPs | 2025-08-08 → 2025-08-15 (+7d) | 2025-08-08 → 2025-08-15 (+7d) |  |  | 619d → 614d |  |  |
| 1654 | **SIT Non-Functional Testing (all SIT PPs)** |  | 2025-07-16 → 2025-08-06 (+21d) | 98d? → 112d? | 55% → 68% | 636d → 622d |  |  |
| 1660 | **SIT Non-Functional Testing Test Exit Report (all SIT PPs)** | 2025-05-26 A | 2025-07-16 → 2025-08-06 (+21d) | 38d → 52d | 0% → 43% | 57d → 622d |  |  |
| 1661 | Programme drafts Non-Functional PP Exit Report | 2025-05-26 A | 2025-06-13 → 2025-06-27 A (+14d) | 15d → 25d | 0% → 100% | 659d → none |  | baseline finish 2025-06-13 → 2025-06-27 |
| 1662 | Non-Functional PP Exit Reports shared with PPs | 2025-06-13 → 2025-06-27 A (+14d) | 2025-06-13 → 2025-06-27 A (+14d) |  | 0% → 100% | 659d → none |  | baseline start 2025-06-13 → 2025-06-27; baseline finish 2025-06-13 → 2025-06-27 |
| 1663 | PPs review Exit Report and Sign PP Exit Declaration | 2025-06-16 → 2025-06-27 A (+11d) | 2025-06-27 → 2025-07-11 (+14d) | 10d → 11d | 0% → 27% | 649d → 639d |  | was named PPs complete and return PP Exit Reports; constraint finish no earlier than 2025-06-27 → start no earlier than 2025-06-27; baseline start 2025-06-16 → 2025-06-27; baseline finish 2025-06-27 → 2025-07-11 |
| 1664 | PPs Exit Report submission deadline | 2025-06-27 → 2025-07-11 (+14d) | 2025-06-27 → 2025-07-11 (+14d) |  |  | 649d → 639d | 1663 → none | constraint none → finish no earlier than 2025-07-11; baseline start 2025-06-27 → 2025-07-11; baseline finish 2025-06-27 → 2025-07-11 |
| 1665 | Programme drafts SI SIT Non-Functional Overarching Exit Report | 2025-06-16 → 2025-06-27 A (+11d) | 2025-07-04 → 2025-07-18 (+14d) | 15d → 16d | 0% → 19% | 42d → 25d | 1663SS → 1655, 1656, 1657, 1658, 1659 | baseline start 2025-06-16 → 2025-06-27; baseline finish 2025-07-04 → 2025-07-18 |
| 1666 | Draft of SI SIT Non-Functional Overarching Exit Report available for SRO review | 2025-06-23 → 2025-07-07 (+14d) | 2025-06-27 → 2025-07-11 (+14d) |  |  | 649d → 634d |  | was named SRO Review SI SIT Non-Functional Overarching Exit Report; constraint start no earlier than 2025-06-23 → start no earlier than 2025-07-07; baseline start 2025-06-23 → 2025-07-07; baseline finish 2025-06-27 → 2025-07-11 |
| 1668 | SITWG Review status of SI SIT Non-Functional Overarching Exit Report | 2025-07-03 → 2025-07-18 (+15d) | 2025-07-03 → 2025-07-18 (+15d) |  |  | 646d → 25d | none → 1665 | baseline start 2025-07-03 → 2025-07-18; baseline finish 2025-07-03 → 2025-07-18 |
| 1671 | SIT Non-Functional Testing Test Exit Report (all SIT PPs) Approved | 2025-07-16 → 2025-08-06 (+21d) | 2025-07-16 → 2025-08-06 (+21d) |  |  | 37d → 23d | 1665FS+3d → 1665FS+3d, 1670 | constraint finish no earlier than 2025-07-16 → start no earlier than 2025-08-06; baseline start 2025-07-16 → 2025-08-06; baseline finish 2025-07-16 → 2025-08-06 |
| 1672 | SITAG Approves SI SIT Non-Functional Overarching Test Exit Report | 2025-07-16 → 2025-08-06 (+21d) | 2025-07-16 → 2025-08-06 (+21d) |  |  | 38d → 23d | 1665FS+3d → 1665FS+3d, 1671 | baseline start 2025-07-16 → 2025-08-06; baseline finish 2025-07-16 → 2025-08-06 |
| 1673 | **SIT Operational Testing (all SIT PPs)** |  | 2025-08-06 → 2025-08-29 (+23d) | 133d? → 150d? | 58% → 60% | 621d → 604d |  |  |
| 1677 | **SIT B Testing** |  |  |  | 86% → 89% |  |  |  |
| 1679 | SIT Operational Testing Execution Theme 1 |  | 2025-07-04 A |  | 95% → 100% | 644d → none |  |  |
| 1687 | **SIT Operational Testing Test Exit Report (all SIT PPs)** | 2025-06-02 → 2025-06-23 A (+21d) | 2025-08-06 → 2025-08-29 (+23d) | 48d → 50d? | 0% → 7% | 37d → 604d |  |  |
| 1688 | Programme drafts Pathway 2 PP Exit Report (when Participant completes Operational testing) | 2025-06-02 → 2025-06-30 (+28d) | 2025-07-11 → 2025-07-18 (+7d) | 30d → 15d |  | 37d → 604d | 1679SS → 1679SS, 1680SS | was named Programme drafts PP Exit Report (when Participant completes Operational testing); constraint start no earlier than 2025-06-02 → start no earlier than 2025-06-30; baseline start 2025-06-02 → 2025-06-30; baseline finish 2025-07-11 → 2025-07-18 |
| 1689 | All Pathway 2 Operational Exit Reports and Exit Declarations shared with PPs | 2025-07-11 → 2025-07-21 (+10d) | 2025-07-11 → 2025-07-21 (+10d) |  |  | 639d → 633d | 1688 → 1688FS+1d | was named All Operational Completion PP Exit Reports have been shared with PPs; baseline start 2025-07-11 → 2025-07-21; baseline finish 2025-07-11 → 2025-07-21 |
| 1690 | Pathway 2 PPs have reviewed Exit Report and signed Exit Declaration | 2025-06-13 → 2025-07-21 (+38d) |  | 31d → 5d |  | 28d → 629d | 1688SS → 1688 | was named PPs complete and return PP Exit Reports; baseline start 2025-06-13 → 2025-07-21 |
| 1695 | PPs Exit Report submission deadline | 2025-06-24 → 2025-08-18 (+55d) | 2025-06-24 → 2025-08-18 (+55d) | 0d → 1d? |  | 648d → 613d | 1579 → 1694 | constraint start no earlier than 2025-06-06 → none; baseline start 2025-06-06 → 2025-08-18; baseline finish 2025-06-06 → 2025-08-18 |
| 1697 | Programme drafts SI SIT Operational Overarching Exit Report | 2025-06-23 A |  |  | 0% → 23% | 22d → 621d | 1690SS → none |  |
| 1699 | eSITWG Review SI SIT Operational Overarching Exit Report | 2025-07-03 → 2025-08-01 (+29d) | 2025-07-03 → 2025-08-01 (+29d) |  |  | 646d → 614d |  | was named SITWG Review status of SI SIT Operational Overarching Exit Report; constraint start no earlier than 2025-07-03 → finish no earlier than 2025-08-01; baseline start 2025-07-03 → 2025-08-01; baseline finish 2025-07-03 → 2025-08-01 |
| 1701 | SIT Operational Testing Test Exit Report (all SIT PPs) Approved | 2025-08-06 → 2025-08-15 (+9d) | 2025-08-06 → 2025-08-15 (+9d) |  |  | 22d → 614d |  | constraint none → finish no earlier than 2025-08-15; baseline start 2025-08-06 → 2025-08-15; baseline finish 2025-08-06 → 2025-08-15 |
| 1702 | eSITAG Approves SI SIT Operational Testing Test Exit Report | 2025-08-06 → 2025-08-15 (+9d) | 2025-08-06 → 2025-08-15 (+9d) |  |  | 22d → 614d |  | was named SITAG Approves SI SIT Operational Testing Test Exit Report; constraint start no earlier than 2025-08-06 → finish no earlier than 2025-08-15; baseline start 2025-08-06 → 2025-08-15; baseline finish 2025-08-06 → 2025-08-15 |

| ID | Task | Start | Finish | Duration | Complete | Total float | Predecessors | Other |
| --- | --- | --- | --- | --- | --- | --- | --- | --- |
| 1703 | SIT Complete (SIT Test Exit Report Approved) |  |  |  |  |  | 1500, 1597, 1671, 1701, 1651, 1702, 1672, 1599 → 1500, 1671, 1651, 1672, 1596, 1597 |  |
| 1704 | **SIT (Contingency)** | 2025-06-13 → 2025-06-27 (+14d) | 2025-11-26 → 2025-12-10 (+14d) |  |  | 541d → 531d |  |  |
| 1705 | **SIT Functional Testing (Contingency)** | 2025-06-13 → 2025-06-27 (+14d) | 2025-11-13 → 2025-11-27 (+14d) |  |  | 541d → 531d |  |  |
| 1706 | **SIT Functional Testing Execution (Contingency)** | 2025-06-13 → 2025-06-27 (+14d) | 2025-10-23 → 2025-11-06 (+14d) |  |  | 541d → 531d |  |  |
| 1707 | Test Execution (Cycle 3 Completion and Regression Testing) | 2025-06-13 → 2025-06-27 (+14d) | 2025-10-23 → 2025-11-06 (+14d) |  |  | 541d → 531d |  |  |
| 1708 | SIT Functional Testing End (Contingency) (incl. confirmation that PPs have submitted their Test Exit Reports to Programme for assurance) | 2025-10-23 → 2025-11-06 (+14d) | 2025-10-23 → 2025-11-06 (+14d) |  |  | 541d → 531d |  |  |
| 1709 | Assurance of PPs Test Exit Reports | 2025-10-31 → 2025-11-14 (+14d) | 2025-11-06 → 2025-11-20 (+14d) |  |  | 541d → 531d |  |  |
| 1710 | **SIT Functional Testing Test Completion Report (Contingency)** | 2025-10-03 → 2025-10-17 (+14d) | 2025-11-06 → 2025-11-20 (+14d) |  |  | 541d → 531d |  |  |
| 1711 | Develop document | 2025-10-03 → 2025-10-17 (+14d) | 2025-10-23 → 2025-11-06 (+14d) |  |  | 546d → 536d |  |  |
| 1712 | Review & agree document | 2025-10-31 → 2025-11-14 (+14d) | 2025-11-06 → 2025-11-20 (+14d) |  |  | 541d → 531d |  |  |
| 1713 | SIT Functional Testing Test Exit Report (Contingency) Approved | 2025-11-13 → 2025-11-27 (+14d) | 2025-11-13 → 2025-11-27 (+14d) |  |  | 541d → 531d |  |  |
| 1714 | **SIT Migration Testing (Contingency)** | 2025-06-13 → 2025-06-27 (+14d) | 2025-11-13 → 2025-11-27 (+14d) |  |  | 541d → 531d |  |  |
| 1715 | Test Execution (Cycle 3 Completion and Regression Testing) | 2025-06-13 → 2025-06-27 (+14d) | 2025-10-23 → 2025-11-06 (+14d) |  |  | 541d → 531d |  |  |
| 1716 | SIT Migration Testing End (Contingency) (incl. confirmation that PPs have submitted their Test Exit Reports to Programme for assurance) | 2025-10-23 → 2025-11-06 (+14d) | 2025-10-23 → 2025-11-06 (+14d) |  |  | 541d → 531d |  |  |
| 1717 | Assurance of PPs Test Exit Reports | 2025-10-31 → 2025-11-14 (+14d) | 2025-11-06 → 2025-11-20 (+14d) |  |  | 541d → 531d |  |  |
| 1718 | **SIT Migration Testing Test Completion Report (Contingency)** | 2025-10-03 → 2025-10-17 (+14d) | 2025-11-06 → 2025-11-20 (+14d) |  |  | 541d → 531d |  |  |
| 1719 | Develop document | 2025-10-03 → 2025-10-17 (+14d) | 2025-10-23 → 2025-11-06 (+14d) |  |  | 546d → 536d |  |  |
| 1720 | Review & agree document | 2025-10-31 → 2025-11-14 (+14d) | 2025-11-06 → 2025-11-20 (+14d) |  |  | 541d → 531d |  |  |
| 1721 | SIT Migration Testing Test Exit Report (Contingency) Approved | 2025-11-13 → 2025-11-27 (+14d) | 2025-11-13 → 2025-11-27 (+14d) |  |  | 541d → 531d |  |  |
| 1722 | **SIT Contingency Test Exit Report** | 2025-10-24 → 2025-11-07 (+14d) | 2025-11-20 → 2025-12-04 (+14d) |  |  | 541d → 531d |  |  |
| 1723 | Develop document | 2025-10-24 → 2025-11-07 (+14d) | 2025-11-13 → 2025-11-27 (+14d) |  |  | 541d → 531d |  |  |
| 1724 | Review & agree document | 2025-11-14 → 2025-11-28 (+14d) | 2025-11-20 → 2025-12-04 (+14d) |  |  | 541d → 531d |  |  |
| 1725 | SIT Contingency Complete | 2025-11-26 → 2025-12-10 (+14d) | 2025-11-26 → 2025-12-10 (+14d) |  |  | 541d → 531d |  |  |
| 1726 | **UIT Environment Preparation** |  | 2025-06-19 → 2026-08-28 (+435d) | 689d → 1000d | 54% → 50% | 655d → 344d |  |  |
| 1727 | **Test Artefact Development** |  | 2025-06-19 A |  | 99% → 100% | 655d → none |  |  |
| 1728 | **E2E Sandbox Guidance** |  | 2025-06-19 A |  | 99% → 100% | 655d → none |  |  |
| 1739 | E2E Sandbox guidance update approved at QAG | 2025-06-19 A | 2025-06-19 A |  | 0% → 100% | 655d → none |  |  |
| 1740 | **E2E Sandbox Test Data Approach & Plan** |  | 2025-06-19 A |  | 99% → 100% | 656d → none |  |  |
| 1756 | E2E Sandbox Test Data Approach and Plan Approved at QAG | 2025-06-19 A | 2025-06-19 A |  | 0% → 100% | 656d → none |  |  |
| 1763 | **Environments (UIT)** |  |  |  | 50% → 51% |  |  |  |
| 1770 | **SI Environments (UIT)** |  | 2024-09-30 A |  | 99% → 100% | 843d → none |  |  |
| 1772 | Assure Central Parties' self-declaration of environment preparation complete (incl. security certificates and security compliance) |  | 2024-08-23 A |  | 97% → 100% | 869d → none |  |  |
| 1776 | Coordinate Central Parties' UIT environment Regression Testing | 2024-07-31 A | 2024-07-31 A |  | 0% → 100% | 886d → none |  |  |
| 1783 | **Onboarding and Test Data (Sandbox UIT)** | 2024-08-26 A | 2024-10-04 → 2026-08-28 (+693d) | 30d → 525d | 0% → 2% | 819d → 344d |  | was named Test Data |
| 1811 | **SIT PPs Early Sandbox Testing Execution (SIT-A)** | 2025-07-21 → 2025-08-08 (+18d) | 2025-10-24 → 2025-11-13 (+20d) |  |  | 564d → 550d |  |  |
| 1812 | SIT PPs E2E Sandbox Testing Start | 2025-07-21 → 2025-08-08 (+18d) | 2025-07-21 → 2025-08-08 (+18d) |  |  | 634d → 619d |  |  |
| 1813 | SIT PPs E2E Sandbox Testing Execution | 2025-07-21 → 2025-08-08 (+18d) | 2025-10-24 → 2025-11-13 (+20d) |  |  | 564d → 550d |  |  |
| 1814 | SIT PPs E2E Sandbox Testing End | 2025-10-24 → 2025-11-13 (+20d) | 2025-10-24 → 2025-11-13 (+20d) |  |  | 564d → 550d |  |  |
| 1815 | **Sandbox Testing Execution (UIT) - LDSO Participants** | 2025-06-02 A → 2025-05-26 A (-7d) |  | 169d → 174d |  |  |  |  |
| 1817 | Sandbox Testing Start (UIT) - LDSO Participants |  |  |  |  |  | 1809 → 1809, 1816 |  |
| 1820 | **Sandbox Testing Execution (UIT) - Supplier & Agent Participants** | 2025-09-01 → 2025-08-25 (-7d) |  | 260d → 265d |  |  |  |  |
| 1822 | Sandbox Testing Start (UIT) - Supplier & Agent Participants |  |  |  |  |  | 1703, 2736FS+5d, 1809 → 1703, 2736FS+5d, 1809, 1821 |  |
| 1851 | M10 Checkpoint 2 Complete | 2025-07-02 A | 2025-07-02 A |  | 0% → 100% | 646d → none |  |  |
| 2014 | **HELIX / ELEXON M10 READINESS** |  |  |  | 47% → 53% |  |  |  |
| 2015 | **Service Management - M10 Readiness** |  |  |  | 25% → 31% |  |  |  |
| 2016 | **Service Model Design (Cross Party Service Desk)** |  | 2025-07-18 → 2025-08-13 (+26d) | 100d → 118d | 92% → 86% | 634d → 616d |  |  |
| 2032 | **Service Documentation** |  | 2025-07-18 → 2025-08-13 (+26d) | 59d → 77d | 72% → 79% | 634d → 616d |  |  |
| 2033 | Operations Manual Updates Post-Consultation |  |  |  |  |  |  | was named Operations Manual and LLSD Updates Post-Consultation |
| 2034 | Operations Manual Version 1.3 (TORWG) |  |  |  |  |  |  | was named Operations Manual Version 1.3 |
| 2035 | Operations Manual Updates Pre-ORT | 2025-06-04 A → 2025-05-16 A (-19d) |  | 0d → 14d |  |  | none → 2034 | was named ORT version of LLSD SOM CPSD; constraint start no earlier than 2025-06-04 → start no earlier than 2025-05-16 |
| 2036 | Operations Manual version 1.4 (ORT) (TORWG Paper Day) | 2025-06-11 A → 2025-06-04 A (-7d) | 2025-06-11 A → 2025-06-04 A (-7d) |  |  |  | 2035FS+5d → none | was named Operations Manual version 1.4 (ORT) brought to TORWG; constraint start no earlier than 2025-06-11 → start no earlier than 2025-06-04 |
| 2046 | Post-ORT Operations Manual and LLSD Updates |  | 2025-07-18 → 2025-07-16 (-2d) | 5d → 3d |  | 634d → 616d | Service User LLSD Version 1.2, 2034 → 2034, 2089 |  |
| 2047 | M10 Operations Manual Version 2.0 & LLSD Issued for Consultation | 2025-07-18 → 2025-07-16 (-2d) | 2025-07-18 → 2025-07-16 (-2d) |  |  | 634d → 616d |  | was named M10 Operations Manual Version 2.0 & LLSD ORT Learning |
| 2055 | **Operational Readiness Testing** |  |  |  | 62% → 66% | 569d → 571d |  |  |
| 2087 | **ORT Execution** |  |  |  | 10% → 55% | 590d → 592d |  |  |
| 2088 | ORT Execution |  |  |  | 10% → 55% | 590d → 592d |  |  |
| 2114 | **Business Readiness (inc DIP)** |  |  |  | 46% → 49% |  |  |  |
| 2116 | Elexon Leading Triage |  |  |  | 4% → 20% |  |  |  |
| 2117 | MHHS Transition (Knowledge Transfer) |  |  |  | 48% → 56% |  |  |  |
| 2119 | Operational Control Centre (OCC) Development |  |  |  | 61% → 72% |  |  |  |
| 2121 | Operational Control Centre (OCC) Live | 2025-08-04 → 2025-08-29 (+25d) | 2025-08-04 → 2025-08-29 (+25d) |  |  | -83d → 604d | 2119FS+1d → none | constraint none → finish no earlier than 2025-08-29; baseline start 2025-08-04 → 2025-08-29; baseline finish 2025-08-04 → 2025-08-29 |
| 2134 | **Service Activation Readiness** |  |  |  | 45% → 49% |  |  |  |
| 2135 | **Phase 1 - Preparation** |  | 2025-09-26 → 2025-08-29 (-28d) | 389d? → 369d? | 79% → 85% | 584d → 604d |  |  |
| 2155 | **Operational Training for Service Activation** |  |  |  | 31% → 43% |  |  |  |
| 2156 | Training Execution [Placeholder] |  |  |  | 31% → 43% |  |  |  |
| 2163 | **Service Activation Go / No Go** | 2025-08-13 → 2025-08-22 (+9d) |  | 7d → 1d |  | -89d → -96d |  |  |
| 2164 | **Final Service Activation Go/No Go Decision** | 2025-08-13 → 2025-08-22 (+9d) |  | 7d → 1d |  | -89d → -96d |  |  |
| 2165 | DIP Team Ready | 2025-08-13 → 2025-08-22 (+9d) | 2025-08-13 → 2025-08-22 (+9d) |  |  | 616d → 609d | 2162, 2160 → 2162FS+7d, 2160 | baseline start 2025-08-13 → 2025-08-22; baseline finish 2025-08-13 → 2025-08-22 |
| 2171 | **SOLR Consultation** |  | 2025-09-26 → 2025-08-26 (-31d) | 122d → 99d | 8% → 67% | 584d → 607d |  |  |
| 2174 | **SOLR consultation** | 2025-08-27 → 2025-04-10 (-139d) | 2025-09-26 → 2025-07-31 (-57d) | 23d → 81d |  | 584d → none | 2186SF → none | constraint finish no earlier than 2025-09-26 → none; baseline start 2025-08-27 → 2025-04-10; baseline finish 2025-09-26 → 2025-07-31 |

| ID | Task | Start | Finish | Duration | Complete | Total float | Predecessors | Other |
| --- | --- | --- | --- | --- | --- | --- | --- | --- |
| 2186 | Service Activation Go / No Go |  |  |  |  |  | 2166FF, 2167FF, 2168FF, 2169FF, 2121FF, 2170FF, 2414, 2415 → 2166FF, 2167FF, 2168FF, 2169FF, 2120FF, 2170FF, 2414, 2415 |  |
| 2187 | **Phase 2 - Implementation** |  |  |  | 14% → 19% |  |  |  |
| 2215 | 1st ISD Publish (7 day window for this activity is consistent with Code requirements) |  |  |  |  |  |  | was named 1st ISD Publish |
| 2217 | M10-Ready Service Activation Implementation Completed |  |  |  |  |  | 2208, 2207, 2209, 2271, 2212, 2215, 2216 → 2208, 2207, 2209, 2210, 2212, 2215, 2216 |  |
| 2226 | **Non-SIT LDSO & SIT Service Activation Hypercare (M10 Ready)** |  |  |  |  |  |  | was named Non-SIT LDSO & SIT MVC Service Activation Hypercare (M10 Ready) |
| 2232 | **DIP Guidance Notes** |  |  |  | 58% → 67% |  |  |  |
| 2233 | GN/LWI creation & publication |  |  |  | 58% → 67% |  |  |  |
| 2234 | Tranche 1 GN/LWI created & published (critical for M10) | 2025-06-20 A | 2025-06-20 A |  | 0% → 100% | 655d → none |  |  |
| 2238 | Functional Training Execution |  |  |  | 27% → 44% |  |  |  |
| 2239 | **Operational Readiness E2E Testing** |  |  |  | 6% → 34% |  |  |  |
| 2240 | Phase 1 Test Execution (Service Activation and Participant Management) |  | 2025-06-27 → 2025-07-11 (+14d) | 34d → 44d | 10% → 40% | 649d → 639d |  |  |
| 2241 | Phase 2 Test Execution (S&I) |  |  |  | 5% → 40% |  |  |  |
| 2242 | Phase 3 Test Execution (Assurance & mop-up) | 2025-06-23 → 2025-06-26 (+3d) | 2025-07-18 → 2025-07-11 (-7d) | 20d → 12d |  | 634d → 639d |  | constraint start no earlier than 2025-06-23 → start no earlier than 2025-06-26 |
| 2254 | **M11-Ready Service Activation Implementation** | 2025-10-15 → 2025-09-25 (-20d) |  | 6d? → 19d? |  |  |  |  |
| 2256 | PAB Approval Completed | 2025-10-15 → 2025-09-25 (-20d) | 2025-10-15 → 2025-09-25 (-20d) |  |  | 569d → 585d |  |  |
| 2257 | MHHSP Enabled Confirmation | 2025-10-15 → 2025-09-25 (-20d) | 2025-10-15 → 2025-09-25 (-20d) |  |  | 569d → 579d |  | constraint start no earlier than 2025-09-08 → start no earlier than 2025-09-25 |
| 2258 | Add EFD (ISD Calendar Date) to DIP | 2025-10-16 → 2025-09-25 (-21d) | 2025-10-16 → 2025-09-25 (-21d) | 1d → 0d |  | 569d → 584d | 2249, 2250, 2257, 2256 → 2257 | constraint start no earlier than 2025-10-15 → none |
| 2259 | DIP Promoted to Production | 2025-10-17 → 2025-09-26 (-21d) | 2025-10-17 → 2025-09-26 (-21d) |  |  | 569d → 584d |  |  |
| 2260 | Create M16 in Customer Solution | 2025-10-16 → 2025-09-25 (-21d) | 2025-10-16 → 2025-09-25 (-21d) | 1d → 0d |  | 569d → 584d | none → 2257 | constraint start no earlier than 2025-10-16 → none |
| 2261 | DIP Production Success Checks | 2025-10-17 → 2025-09-26 (-21d) | 2025-10-17 → 2025-09-26 (-21d) |  |  | 569d → 584d |  |  |
| 2262 | Publish ISD | 2025-10-15 → 2025-09-26 (-19d) | 2025-10-22 → 2025-10-03 (-19d) |  |  | 566d → 579d | none → 2257 | constraint start no earlier than 2025-10-15 → start no earlier than 2025-09-26 |
| 2263 | Go Live ISD | 2025-10-22 → 2025-10-03 (-19d) | 2025-10-22 → 2025-10-03 (-19d) |  |  | 566d → 579d |  | constraint start no earlier than 2025-10-17 → none |
| 2265 | MDD Go Live | 2022-11-04 → 2025-10-03 (+1064d) | 2022-11-04 → 2025-10-03 (+1064d) |  |  | 1339d → 579d | MDD Publish → 2264 | baseline start none → 2025-10-03; baseline finish none → 2025-10-03 |
| 2266 | Pathway 4 Service Activation Implementation Completed | 2025-10-22 → 2025-10-03 (-19d) | 2025-10-22 → 2025-10-03 (-19d) |  |  | 566d → 579d | 2257, 2256, 2258, 2259, 2260, 2263 → 2258, 2259, 2260, 2263, 2265 | was named M11-Ready Service Activation Implementation Completed |
| 2269 | MHHSP Enabled Confirmation | 2022-10-31 → 2025-10-15 (+1080d) | 2022-10-31 → 2025-10-15 (+1080d) |  |  | 1338d → 566d | none → 2510 | constraint none → start no earlier than 2025-09-08; baseline start none → 2025-10-15; baseline finish none → 2025-10-15 |
| 2271 | DIP Promoted to Production | 2025-09-12 → 2025-10-16 (+34d) | 2025-09-12 → 2025-10-16 (+34d) |  |  | 594d → 570d | 2209 → 2270 | baseline start 2025-09-12 → 2025-10-17; baseline finish 2025-09-12 → 2025-10-17 |
| 2272 | Create M16 in Customer Solution | 2022-10-31 → 2025-10-16 (+1081d) | 2022-10-31 → 2025-10-16 (+1081d) | 1d → 0d |  | 1343d → 570d | none → 2269 | constraint none → start no earlier than 2025-10-16; baseline start none → 2025-10-16; baseline finish none → 2025-10-16 |
| 2273 | DIP Production Success Checks | 2022-11-01 → 2025-10-16 (+1080d) | 2022-11-09 → 2025-10-16 (+1072d) | 7d → 1d? |  | 1336d → 570d | Business Readiness Governance Approval → 2270, 2272 | baseline start none → 2025-10-17; baseline finish none → 2025-10-17 |
| 2274 | Publish ISD | 2022-10-31 → 2025-10-16 (+1081d) | 2022-11-04 → 2025-10-22 (+1083d) |  |  | 1339d → 566d | PAB ApprovalSS → 2269 | constraint none → start no earlier than 2025-10-15; baseline start none → 2025-10-15; baseline finish none → 2025-10-22 |
| 2275 | Go Live ISD | 2022-11-04 → 2025-10-22 (+1083d) | 2022-11-04 → 2025-10-22 (+1083d) |  |  | 1339d → 566d |  | constraint none → start no earlier than 2025-10-17; baseline start none → 2025-10-22; baseline finish none → 2025-10-22 |
| 2280 | MDD Final Circular Completed |  |  |  |  |  | 2257 → 2257, 2269 |  |
| 2292 | **Not M11-Ready Service Activation Preparation Tasks** | 2025-12-01 → 2025-10-13 (-49d) |  | 9d? → 44d? |  | 528d → 530d |  |  |
| 2297 | Engagement / Communications with Participants | 2025-12-04 → 2025-10-16 (-49d) | 2025-12-04 → 2025-10-16 (-49d) |  |  | 535d → 570d |  | constraint start no earlier than 2025-08-29 → start no earlier than 2025-10-16 |
| 2298 | Validate User Access | 2025-12-08 → 2025-10-13 (-56d) | 2025-12-08 → 2025-10-13 (-56d) |  |  | 524d → 573d |  | constraint start no earlier than 2025-12-08 → start no earlier than 2025-10-13 |
| 2303 | **Not M11-Ready Service Activation Implementation** | 2025-12-17 → 2025-10-30 (-48d) | 2025-12-31 → 2025-12-30 (-1d) | 10d → 43d? |  | 516d → 517d |  | was named Not M11-Ready (Inlcuding Non-SIT LDSOs) Service Activation Implementation |
| 2306 | MHHSP Enabled Confirmation | 2025-12-17 → 2025-10-30 (-48d) | 2025-12-17 → 2025-10-30 (-48d) |  |  | 517d → 553d | 2520 → 2518, 2520 |  |
| 2307 | Add EFD (ISD Calendar Date) to DIP | 2025-12-18 → 2025-10-30 (-49d) | 2025-12-19 → 2025-10-30 (-50d) | 2d → 0d |  | 517d → 559d | 2298, 2299, 2301, 2306, 2305 → 2306, 2305 |  |
| 2308 | DIP Promoted to Production | 2025-12-22 → 2025-10-31 (-52d) | 2025-12-22 → 2025-10-31 (-52d) |  |  | 523d → 559d |  |  |
| 2309 | Create M16 in Customer Solution | 2025-12-22 → 2025-12-19 (-3d) | 2025-12-22 → 2025-12-19 (-3d) | 1d → 0d |  | 516d → 524d |  |  |
| 2310 | DIP Production Success Checks |  | 2025-12-31 → 2025-12-23 (-8d) | 7d → 1d? |  | 516d → 522d |  |  |
| 2311 | Publish ISD | 2025-12-22 → 2025-10-31 (-52d) | 2025-12-26 → 2025-11-07 (-49d) | 5d → 6d |  | 516d → 554d | 2307SS → 2306, 2307SS | constraint start no earlier than 2025-12-22 → none |
| 2312 | Go Live ISD | 2025-12-26 → 2025-11-07 (-49d) | 2025-12-26 → 2025-11-07 (-49d) |  |  | 519d → 554d |  |  |
| 2315 | Service Activation Implementation Completed | 2025-12-31 → 2025-11-07 (-54d) | 2025-12-31 → 2025-11-07 (-54d) |  |  | 517d → 554d | 2306, 2305, 2307, 2308, 2309, 2311, 2312 → 2312, 2314, 2307, 2308, 2309, 2311 | was named Not M11-Ready Service Activation Implementation Completed; constraint start no earlier than 2025-12-31 → none |
| 2327 | MDD Final Circular |  |  |  |  |  | 2306 → 2306, 2317 |  |
| 2339 | **Helix Solution Build** |  | 2025-08-07 → 2025-08-08 (+1d) | 254d? → 255d? | 75% → 87% | 620d → 619d |  |  |
| 2340 | M10 Build Candidate |  | 2025-07-16 → 2025-07-08 (-8d) | 58d → 52d | 64% → 71% | 634d → 619d |  |  |
| 2341 | Helix Code Uplifts (TBC) | 2025-07-17 → 2025-07-09 (-8d) | 2025-07-18 → 2025-08-08 (+21d) | 2d → 23d |  | 634d → 619d |  | constraint finish no earlier than 2025-07-16 → start no earlier than 2025-07-09; baseline start 2025-07-17 → 2025-07-09; baseline finish 2025-07-18 → 2025-08-08 |
| 2342 | **Helix E2E Settlement Assurance Testing (SAT)** |  |  |  | 87% → 93% |  |  |  |
| 2351 | **Execution** |  |  |  | 69% → 84% |  |  |  |
| 2356 | **SAT Cycle 1** |  |  |  | 68% → 91% |  |  |  |
| 2357 | **Legacy** |  | 2025-06-25 A |  | 87% → 100% | 651d → none |  |  |
| 2361 | Long |  | 2025-06-13 A |  | 88% → 100% | 659d → none |  |  |
| 2365 | NESO Validation Period (Long) |  | 2025-06-20 A |  | 40% → 100% | 654d → none |  |  |
| 2366 | BST |  | 2025-06-18 A |  | 61% → 100% | 656d → none |  |  |
| 2367 | P0210 file shared for NESO Validation | 2025-06-18 A | 2025-06-18 A |  | 0% → 100% | 656d → none |  |  |
| 2368 | NESO Validation Period (BST) | 2025-06-19 A | 2025-06-25 A |  | 0% → 100% | 651d → none |  |  |
| 2369 | Trading Dispute |  | 2025-06-20 A |  | 24% → 100% | 654d → none |  |  |
| 2370 | **Transition** |  |  |  | 27% → 71% |  |  |  |
| 2371 | GMT |  |  |  | 74% → 96% |  |  |  |
| 2373 | NESO Validation Period (GMT) | 2025-06-17 A | 2025-06-23 A |  | 0% → 100% | 653d → none |  |  |
| 2374 | Long |  |  |  | 18% → 82% | 644d → 649d |  |  |
| 2375 | P0210 file shared for NESO Validation | 2025-06-27 A | 2025-06-27 A |  | 0% → 100% | 644d → none |  |  |
| 2376 | NESO Validation Period (Long) | 2025-06-30 A | 2025-07-04 A |  | 0% → 100% | 644d → none |  |  |
| 2377 | BST | 2025-06-26 A |  |  | 0% → 82% | 642d → 647d |  |  |
| 2378 | P0210 file shared for NESO Validation | 2025-07-01 A | 2025-07-01 A |  | 0% → 100% | 642d → none |  |  |
| 2379 | NESO Validation Period (BST) | 2025-07-03 A |  |  | 0% → 50% |  |  |  |
| 2380 | Short | 2025-07-01 A |  |  | 0% → 49% |  |  |  |
| 2381 | P0210 file shared for NESO Validation | 2025-07-03 A |  |  | 0% → 25% |  |  |  |
| 2385 | Data Agg | 2025-07-04 A |  |  | 0% → 25% |  |  |  |
| 2386 | M16 | 2025-07-14 A | 2025-07-16 A |  | 0% → 100% | 636d → none |  |  |

| ID | Task | Start | Finish | Duration | Complete | Total float | Predecessors | Other |
| --- | --- | --- | --- | --- | --- | --- | --- | --- |
| 2400 | DR Testing | 2025-04-28 A | 2025-06-06 → 2025-06-27 (+21d) | 30d → 45d | 0% → 93% | 664d → 649d |  |  |
| 2401 | Pen Testing | 2025-04-28 A | 2025-06-20 A |  | 0% → 100% | 654d → none |  |  |
| 2402 | Production Environment Build |  |  |  |  |  |  | was named Post Environment Build |
| 2403 | Production Environment Base Platform Sign-off | 2025-07-31 → 2025-08-08 (+8d) | 2025-07-31 → 2025-08-08 (+8d) |  |  | -91d → -97d |  | constraint start no earlier than 2025-07-31 → finish no earlier than 2025-08-08 |
| 2404 | **Implementation (Helix & DIP)** |  |  |  | 28% → 40% |  |  |  |
| 2405 | Go / No-Go (DIP & SM) |  |  |  |  | 591d → 592d | none → 2110, 2124, 2125, 2126 |  |
| 2406 | Implementation Readiness (inc Technical Readiness, Approach and Runbook, Walkthrough / Rehearsals |  | 2025-07-31 → 2025-08-04 (+4d) | 69d → 71d | 46% → 59% | 625d → 623d |  |  |
| 2407 | M10 Implementation Approach & Go-Live Runbook |  | 2025-06-13 → 2025-06-30 (+17d) | 35d → 46d |  | 659d → 648d |  |  |
| 2408 | DIP Production Build | 2025-06-09 A |  |  | 0% → 80% |  |  |  |
| 2409 | Final Production Deployment |  | 2025-08-01 → 2025-07-31 (-1d) | 20d → 19d |  | 588d → 591d |  |  |
| 2410 | DIP Portal Available |  |  |  |  | 588d → 590d | 2409FS+1d → 2409 | constraint none → finish no earlier than 2025-08-04 |
| 2411 | DIP Technical Onboarding for LDSOs | 2025-08-05 → 2025-08-04 (-1d) | 2025-09-22 → 2025-09-18 (-4d) | 35d → 34d |  | 588d → 590d | 2409, 2410, 2112, 2405 → 2409, 2410FS-1d, 2112FS-1d, 2405 |  |
| 2413 | Go / No-Go (Helix Central Systems) | 2025-08-11 → 2025-08-08 (-3d) | 2025-08-11 → 2025-08-08 (-3d) |  |  |  | 2399, 1573, 2403 → 2399, 2403, 1570 | constraint start no earlier than 2025-08-11 → finish no earlier than 2025-08-08 |
| 2417 | Dual Run (Pre-Prod) | 2025-08-26 → 2025-08-27 (+1d) | 2025-09-15 → 2025-09-17 (+2d) | 15d → 16d |  |  |  | constraint none → start no earlier than 2025-08-27 |
| 2418 | M10 Cutover Weekend (20/09 and 21/09) |  | 2025-09-19 → 2025-09-22 (+3d) | 1d → 2d |  | 8d → 7d | 2417FS+3d → 2417 | constraint none → start no earlier than 2025-09-19 |
| 2419 | Post Implementation Review |  |  |  |  |  | 2418FS+10d → 2418FS+9d | constraint none → start no earlier than 2025-10-06 |
| 2420 | **S & A QUALIFICATION** |  |  |  | 65% → 66% |  |  |  |
| 2494 | **SIT / LDSO Pathway 2** |  |  |  |  |  | none → 1588 |  |
| 2497 | **SIT / LDSO Pathway 3** |  |  |  |  |  | none → 1591 |  |
| 2518 | REC Code Manager / BSC PAB Approval of Qualification (first Pathway 6 PAB) |  |  |  |  | 560d → 553d |  | was named REC Code Manager / BSC PAB Approval of Qualification |
| 2520 | REC Code Manager / BSC PAB Approval of Qualification (final Pathway 6 PAB) |  |  |  |  |  |  | was named REC Code Manager / BSC PAB Approval of Qualification |
| 2522 | **MHHS Qualification - Non-SIT LDSO (M10-Ready)** |  |  |  | 71% → 74% |  |  |  |
| 2531 | Completion of Code Bodies review of the Final QAD |  | 2025-06-20 A |  | 85% → 100% | 596d → none |  |  |
| 2532 | QAD Finalisation | 2025-06-23 A |  |  | 0% → 4% |  |  |  |
| 2535 | **MHHS Qualification - Qualification Waves** |  |  |  | 59% → 60% |  |  |  |
| 2716 | **Qualification Wave 1** |  |  |  | 11% → 14% |  |  |  |
| 2717 | **Qualification Wave 1 QAD Prep** |  |  |  | 40% → 46% |  |  |  |
| 2719 | Qualification Wave 1 Participants Submit Initial QAD |  |  |  | 64% → 74% |  |  |  |
| 2723 | **Qualification Wave 1 Test Prep** |  |  |  | 15% → 22% |  |  |  |
| 2725 | Qualification Wave 1 Participants DIP Onboarding Window |  |  |  | 49% → 63% |  |  |  |
| 2727 | Qualification Wave 1 Participants' to provide status of PIT completion and submit QT Test Plan | 2025-06-16 → 2025-07-14 (+28d) | 2025-06-16 → 2025-07-14 (+28d) |  |  | 658d → 639d |  | constraint finish no earlier than 2025-06-16 → start no earlier than 2025-07-14; baseline start 2025-06-16 → 2025-07-14; baseline finish 2025-06-16 → 2025-07-14 |
| 2728 | Review of Participants' PIT Status and QT Test Plan |  |  |  | 4% → 16% |  |  | baseline finish 2025-07-04 → 2025-08-15 |
| 2729 | Qualification Test Plans for Wave 1 Participants approved |  |  |  |  |  |  | baseline start 2025-07-04 → 2025-08-15; baseline finish 2025-07-04 → 2025-08-15 |
| 2746 | **Qualification Wave 2** |  |  |  | 2% → 3% |  |  |  |
| 2747 | **Qualification Wave 2 QAD Prep** |  |  |  | 7% → 13% |  |  |  |
| 2749 | Qualification Wave 2 Participants Submit Initial QAD |  |  |  | 10% → 17% |  |  |  |
| 2849 | PAB297 | 2025-06-26 A | 2025-06-26 A |  | 0% → 100% | 651d → none |  |  |
| 2995 | Send to Ofgem for SCR Direction | 2025-06-25 A | 2025-06-25 A |  | 0% → 100% | 651d → none |  |  |
| 2996 | Freeze M8 Change Control Log 1.0 and create V2.0 | 2025-07-02 A | 2025-07-02 A |  | 0% → 100% | 646d → none |  |  |
| 2997 | Agree Fast Track Code Change Process | 2025-07-02 A | 2025-07-02 A |  | 0% → 100% | 646d → none |  |  |
| 2998 | Ofgem direct SCR Code change | 2025-07-03 A | 2025-07-03 A |  | 0% → 100% | 645d → none |  |  |
| 3012 | **MIGRATION** |  |  |  | 67% → 70% |  |  |  |
| 3069 | **MCC Stood up** |  |  |  | 54% → 59% |  |  |  |
| 3070 | Migration Planning Management Tool Delivery |  |  |  | 57% → 59% |  |  |  |
| 3071 | **MCC Operational** |  |  |  | 0% → 47% |  |  |  |
| 3072 | **MCC Dress Rehersal 1 - Initialise Schedule (Weekly) Drop 1, 2** |  |  |  | 0% → 47% |  |  |  |
| 3079 | Supplier Schedule Submission #2 complete | 2025-06-20 A | 2025-06-20 A |  | 0% → 100% | 638d → none |  |  |
| 3080 | Consolidate baseline schedule | 2025-06-23 A |  |  | 0% → 47% |  |  |  |
| 3086 | MCAG approval of Baseline Migration schedule |  |  |  |  |  |  | baseline start none → 2025-07-22; baseline finish none → 2025-07-22 |
| 3099 | **Migration Artefact Development and Publication** |  |  |  | 77% → 81% |  |  |  |
| 3142 | **Data Cleanse Plan** |  |  |  | 97% → 98% |  |  |  |
| 3147 | **MTDs** |  |  |  | 91% → 95% |  |  |  |
| 3154 | **Meter Location and Number of Displayed Register Digits** |  |  |  | 84% → 91% |  |  |  |
| 3158 | Suppliers complete Work Off plans |  |  |  | 81% → 89% |  |  |  |
| 3173 | **Connection Type and Meter Type Misalignments** |  |  |  | 53% → 62% |  |  |  |
| 3174 | **Traditional Meters installed on Current Transformers** |  |  |  | 20% → 30% |  |  |  |
| 3177 | Suppliers to have ensured that Meter Operators have sent the necessary D0312s for MPANs in pot 2 |  | 2025-06-30 A |  | 57% → 100% | 648d → none |  |  |
| 3178 | LDSOs will be required to have corrected all of these Connection Types in pot 3 |  | 2025-07-25 A |  | 30% → 100% | 629d → none |  |  |
| 3179 | Suppliers to have completed meter exchanges for those MPANs in pot 1 |  |  |  | 3% → 6% |  |  |  |
| 3186 | **Smart Meter Types installed on CT Connection Types** |  |  |  | 69% → 80% |  |  |  |
| 3190 | Suppliers resolve all issues |  |  |  | 30% → 55% |  |  |  |
| 3192 | **Linked Import / Export MPANs** |  |  |  | 73% → 83% |  |  |  |
| 3193 | LDSOs review and correct linked Import / Export MPANs with Different Connection Types |  |  |  | 73% → 83% |  |  |  |
| 3194 | LDSOs, Import and Export Suppliers review and correct linked Import / Export MPANs with meters in the Advanced and Traditional or Smart Meter Groups |  |  |  | 73% → 83% |  |  |  |
| 3196 | **Related MPANs** |  |  |  | 73% → 83% |  |  |  |
| 3197 | LDSOs review and correct related MPANs with different Connection Types |  | 2025-06-20 A |  | 96% → 100% | 629d → none |  |  |
| 3198 | Suppliers unrelate any MPANs required | 2025-06-23 A |  |  | 0% → 28% |  |  |  |
| 3199 | Suppliers should investigate Related MPANs within different meter groups and verify that they are correct or request that their Meter Operators update the Meter Types where they are incorrect |  |  |  | 73% → 83% |  |  |  |
| 3231 | **Preparation for Cutover to Live** | 2022-10-31 A → 2024-06-28 A (+606d) |  | 1178d → 744d | 24% → 27% |  |  |  |
| 3232 | **Central Systems Prepare for Cutover to Live** |  |  |  | 65% → 74% |  |  |  |

| ID | Task | Start | Finish | Duration | Complete | Total float | Predecessors | Other |
| --- | --- | --- | --- | --- | --- | --- | --- | --- |
| 3234 | **Development of Comms Approach and Declaration Guidance** |  |  |  | 63% → 80% |  |  |  |
| 3235 | Draft Cutover Comms Approach |  |  |  | 63% → 80% |  |  |  |
| 3238 | **Development of Cutover Plan requirements with Participants** |  |  |  | 66% → 73% |  |  |  |
| 3240 | Development of Programme Participant Cutover Plans |  | 2025-06-30 → 2025-07-11 (+11d) | 57d → 66d | 84% → 80% | 67d → 28d |  | constraint finish no earlier than 2025-06-27 → finish no earlier than 2025-07-11; baseline finish 2025-06-30 → 2025-07-11 |
| 3242 | Consolidated MHHS Cutover Plan Developed |  | 2025-06-27 A |  | 73% → 100% | 649d → none |  |  |
| 3243 | LDSO Cutover Plan Assurance | 2025-06-30 → 2025-07-14 (+14d) | 2025-07-18 → 2025-08-01 (+14d) |  |  | 634d → 624d | 3240FF → 3240 |  |
| 3244 | SIT Supplier and SIT Agent Cutover Plan Assurance | 2025-06-30 → 2025-07-14 (+14d) |  | 40d → 30d |  |  | 3240FF → 3240 |  |
| 3290 | **Migration Sprints** | 2022-10-31 → 2025-09-25 (+1060d) |  | 1178d → 420d |  |  |  |  |
| 3297 | Sprint Execution Start |  |  |  |  |  |  | constraint none → start no earlier than 2025-10-22 |
| 3309 | **Migration Sprint 2** | 2022-10-31 → 2026-03-04 (+1220d) |  | 937d → 65d |  |  |  |  |
| 3317 | Non-SIT Participants Migration Start | 2022-10-31 → 2026-05-15 (+1292d) | 2022-10-31 → 2026-05-15 (+1292d) |  |  | 1344d → 419d |  | constraint none → finish no earlier than 2026-05-15 |
| 3395 | **BUSINESS & OPERATIONAL READINESS** |  |  |  | 35% → 36% |  |  |  |
| 3396 | **Service Management** |  |  |  | 21% → 22% |  |  |  |
| 3613 | **READINESS ASSESSMENTS** |  |  |  | 33% → 46% |  |  |  |
| 3621 | **Readiness Assessment 5 / 6 - Start of Qualification and Participant Readiness for M10 and M11 and CP3/CP4 check** |  |  |  | 46% → 96% |  |  |  |
| 3624 | Analyse survey responses |  |  |  | 43% → 95% |  |  |  |
| 3625 | Conduct deep-dive interviews (sample of PPs) |  |  |  | 43% → 95% |  |  |  |
| 3626 | Produce Readiness Assessment Reports (Overall Report & Individual Participant Reports) | 2025-06-09 A |  |  | 0% → 95% |  |  |  |

## Version 13 (data date 2025-07-16, saved 2025-07-16, file MHHS-DEL1139 - MHHS Plan v6.29.mpp)

Last finish stays 2027-12-23. Complete tasks 1978 → 2022.

Added:

| ID | Task | Duration | Start | Finish | Predecessors | Constraint |
| --- | --- | --- | --- | --- | --- | --- |
| 1571 | Cycle 1 SAT Regression | 10d | 2025-07-21 | 2025-08-01 | 1570SS, 2283 |  |
| 1572 | Cycle 2 SAT Regression | 5d | 2025-08-04 | 2025-08-08 | 1570SS, 2293 | start no earlier than 2025-08-04 |
| 1663 | Programme drafts Pathway 4 PP Exit Report (when Participant completes Operational testing) | 10d | 2025-08-04 | 2025-08-15 | 1668 |  |
| 1664 | All Pathway 4 Operational Exit Reports and Exit Declarations shared with PPs | 0d | 2025-08-15 | 2025-08-15 | 1663 |  |
| 1665 | Pathway 4 PPs have reviewed Exit Report and signed Exit Declaration | 5d | 2025-08-18 | 2025-08-22 | 1664 |  |
| 1995 | **LDSO Onboarding** | 28d | 2025-06-23 A | 2025-07-30 |  |  |
| 1996 | LDSO Communication and Information Gathering | 18d | 2025-06-23 A | 2025-07-16 |  | start no earlier than 2025-06-23 |
| 1997 | LDSO ServiceNow Configuration | 10d | 2025-07-10 A | 2025-07-23 | 1996SS+13d |  |
| 1998 | LDSO Testing and Further Communication | 6d | 2025-07-23 | 2025-07-30 | 1997SS+9d |  |
| 1999 | LDSOs Onboarded | 0d | 2025-07-30 | 2025-07-30 | 1998 |  |
| 2119 | SOLR consultation | 81d? | 2025-04-10 A | 2025-07-31 |  | start no earlier than 2025-04-10 |
| 2984 | Kestrel Webinar 1 | 0d | 2025-07-14 A | 2025-07-14 A | 2983 |  |

Removed: 1573 Regression Contingency Week; 1574 SIT Functional Testing End; 1587 All Settlement and Regression Pathway 2 PP Exit Reports shared with PPs; 1593 Pathway 3 PPs Exit Report and Regression Exit Decleration submission deadline; 1598 SI SIT Migration Testing End (incl. confirmation that PPs have submitted their Test Exit Reports to Programme for assurance); 1627 SIT Migration Regression Testing (code freeze); 1628 Regression Test Execution Start; 1629 Regression Execution; 1630 Regression Sprint 1; 1631 Regression Sprint 2; 1632 Regression Sprint 3; 1633 Regression Contingency Week; 1634 SIT Migration Testing End (incl. confirmation that PPs have submitted their Test Completion Reports to Programme for assurance); 1635 SIT Functional & Migration Test Exit Report; 1636 Programme drafts Functional & Migration PP Exit Report; 1637 SRO Review PP Exit Reports; 1638 Functional & Migration PP Exit Reports shared with PPs; 1639 PPs complete and return Exit Reports; 1640 PPs Exit Report submission deadline; 1641 Programme drafts SI SIT Functional & Migration Overarching Exit Report; 1642 SITWG Review status of Functional & Migration Overarching Completion Report; 1643 SIT Settlement and Regression Test Exit Report; 1644 Programme drafts Settlement and Regression PP Exit Report (when Participant completes Regression testing); 1645 All Settlement and Regression PP Exit Reports shared with PPs; 1646 PPs complete and return PP Exit Reports; 1647 PPs Exit Report and Regression Exit Deceleration submission deadline; 1648 Programme drafts SI SIT Settlement and Regression Overarching Exit Report; 1649 SRO Review SI SIT Settlement and Regression Overarching Exit Report; 1650 SITWG Review status of SI SIT Settlement and Regression Overarching Exit Report; 1651 SIT Migration Testing Test Exit Report Approved; 1652 SIT Migration Testing End (incl. confirmation that PPs have submitted their Test Exit Reports to Programme for assurance); 1653 SITAG Approves SI SIT Functional & Migration (Post-Regression) Overarching Test Exit Report; 1664 PPs Exit Report submission deadline; 1691 PPs Exit Report submission deadline; 1695 PPs Exit Report submission deadline; 1777 E2E Sandbox Participants (UIT); 1778 E2E Sandbox Participants environment preparation (incl. security certificates and security compliance); 1779 Submit self-declaration of environment preparation complete (incl. security certificates and security compliance) to Programme for assurance; 1780 E2E Sandbox Participants UIT environment connectivity proving; 1781 Deployment of MHHS solution code to UIT environments; 1782 Coordinate E2E Sandbox Participants' UIT environment preparation (for E2E Sandbox Testing Start); 1786 Central Parties (for E2E Sandbox & Qualification); 1787 Central Parties' UIT environment test data loading & verification (& data cleansing, if required); 1788 Submit self-declaration to Programme to confirm loading & verification of test data; 1789 E2E Sandbox Participants; 1790 UIT environment test data loading and verification (and data cleansing, if required) (for E2E Sandbox Testing Start); 1791 SI Test Data; 1792 Coordinate Central Parties' UIT environment test data loading and verification (and data cleansing, if required); 1793 Assure evidence of Central Parties' UIT environment test data load and verification; 1794 Coordinate E2E Sandbox Participants' UIT environment test data loading and verification (and data cleansing, if required) (for E2E Sandbox Testing Start); 1795 Other Preparation; 1796 SI Other Preparation; 1797 Onboarding of UIT E2E Sandbox Participants to Test Management Tool for E2E Sandbox Testing Start (onboarding of participants will be ongoing hereafter); 1798 Other Preparation (for Central Parties & E2E Sandbox Participants); 1799 Test Management Tool onboarding for E2E Sandbox Testing Start (onboarding will be ongoing hereafter); 1800 Other Preparation (incl. test execution planning); 1801 UIT E2E Sandbox Test Readiness Report; 1802 Central Parties E2E Sandbox Test Readiness Report; 1803 Develop draft Test Readiness Report and submit to Programme for assurance; 1804 Finalise Test Readiness Report and submit to Programme for assurance; 1805 SI E2E Sandbox Test Readiness Report; 1806 Assure Central Parties' E2E Sandbox Test Readiness Reports; 1807 Develop Overarching E2E Sandbox Test Readiness Report; 1808 Artefact review (via SITAG) and updates; 1809 UIT E2E Sandbox Preparation Complete; 2111 Registration of LDSOs into ServiceNow; 2207 PAB Approval Completed; 2218 Non-SIT LDSO Service Activation Data Loading Completed; 2225 Non-SIT LDSO & SIT MVC Service Activation Implementation MDD Completed; 2232 DIP Guidance Notes; 2233 GN/LWI creation & publication; 2234 Tranche 1 GN/LWI created & published (critical for M10); 2235 Tranche 2 GN/LWI created & published; 2236 Tranche 3 GN/LWI created & published; 2237 DIP Reporting (M11); 2238 Functional Training Execution; 2239 Operational Readiness E2E Testing; 2240 Phase 1 Test Execution (Service Activation and Participant Management); 2241 Phase 2 Test Execution (S&I); 2242 Phase 3 Test Execution (Assurance & mop-up); 2243 E2E Operational Testing Completed; 2245 Identify Resources; 2246 Agree & Understand Support Model; 2247 Confirm Training complete; 2250 Target Systems and Environments Ready; 2251 Provide LWIs; 2252 Business Readiness Governance Approval; 2256 PAB Approval Completed; 2259 DIP Promoted to Production; 2264 Publish MDD; 2265 MDD Go Live; 2268 PAB Approval Completed; 2271 DIP Promoted to Production; 2279 M11-Ready Service Activation Implementation MDD; 2280 MDD Final Circular Completed; 2281 MDD Manual Update; 2282 MDD Publish; 2283 MDD Go Live; 2284 M11-Ready Service Activation Implementation MDD Completed; 2293 Review Entry / Exit Criteria & Lessons Learned; 2294 Identify Resources; 2295 Agree & Understand Support Model; 2296 Confirm Training complete; 2299 Target Systems and Environments Ready; 2300 Provide LWIs; 2301 Business Readiness Governance Approval; 2302 Not M11-Ready Participants Service Activation Preparation Completed; 2305 PAB Approval Completed; 2308 DIP Promoted to Production; 2326 Not M11-Ready Service Activation Implementation MDD; 2327 MDD Final Circular; 2328 MDD Manual Update; 2329 MDD Publish; 2330 MDD Go Live; 2331 Non-SIT LDSO & SIT MVC Service Activation Implementation MDD Completed; 3068 Q+A documents from sessions published

Changed:

| ID | Task | Start | Finish | Duration | Complete | Total float | Predecessors | Other |
| --- | --- | --- | --- | --- | --- | --- | --- | --- |
| 1 | **PROGRAMME PLAN.** |  |  |  | 69% → 72% |  |  |  |
| 509 | **SYSTEMS INTEGRATION TESTING (SIT)** |  |  |  | 77% → 90% |  |  |  |
| 1484 | **SIT Execution** |  | 2025-12-10 → 2025-11-27 (-13d) | 553d? → 544d? | 65% → 73% | 531d → 540d |  |  |
| 1501 | **SIT** |  |  |  | 72% → 83% |  |  |  |
| 1502 | **SIT Functional Testing (MVC)** |  |  |  | 78% → 81% |  |  |  |
| 1541 | **SIT Functional Settlement Testing** |  |  |  | 62% → 66% |  |  |  |
| 1566 | **SIT Functional & Migration Regression Testing (code freeze)** |  | 2025-09-19 → 2025-09-12 (-7d) | 60d? → 55d? | 3% → 17% | 589d → 594d |  |  |
| 1568 | Regression Execution |  | 2025-07-04 A |  | 40% → 100% | -97d → none |  |  |
| 1569 | Regression Sprint 1 | 2025-07-07 A |  |  | 0% → 70% |  |  |  |
| 1575 | **SIT Functional & Migration Overarching Exit Report** |  |  |  | 84% → 96% |  |  |  |
| 1581 | SRO/Code Bodies Review SI SIT Funcational & Migration Overarching Exit Report |  | 2025-07-02 A |  | 50% → 100% | 636d → none |  |  |
| 1582 | SITWG Review status of SI SIT Functional & Migration Overarching Exit Report | 2025-07-03 A | 2025-07-03 A |  | 0% → 100% | 635d → none |  |  |
| 1583 | SI SIT Functional & Migration Overarching Exit Report Industry Review | 2025-07-04 A |  |  | 0% → 70% |  |  |  |
| 1584 | **SIT Settlement and Regression Test Exit Report** | 2025-07-07 A |  |  | 0% → 7% | 30d → 589d |  |  |
| 1585 | Programme drafts Settlement and Regression Pathway 2 PP Exit Reports | 2025-07-07 A |  |  | 0% → 46% | 616d → 631d |  |  |
| 1597 | **SIT Migration Testing** |  | 2025-08-22 → 2025-04-25 A (-119d) | 380d? → 295d? | 71% → 100% | 609d → none |  |  |
| 1599 | **SIT Migration Testing Execution** |  | 2025-08-22 → 2025-04-25 A (-119d) | 380d? → 295d? | 71% → 100% | 609d → none |  |  |
| 1624 | **SIT Non-Functional Testing (all SIT PPs)** |  |  |  | 68% → 87% |  |  |  |
| 1630 | **SIT Non-Functional Testing Test Exit Report (all SIT PPs)** |  |  |  | 43% → 77% |  |  |  |
| 1633 | PPs review Exit Report and Sign PP Exit Declaration |  |  |  | 27% → 75% |  |  |  |
| 1634 | Programme drafts SI SIT Non-Functional Overarching Exit Report |  | 2025-07-18 A |  | 19% → 100% | 25d → none |  |  |
| 1635 | Draft of SI SIT Non-Functional Overarching Exit Report available for SRO review | 2025-07-07 A | 2025-07-11 A |  | 0% → 100% | 634d → none |  |  |
| 1636 | SRO / Code Bodies / DIP Manager formal review SI SIT Non-Functional Overarching Exit Report | 2025-07-14 A |  |  | 0% → 20% |  |  |  |
| 1637 | eSITWG Review status of SI SIT Non-Functional Overarching Exit Report |  |  |  |  | 25d → 43d |  | was named SITWG Review status of SI SIT Non-Functional Overarching Exit Report |
| 1641 | eSITAG Approves SI SIT Non-Functional Overarching Test Exit Report |  |  |  |  | 23d → 41d |  | was named SITAG Approves SI SIT Non-Functional Overarching Test Exit Report |
| 1642 | **SIT Operational Testing (all SIT PPs)** |  |  |  | 60% → 69% |  |  |  |
| 1646 | **SIT B Testing** |  | 2025-07-04 A |  | 89% → 100% | 644d → none |  |  |
| 1649 | SIT Operational Testing Execution Theme 2 |  | 2025-07-04 A |  | 90% → 100% | 644d → none |  |  |
| 1650 | SIT Operational Testing Execution Theme 3 Batch 2 |  | 2025-07-04 A |  | 35% → 100% | 644d → none |  |  |
| 1655 | SIT Operational Testing End (all SIT PPs) (incl. confirmation that PPs have submitted their Test Completion Reports to Programme for assurance) | 2025-07-04 A | 2025-07-04 A |  | 0% → 100% | 644d → none |  |  |
| 1656 | **SIT Operational Testing Test Exit Report (all SIT PPs)** |  |  | 50d? → 50d | 7% → 20% |  |  |  |
| 1657 | Programme drafts Pathway 2 PP Exit Report (when Participant completes Operational testing) | 2025-06-30 A |  |  | 0% → 80% | 604d → 3.75d |  |  |
| 1660 | Programme drafts Pathway 3 PP Exit Report (when Participant completes Operational testing) | 2025-07-21 A |  |  | 0% → 25% |  |  |  |
| 1666 | Programme drafts Pathway 5 & 6 PP Exit Report (when Participant completes Operational testing) |  |  |  |  |  |  | was named Programme drafts Pathway 4, 5 & 6 PP Exit Report (when Participant completes Operational testing) |
| 1673 | SIT Complete (SIT Test Exit Report Approved) |  |  |  |  | 10d → 28d | 1500, 1640, SIT Migration Testing Test Exit Report Approved, 1641, 1594, 1595 → 1500, 1640, 1641, 1594, 1595 |  |
| 1674 | **SIT (Contingency)** |  | 2025-12-10 → 2025-11-27 (-13d) | 119d? → 110d |  | 531d → 540d |  |  |
| 1675 | **SIT Functional Testing (Contingency)** |  | 2025-11-27 → 2025-11-14 (-13d) | 110d? → 101d |  | 531d → 540d |  |  |
| 1676 | **SIT Functional Testing Execution (Contingency)** |  | 2025-11-06 → 2025-10-24 (-13d) | 95d? → 86d |  | 531d → 540d |  |  |
| 1677 | Test Execution (Cycle 3 Completion and Regression Testing) |  | 2025-11-06 → 2025-10-24 (-13d) | 95d? → 86d |  | 531d → 540d |  |  |
| 1678 | SIT Functional Testing End (Contingency) (incl. confirmation that PPs have submitted their Test Exit Reports to Programme for assurance) | 2025-11-06 → 2025-10-24 (-13d) | 2025-11-06 → 2025-10-24 (-13d) |  |  | 531d → 540d |  |  |
| 1679 | Assurance of PPs Test Exit Reports | 2025-11-14 → 2025-11-03 (-11d) | 2025-11-20 → 2025-11-07 (-13d) |  |  | 531d → 540d |  |  |
| 1680 | **SIT Functional Testing Test Completion Report (Contingency)** | 2025-10-17 → 2025-10-06 (-11d) | 2025-11-20 → 2025-11-07 (-13d) |  |  | 531d → 540d |  |  |
| 1681 | Develop document | 2025-10-17 → 2025-10-06 (-11d) | 2025-11-06 → 2025-10-24 (-13d) |  |  | 536d → 545d |  |  |
| 1682 | Review & agree document | 2025-11-14 → 2025-11-03 (-11d) | 2025-11-20 → 2025-11-07 (-13d) |  |  | 531d → 540d |  |  |
| 1683 | SIT Functional Testing Test Exit Report (Contingency) Approved | 2025-11-27 → 2025-11-14 (-13d) | 2025-11-27 → 2025-11-14 (-13d) |  |  | 531d → 540d |  |  |
| 1684 | **SIT Migration Testing (Contingency)** |  | 2025-11-27 → 2025-11-14 (-13d) | 110d → 101d |  | 531d → 540d |  |  |
| 1685 | Test Execution (Cycle 3 Completion and Regression Testing) |  | 2025-11-06 → 2025-10-24 (-13d) | 95d → 86d |  | 531d → 540d |  |  |
| 1686 | SIT Migration Testing End (Contingency) (incl. confirmation that PPs have submitted their Test Exit Reports to Programme for assurance) | 2025-11-06 → 2025-10-24 (-13d) | 2025-11-06 → 2025-10-24 (-13d) |  |  | 531d → 540d |  |  |
| 1687 | Assurance of PPs Test Exit Reports | 2025-11-14 → 2025-11-03 (-11d) | 2025-11-20 → 2025-11-07 (-13d) |  |  | 531d → 540d |  |  |
| 1688 | **SIT Migration Testing Test Completion Report (Contingency)** | 2025-10-17 → 2025-10-06 (-11d) | 2025-11-20 → 2025-11-07 (-13d) |  |  | 531d → 540d |  |  |
| 1689 | Develop document | 2025-10-17 → 2025-10-06 (-11d) | 2025-11-06 → 2025-10-24 (-13d) |  |  | 536d → 545d |  |  |
| 1690 | Review & agree document | 2025-11-14 → 2025-11-03 (-11d) | 2025-11-20 → 2025-11-07 (-13d) |  |  | 531d → 540d |  |  |
| 1691 | SIT Migration Testing Test Exit Report (Contingency) Approved | 2025-11-27 → 2025-11-14 (-13d) | 2025-11-27 → 2025-11-14 (-13d) |  |  | 531d → 540d |  |  |
| 1692 | **SIT Contingency Test Exit Report** | 2025-11-07 → 2025-10-27 (-11d) | 2025-12-04 → 2025-11-21 (-13d) |  |  | 531d → 540d |  |  |
| 1693 | Develop document | 2025-11-07 → 2025-10-27 (-11d) | 2025-11-27 → 2025-11-14 (-13d) |  |  | 531d → 540d |  |  |
| 1694 | Review & agree document | 2025-11-28 → 2025-11-17 (-11d) | 2025-12-04 → 2025-11-21 (-13d) |  |  | 531d → 540d |  |  |
| 1695 | SIT Contingency Complete | 2025-12-10 → 2025-11-27 (-13d) | 2025-12-10 → 2025-11-27 (-13d) |  |  | 531d → 540d |  |  |
| 1696 | **UIT Environment Preparation** | 2022-10-31 A → 2022-11-16 A (+16d) |  | 1000d → 988d | 50% → 85% |  |  |  |
| 1733 | **Environments (UIT)** | 2022-10-31 A → 2022-11-16 A (+16d) | 2025-06-06 → 2024-09-30 A (-249d) | 680d → 489d | 51% → 100% | 664d → none |  |  |
| 1747 | **Onboarding and Test Data (Sandbox UIT)** | 2024-08-26 A → 2025-06-02 A (+280d) |  | 525d → 325d | 2% → 3% |  |  |  |
| 1750 | **Sandbox Execution** |  |  |  | 2% → 5% |  |  |  |
| 1751 | **SIT PPs Early Sandbox Testing Execution (SIT-A)** |  | 2025-11-13 → 2025-10-24 (-20d) | 70d → 56d |  | 550d → 564d |  |  |
| 1752 | SIT PPs E2E Sandbox Testing Start |  |  |  |  |  | UIT E2E Sandbox Preparation CompleteFS+5d, 1570 → 1570 |  |
| 1753 | SIT PPs E2E Sandbox Testing Execution |  | 2025-11-13 → 2025-10-24 (-20d) | 70d → 56d |  | 550d → 564d |  |  |
| 1754 | SIT PPs E2E Sandbox Testing End | 2025-11-13 → 2025-10-24 (-20d) | 2025-11-13 → 2025-10-24 (-20d) |  |  | 550d → 564d |  |  |
| 1755 | **Sandbox Testing Execution (UIT) - LDSO Participants** |  |  |  | 7% → 15% |  |  |  |
| 1757 | Sandbox Testing Start (UIT) - LDSO Participants |  |  |  |  |  | UIT E2E Sandbox Preparation Complete, 1756 → 1756 |  |
| 1758 | Sandbox Testing Execution (UIT) - LDSO Participants |  |  |  | 7% → 15% |  |  |  |
| 1760 | **Sandbox Testing Execution (UIT) - Supplier & Agent Participants** | 2025-08-25 → 2025-09-01 (+7d) |  | 265d → 260d |  |  |  |  |
| 1761 | UIT E2E Sandbox Preparation Complete - Supplier and Agent | 2025-08-25 → 2025-09-01 (+7d) | 2025-08-25 → 2025-09-01 (+7d) |  |  | 609d → 603d |  | constraint start no earlier than 2025-08-25 → finish no earlier than 2025-09-01 |

| ID | Task | Start | Finish | Duration | Complete | Total float | Predecessors | Other |
| --- | --- | --- | --- | --- | --- | --- | --- | --- |
| 1762 | Sandbox Testing Start (UIT) - Supplier & Agent Participants |  |  |  |  |  | 1673, 2632FS+5d, UIT E2E Sandbox Preparation Complete, 1761 → 1673, 2632FS+5d, 1761 |  |
| 1793 | End of SIT MVC testing |  |  |  |  |  | 1673 → none |  |
| 1813 | Central Programme Party Cutover Plans in place | 2025-07-15 A | 2025-07-15 A |  | 0% → 100% | 637d → none |  |  |
| 1825 | Central systems ready for migrating MPANs (M10) |  |  |  |  |  | 1673FS+18d, 3157, 3154, 3172, 3133, 3140, 2314 → 1673, 3157, 3154, 3172, 3133, 3140, 2314 |  |
| 1838 | **NON SIT LDSO QUALIFICATION** |  |  |  | 98% → 99% |  |  |  |
| 1898 | **Pre-Integration Testing** |  | 2025-01-31 A |  | 97% → 100% | 754d → none |  |  |
| 1903 | PIT Execution (Non-Functional and Operational) |  | 2025-01-31 A |  | 85% → 100% | 754d → none |  |  |
| 1905 | Non-SIT LDSO Participants have submitted non-functional PIT Test Completion Report | 2025-01-31 A | 2025-01-31 A |  | 0% → 100% | 754d → none |  |  |
| 1933 | **Test Window** |  |  |  | 94% → 97% |  |  |  |
| 1946 | Potential for non-SIT LDSO QT Regression for Qualification |  |  |  | 31% → 60% |  |  |  |
| 1954 | **HELIX / ELEXON M10 READINESS** |  |  |  | 53% → 61% |  |  |  |
| 1955 | **Service Management - M10 Readiness** |  |  |  | 31% → 33% |  |  |  |
| 1956 | **Service Model Design (Cross Party Service Desk)** |  |  |  | 86% → 82% |  |  |  |
| 1972 | **Service Documentation** |  |  |  | 79% → 82% |  |  |  |
| 1977 | Service User LLSD Updates Post Consultation |  |  |  |  |  |  | baseline start none → 2025-05-19; baseline finish none → 2025-06-04 |
| 1978 | Service User LLSD Version 1.2 (ORT) (TORWG Paper Day) |  |  |  |  |  |  | baseline start none → 2025-06-04; baseline finish none → 2025-06-04 |
| 1979 | CPSD Scenarios and Runbook |  |  |  |  |  |  | baseline start none → 2025-04-29; baseline finish none → 2025-05-23 |
| 1980 | CPSD Scenarios and Runbook Shared with MHHS Team for Review |  |  |  |  |  |  | baseline start none → 2025-05-23; baseline finish none → 2025-05-23 |
| 1981 | CPSD Scenarios and Runbook Review Window |  |  |  |  |  |  | baseline start none → 2025-05-26; baseline finish none → 2025-06-04 |
| 1982 | CPSD Scenarios and Runbook Released for TORWG (Paper Day) |  |  |  |  |  |  | baseline start none → 2025-06-04; baseline finish none → 2025-06-04 |
| 1983 | Parent/Child Industry Engagement Session |  |  |  |  |  |  | baseline start none → 2025-06-06; baseline finish none → 2025-06-06 |
| 1984 | CPSD Runbook Completed |  |  |  |  |  |  | baseline start none → 2025-06-11; baseline finish none → 2025-06-11 |
| 1985 | **Service Documentation V2** | 2025-07-14 A |  |  | 0% → 17% |  |  | baseline start none → 2025-07-14; baseline finish none → 2025-08-13 |
| 1986 | Post-ORT Operations Manual and LLSD Updates | 2025-07-14 A | 2025-07-16 A |  | 0% → 100% | 616d → none |  | baseline finish 2025-07-25 → 2025-07-16 |
| 1987 | M10 Operations Manual Version 2.0 & LLSD Issued for Consultation | 2025-07-16 A | 2025-07-16 A |  | 0% → 100% | 616d → none |  | baseline start 2025-07-25 → 2025-07-16; baseline finish 2025-07-25 → 2025-07-16 |
| 1988 | Operations Manual and LLSD v2 Consultation |  |  |  |  |  |  | baseline start none → 2025-07-17; baseline finish none → 2025-07-30 |
| 1989 | Operations Manual and LLSD v2 Consultation Completed |  |  |  |  |  |  | baseline start none → 2025-07-30; baseline finish none → 2025-07-30 |
| 1990 | Consultation Feedback Implemented Operations Manual and LLSD v2 |  |  |  |  |  |  | baseline start none → 2025-07-31; baseline finish none → 2025-08-06 |
| 1991 | Operations Manual and LLSD v2 Feedback Implemented |  |  |  |  |  |  | baseline start none → 2025-08-06; baseline finish none → 2025-08-06 |
| 1992 | TORWG Paper Day |  |  |  |  |  |  | baseline start none → 2025-08-06; baseline finish none → 2025-08-06 |
| 1993 | TORWG Operations Manual and LLSD v2 Approval |  |  |  |  |  |  | baseline start none → 2025-08-13; baseline finish none → 2025-08-13 |
| 1994 | Operations Manual and LLSD v2 Approved and Completed |  |  |  |  |  |  | baseline start none → 2025-08-13; baseline finish none → 2025-08-13 |
| 2000 | **Operational Readiness Testing** |  |  |  | 66% → 71% | 571d → 604d |  |  |
| 2032 | **ORT Execution** |  | 2025-07-11 A |  | 55% → 100% | 592d → none |  |  |
| 2033 | ORT Execution |  | 2025-07-11 A |  | 55% → 100% | 592d → none |  |  |
| 2034 | ORT Execution Completed | 2025-07-11 A | 2025-07-11 A |  | 0% → 100% | 592d → none |  |  |
| 2035 | **ORT Exit** | 2025-07-14 A |  |  | 0% → 13% | 592d → 625d |  |  |
| 2036 | ORT Wrap Up | 2025-07-14 A |  |  | 0% → 20% | 598d → 600d |  |  |
| 2037 | ORT Exit Report | 2025-07-14 A |  |  | 0% → 10% | 592d → 625d |  |  |
| 2039 | ORT eSITWG Exit Report Endorsement |  |  |  |  | 592d → 625d |  | was named ORT eSITAG Exit Report Endorsement |
| 2056 | Helix Service Management Live for LDSO DIP Onboarding |  |  |  |  | 590d → 591d | Registration of LDSOs into ServiceNow → 1999 |  |
| 2058 | **Business Readiness (inc DIP)** |  |  |  | 49% → 62% |  |  |  |
| 2060 | Elexon Leading Triage |  |  |  | 20% → 38% |  |  |  |
| 2061 | MHHS Transition (Knowledge Transfer) |  |  |  | 56% → 78% |  |  |  |
| 2063 | Operational Control Centre (OCC) Development |  |  |  | 72% → 84% |  |  |  |
| 2069 | Tranche 2 GN/LWI created & published | 2025-07-04 A | 2025-07-04 A |  | 0% → 100% | 611d → none |  |  |
| 2071 | DIP Reporting (M11) |  |  |  | 28% → 71% |  |  |  |
| 2072 | Functional Training Execution |  |  |  | 44% → 60% |  |  |  |
| 2073 | **Operational Readiness E2E Testing** |  |  |  | 34% → 76% |  |  |  |
| 2074 | Phase 1 Test Execution (Service Activation and Participant Management) |  |  |  | 37% → 92% | 633d → 634d |  |  |
| 2075 | Phase 2 Test Execution (S&I) |  | 2025-07-11 → 2025-07-18 (+7d) | 17d → 22d | 56% → 82% | 638d → 634d |  | baseline start 2025-06-10 → 2025-06-11; baseline finish 2025-07-18 → 2025-07-11 |
| 2076 | Phase 3 Test Execution (Assurance & mop-up) | 2025-07-02 → 2025-07-15 (+13d) | 2025-07-18 → 2025-07-30 (+12d) | 13d → 12d |  | 633d → 626d |  | constraint start no earlier than 2025-07-02 → start no earlier than 2025-07-15 |
| 2077 | E2E Operational Testing Completed | 2025-08-08 → 2025-07-30 (-9d) | 2025-08-08 → 2025-07-30 (-9d) | 1d → 0d |  | 619d → 626d |  | constraint finish no earlier than 2025-08-08 → none; baseline start 2025-08-08 → 2025-07-18; baseline finish 2025-08-08 → 2025-07-18 |
| 2078 | **Service Activation Readiness** |  |  |  | 49% → 56% |  |  |  |
| 2099 | **Operational Training for Service Activation** |  |  |  | 43% → 56% |  |  |  |
| 2100 | Training Execution [Placeholder] |  |  |  | 43% → 56% |  |  |  |
| 2115 | **SOLR Consultation** |  |  | 99d → 99d? | 67% → 77% |  |  |  |
| 2118 | **SOLR consultation** | 2025-04-10 A |  | 81d → 81d? | 0% → 78% |  |  |  |
| 2120 | LDSO Workshop | 2025-06-30 A | 2025-06-30 A |  | 0% → 100% | 649d → none |  |  |
| 2121 | GLIG | 2025-07-04 A | 2025-07-04 A |  | 0% → 100% | 645d → none |  |  |
| 2122 | QWG | 2025-07-08 A | 2025-07-08 A |  | 0% → 100% | 643d → none |  |  |
| 2125 | **MDR Process** |  |  |  | 58% → 60% |  |  |  |
| 2130 | MDR consultation ongoing actions |  |  |  | 48% → 50% |  |  |  |
| 2132 | **Phase 2 - Implementation** |  |  |  | 19% → 2% |  |  |  |
| 2151 | **M10-Ready (Inlcuding Non-SIT LDSOs) Service Activation Implementation** | 2025-08-06 → 2025-09-10 (+35d) |  | 31d? → 6d |  |  |  |  |
| 2153 | Add EFD (ISD Calendar Date) to DIP |  |  |  |  |  | 2145, 2146, 2149, 2152, PAB Approval Completed → 2145, 2146, 2149, 2152 |  |
| 2154 | Non-SIT LDSO PP DIP User Promoted to Production |  |  |  |  |  |  | was named Non-LDSO SIT PP DIP User Promoted to Production |
| 2157 | DIP Production Success Checks |  |  | 1d? → 1d |  |  |  |  |
| 2160 | Go Live ISD |  |  | 1d? → 1d |  |  |  |  |
| 2161 | M10-Ready Service Activation Implementation Completed |  |  |  |  |  | 2152, PAB Approval Completed, 2153, 2154, 2156, 2159, 2160 → 2152, 2153, 2154, 2156, 2159, 2160 |  |

| ID | Task | Start | Finish | Duration | Complete | Total float | Predecessors | Other |
| --- | --- | --- | --- | --- | --- | --- | --- | --- |
| 2162 | **M10-Ready Service Activation Implementation MDD** |  | 2025-09-19 → 2025-09-18 (-1d) | 7d → 6d |  | 589d → 590d |  |  |
| 2174 | **M11-Ready Activation Preparation Tasks** | 2025-10-06 → 2025-10-09 (+3d) | 2025-10-16 → 2025-10-13 (-3d) | 9d? → 3d |  | 570d → 573d |  |  |
| 2177 | M11-Ready Participants Service Activation Preparation Completed | 2025-10-16 → 2025-10-13 (-3d) | 2025-10-16 → 2025-10-13 (-3d) |  |  | 570d → 573d | Identify Resources, Agree & Understand Support Model, Confirm Training complete, 2175, 2176, Target Systems and Environments Ready, Business Readiness Governance Approval → 2175, 2176 |  |
| 2180 | MHHSP Enabled Confirmation |  |  |  |  |  | 2403, 2406 → 2403 |  |
| 2186 | Pathway 4 Service Activation Implementation Completed |  |  |  |  |  | 2181, DIP Promoted to Production, 2182, 2185, MDD Go Live → 2181, 2182, 2185 |  |
| 2196 | Pathway 5 Service Activation Implementation Completed |  |  |  |  |  | 2188, PAB Approval Completed, 2189, DIP Promoted to Production, 2190, 2193 → 2188, 2189, 2190, 2193 |  |
| 2204 | **Not M11-Ready Service Activation Preparation Tasks** |  | 2025-12-11 → 2025-10-16 (-56d) | 44d? → 4d |  | 530d → 570d |  |  |
| 2205 | Engagement / Communications with Participants |  |  |  |  |  | Confirm Training complete → none |  |
| 2209 | MHHSP Enabled Confirmation |  |  |  |  | 553d → 554d | 2414, 2416 → 2414 |  |
| 2210 | Add EFD (ISD Calendar Date) to DIP |  |  |  |  |  | 2209, PAB Approval Completed → 2209 |  |
| 2213 | Publish ISD |  |  |  |  |  | 2209, 2210SS → 2209 |  |
| 2217 | Service Activation Implementation Completed |  |  |  |  |  | 2214, 2216, 2210, DIP Promoted to Production, 2211, 2213 → 2214, 2216 |  |
| 2235 | **Helix Solution Build** |  |  |  | 87% → 91% |  |  |  |
| 2236 | M10 Build Candidate |  |  |  | 71% → 98% | 619d → 1.98d |  |  |
| 2237 | Helix Code Uplifts (TBC) | 2025-07-09 A | 2025-08-08 → 2025-08-01 (-7d) | 23d → 18d | 0% → 11% | 619d → 624d |  |  |
| 2238 | **Helix E2E Settlement Assurance Testing (SAT)** |  |  |  | 93% → 96% |  |  |  |
| 2247 | **Execution** |  |  |  | 84% → 91% |  |  |  |
| 2252 | **SAT Cycle 1** |  | 2025-07-16 A |  | 91% → 100% | 636d → none |  |  |
| 2266 | **Transition** |  | 2025-07-16 A |  | 71% → 100% | 636d → none |  |  |
| 2267 | GMT |  | 2025-06-23 A |  | 96% → 100% | 653d → none |  |  |
| 2270 | Long |  | 2025-06-27 A |  | 82% → 100% | 649d → none |  |  |
| 2273 | BST |  | 2025-07-01 A |  | 82% → 100% | 647d → none |  |  |
| 2275 | NESO Validation Period (BST) |  | 2025-07-09 A |  | 50% → 100% | 641d → none |  |  |
| 2276 | Short |  | 2025-07-03 → 2025-07-09 A (+6d) | 3d → 7d | 49% → 100% | 640d → none |  |  |
| 2277 | P0210 file shared for NESO Validation |  | 2025-07-03 A |  | 25% → 100% | 640d → none |  |  |
| 2278 | NESO Validation Period (Short) | 2025-07-04 → 2025-07-08 A (+4d) | 2025-07-10 → 2025-07-14 A (+4d) |  | 0% → 100% | 640d → none |  | constraint start no earlier than 2025-07-04 → start no earlier than 2025-07-08 |
| 2280 | ISD | 2025-07-01 A | 2025-07-03 A |  | 0% → 100% | 645d → none |  |  |
| 2281 | Data Agg |  | 2025-07-11 A |  | 25% → 100% | 639d → none |  |  |
| 2283 | End of Cycle 1 | 2025-07-16 A | 2025-07-16 A |  | 0% → 100% | 637d → none |  |  |
| 2296 | DR Testing |  | 2025-06-27 → 2025-07-31 (+34d) | 45d → 69d | 93% → 74% | 649d → 625d |  |  |
| 2298 | Production Environment Build | 2025-06-30 A |  |  | 0% → 25% | -91d → 0d |  |  |
| 2300 | **Implementation (Helix & DIP)** |  |  |  | 40% → 47% |  |  |  |
| 2302 | Implementation Readiness (inc Technical Readiness, Approach and Runbook, Walkthrough / Rehearsals |  |  |  | 59% → 72% |  |  |  |
| 2303 | M10 Implementation Approach & Go-Live Runbook |  | 2025-06-30 A |  | 91% → 100% | 648d → none |  |  |
| 2304 | DIP Production Build |  | 2025-06-27 A |  | 80% → 100% | 649d → none |  |  |
| 2305 | Final Production Deployment | 2025-07-07 A |  |  | 0% → 5% |  |  |  |
| 2308 | ISD Dress Rehearsals | 2025-07-07 A |  |  | 0% → 4% |  |  |  |
| 2316 | **S & A QUALIFICATION** |  |  |  | 66% → 67% |  |  |  |
| 2378 | **MHHS Qualification - SIT Participants** |  |  |  | 63% → 74% |  |  |  |
| 2388 | QAD Sign Off Deadline + Test Reports |  |  |  |  |  | 2386, Regression Sprint 1FF → 2386 |  |
| 2391 | QAD Sign Off Deadline + Test Reports |  |  |  |  |  | 2386, Regression Sprint 1FF → 2386 |  |
| 2394 | QAD Sign Off Deadline + Test Reports |  |  |  |  |  | 2386, 1673, Regression Sprint 1FF → 2386 | constraint none → finish no earlier than 2025-08-22 |
| 2395 | REC Code Manager / BSC PAB Approval of Qualification (M10-Ready) |  |  |  |  |  |  | constraint none → start no earlier than 2025-09-09 |
| 2396 | M10-Ready SIT Participants are qualified |  |  |  |  |  |  | constraint none → finish no earlier than 2025-09-10 |
| 2397 | **MHHS Qualification - M11-Ready** |  |  |  | 80% → 99% |  |  |  |
| 2400 | Completion of Code Bodies review of Final QAD (M11-Ready) |  | 2025-07-04 A |  | 35% → 100% | 622d → none |  |  |
| 2402 | QAD Sign Off Deadline + Test Reports |  |  |  |  |  | 2400, Regression Sprint 1FF → 2400 |  |
| 2405 | QAD Sign Off Deadline + Test Reports |  |  |  |  |  | 2400, Regression Sprint 1FF → 2400 |  |
| 2408 | **MHHS Qualification - Not M11-Ready** |  |  |  | 19% → 37% |  |  |  |
| 2410 | SIT Not M11-Ready Participants submit Final QAD |  |  |  | 24% → 47% |  |  |  |
| 2418 | **MHHS Qualification - Non-SIT LDSO (M10-Ready)** |  | 2025-09-10 → 2025-09-11 (+1d) | 178d → 179d | 74% → 97% | 596d → 595d |  |  |
| 2428 | QAD Finalisation |  | 2025-08-22 → 2025-08-19 (-3d) | 45d → 42d | 4% → 90% | 596d → 599d |  | baseline finish 2025-08-22 → 2025-08-19 |
| 2429 | QAD Sign Off Deadline (Non-SIT LDSOs) |  |  |  |  |  | 2427FS+5d, 1673, 1945, 2428 → 2427FS+5d, 1945, 2428 | constraint none → finish no earlier than 2025-08-22 |
| 2430 | BSC PAB & REC Manager approval of Qualification for Non-SIT LDSOs | 2025-09-10 → 2025-09-11 (+1d) | 2025-09-10 → 2025-09-11 (+1d) |  |  | 596d → 595d |  | constraint none → finish no earlier than 2025-09-11 |
| 2576 | **Wave 1 Test Data** |  |  |  | 0% → 4% |  |  |  |
| 2577 | Test Data Request + Templates Completed | 2025-07-14 A |  |  | 0% → 50% |  |  |  |
| 2612 | **Qualification Wave 1** |  |  |  | 14% → 15% |  |  |  |
| 2613 | **Qualification Wave 1 QAD Prep** |  |  |  | 46% → 31% |  |  |  |
| 2615 | Qualification Wave 1 Participants Submit Initial QAD |  |  |  | 74% → 50% |  |  |  |
| 2619 | **Qualification Wave 1 Test Prep** |  |  |  | 22% → 32% |  |  |  |
| 2621 | Qualification Wave 1 Participants DIP Onboarding Window |  |  |  | 63% → 50% |  |  |  |
| 2624 | Review of Participants' PIT Status and QT Test Plan |  |  |  | 16% → 49% |  |  |  |
| 2628 | Onboarding to QTF & ADO | 2025-07-14 A |  |  | 0% → 8% |  |  |  |
| 2642 | **Qualification Wave 2** |  |  |  | 3% → 5% |  |  |  |
| 2643 | **Qualification Wave 2 QAD Prep** |  |  |  | 13% → 22% |  |  |  |
| 2645 | Qualification Wave 2 Participants Submit Initial QAD |  |  |  | 17% → 30% |  |  |  |
| 2746 | PAB298 | 2025-07-16 A | 2025-07-16 A |  | 0% → 100% | 637d → none |  |  |
| 2895 | Present to Panel | 2025-07-10 A | 2025-07-10 A |  | 0% → 100% | 640d → none |  |  |
| 2908 | **MIGRATION** |  |  |  | 70% → 72% |  |  |  |
| 2956 | **Supplier Submission Support** |  | 2025-06-18 A |  | 99% → 100% | 657d → none |  |  |

| ID | Task | Start | Finish | Duration | Complete | Total float | Predecessors | Other |
| --- | --- | --- | --- | --- | --- | --- | --- | --- |
| 2964 | **MCC Stood up** |  |  |  | 59% → 65% |  |  |  |
| 2965 | Migration Planning Management Tool Delivery |  |  |  | 59% → 63% |  |  |  |
| 2966 | **MCC Operational** |  |  |  | 47% → 99% |  |  |  |
| 2967 | **MCC Dress Rehersal 1 - Initialise Schedule (Weekly) Drop 1, 2** |  |  |  | 47% → 99% |  |  |  |
| 2975 | Consolidate baseline schedule |  | 2025-07-11 A |  | 47% → 100% | 638d → none |  |  |
| 2976 | Consolidated baseline schedule published to industry | 2025-07-11 A | 2025-07-11 A |  | 0% → 100% | 638d → none |  |  |
| 2977 | Baselined Schedule available for download | 2025-07-14 A | 2025-07-14 A |  | 0% → 100% | 638d → none |  |  |
| 2978 | Test execution report (weekly) | 2025-07-15 A | 2025-07-15 A |  | 0% → 100% | 637d → none |  |  |
| 2979 | Dress rehearsal completion report | 2025-07-15 A | 2025-07-15 A |  | 0% → 100% | 637d → none |  |  |
| 2980 | MCC Dress Rehersal 1 - complete | 2025-07-15 A | 2025-07-15 A |  | 0% → 100% | 637d → none |  |  |
| 2982 | **MCC Dress Rehersal 2 - complete** | 2025-07-14 A |  |  |  |  |  |  |
| 2983 | Issue Dress Rehearsal support information to Participants | 2025-07-14 A | 2025-07-14 A |  | 0% → 100% | 604d → none |  |  |
| 2985 | Kestrel Webinar 2 | 2025-07-14 → 2025-08-06 (+23d) | 2025-07-14 → 2025-08-06 (+23d) |  |  | 604d → 621d | 2983 → none | constraint none → finish no earlier than 2025-08-06; baseline start 2025-07-14 → 2025-08-06; baseline finish 2025-07-14 → 2025-08-06 |
| 2986 | Onboard and connectivity testing - Dress Rehearsal with Suppliers (remaining suppliers and non-supplier PPs) |  |  |  |  | 604d → 619d | 2985FS+6d → 2984FS+6d |  |
| 2987 | Dress rehearsal start | 2025-07-21 → 2025-08-11 (+21d) | 2025-07-21 → 2025-08-11 (+21d) |  |  |  |  | constraint none → finish no earlier than 2025-08-11; baseline start 2025-07-21 → 2025-08-11; baseline finish 2025-07-21 → 2025-08-11 |
| 2988 | Test execution report (weekly) |  |  |  |  |  | 2987FS+29d → 2987FS+14d |  |
| 2995 | **Migration Artefact Development and Publication** |  |  |  | 81% → 84% |  |  |  |
| 3038 | **Data Cleanse Plan** |  |  |  | 98% → 99% |  |  |  |
| 3043 | **MTDs** |  |  |  | 95% → 99% |  |  |  |
| 3050 | **Meter Location and Number of Displayed Register Digits** |  |  |  | 91% → 98% |  |  |  |
| 3054 | Suppliers complete Work Off plans |  |  |  | 89% → 98% |  |  |  |
| 3069 | **Connection Type and Meter Type Misalignments** |  |  |  | 62% → 67% |  |  |  |
| 3070 | **Traditional Meters installed on Current Transformers** |  |  |  | 30% → 32% |  |  |  |
| 3075 | Suppliers to have completed meter exchanges for those MPANs in pot 1 |  |  |  | 6% → 9% |  |  |  |
| 3082 | **Smart Meter Types installed on CT Connection Types** |  |  |  | 80% → 91% |  |  |  |
| 3086 | Suppliers resolve all issues |  |  |  | 55% → 80% |  |  |  |
| 3088 | **Linked Import / Export MPANs** |  |  |  | 83% → 92% |  |  |  |
| 3089 | LDSOs review and correct linked Import / Export MPANs with Different Connection Types |  |  |  | 83% → 92% |  |  |  |
| 3090 | LDSOs, Import and Export Suppliers review and correct linked Import / Export MPANs with meters in the Advanced and Traditional or Smart Meter Groups |  |  |  | 83% → 92% |  |  |  |
| 3092 | **Related MPANs** |  |  |  | 83% → 92% |  |  |  |
| 3094 | Suppliers unrelate any MPANs required |  |  |  | 28% → 68% |  |  |  |
| 3095 | Suppliers should investigate Related MPANs within different meter groups and verify that they are correct or request that their Meter Operators update the Meter Types where they are incorrect |  |  |  | 83% → 92% |  |  |  |
| 3127 | **Preparation for Cutover to Live** |  |  |  | 27% → 31% |  |  |  |
| 3128 | **Central Systems Prepare for Cutover to Live** |  |  |  | 74% → 84% |  |  |  |
| 3130 | **Development of Comms Approach and Declaration Guidance** |  |  |  | 80% → 97% |  |  |  |
| 3131 | Draft Cutover Comms Approach |  |  |  | 80% → 97% |  |  |  |
| 3134 | **Development of Cutover Plan requirements with Participants** |  |  |  | 73% → 81% |  |  |  |
| 3136 | Development of Programme Participant Cutover Plans |  | 2025-07-11 A |  | 80% → 100% | 28d → none |  |  |
| 3139 | LDSO Cutover Plan Assurance | 2025-07-14 A |  |  | 0% → 13% |  |  | baseline start 2025-06-30 → 2025-07-14; baseline finish 2025-07-18 → 2025-08-01 |
| 3140 | SIT Supplier and SIT Agent Cutover Plan Assurance | 2025-07-14 A |  |  | 0% → 7% |  |  |  |
| 3141 | **M10/M11 Cutover Activities** | 2025-09-05 → 2025-04-14 (-144d) |  | 15d → 120d |  | 14d → none |  |  |
| 3142 | Production DIP Portal (DIP Deployment) |  |  |  |  |  | 1673FS+10d → none | constraint none → finish no earlier than 2025-09-05 |
| 3143 | Production Certificates (DIP Deployment) |  |  |  |  |  | 1673FS+10d → none | constraint none → finish no earlier than 2025-09-05 |
| 3144 | Completion of the pre-M10 MHHS Data Cleanse | 2025-09-22 → 2025-09-24 (+2d) | 2025-09-22 → 2025-09-24 (+2d) |  |  | 588d → 586d |  | constraint none → finish no earlier than 2025-09-24 |
| 3158 | SIT Participant Qualification - The final date by which participant qualification status can be confirmed for participants to be ready for the start of Migration at M11. |  |  |  |  |  | 1673FS+25d → none | constraint none → finish no earlier than 2025-09-26 |
| 3291 | **BUSINESS & OPERATIONAL READINESS** |  |  |  | 36% → 41% |  |  |  |
| 3292 | **Service Management** |  | 2026-03-26 → 2026-10-23 (+211d) | 889d → 1040d | 22% → 28% | 455d → 304d |  |  |
| 3306 | **Wave 1** |  | 2025-09-26 → 2026-05-12 (+228d) | 760d → 922d |  | 584d → 422d |  | baseline finish 2026-05-14 → 2026-05-12 |
| 3307 | **SIT Non-MVC Service Activation Preparation Tasks** |  |  |  |  |  |  | baseline finish 2026-05-14 → 2022-11-29 |
| 3310 | Wave 1 Service Activation |  |  |  |  |  |  | baseline start 2026-04-13 → 2022-11-01; baseline finish 2026-05-14 → 2022-11-29 |
| 3311 | **Wave 1 - Service Activation Implementation** | 2025-09-01 → 2026-04-14 (+225d) | 2025-09-11 → 2026-04-24 (+225d) |  |  | 585d → 434d |  | baseline start 2025-09-01 → 2026-04-14; baseline finish 2025-09-05 → 2026-04-24 |
| 3312 | MHHSP Enabled Confirmation | 2025-09-01 → 2026-04-14 (+225d) | 2025-09-02 → 2026-04-14 (+224d) | 2d → 1d |  | 602d → 442d |  | constraint finish no earlier than 2025-09-02 → finish no earlier than 2026-04-14; baseline start 2025-09-01 → 2026-04-14; baseline finish 2025-09-02 → 2026-04-14 |
| 3313 | PAB Approval | 2025-09-01 → 2026-04-15 (+226d) | 2025-09-02 → 2026-04-15 (+225d) | 2d → 1d |  | 602d → 441d |  | constraint finish no earlier than 2025-09-02 → finish no earlier than 2026-04-15; baseline start 2025-09-01 → 2026-04-15; baseline finish 2025-09-02 → 2026-04-15 |
| 3314 | Add EFD to DIP | 2025-09-02 → 2026-04-16 (+226d) | 2025-09-03 → 2026-04-16 (+225d) | 2d → 1d |  | 584d → 435d |  | constraint finish no earlier than 2025-09-03 → finish no earlier than 2026-04-16; baseline start 2025-09-02 → 2026-04-16; baseline finish 2025-09-03 → 2026-04-16 |
| 3315 | DIP Promoted to Production | 2025-09-04 → 2026-04-20 (+228d) | 2025-09-05 → 2026-04-24 (+231d) | 2d → 5d |  | 584d → 434d |  | constraint finish no earlier than 2025-09-04 → finish no earlier than 2026-04-24; baseline start 2025-09-03 → 2026-04-20; baseline finish 2025-09-04 → 2026-04-24 |
| 3316 | Create M16 in Customer Solution | 2025-09-08 → 2026-04-17 (+221d) | 2025-09-09 → 2026-04-17 (+220d) | 2d → 1d |  | 584d → 439d | 3315 → none | constraint finish no earlier than 2025-09-05 → finish no earlier than 2026-04-17; baseline start 2025-09-04 → 2026-04-17; baseline finish 2025-09-05 → 2026-04-17 |
| 3317 | Publish ISD | 2025-09-10 → 2026-04-17 (+219d) | 2025-09-11 → 2026-04-24 (+225d) | 2d → 6d |  | 584d → 434d | 3316 → none | constraint finish no earlier than 2025-09-05 → finish no earlier than 2026-04-24; baseline start 2025-09-04 → 2026-04-17; baseline finish 2025-09-05 → 2026-04-24 |
| 3318 | Wave 1 - Service Activation Implementation Complete (M) | 2025-09-11 → 2026-04-24 (+225d) | 2025-09-11 → 2026-04-24 (+225d) |  |  | 595d → 434d |  | baseline start 2025-09-05 → 2026-04-24; baseline finish 2025-09-05 → 2026-04-24 |
| 3319 | **Wave 1 - Service Activation Implementation MDD** | 2025-09-12 → 2026-04-17 (+217d) | 2025-09-26 → 2026-05-11 (+227d) | 11d → 17d |  | 584d → 423d |  | baseline start 2025-09-04 → 2026-04-17; baseline finish 2025-09-17 → 2026-05-11 |
| 3320 | MDD Manual Load | 2025-09-12 → 2026-04-17 (+217d) | 2025-09-18 → 2026-04-21 (+215d) | 5d → 3d |  | 584d → 437d | 3317 → none | constraint finish no earlier than 2025-09-10 → finish no earlier than 2026-04-21; baseline start 2025-09-04 → 2026-04-17; baseline finish 2025-09-10 → 2026-04-21 |
| 3321 | MDD Update | 2025-09-19 → 2026-04-17 (+210d) | 2025-09-26 → 2026-04-24 (+210d) |  |  | 584d → 433d | 3320 → 3320SS | constraint finish no earlier than 2025-09-17 → start no earlier than 2026-04-17; baseline start 2025-09-10 → 2026-04-17; baseline finish 2025-09-17 → 2026-04-24 |
| 3322 | Wave 1 - Service Activation Implementation MDD Complete (M) | 2025-09-26 → 2026-05-11 (+227d) | 2025-09-26 → 2026-05-11 (+227d) | 0d → 1d |  | 584d → 423d |  | constraint finish no earlier than 2025-09-17 → start no earlier than 2026-05-11; baseline start 2025-09-17 → 2026-05-11; baseline finish 2025-09-17 → 2026-05-11 |
| 3323 | **Wave 1 - Service Activation Hypercare** | 2025-09-01 → 2026-04-16 (+227d) | 2025-09-24 → 2026-05-12 (+230d) | 18d → 19d |  | 586d → 422d |  | baseline start 2022-10-31 → 2026-04-16; baseline finish 2025-09-18 → 2026-05-12 |
| 3324 | Service& Process Monitoring | 2025-09-02 → 2026-04-16 (+226d) | 2025-09-19 → 2026-05-12 (+235d) | 14d → 19d |  | 589d → 422d |  | baseline start 2025-09-01 → 2026-04-16; baseline finish 2025-09-18 → 2026-05-12 |
| 3325 | Daily Reporting | 2025-09-02 → 2026-04-16 (+226d) | 2025-09-19 → 2026-05-12 (+235d) | 14d → 19d |  | 589d → 422d |  | baseline start 2025-09-01 → 2026-04-16; baseline finish 2025-09-18 → 2026-05-12 |
| 3326 | Issue Management | 2025-09-02 → 2026-04-16 (+226d) | 2025-09-19 → 2026-05-12 (+235d) | 14d → 19d |  | 589d → 422d |  | baseline start 2025-09-01 → 2026-04-16; baseline finish 2025-09-18 → 2026-05-12 |
| 3327 | SA Hypercare Close Down Activities | 2025-09-01 → 2026-05-11 (+252d) | 2025-09-18 → 2026-05-12 (+236d) | 14d → 2d |  | 586d → 422d |  | constraint finish no earlier than 2025-09-18 → start no earlier than 2026-05-11; baseline start 2025-09-01 → 2026-05-11; baseline finish 2025-09-18 → 2026-05-12 |
| 3328 | Handover to MHHSP | 2025-09-19 → 2026-05-11 (+234d) | 2025-09-24 → 2026-05-12 (+230d) | 4d → 2d |  | 586d → 422d | 3327 → 3327SS | baseline start 2025-09-15 → 2026-05-11; baseline finish 2025-09-18 → 2026-05-12 |
| 3329 | Non-SIT LDSO Service Activation Hypercare Complete (M) | 2025-09-24 → 2026-05-12 (+230d) | 2025-09-24 → 2026-05-12 (+230d) |  |  | 586d → 422d |  | baseline start 2022-10-31 → 2026-05-12; baseline finish 2022-10-31 → 2026-05-12 |
| 3330 | **Wave 2** |  | 2025-11-20 → 2026-06-08 (+200d) | 799d → 941d |  | 545d → 403d |  | baseline finish 2026-06-30 → 2026-06-08 |

| ID | Task | Start | Finish | Duration | Complete | Total float | Predecessors | Other |
| --- | --- | --- | --- | --- | --- | --- | --- | --- |
| 3331 | **SIT Non-MVC Service Activation Preparation Tasks** |  |  |  |  |  |  | baseline finish 2026-06-30 → 2022-12-02 |
| 3334 | Wave 2 Service Activation |  |  |  |  |  |  | baseline start 2026-05-28 → 2022-11-01; baseline finish 2026-06-30 → 2022-12-02 |
| 3335 | **Wave 2 - Service Activation Implementation** | 2025-11-03 → 2026-05-27 (+205d) | 2025-11-13 → 2026-06-08 (+207d) | 9d → 8d |  | 550d → 404d |  | baseline start 2025-11-03 → 2026-05-27; baseline finish 2025-11-07 → 2026-06-08 |
| 3336 | MHHSP Enabled Confirmation | 2025-11-03 → 2026-05-27 (+205d) | 2025-11-04 → 2026-05-27 (+204d) | 2d → 1d |  | 557d → 407d |  | constraint finish no earlier than 2025-11-04 → start no earlier than 2026-05-27; baseline start 2025-11-03 → 2026-05-27; baseline finish 2025-11-04 → 2026-05-27 |
| 3337 | PAB Approval | 2025-11-03 → 2026-05-28 (+206d) | 2025-11-04 → 2026-05-28 (+205d) | 2d → 1d |  | 557d → 407d | none → 3336 | baseline start 2025-11-03 → 2026-05-28; baseline finish 2025-11-04 → 2026-05-28 |
| 3338 | Add EFD to DIP | 2025-11-04 → 2026-05-29 (+206d) | 2025-11-05 → 2026-05-29 (+205d) | 2d → 1d |  | 550d → 407d | none → 3337 | baseline start 2025-11-04 → 2026-05-29; baseline finish 2025-11-05 → 2026-05-29 |
| 3339 | DIP Promoted to Production | 2025-11-06 → 2026-06-01 (+207d) | 2025-11-07 → 2026-06-01 (+206d) | 2d → 1d |  | 550d → 407d |  | baseline start 2025-11-05 → 2026-06-01; baseline finish 2025-11-06 → 2026-06-01 |
| 3340 | Create M16 in Customer Solution | 2025-11-10 → 2026-06-02 (+204d) | 2025-11-11 → 2026-06-02 (+203d) | 2d → 1d |  | 550d → 407d |  | baseline start 2025-11-06 → 2026-06-02; baseline finish 2025-11-07 → 2026-06-02 |
| 3341 | Publish ISD | 2025-11-12 → 2026-05-29 (+198d) | 2025-11-13 → 2026-06-05 (+204d) | 2d → 6d |  | 550d → 404d | 3340 → none | constraint finish no earlier than 2025-11-07 → start no earlier than 2026-05-29; baseline start 2025-11-06 → 2026-05-29; baseline finish 2025-11-07 → 2026-06-05 |
| 3342 | Wave 2 - Service Activation Implementation Complete (M) | 2025-11-13 → 2026-06-08 (+207d) | 2025-11-13 → 2026-06-08 (+207d) |  |  | 550d → 404d |  | constraint finish no earlier than 2025-11-07 → start no earlier than 2026-06-08; baseline start 2025-11-07 → 2026-06-08; baseline finish 2025-11-07 → 2026-06-08 |
| 3343 | **Wave 2 - Service Activation Implementation MDD** | 2025-11-06 → 2025-06-12 (-147d) |  | 10d → 115d |  |  |  | baseline start 2025-11-06 → 2025-06-12 |
| 3344 | MDD Manual Load | 2025-11-06 → 2025-06-12 (-147d) | 2025-11-12 → 2025-06-17 (-148d) | 5d → 4d |  | 551d → 657d |  | constraint finish no earlier than 2025-11-12 → start no earlier than 2025-06-12; baseline start 2025-11-06 → 2025-06-12; baseline finish 2025-11-12 → 2025-06-17 |
| 3345 | MDD Update | 2025-11-12 → 2025-06-12 (-153d) | 2025-11-19 → 2025-06-19 (-153d) |  |  | 546d → 655d |  | constraint finish no earlier than 2025-11-19 → start no earlier than 2025-06-12; baseline start 2025-11-12 → 2025-06-12; baseline finish 2025-11-19 → 2025-06-19 |
| 3347 | **Wave 2 - Service Activation Hypercare** | 2025-11-03 → 2026-05-27 (+205d) | 2025-11-20 → 2026-06-08 (+200d) | 14d → 9d |  | 545d → 403d |  | baseline start 2025-11-03 → 2026-05-27; baseline finish 2025-11-20 → 2026-06-08 |
| 3348 | Service& Process Monitoring | 2025-11-03 → 2026-05-27 (+205d) | 2025-11-20 → 2026-06-08 (+200d) | 14d → 9d |  | 545d → 403d |  | constraint finish no earlier than 2025-11-20 → start no earlier than 2026-05-27; baseline start 2025-11-03 → 2026-05-27; baseline finish 2025-11-20 → 2026-06-08 |
| 3349 | Daily Reporting | 2025-11-03 → 2026-05-27 (+205d) | 2025-11-20 → 2026-06-08 (+200d) | 14d → 9d |  | 545d → 403d | none → 3348SS | baseline start 2025-11-03 → 2026-05-27; baseline finish 2025-11-20 → 2026-06-08 |
| 3350 | Issue Management | 2025-11-03 → 2026-05-27 (+205d) | 2025-11-20 → 2026-06-08 (+200d) | 14d → 9d |  | 545d → 403d | none → 3349SS | baseline start 2025-11-03 → 2026-05-27; baseline finish 2025-11-20 → 2026-06-08 |
| 3351 | SA Hypercare Close Down Activities | 2025-11-03 → 2026-06-04 (+213d) | 2025-11-20 → 2026-06-08 (+200d) | 14d → 3d |  | 545d → 403d |  | constraint finish no earlier than 2025-11-20 → start no earlier than 2026-06-04; baseline start 2025-11-03 → 2026-06-04; baseline finish 2025-11-20 → 2026-06-08 |
| 3352 | Handover to MHHSP | 2025-11-17 → 2026-06-08 (+203d) | 2025-11-20 → 2026-06-08 (+200d) | 4d → 1d |  | 545d → 403d |  | constraint finish no earlier than 2025-11-20 → start no earlier than 2026-06-08; baseline start 2025-11-17 → 2026-06-08; baseline finish 2025-11-20 → 2026-06-08 |
| 3353 | Wave 2 - Service Activation Hypercare Complete (M) | 2025-11-19 → 2026-06-08 (+201d) | 2025-11-19 → 2026-06-08 (+201d) |  |  | 546d → 404d |  | constraint finish no earlier than 2025-11-19 → start no earlier than 2026-06-08; baseline start 2025-11-19 → 2026-06-08; baseline finish 2025-11-19 → 2026-06-08 |
| 3354 | **Wave 3** |  | 2026-01-16 → 2026-08-21 (+217d) | 840d → 995d |  | 504d → 349d |  | baseline finish 2026-08-26 → 2026-08-21 |
| 3355 | **SIT Non-MVC Service Activation Preparation Tasks** |  |  |  |  |  |  | baseline finish 2026-08-26 → 2022-11-14 |
| 3358 | Wave 3 Service Activation |  |  |  |  |  |  | baseline start 2026-07-24 → 2022-11-01; baseline finish 2026-08-26 → 2022-11-14 |
| 3359 | **Wave 3 - Service Activation Implementation** | 2025-12-22 → 2026-07-29 (+219d) | 2026-01-05 → 2026-08-10 (+217d) | 11d → 8d |  | 513d → 359d |  | baseline start 2025-12-22 → 2026-07-29; baseline finish 2025-12-30 → 2026-08-10 |
| 3360 | MHHSP Enabled Confirmation | 2025-12-22 → 2026-07-29 (+219d) | 2025-12-23 → 2026-07-29 (+218d) | 2d → 1d |  | 522d → 364d |  | constraint finish no earlier than 2025-12-23 → start no earlier than 2026-07-29; baseline start 2025-12-22 → 2026-07-29; baseline finish 2025-12-23 → 2026-07-29 |
| 3361 | PAB Approval | 2025-12-22 → 2026-07-30 (+220d) | 2025-12-23 → 2026-07-30 (+219d) | 2d → 0d |  | 514d → 364d | none → 3360 | constraint finish no earlier than 2025-12-23 → start no earlier than 2026-07-30; baseline start 2025-12-22 → 2026-07-30; baseline finish 2025-12-23 → 2026-07-30 |
| 3362 | Add EFD to DIP | 2025-12-24 → 2026-07-31 (+219d) | 2025-12-25 → 2026-07-31 (+218d) | 2d → 1d |  | 514d → 363d |  | constraint finish no earlier than 2025-12-24 → start no earlier than 2026-07-31; baseline start 2025-12-23 → 2026-07-31; baseline finish 2025-12-24 → 2026-07-31 |
| 3363 | DIP Promoted to Production | 2025-12-29 → 2026-08-03 (+217d) | 2025-12-30 → 2026-08-03 (+216d) | 2d → 1d |  | 513d → 363d |  | baseline start 2025-12-29 → 2026-08-03; baseline finish 2025-12-30 → 2026-08-03 |
| 3364 | Create M16 in Customer Solution | 2025-12-31 → 2026-07-31 (+212d) | 2026-01-01 → 2026-07-31 (+211d) | 2d → 1d |  | 513d → 359d | 3363 → none | constraint finish no earlier than 2025-12-30 → start no earlier than 2026-07-31; baseline start 2025-12-29 → 2026-07-31; baseline finish 2025-12-30 → 2026-07-31 |
| 3365 | Publish ISD | 2026-01-02 → 2026-07-31 (+210d) | 2026-01-05 → 2026-08-07 (+214d) | 2d → 6d |  | 513d → 359d | 3364 → 3364SS | baseline start 2025-12-29 → 2026-07-31; baseline finish 2025-12-30 → 2026-08-07 |
| 3366 | Wave 3 - Service Activation Implementation Complete (M) | 2026-01-05 → 2026-08-10 (+217d) | 2026-01-05 → 2026-08-10 (+217d) |  |  | 513d → 359d |  | constraint finish no earlier than 2025-12-30 → start no earlier than 2026-08-10; baseline start 2025-12-30 → 2026-08-10; baseline finish 2025-12-30 → 2026-08-10 |
| 3367 | **Wave 3 - Service Activation Implementation MDD** | 2022-10-31 → 2026-08-14 (+1383d) | 2026-01-15 → 2026-08-21 (+218d) | 839d → 6d |  | 505d → 349d |  | baseline start 2022-10-31 → 2026-08-14; baseline finish 2026-01-15 → 2026-08-21 |
| 3368 | MDD Manual Load | 2025-12-29 → 2026-08-14 (+228d) | 2026-01-06 → 2026-08-19 (+225d) | 7d → 4d |  | 512d → 349d |  | constraint finish no earlier than 2026-01-06 → start no earlier than 2026-08-14; baseline start 2025-12-29 → 2026-08-14; baseline finish 2026-01-06 → 2026-08-19 |
| 3369 | MDD Update | 2025-01-06 → 2026-08-14 (+585d) | 2026-01-15 → 2026-08-21 (+218d) | 269d → 6d |  | 505d → 349d | none → 3368SS | baseline start 2025-01-06 → 2026-08-14; baseline finish 2026-01-15 → 2026-08-21 |
| 3370 | Wave 3 - Service Activation Implementation MDD Complete (M) | 2022-10-31 → 2026-08-21 (+1390d) | 2022-10-31 → 2026-08-21 (+1390d) |  |  | 1344d → 349d | none → 3369 | baseline start 2022-10-31 → 2026-08-21; baseline finish 2022-10-31 → 2026-08-21 |
| 3371 | **Wave 3 - Service Activation Hypercare** | 2022-10-31 → 2026-07-29 (+1367d) | 2026-01-16 → 2026-08-10 (+206d) | 840d → 9d |  | 504d → 358d |  | baseline start 2022-10-31 → 2026-07-29; baseline finish 2026-01-16 → 2026-08-10 |
| 3372 | Service& Process Monitoring | 2025-12-22 → 2026-07-29 (+219d) | 2026-01-16 → 2026-08-10 (+206d) | 20d → 9d |  | 504d → 358d |  | constraint finish no earlier than 2026-01-16 → start no earlier than 2026-07-29; baseline start 2025-12-22 → 2026-07-29; baseline finish 2026-01-16 → 2026-08-10 |
| 3373 | Daily Reporting | 2025-12-22 → 2026-07-29 (+219d) | 2026-01-16 → 2026-08-10 (+206d) | 20d → 9d |  | 504d → 358d | none → 3372SS | baseline start 2025-12-22 → 2026-07-29; baseline finish 2026-01-16 → 2026-08-10 |
| 3374 | Issue Management | 2025-12-22 → 2026-07-29 (+219d) | 2026-01-16 → 2026-08-10 (+206d) | 20d → 9d |  | 504d → 358d | none → 3373SS | baseline start 2025-12-22 → 2026-07-29; baseline finish 2026-01-16 → 2026-08-10 |
| 3375 | SA Hypercare Close Down Activities | 2025-12-22 → 2026-08-06 (+227d) | 2026-01-16 → 2026-08-10 (+206d) | 20d → 3d |  | 504d → 358d |  | constraint finish no earlier than 2026-01-16 → start no earlier than 2026-08-06; baseline start 2025-12-22 → 2026-08-06; baseline finish 2026-01-16 → 2026-08-10 |
| 3376 | Handover to MHHSP | 2026-01-12 → 2026-08-10 (+210d) | 2026-01-15 → 2026-08-10 (+207d) | 4d → 1d |  | 505d → 358d |  | constraint finish no earlier than 2026-01-15 → start no earlier than 2026-08-10; baseline start 2026-01-12 → 2026-08-10; baseline finish 2026-01-15 → 2026-08-10 |
| 3377 | Wave 3 Service Activation Hypercare Complete (M) | 2022-10-31 → 2026-08-10 (+1379d) | 2022-10-31 → 2026-08-10 (+1379d) |  |  | 1344d → 358d | none → 3376 | baseline start 2022-10-31 → 2026-08-10; baseline finish 2022-10-31 → 2026-08-10 |
| 3378 | **Wave 4** |  | 2026-03-26 → 2026-10-23 (+211d) | 889d → 1040d |  | 455d → 304d |  | baseline finish 2026-10-22 → 2026-10-23 |
| 3379 | **SIT Non-MVC Service Activation Preparation Tasks** |  |  |  |  |  |  | baseline finish 2026-10-22 → 2022-12-02 |
| 3382 | Wave 4 Service Activation |  |  |  |  |  |  | baseline start 2026-09-21 → 2022-11-01; baseline finish 2026-10-22 → 2022-12-02 |
| 3383 | **Wave 4 - Service Activation Implementation** | 2025-03-03 → 2026-09-23 (+569d) | 2026-03-12 → 2026-10-05 (+207d) | 269d → 8d |  | 465d → 319d |  | baseline start 2025-03-03 → 2026-09-23; baseline finish 2026-03-06 → 2026-10-05 |
| 3384 | MHHSP Enabled Confirmation | 2026-03-02 → 2026-09-23 (+205d) | 2026-03-03 → 2026-09-23 (+204d) | 2d → 1d |  | 472d → 323d |  | constraint finish no earlier than 2026-03-03 → start no earlier than 2026-09-23; baseline start 2026-03-02 → 2026-09-23; baseline finish 2026-03-03 → 2026-09-23 |
| 3385 | PAB Approval | 2025-03-03 → 2026-09-24 (+570d) | 2025-03-03 → 2026-09-24 (+570d) |  |  | 725d → 323d | none → 3384 | constraint finish no earlier than 2025-03-03 → none; baseline start 2025-03-03 → 2026-09-24; baseline finish 2025-03-03 → 2026-09-24 |
| 3386 | Add EFD to DIP | 2026-03-03 → 2026-09-25 (+206d) | 2026-03-04 → 2026-09-25 (+205d) | 2d → 1d |  | 465d → 323d |  | baseline start 2026-03-03 → 2026-09-25; baseline finish 2026-03-04 → 2026-09-25 |
| 3387 | DIP Promoted to Production | 2026-03-05 → 2026-09-28 (+207d) | 2026-03-06 → 2026-09-28 (+206d) | 2d → 1d |  | 465d → 323d |  | baseline start 2026-03-04 → 2026-09-28; baseline finish 2026-03-05 → 2026-09-28 |
| 3388 | Create M16 in Customer Solution | 2026-03-09 → 2026-09-25 (+200d) | 2026-03-10 → 2026-09-25 (+199d) | 2d → 1d |  | 465d → 319d | 3387 → none | constraint finish no earlier than 2026-03-06 → start no earlier than 2026-09-25; baseline start 2026-03-05 → 2026-09-25; baseline finish 2026-03-06 → 2026-09-25 |
| 3389 | Publish ISD | 2026-03-11 → 2026-09-25 (+198d) | 2026-03-12 → 2026-10-02 (+204d) | 2d → 6d |  | 465d → 319d | 3388 → 3388SS | baseline start 2026-03-05 → 2026-09-25; baseline finish 2026-03-06 → 2026-10-02 |
| 3390 | Wave 4 - Service Activation Implementation Complete (M) | 2026-03-12 → 2026-10-05 (+207d) | 2026-03-12 → 2026-10-05 (+207d) |  |  | 465d → 319d |  | constraint finish no earlier than 2026-03-06 → start no earlier than 2026-10-05; baseline start 2026-03-06 → 2026-10-05; baseline finish 2026-03-06 → 2026-10-05 |
| 3391 | **Wave 4 - Service Activation Implementation MDD** | 2026-03-06 → 2026-10-16 (+224d) | 2026-03-26 → 2026-10-23 (+211d) | 15d → 6d |  | 455d → 304d |  | baseline start 2026-03-06 → 2026-10-16; baseline finish 2026-03-26 → 2026-10-23 |
| 3392 | MDD Manual Load | 2026-03-06 → 2026-10-16 (+224d) | 2026-03-16 → 2026-10-20 (+218d) | 7d → 3d |  | 463d → 307d |  | constraint finish no earlier than 2026-03-16 → start no earlier than 2026-10-16; baseline start 2026-03-06 → 2026-10-16; baseline finish 2026-03-16 → 2026-10-20 |
| 3393 | MDD Update | 2026-03-16 → 2026-10-16 (+214d) | 2026-03-26 → 2026-10-23 (+211d) | 9d → 6d |  | 455d → 304d |  | constraint finish no earlier than 2026-03-26 → start no earlier than 2026-10-16; baseline start 2026-03-16 → 2026-10-16; baseline finish 2026-03-26 → 2026-10-23 |
| 3394 | Wave 4 - Service Activation Implementation MDD Complete | 2026-03-25 → 2026-10-23 (+212d) | 2026-03-25 → 2026-10-23 (+212d) |  |  | 456d → 304d | none → 3393 | baseline start 2026-03-25 → 2026-10-23; baseline finish 2026-03-25 → 2026-10-23 |
| 3395 | **Wave 4 - Service Activation Hypercare** | 2026-03-02 → 2026-09-23 (+205d) | 2026-03-26 → 2026-10-05 (+193d) | 19d → 9d |  | 455d → 318d |  | baseline start 2026-03-02 → 2026-09-23; baseline finish 2026-03-26 → 2026-10-05 |
| 3396 | Service& Process Monitoring | 2026-03-02 → 2026-09-23 (+205d) | 2026-03-26 → 2026-10-05 (+193d) | 19d → 9d |  | 455d → 318d |  | constraint finish no earlier than 2026-03-26 → start no earlier than 2026-09-23; baseline start 2026-03-02 → 2026-09-23; baseline finish 2026-03-26 → 2026-10-05 |
| 3397 | Daily Reporting | 2026-03-02 → 2026-09-23 (+205d) | 2026-03-26 → 2026-10-05 (+193d) | 19d → 9d |  | 455d → 318d |  | constraint finish no earlier than 2026-03-26 → start no earlier than 2026-09-23; baseline start 2026-03-02 → 2026-09-23; baseline finish 2026-03-26 → 2026-10-05 |
| 3398 | Issue Management | 2026-03-02 → 2026-09-23 (+205d) | 2026-03-26 → 2026-10-05 (+193d) | 19d → 9d |  | 455d → 318d |  | constraint finish no earlier than 2026-03-26 → start no earlier than 2026-09-23; baseline start 2026-03-02 → 2026-09-23; baseline finish 2026-03-26 → 2026-10-05 |
| 3399 | SA Hypercare Close Down Activities | 2026-03-02 → 2026-10-02 (+214d) | 2026-03-26 → 2026-10-05 (+193d) | 19d → 2d |  | 455d → 318d |  | constraint finish no earlier than 2026-03-26 → start no earlier than 2026-10-02; baseline start 2026-03-02 → 2026-10-02; baseline finish 2026-03-26 → 2026-10-05 |
| 3400 | Handover to MHHSP | 2026-03-02 → 2026-10-05 (+217d) | 2026-03-05 → 2026-10-05 (+214d) | 4d → 1d |  | 470d → 318d |  | constraint finish no earlier than 2026-03-05 → start no earlier than 2026-10-05; baseline start 2026-03-02 → 2026-10-05; baseline finish 2026-03-05 → 2026-10-05 |
| 3401 | Wave 4 - Service Activation Hypercare Complete (M) | 2026-03-25 → 2026-10-05 (+194d) | 2026-03-25 → 2026-10-05 (+194d) |  |  | 456d → 318d | none → 3400 | baseline start 2026-03-25 → 2026-10-05; baseline finish 2026-03-25 → 2026-10-05 |
| 3509 | **READINESS ASSESSMENTS** |  |  |  | 46% → 47% |  |  |  |
| 3517 | **Readiness Assessment 5 / 6 - Start of Qualification and Participant Readiness for M10 and M11 and CP3/CP4 check** |  | 2025-07-01 A |  | 96% → 100% | 647d → none |  |  |
| 3520 | Analyse survey responses |  | 2025-06-27 A |  | 95% → 100% | 649d → none |  |  |
| 3521 | Conduct deep-dive interviews (sample of PPs) |  | 2025-06-27 A |  | 95% → 100% | 649d → none |  |  |
| 3522 | Produce Readiness Assessment Reports (Overall Report & Individual Participant Reports) |  | 2025-06-27 A |  | 95% → 100% | 647d → none |  |  |
| 3523 | Readiness Assessment 5 / 6 - Start of Qualification and Participant Readiness for M10 and M11 and CP3/CP4 check (incl. Readiness Assessment Report approval) Completed | 2025-07-01 A | 2025-07-01 A |  | 0% → 100% | 647d → none |  |  |

| ID | Task | Start | Finish | Complete | Total float |
| --- | --- | --- | --- | --- | --- |
| 3545 | **Readiness Assessments - Tier 1 Milestones** | 2025-07-01 A |  |  |  |
| 3546 | Readiness Assessment 6 - Start of Migration - Completed (incl. Readiness Assessment Report approval) | 2025-07-01 A | 2025-07-01 A | 0% → 100% | 647d → none |

## Version 14 (data date 2025-10-22, saved 2025-10-22, file MHHS-DEL1139 - MHHS Plan v6.36.mpp)

Last finish stays 2027-12-23. Complete tasks 2022 → 2442.

Added:

| ID | Task | Duration | Start | Finish | Predecessors | Constraint |
| --- | --- | --- | --- | --- | --- | --- |
| 1572 | Supplementary Regression Testing | 20d | 2025-07-21 A | 2025-08-15 A | 1571SS |  |
| 1976 | LDSO Communication and Information Gathering Completed - Phase 1 | 0d | 2025-07-16 A | 2025-07-16 A |  | start no earlier than 2025-07-16 |
| 1978 | LDSO ServiceNow Configuration Completed - Phase 1/2 | 0d | 2025-07-16 A | 2025-07-16 A |  | finish no earlier than 2025-07-16 |
| 1980 | LDSO Testing and Further Communication Completed - Phase 1 | 0d | 2025-07-30 A | 2025-07-30 A |  | start no earlier than 2025-07-30 |
| 1982 | **LDSO Onboarding - Phase 2** | 27d | 2025-07-31 A | 2025-09-05 A |  |  |
| 1983 | LDSO Resources Enrolled in Authenticator - Phase 2 | 20d | 2025-07-31 A | 2025-08-27 A |  | start no earlier than 2025-07-31 |
| 1984 | LDSO Resources Enrolled in Authenticator Completed - Phase 2 | 0d | 2025-08-27 A | 2025-08-27 A |  | start no earlier than 2025-08-27 |
| 1985 | Elexon Phase 2 Resources Setup in Portal - Phase 2 | 7d | 2025-08-28 A | 2025-09-05 A | 1983 |  |
| 1986 | Elexon Phase 2 Resources Setup in Portal Completed - Phase 2 | 0d | 2025-09-05 A | 2025-09-05 A | 1985 |  |
| 2030 | DIP Code Change Presented at DCAB | 0d | 2025-08-12 A | 2025-08-12 A |  | start no earlier than 2025-08-12 |
| 2035 | **Non-LDSO SIT PPs ServiceNow Onboarding** | 12d | 2025-09-05 A | 2025-09-24 A |  |  |
| 2036 | Pathway 2 | 0d | 2025-09-05 A | 2025-09-05 A |  | finish no earlier than 2025-09-05 |
| 2037 | Pathway 3 | 0d | 2025-09-09 A | 2025-09-09 A |  | start no earlier than 2025-09-09 |
| 2038 | Pathway 4 | 0d | 2025-09-24 A | 2025-09-24 A |  | start no earlier than 2025-09-24 |
| 2054 | **DIP UIT Onboarding** | 828d? | 2022-10-31 | 2025-12-31 |  |  |
| 2055 | **LDSOs** | 0d | 2025-07-25 A | 2025-07-25 A |  |  |
| 2056 | Date to be Onboarded by | 0d | 2025-07-25 A | 2025-07-25 A |  | start no earlier than 2025-07-25 |
| 2057 | **Pathway 2** | 23d | 2025-07-25 A | 2025-08-27 A |  |  |
| 2058 | Proforma Issued | 0d | 2025-07-25 A | 2025-07-25 A |  | start no earlier than 2025-07-25 |
| 2059 | Invite to Onbaord Issued | 0d | 2025-08-08 A | 2025-08-08 A |  | start no earlier than 2025-08-08 |
| 2060 | Date to be Onboarded by | 0d | 2025-08-27 A | 2025-08-27 A |  | start no earlier than 2025-08-27 |
| 2061 | **Pathway 3** | 0d | 2022-10-31 | 2022-10-31 |  |  |
| 2062 | Proforma Issued | 0d | 2025-08-04 A | 2025-08-04 A |  | start no earlier than 2025-08-04 |
| 2063 | Invite to Onbaord Issued | 0d | 2025-08-18 A | 2025-08-18 A |  | start no earlier than 2025-08-18 |
| 2064 | Date to be Onboarded by | 0d | 2025-09-09 A | 2025-09-09 A |  | start no earlier than 2025-09-09 |
| 2065 | **Pathway 4** | 0d | 2022-10-31 | 2022-10-31 |  |  |
| 2066 | Proforma Issued | 0d | 2025-08-22 A | 2025-08-22 A |  | start no earlier than 2025-08-22 |
| 2067 | Invite to Onbaord Issued | 0d | 2025-09-05 A | 2025-09-05 A |  | start no earlier than 2025-09-05 |
| 2068 | Date to be Onboarded by | 0d | 2025-09-24 A | 2025-09-24 A |  | start no earlier than 2025-09-24 |
| 2120 | Process Refinement | 33d | 2025-06-17 A | 2025-07-31 A |  | start no earlier than 2025-06-17 |
| 2121 | Process Test | 26d | 2025-08-01 A | 2025-09-05 A | 2120 |  |
| 2311 | **ELEXON / HELIX M10 - M16** | 81d | 2026-04-08 | 2026-07-30 |  |  |
| 2312 | SAT M16 Test Case Execution | 22d | 2026-07-01 | 2026-07-30 |  | start no earlier than 2026-07-01 |
| 2313 | LSS provides Load Shape data that is publicly accessible - Business Requirement MHHSP-37 | 0d | 2026-04-08 | 2026-04-08 | 3315FS+120d |  |
| 2982 | MCC Dress Rehersal 2 start | 1d | 2025-08-11 A | 2025-08-11 A |  | finish no earlier than 2025-08-11 |
| 2985 | PPs return test scripts | 0d | 2025-09-05 A | 2025-09-05 A |  | finish no earlier than 2025-09-05 |
| 2990 | MCAG Approve Sprint 0 Day 1 Baseline Schedule | 0d | 2025-10-20 A | 2025-10-20 A |  | start no earlier than 2025-10-20 |
| 2992 | Legacy Settlement run stability assessment | 16d | 2025-09-26 A | 2025-10-17 A | 1804, 2308 | start no earlier than 2025-09-26 |
| 2993 | Checkpoint 1 | 0d | 2025-10-03 A | 2025-10-03 A |  | finish no earlier than 2025-10-03 |
| 2994 | Checkpoint 2 | 0d | 2025-10-10 A | 2025-10-10 A |  | finish no earlier than 2025-10-10 |
| 2995 | Checkpoint 3 | 0d | 2025-10-17 A | 2025-10-17 A |  | finish no earlier than 2025-10-17 |
| 3142 | Monitor Participant Cutover Plan reporting | 56d | 2025-08-06 A | 2025-10-22 A |  | start no earlier than 2025-08-06 |
| 3144 | Load Shaping Service (LSS) | 10d | 2025-07-14 A | 2025-07-25 A |  | start no earlier than 2025-07-14 |
| 3145 | Volume Allocation Service (VAS) | 10d | 2025-07-14 A | 2025-07-25 A |  | start no earlier than 2025-07-14 |
| 3146 | Market-wide Data Service (MDS) | 10d | 2025-07-14 A | 2025-07-25 A |  | start no earlier than 2025-07-14 |
| 3147 | Deployment of Industry Standing Data (ISD) Work Package (WP3) source code | 10d | 2025-07-14 A | 2025-07-25 A |  | start no earlier than 2025-07-14 |
| 3148 | ISD Service Activation | 0d | 2025-08-05 A | 2025-08-05 A | 3147 | start no earlier than 2025-08-05 |
| 3149 | ISD Data Migration (PR-3) | 14d | 2025-08-05 A | 2025-08-22 A | 3148 | start no earlier than 2025-08-05 |
| 3150 | ISD Data Migration (PR-4) | 11d | 2025-08-15 A | 2025-08-29 A |  | start no earlier than 2025-08-15 |
| 3151 | ISD Catalogue Published | 0d | 2025-09-11 A | 2025-09-11 A | 3150 | start no earlier than 2025-09-11 |
| 3152 | DIP Production Environment stood up | 0d | 2025-07-18 A | 2025-07-18 A |  | start no earlier than 2025-07-18 |
| 3156 | DIP Onboarding | 15d | 2025-08-04 A | 2025-08-22 A |  | start no earlier than 2025-08-04 |
| 3157 | Deployment of MPRS 9 | 19d | 2025-08-06 A | 2025-09-01 A |  | start no earlier than 2025-08-06 |
| 3158 | ISD Population | 0d | 2025-09-11 A | 2025-09-11 A |  | start no earlier than 2025-09-11 |
| 3159 | Population of Market Segment (95%) | 28d | 2025-08-06 A | 2025-09-12 A | 3157SS | start no earlier than 2025-08-06 |
| 3160 | Population of Market Segment (100%) | 7d | 2025-09-12 A | 2025-09-22 A | 3159FS-1d | start no earlier than 2025-09-12 |
| 3161 | Population of Domestic Premises Indicator (Weekend start) | 2d | 2025-09-05 A | 2025-09-08 A |  | start no earlier than 2025-09-05 |
| 3167 | Pre-M10 Service Activation - LDSOs | 6d | 2025-09-11 A | 2025-09-18 A |  | start no earlier than 2025-09-11 |
| 3168 | Pre-M10 Service Activation - Suppliers and Agents | 25d | 2025-09-11 A | 2025-10-15 A |  | start no earlier than 2025-09-11 |
| 3169 | Load Shaping Service (LSS) | 2d | 2025-09-19 A | 2025-09-22 A | 3144 | start no earlier than 2025-09-19 |
| 3170 | Volume Allocation Service (VAS) | 2d | 2025-09-19 A | 2025-09-22 A | 3145 | start no earlier than 2025-09-19 |
| 3171 | Market-wide Data Service (MDS) | 2d | 2025-09-19 A | 2025-09-22 A | 3146 | start no earlier than 2025-09-19 |
| 3172 | DTS | 2d | 2025-09-19 A | 2025-09-22 A |  | start no earlier than 2025-09-19 |
| 3173 | EES | 2d | 2025-09-19 A | 2025-09-22 A |  | start no earlier than 2025-09-19 |
| 3174 | DCC | 20d | 2024-06-03 A | 2024-06-28 A |  | start no earlier than 2024-06-01 |
| 3175 | MPRS – Registration Services, UMSO Role, LDSO Role | 2d | 2025-09-19 A | 2025-09-22 A |  | start no earlier than 2025-09-19 |
| 3176 | Qualification Pathway 4 Service Activation | 6d | 2025-09-26 A | 2025-10-03 A |  | start no earlier than 2025-09-26 |
| 3177 | Qualification Pathway 5 Service Activation | 5d | 2025-10-16 A | 2025-10-22 A |  | start no earlier than 2025-10-16 |
| 3179 | IF-047 sent at 9am on Monday 22nd September by Elexon via the DIP to all LDSOs and EES | 0d | 2025-09-22 A | 2025-09-22 A |  | start no earlier than 2025-09-22 |
| 3180 | All LDSOs and EES to load ISD files via the URL published within the IF-047 via the Elexon data store (note, this should contain the same ISD file as uploaded to the Elexon portal following 11th September, therefore it may not need to be applied by each p | 0d | 2025-09-22 A | 2025-09-22 A |  | start no earlier than 2025-09-22 |
| 3181 | Following successful loading of ISD data LDSOs can process New Connections via their DB01 interface to MPRS | 0d | 2025-09-22 A | 2025-09-22 A | 3180 | start no earlier than 2025-09-22 |
| 3182 | Each LDSO will track successful sending of the IF-050 message to the DIP | 0d | 2025-09-22 A | 2025-09-22 A | 3181 | start no earlier than 2025-09-22 |
| 3183 | EES will track successful receipt and processing of the IF-050 | 0d | 2025-09-22 A | 2025-09-22 A | 3182 | start no earlier than 2025-09-22 |
| 3184 | IF-047 sent at 9am on Wednesday 22nd October by Elexon via the DIP | 0d | 2025-10-22 A | 2025-10-22 A |  | start no earlier than 2025-10-22 |
| 3186 | Confirmation from all LDSOs that DIP onboarding has taken place | 0d | 2025-08-22 A | 2025-08-22 A |  | start no earlier than 2025-08-22 |
| 3190 | Confirmation of all pre-M10 parties | 0d | 2025-09-15 A | 2025-09-15 A |  | start no earlier than 2025-09-15 |
| 3191 | Confirmation that all LDSOs have populated the ISD | 0d | 2025-09-15 A | 2025-09-15 A |  | start no earlier than 2025-09-15 |
| 3193 | Market-wide Participant MHHS Migration Supporting Functionality is ready to be deployed | 0d | 2025-09-15 A | 2025-09-15 A |  | start no earlier than 2025-09-15 |
| 3194 | Recommendation from TORWG that the Programme should enter M10 | 0d | 2025-09-17 A | 2025-09-17 A |  | start no earlier than 2025-09-17 |
| 3195 | Production Service Activation Activities have taken place for all pre-M10 qualified parties | 0d | 2025-09-18 A | 2025-09-18 A |  | start no earlier than 2025-09-18 |
| 3196 | Early Life Support model is in place | 0d | 2025-09-19 A | 2025-09-19 A |  | start no earlier than 2025-09-19 |
| 3201 | Confirmation that Market Segment has been populated for 100% of LDSO portfolios | 0d | 2025-09-22 A | 2025-09-22 A |  | start no earlier than 2025-09-22 |
| 3202 | IF-047 message has been sent | 0d | 2025-09-22 A | 2025-09-22 A |  | start no earlier than 2025-09-22 |
| 3203 | LDSOs have received the IF-047 message | 0d | 2025-09-22 A | 2025-09-22 A |  | start no earlier than 2025-09-22 |
| 3204 | EES has received the IF-047 message and loaded the ISD file | 0d | 2025-09-22 A | 2025-09-22 A |  | start no earlier than 2025-09-22 |
| 3205 | Confirmation that the IF-050 has been sent and the number sent | 0d | 2025-09-22 A | 2025-09-22 A |  | start no earlier than 2025-09-22 |
| 3206 | Confirmation of the number of IF-050s | 0d | 2025-09-22 A | 2025-09-22 A |  | start no earlier than 2025-09-22 |
| 3207 | Recommendation from TORWG that the M10 acceptance criteria have been met | 0d | 2025-09-23 A | 2025-09-23 A |  | start no earlier than 2025-09-23 |
| 3211 | Qualification of all pre-M11 parties | 0d | 2025-10-16 A | 2025-10-16 A |  | start no earlier than 2025-10-16 |
| 3212 | Self-Declaration that ISD file has been manually accessed and applied by all qualified Suppliers and Agents | 0d | 2025-10-16 A | 2025-10-16 A |  | start no earlier than 2025-10-16 |
| 3213 | Confirmation of Qualified Parties from TORWG and their readiness | 0d | 2025-10-17 A | 2025-10-17 A |  | start no earlier than 2025-10-17 |
| 3214 | Recommendation from MCAG that the Programme can approve M11 / M12 | 0d | 2025-10-20 A | 2025-10-20 A |  | start no earlier than 2025-10-20 |
| 3337 | **Wave 1 - Service Activation Preparation Tasks** | 9d | 2026-03-31 | 2026-04-10 |  |  |
| 3338 | Review Entry/Exit Criteria & Lessons Learned | 0d | 2026-03-31 | 2026-03-31 |  | finish no earlier than 2026-03-31 |
| 3339 | Identify Resources | 1d | 2026-03-31 | 2026-03-31 |  | start no earlier than 2026-03-31 |
| 3340 | Confirmation from Qualification of Wave Participants Complete | 0d | 2026-03-31 | 2026-03-31 |  | finish no earlier than 2026-03-31 |
| 3341 | Agree & Understand Support Model | 1d | 2026-04-01 | 2026-04-01 |  | start no earlier than 2026-04-01 |
| 3342 | Training Confirmation | 1d | 2026-04-02 | 2026-04-02 |  | start no earlier than 2026-04-02 |
| 3343 | Training Confirmation Completed | 0d | 2026-04-02 | 2026-04-02 |  | finish no earlier than 2026-04-02 |
| 3344 | Engagement / Communications with Participants Completed | 0d | 2026-04-03 | 2026-04-03 |  | finish no earlier than 2026-04-03 |
| 3345 | **Internal Communications** | 1d | 2026-04-06 | 2026-04-06 |  |  |
| 3346 | Agree Content for Livewire | 1d | 2026-04-06 | 2026-04-06 |  | start no earlier than 2026-04-06 |
| 3347 | Publish Content for Livewire | 0d | 2026-04-06 | 2026-04-06 |  | finish no earlier than 2026-04-06 |
| 3348 | Validate User Access | 1d | 2026-04-07 | 2026-04-07 |  | start no earlier than 2026-04-07 |
| 3349 | Target Systems and Environments Ready | 1d | 2026-04-08 | 2026-04-08 |  | start no earlier than 2026-04-08 |
| 3350 | Provide LWIs | 1d | 2026-04-09 | 2026-04-09 |  | start no earlier than 2026-04-09 |
| 3351 | Business Readiness Governance Approval | 1d | 2026-04-10 | 2026-04-10 |  | start no earlier than 2026-04-10 |
| 3352 | Wave 1 - Service Activation Preparation Tasks (M) | 0d | 2026-04-10 | 2026-04-10 |  | finish no earlier than 2026-04-10 |
| 3354 | Market Entry to obtain Effective from Date from PP | 1d | 2026-04-02 | 2026-04-02 |  | start no earlier than 2026-04-02 |
| 3359 | MDD & ISD Go-Live | 0d | 2026-04-24 | 2026-04-24 | 3358FS+5d | start no earlier than 2026-04-24 |
| 3361 | Seondary Publish ISD | 1d? | 2026-05-01 | 2026-05-01 |  | start no earlier than 2026-05-01 |
| 3362 | Secondary Go Live ISD | 0d | 2026-05-08 | 2026-05-08 | 3361FS+5d |  |
| 3364 | MDD Final Circular Completed | 0d | 2026-04-15 | 2026-04-15 |  | start no earlier than 2026-04-15 |
| 3365 | MDD Manual Update | 2d | 2026-04-15 | 2026-04-16 | 3364 |  |
| 3373 | **Wave 1 - Service Activation Retro & Go/No Go** | 9d | 2026-05-12 | 2026-05-22 |  |  |
| 3374 | Review | 0d | 2026-05-12 | 2026-05-12 |  | start no earlier than 2026-05-12 |
| 3375 | Lessons Learned | 5d | 2026-05-12 | 2026-05-18 | 3374FF | start no earlier than 2026-05-12 |
| 3376 | Wave 2 - Service Activation Readiness Review Against Entry/Exit Criteria | 5d | 2026-05-18 | 2026-05-22 |  | start no earlier than 2026-05-18 |
| 3379 | Market Entry to obtain Effective from Date from PP | 1d | 2026-05-15 | 2026-05-15 |  | start no earlier than 2026-05-15 |
| 3386 | MDD & ISD Go-Live | 0d | 2026-06-05 | 2026-06-05 | 3385FS+5d |  |
| 3389 | MDD Final Circular Completed | 0d | 2026-05-28 | 2026-05-28 |  | start no earlier than 2026-05-28 |
| 3390 | MDD Manual Update | 2d | 2026-06-12 | 2026-06-15 |  | start no earlier than 2026-06-12 |
| 3398 | **Wave 2 - Service Activation Retro & Go/No Go** | 10d | 2026-06-08 | 2026-06-19 |  |  |
| 3399 | Review | 0d | 2026-06-08 | 2026-06-08 |  | start no earlier than 2026-06-08 |
| 3400 | Lessons Learned | 5d | 2026-06-08 | 2026-06-12 |  | start no earlier than 2026-06-08 |
| 3401 | Wave 3 - Service Activation Readiness Review Against Entry/Exit Criteria | 5d | 2026-06-15 | 2026-06-19 |  | start no earlier than 2026-06-15 |
| 3403 | **Wave 3 - Service Activation Preparation Tasks** | 10d | 2026-07-13 | 2026-07-24 |  |  |
| 3404 | Review Entry/Exit Criteria & Lessons Learned | 0d | 2026-07-13 | 2026-07-13 |  | start no earlier than 2026-07-13 |
| 3405 | Identify Resources | 1d | 2026-07-13 | 2026-07-13 |  | start no earlier than 2026-07-13 |
| 3406 | Confirmation from Qualification of Wave Participants Complete | 0d | 2026-07-13 | 2026-07-13 |  | start no earlier than 2026-07-13 |
| 3407 | Review Handover from Wave 2 | 1d | 2026-07-14 | 2026-07-14 |  | start no earlier than 2026-07-14 |
| 3408 | Agree & Understand Support Model | 1d | 2026-07-15 | 2026-07-15 |  | start no earlier than 2026-07-15 |
| 3409 | Confirm Training complete | 1d | 2026-07-16 | 2026-07-16 |  | start no earlier than 2026-07-16 |
| 3410 | Engagement / Communications with Participants | 1d | 2026-07-17 | 2026-07-17 |  | start no earlier than 2026-07-17 |
| 3411 | **Internal Communications** | 1d | 2026-07-20 | 2026-07-20 |  |  |
| 3412 | Agree Content for Livewire | 1d | 2026-07-20 | 2026-07-20 |  | start no earlier than 2026-07-20 |
| 3413 | Publish Content for Livewire | 0d | 2026-07-20 | 2026-07-20 |  | start no earlier than 2026-07-20 |
| 3414 | Validate User Access | 1d | 2026-07-21 | 2026-07-21 |  | start no earlier than 2026-07-21 |
| 3415 | Target Systems and Environments Ready | 1d | 2026-07-22 | 2026-07-22 |  | start no earlier than 2026-07-22 |
| 3416 | Provide LWIs | 1d | 2026-07-23 | 2026-07-23 |  | start no earlier than 2026-07-23 |
| 3417 | Business Readiness Governance Approval | 1d | 2026-07-24 | 2026-07-24 |  | finish no earlier than 2026-07-24 |
| 3418 | Wave 3 - Service Activation Preparation Tasks Completed | 0d | 2026-07-24 | 2026-07-24 | 3405, 3407, 3408, 3409, 3410, 3411, 3414, 3415, 3416, 3417 | finish no earlier than 2026-07-24 |
| 3420 | Market Entry to obtain Effective from Date from PP | 1d | 2026-07-17 | 2026-07-17 |  | start no earlier than 2026-07-17 |
| 3427 | MDD Final Circular Completed | 1d? | 2026-07-30 | 2026-07-30 |  | start no earlier than 2026-07-30 |
| 3428 | MDD Manual Update | 1d? | 2026-08-14 | 2026-08-14 |  | start no earlier than 2026-08-14 |
| 3436 | **Wave 3 - Service Activation Retro & Go/No Go** | 43d | 2026-06-17 | 2026-08-14 |  |  |
| 3437 | Review | 0d | 2026-08-10 | 2026-08-10 |  | start no earlier than 2026-08-10 |
| 3438 | Lessons Learned | 5d | 2026-08-10 | 2026-08-14 |  | start no earlier than 2026-08-10 |
| 3439 | Wave 4 - Service Activation Readiness Review Against Entry/Exit Criteria | 5d | 2026-06-17 | 2026-06-23 |  | start no earlier than 2026-06-17 |
| 3441 | **Wave 4 - Service Activation Preparation Tasks** | 10d | 2026-09-07 | 2026-09-18 |  |  |
| 3442 | Review Entry/Exit Criteria & Lessons Learned | 0d | 2026-09-07 | 2026-09-07 |  | start no earlier than 2026-09-07 |
| 3443 | Identify Resources | 1d | 2026-09-07 | 2026-09-07 |  | start no earlier than 2026-09-07 |
| 3444 | Confirmation from Qualification of Wave Participants Complete | 0d | 2026-09-07 | 2026-09-07 |  | start no earlier than 2026-09-07 |
| 3445 | Review Handover from Wave 3 | 1d | 2026-09-08 | 2026-09-08 |  | finish no earlier than 2026-09-08 |
| 3446 | Agree & Understand Support Model | 1d | 2026-09-09 | 2026-09-09 |  | start no earlier than 2026-09-09 |
| 3447 | Confirm Training complete | 1d | 2026-09-10 | 2026-09-10 |  | start no earlier than 2026-09-10 |
| 3448 | Engagement / Communications with Participants | 1d | 2026-09-11 | 2026-09-11 |  | start no earlier than 2026-09-11 |
| 3449 | **Internal Communications** | 1d | 2026-09-14 | 2026-09-14 |  |  |
| 3450 | Agree Content for Livewire | 1d | 2026-09-14 | 2026-09-14 |  | start no earlier than 2026-09-14 |
| 3451 | Publish Content for Livewire | 0d | 2026-09-14 | 2026-09-14 |  | start no earlier than 2026-09-14 |
| 3452 | Validate User Access | 1d | 2026-09-15 | 2026-09-15 |  | start no earlier than 2026-09-15 |
| 3453 | Target Systems and Environments Ready | 1d | 2026-09-16 | 2026-09-16 |  | start no earlier than 2026-09-16 |
| 3454 | Provide LWIs | 1d | 2026-09-17 | 2026-09-17 |  | finish no earlier than 2026-09-17 |
| 3455 | Business Readiness Governance Approval | 1d | 2026-09-18 | 2026-09-18 |  | finish no earlier than 2026-09-18 |
| 3456 | Wave 4 - Service Activation Preparation Tasks Completed | 0d | 2026-09-18 | 2026-09-18 | 3443, 3445, 3446, 3447, 3448, 3449, 3452, 3453, 3454, 3455 | finish no earlier than 2026-09-18 |
| 3458 | Market Entry to obtain Effective from Date from PP | 1d | 2026-09-11 | 2026-09-11 |  | start no earlier than 2026-09-11 |
| 3463 | MDD & ISD Go-Live | 0d | 2026-10-02 | 2026-10-02 | 3462FS+5d |  |
| 3466 | MDD Final Circular Completed | 1d? | 2026-09-24 | 2026-09-24 |  | start no earlier than 2026-09-24 |
| 3467 | MDD Manual Update | 1d? | 2026-10-16 | 2026-10-16 |  | start no earlier than 2026-10-16 |
| 3475 | **Service Activation Transition Completion** | 25d | 2026-10-12 | 2026-11-14 |  |  |
| 3476 | Lessons Learnt Review | 5d | 2026-10-12 | 2026-10-16 |  | start no earlier than 2026-10-12 |
| 3477 | Document and circulate Lessons Learnt | 15d | 2026-10-19 | 2026-11-06 | 3476 | finish no earlier than 2026-11-06 |
| 3478 | Handover to Elexon | 5d | 2026-11-09 | 2026-11-14 | 3477 | finish no earlier than 2026-11-14 |
| 3479 | Service Activation Transition Completed | 0d | 2026-11-14 | 2026-11-14 | 3476, 3477, 3478 | finish no earlier than 2026-11-14 |

Removed: 1674 SIT (Contingency); 1675 SIT Functional Testing (Contingency); 1676 SIT Functional Testing Execution (Contingency); 1677 Test Execution (Cycle 3 Completion and Regression Testing); 1678 SIT Functional Testing End (Contingency) (incl. confirmation that PPs have submitted their Test Exit Reports to Programme for assurance); 1679 Assurance of PPs Test Exit Reports; 1680 SIT Functional Testing Test Completion Report (Contingency); 1681 Develop document; 1682 Review & agree document; 1683 SIT Functional Testing Test Exit Report (Contingency) Approved; 1684 SIT Migration Testing (Contingency); 1685 Test Execution (Cycle 3 Completion and Regression Testing); 1686 SIT Migration Testing End (Contingency) (incl. confirmation that PPs have submitted their Test Exit Reports to Programme for assurance); 1687 Assurance of PPs Test Exit Reports; 1688 SIT Migration Testing Test Completion Report (Contingency); 1689 Develop document; 1690 Review & agree document; 1691 SIT Migration Testing Test Exit Report (Contingency) Approved; 1692 SIT Contingency Test Exit Report; 1693 Develop document; 1694 Review & agree document; 1695 SIT Contingency Complete; 2043 "Codify Service Management" - Item raised; 2044 "Codify Service Management" Item Preparation; 2045 Committee Views Ahead of Panel; 2046 Initial Panel Committee Views; 2047 Consultation on Codify Service Management; 2048 Committee Views Ahead of Final Panel; 2049 Final Panel Committee Views; 2050 Submission for Decision to Ofgem ("Codify Service Management"); 2051 "Codify Service Management" Final Decision Process; 2052 "Codify Service Management" Decision Due (TBC and Indicitavely by End of Aug); 2054 Service Management Go/No Go Decision; 2307 DIP Technical Onboarding for LDSOs; 2308 ISD Dress Rehearsals; 2310 Service Activation Implementation; 2387 SIT / LDSO Pathway 1; 2388 QAD Sign Off Deadline + Test Reports; 2389 REC Code Manager / BSC PAB Approval of Qualification; 2971 Dress rehearsal start; 3147 Elexon Central Services Deployment; 3149 Data Transfer Service (DTS) New Functionality Deployment; 3150 Electricity Enquiry Service (EES) Deployment; 3151 MPRS, UMSO Role, LDSO Role Operational; 3152 Population of Domestic Premises Indicator; 3153 Population of Market Segment; 3158 SIT Participant Qualification - The final date by which participant qualification status can be confirmed for participants to be ready for the start of Migration at M11.; 3162 Confirmation that Pre-migration Data Cleanse Activities have successfully taken place; 3164 Confirmation of Helix E2E Settlement Testing Complete; 3165 Confirmation of assurance of Helix E2E Settlement Testing; 3166 Confirmation of Qualification Status for SIT MVC; 3167 Confirmation of Qualification Status for Non-SIT LDSOs; 3168 Confirmation of Qualification Status of at least one Supplier and their contracted Agents; 3170 Market-wide Participant MHHS Migration Supporting Functionality is Live; 3171 TORWG (Recommendation from TORWG that the Programme should enter M10); 3175 Self-Declarations against all M10 Data Cleanse Activities; 3176 IF-047 has been sent; 3177 Recommendation from TORWG that PSG should approve M10; 3180 Confirmation of Qualified Parties from Code Bodies; 3182 Production Service Activation Activities have taken place; 3183 TORWG (Confirmation of Qualified Parties from TORWG); 3184 MCAG (Provide recommendation to PSG on M11 decision); 3307 SIT Non-MVC Service Activation Preparation Tasks; 3308 Helix Preparatory Activities Complete; 3309 MHHSP Confirms Wave 1 PPs MHHS Enabled; 3310 Wave 1 Service Activation; 3313 PAB Approval; 3314 Add EFD to DIP; 3320 MDD Manual Load; 3321 MDD Update; 3322 Wave 1 - Service Activation Implementation MDD Complete (M); 3331 SIT Non-MVC Service Activation Preparation Tasks; 3332 Helix Preparatory Activities Complete; 3333 MHHSP Confirms Wave 2 PPs MHHS Enabled; 3334 Wave 2 Service Activation; 3344 MDD Manual Load; 3345 MDD Update; 3346 Wave 2 - Service Activation Implementation MDD Complete (M); 3355 SIT Non-MVC Service Activation Preparation Tasks; 3356 Helix Preparatory Activities Complete; 3357 MHHSP Confirms Wave 3 PPs MHHS Enabled; 3358 Wave 3 Service Activation; 3361 PAB Approval; 3362 Add EFD to DIP; 3368 MDD Manual Load; 3369 MDD Update; 3370 Wave 3 - Service Activation Implementation MDD Complete (M); 3379 SIT Non-MVC Service Activation Preparation Tasks; 3380 Helix Preparatory Activities Complete; 3381 MHHSP Confirms Wave 4 PPs MHHS Enabled; 3382 Wave 4 Service Activation; 3385 PAB Approval; 3386 Add EFD to DIP; 3392 MDD Manual Load; 3393 MDD Update; 3394 Wave 4 - Service Activation Implementation MDD Complete; 3402 Non-SIT LDSO; 3403 Non-SIT LDSO Service Activation Data Loading; 3404 Define pre Non-SIT LDSO upfront activities; 3405 Execute Non-SIT LDSO Activities; 3406 Create Entity Forms in Customer Solution; 3407 DIP - Promote to Production Environment; 3408 DIP - Enable Technology capabilities for participants; 3409 DIP - Add EFD to DIP; 3410 ISD - Replicate Entity Forms from CS; 3411 MDD - Load MHHS roles; 3412 Non-SIT LDSO Service Activation Data Loading Completed (M); 3413 SIT Non-MVC Service Activation Preparation Tasks; 3414 Helix Preparatory Activities Complete; 3415 MHHSP Confirms Non-SIT LDSO PPs MHHS Enabled; 3416 Non-SIT LDSO Service Activation; 3417 Non-SIT LDSO Service Activation Implementation; 3418 MHHSP Enabled Confirmation; 3419 PAB Approval; 3420 Add EFD to DIP; 3421 DIP Promoted to Production; 3422 Create M16 in Customer Solution; 3423 Publish ISD; 3424 Non-SIT LDSO Service Activation Implementation Completed (M); 3425 Non-SIT LDSO Service Activation Implementation MDD; 3426 MDD Manual Load; 3427 MDD Update; 3428 Non-SIT LDSO Service Activation Implementation MDD Complete (M); 3429 Non-SIT LDSO Service Activation Hypercare; 3430 Non-SIT LDSO Service Activation Hypercare Support; 3431 Service& Process Monitoring; 3432 Daily Reporting; 3433 Issue Management; 3434 SA Hypercare Close Down Activities; 3435 Handover to MHHSP; 3436 Non-SIT LDSO Service Activation Hypercare Complete (M)

Changed:

| ID | Task | Start | Finish | Complete | Total float |
| --- | --- | --- | --- | --- | --- |
| 1 | **PROGRAMME PLAN.** |  |  | 72% → 83% |  |
| 3 | **PROGRAMME MANAGEMENT** |  |  | 57% → 68% |  |
| 4 | **Programme Management** |  |  | 56% → 67% |  |
| 5 | Sprint-based prioritisation planning and execution |  |  | 56% → 67% |  |
| 6 | Programme governance secretariat |  |  | 56% → 67% |  |
| 7 | RAID management and reporting |  |  | 56% → 67% |  |
| 8 | Tracking against Programme outcomes and KPIs |  |  | 56% → 67% |  |
| 9 | Change control and reporting |  |  | 56% → 67% |  |
| 10 | Ongoing identification of lessons learned relating to the PMO and implementation of improvements |  |  | 56% → 67% |  |
| 11 | **Programme Internal Assurance Reviews** |  |  | 56% → 67% |  |
| 12 | Programme Internal Assurance Reviews |  |  | 56% → 67% |  |
| 13 | **Engagement with PPs** |  |  | 56% → 67% |  |
| 14 | Ongoing PP liaison activities |  |  | 56% → 67% |  |
| 15 | Milestone and Control Point objective setting |  |  | 56% → 67% |  |
| 16 | Reporting |  |  | 56% → 67% |  |
| 17 | **PP Engagement Events** |  |  | 56% → 67% |  |
| 18 | Bilateral meetings |  |  | 56% → 67% |  |
| 19 | Monthly webinars |  |  | 56% → 67% |  |
| 20 | Open days |  |  | 56% → 67% |  |
| 21 | **PP Communications** |  |  | 56% → 67% |  |
| 22 | The Clock updates (weekly) |  |  | 56% → 67% |  |
| 23 | Maintain and update content on public-facing Portal (and ongoing feedback reviews to identify and implement Portal improvements) |  |  | 56% → 67% |  |
| 24 | **Code Change Support / Other Programme Alignment** |  |  | 56% → 67% |  |
| 25 | Support DCC/BEIS on SEC change |  |  | 56% → 67% |  |
| 26 | Support on Smart Meters Act changes |  |  | 56% → 67% |  |
| 27 | Support DCC/RECCo on CSS change |  |  | 56% → 67% |  |
| 28 | Support Elexon on BSC change |  |  | 56% → 67% |  |
| 29 | Support code change inside & outside CCIAG |  |  | 56% → 67% |  |
| 30 | Support code change inside & outside CCAG |  |  | 56% → 67% |  |
| 45 | **DESIGN, BUILD & TEST (PIT)** |  |  | 89% → 96% |  |
| 46 | **Design Baseline & Enduring PP Support** |  |  | 79% → 85% |  |
| 56 | **Establish Design Change Management Processes** |  |  | 54% → 68% |  |
| 61 | Maintain E2E MHHS Design (post-M5 design change management processes operational) |  |  | 52% → 66% |  |
| 187 | **PP Design, Build & Test (DBT)** |  |  | 96% → 99% |  |
| 291 | **SIT Participants DBT** |  |  | 89% → 99% |  |
| 326 | **All SIT Programme Participants PIT (SIT Functional)** |  |  | 79% → 99% |  |
| 378 | **SIT Programme Participants PIT (SIT Operational Theme 1, 2, 3 (Batch 2))** |  |  | 90% → 99% |  |
| 379 | **Test Approach & Plan** |  | 2024-11-21 A | 0% → 100% | 805d → none |
| 381 | SIT Operational Test approach and plan MHHS Review Completed | 2024-11-21 A | 2024-11-21 A | 0% → 100% | 805d → none |
| 382 | **Test Readiness Report** |  | 2024-10-22 A | 90% → 100% | 18d → none |
| 383 | Test readiness reporting |  | 2024-10-22 A | 90% → 100% | 18d → none |
| 384 | **Requirements to test Traceability Matrix (RTTM)** | 2024-11-01 A | 2024-11-29 A | 0% → 100% | 799d → none |
| 385 | SIT Operational PIT RTTM submitted to Programme for assurance | 2024-11-01 A | 2024-11-01 A | 0% → 100% | 799d → none |
| 386 | SIT Operational RTTM MHHS Review Completed | 2024-11-29 A | 2024-11-29 A | 0% → 100% | 799d → none |
| 387 | **Test Scenarios** | 2024-11-01 A | 2024-11-29 A | 0% → 100% | 16.1d → none |
| 388 | SIT Operational PIT test scenarios submitted to Programme for assurance | 2024-11-01 A | 2024-11-01 A | 0% → 100% | 16.1d → none |
| 389 | SIT Operational Test scenarios MHHS Review Completed | 2024-11-29 A | 2024-11-29 A | 0% → 100% | 799d → none |
| 390 | **PIT execution** |  |  | 90% → 99% |  |
| 391 | PIT Test Execution Progress Report |  | 2024-11-21 A | 90% → 100% | 792d → none |
| 392 | PIT Execution |  | 2024-11-29 A | 90% → 100% | 754d → none |
| 393 | SIT Operational Theme 1, 2, 3 (Batch 2) PIT Completion Report submitted to Programme for assurance | 2025-01-14 A | 2025-01-14 A | 0% → 100% | 754d → none |
| 395 | **SIT Programme Participants PIT (SIT Operational Theme 3 (Batch 1))** |  | 2025-01-10 A | 0% → 100% | 769d → none |
| 399 | **Test Readiness Report** | 2024-10-04 A | 2024-10-22 A | 0% → 100% | 787d → none |
| 400 | Test readiness reporting | 2024-10-04 A | 2024-10-22 A | 0% → 100% | 787d → none |
| 407 | **PIT execution** |  | 2025-01-10 A | 0% → 100% | 769d → none |
| 408 | PIT Test Execution Progress Report | 2024-10-23 A | 2024-12-17 A | 0% → 100% | 787d → none |
| 409 | PIT Execution | 2024-11-04 A | 2024-12-26 A | 0% → 100% | 780d → none |
| 463 | **DBT Monitoring and Assurance** |  |  | 85% → 98% |  |
| 464 | **Planning and DBT Progress Monitoring of PPs** |  | 2025-06-30 A | 89% → 100% | 648d → none |
| 465 | Monitor Non-SIT PPs Planning and DBT1 progress (to inform confirmation of Qualification Testing Tranche participants milestones) |  | 2025-06-30 A | 89% → 100% | 648d → none |
| 466 | **DBT Progress Monitoring of Consequential Change** |  |  | 74% → 90% |  |
| 467 | Monitor & report data cleanse progress |  |  | 74% → 90% |  |
| 468 | **Design Assurance** |  | 2025-08-06 A | 89% → 100% | 621d → none |
| 499 | **Non-SIT PPs design assurance** |  | 2025-08-06 A | 75% → 100% | 621d → none |
| 500 | Non-SIT PPs design assurance (risk-based sample) |  | 2025-08-06 A | 75% → 100% | 621d → none |
| 501 | **Test Assurance** |  | 2025-06-30 A | 87% → 100% | 648d → none |
| 502 | Non-SIT PPs test assurance |  | 2025-06-30 A | 87% → 100% | 648d → none |
| 509 | **SYSTEMS INTEGRATION TESTING (SIT)** |  |  | 90% → 96% |  |
| 510 | **SIT Preparation** |  | 2025-05-23 A | 99% → 100% | 674d → none |
| 591 | **SIT Stage-Specific Preparation** |  | 2025-05-23 A | 99% → 100% | 674d → none |

| ID | Task | Start | Finish | Duration | Complete | Total float | Other |
| --- | --- | --- | --- | --- | --- | --- | --- |
| 1158 | **SIT Operational Preparation** |  | 2025-05-23 A |  | 98% → 100% | 674d → none |  |
| 1327 | **SIT Operational Programme RTTM (Theme 1, 2 & 3 (Batch 2))** |  | 2025-05-23 A |  | 75% → 100% | 674d → none |  |
| 1330 | DIP Manager / Code Bodies / Full SRO to review |  | 2025-04-24 A |  | 90% → 100% | 694d → none |  |
| 1331 | Incorporate feedback |  | 2025-04-24 A |  | 26% → 100% | 695d → none |  |
| 1332 | DIP Manager / Code Bodies / SRO acceptance of (Theme 1, 2 & 3 (Batch 2)) Operational RTTM | 2025-04-25 A | 2025-04-25 A |  | 0% → 100% | 694d → none |  |
| 1333 | SIT Operational (Theme 1, 2 & 3 (Batch 2)) RTTM Complete | 2025-05-23 A | 2025-05-23 A |  | 0% → 100% | 674d → none |  |
| 1484 | **SIT Execution** |  | 2025-11-27 → 2025-09-19 A (-69d) | 544d? → 495d? | 73% → 100% | 540d → none |  |
| 1501 | **SIT** |  | 2025-09-19 A |  | 83% → 100% | 589d → none |  |
| 1502 | **SIT Functional Testing (MVC)** |  | 2025-09-19 A |  | 81% → 100% | 589d → none |  |
| 1541 | **SIT Functional Settlement Testing** |  |  |  | 66% → 100% |  |  |
| 1566 | **SIT Functional & Migration Regression Testing (code freeze)** |  | 2025-09-12 A |  | 17% → 100% | 594d → none |  |
| 1569 | Regression Sprint 1 |  | 2025-07-18 A |  | 70% → 100% | -97d → none |  |
| 1570 | Regression Sprint 2 | 2025-07-21 A | 2025-08-08 A |  | 0% → 100% | -97d → none |  |
| 1571 | Cycle 1 SAT Regression | 2025-07-21 A | 2025-08-01 A |  | 0% → 100% | 624d → none |  |
| 1573 | Cycle 2 SAT Regression | 2025-08-04 A | 2025-08-08 A |  | 0% → 100% | 619d → none |  |
| 1574 | Regression Sprint 3 | 2025-08-11 A | 2025-08-22 A |  | 0% → 100% | 594d → none |  |
| 1575 | Regression Sprint 4 | 2025-08-25 A | 2025-09-12 A |  | 0% → 100% | 594d → none |  |
| 1576 | **SIT Functional & Migration Overarching Exit Report** |  | 2025-07-17 A |  | 96% → 100% | 635d → none |  |
| 1584 | SI SIT Functional & Migration Overarching Exit Report Industry Review |  | 2025-07-17 A |  | 70% → 100% | 635d → none |  |
| 1585 | **SIT Settlement and Regression Test Exit Report** |  | 2025-09-19 A |  | 7% → 100% | 589d → none |  |
| 1586 | Programme drafts Settlement and Regression Pathway 2 PP Exit Reports |  | 2025-07-23 A |  | 46% → 100% | 631d → none |  |
| 1587 | SRO Review Settlement and Regression Pathway 2 PP Exit Reports | 2025-07-17 A | 2025-07-23 A |  | 0% → 100% | 631d → none |  |
| 1588 | Pathway 2 PPs review and sign off Regression Exit Declaration | 2025-07-21 A | 2025-07-28 A |  | 0% → 100% | 606d → none |  |
| 1589 | Programme drafts Settlement and Regression Pathway 3 PP Exit Reports | 2025-07-28 A | 2025-08-13 A |  | 0% → 100% | 605d → none |  |
| 1590 | SRO Review Settlement and Regression Pathway 3 PP Exit Reports | 2025-08-07 A | 2025-08-13 A |  | 0% → 100% | 616d → none |  |
| 1591 | Pathway 3 PPs review and sign off Exit Reports | 2025-08-11 A | 2025-08-15 A |  | 0% → 100% | 595d → none |  |
| 1592 | Programme drafts Settlement and Regression Pathway 4, 5 & 6 PP Exit Reports | 2025-08-18 A | 2025-09-19 A |  | 0% → 100% | 589d → none |  |
| 1593 | Programme drafts SI SIT Settlement and Regression Addendum | 2025-07-21 A | 2025-08-08 A |  | 0% → 100% | 38d → none |  |
| 1594 | SRO/Code Bodies Review SI SIT Settlement and Regression Addendum | 2025-08-04 A | 2025-08-08 A |  | 0% → 100% | 619d → none |  |
| 1595 | SI SIT Migration Testing Test Exit Report Approved | 2025-08-15 A | 2025-08-15 A |  | 0% → 100% | 34d → none |  |
| 1596 | SI SIT Functional Testing Test Exit Report Approved | 2025-08-15 A | 2025-08-15 A |  | 0% → 100% | 33d → none |  |
| 1597 | eSITAG Approves SI SIT Functional & Migration (Post-Regression) Overarching Test Exit Report | 2025-08-15 A | 2025-08-15 A |  | 0% → 100% | 615d → none |  |
| 1625 | **SIT Non-Functional Testing (all SIT PPs)** |  | 2025-08-06 A |  | 87% → 100% | 622d → none |  |
| 1631 | **SIT Non-Functional Testing Test Exit Report (all SIT PPs)** |  | 2025-08-06 A |  | 77% → 100% | 622d → none |  |
| 1634 | PPs review Exit Report and Sign PP Exit Declaration |  | 2025-07-11 A |  | 75% → 100% | 639d → none |  |
| 1637 | SRO / Code Bodies / DIP Manager formal review SI SIT Non-Functional Overarching Exit Report |  | 2025-07-18 A |  | 20% → 100% | 634d → none |  |
| 1638 | eSITWG Review status of SI SIT Non-Functional Overarching Exit Report | 2025-07-18 A | 2025-07-18 A |  | 0% → 100% | 43d → none |  |
| 1639 | SI SIT Non-Functional Overarching Exit Report published to PPs for industry review | 2025-07-18 A | 2025-07-18 A |  | 0% → 100% | 43d → none |  |
| 1640 | SI SIT Non-Functional Overarching Exit Report industry review | 2025-07-21 A | 2025-08-01 A |  | 0% → 100% | 43d → none |  |
| 1641 | SIT Non-Functional Testing Test Exit Report (all SIT PPs) Approved | 2025-08-06 A | 2025-08-06 A |  | 0% → 100% | 41d → none |  |
| 1642 | eSITAG Approves SI SIT Non-Functional Overarching Test Exit Report | 2025-08-06 A | 2025-08-06 A |  | 0% → 100% | 41d → none |  |
| 1643 | **SIT Operational Testing (all SIT PPs)** |  | 2025-08-29 A |  | 69% → 100% | 604d → none |  |
| 1657 | **SIT Operational Testing Test Exit Report (all SIT PPs)** |  | 2025-08-29 A |  | 20% → 100% | 604d → none |  |
| 1658 | Programme drafts Pathway 2 PP Exit Report (when Participant completes Operational testing) |  | 2025-07-18 A |  | 80% → 100% | 3.75d → none |  |
| 1659 | All Pathway 2 Operational Exit Reports and Exit Declarations shared with PPs | 2025-07-21 A | 2025-07-21 A |  | 0% → 100% | 633d → none |  |
| 1660 | Pathway 2 PPs have reviewed Exit Report and signed Exit Declaration | 2025-07-21 A | 2025-07-25 A |  | 0% → 100% | 629d → none |  |
| 1661 | Programme drafts Pathway 3 PP Exit Report (when Participant completes Operational testing) |  | 2025-08-08 A |  | 25% → 100% | 604d → none |  |
| 1662 | All Pathway 3 Operational Exit Reports and Exit Declarations shared with PPs | 2025-08-08 A | 2025-08-08 A |  | 0% → 100% | 614d → none |  |
| 1663 | Pathway 3 PPs have reviewed Exit Report and signed Exit Declaration | 2025-08-11 A | 2025-08-15 A |  | 0% → 100% | 614d → none |  |
| 1664 | Programme drafts Pathway 4 PP Exit Report (when Participant completes Operational testing) | 2025-08-04 A | 2025-08-15 A |  | 0% → 100% | 609d → none |  |
| 1665 | All Pathway 4 Operational Exit Reports and Exit Declarations shared with PPs | 2025-08-15 A | 2025-08-15 A |  | 0% → 100% | 609d → none |  |
| 1666 | Pathway 4 PPs have reviewed Exit Report and signed Exit Declaration | 2025-08-18 A | 2025-08-22 A |  | 0% → 100% | 609d → none |  |
| 1667 | Programme drafts Pathway 5 & 6 PP Exit Report (when Participant completes Operational testing) | 2025-08-11 A | 2025-08-29 A |  | 0% → 100% | 604d → none |  |
| 1668 | Programme drafts SI SIT Operational Overarching Exit Report |  | 2025-08-01 A |  | 23% → 100% | 621d → none |  |
| 1669 | SRO/Code Bodies/DIP Manager Review SI SIT Operational Overarching Exit Report | 2025-07-28 A | 2025-08-01 A |  | 0% → 100% | 609d → none |  |
| 1670 | eSITWG Review SI SIT Operational Overarching Exit Report | 2025-08-01 A | 2025-08-01 A |  | 0% → 100% | 614d → none |  |
| 1671 | SI SIT Operational Overarching Exit Report industry review | 2025-08-04 → 2025-08-05 A (+1d) | 2025-08-15 → 2025-08-12 A (-3d) | 10d → 6d | 0% → 100% | 614d → none |  |
| 1672 | SIT Operational Testing Test Exit Report (all SIT PPs) Approved | 2025-08-15 A | 2025-08-15 A |  | 0% → 100% | 614d → none |  |
| 1673 | eSITAG Approves SI SIT Operational Testing Test Exit Report | 2025-08-15 A | 2025-08-15 A |  | 0% → 100% | 614d → none |  |
| 1674 | SIT Complete (SIT Test Exit Report Approved) | 2025-08-22 A | 2025-08-22 A |  | 0% → 100% | 28d → none |  |
| 1675 | **UIT Environment Preparation** |  |  |  | 85% → 89% |  |  |
| 1726 | **Onboarding and Test Data (Sandbox UIT)** |  |  |  | 3% → 28% |  |  |
| 1727 | LDSO Onboarding and Test Data Creation and Support |  |  |  | 7% → 55% |  |  |
| 1728 | Supplier & Agent Onboarding and Test Data Creation and Support | 2025-09-01 A |  |  | 0% → 11% |  |  |
| 1729 | **Sandbox Execution** |  |  |  | 5% → 34% |  |  |
| 1730 | **SIT PPs Early Sandbox Testing Execution (SIT-A)** | 2025-08-08 A |  |  | 0% → 79% |  | baseline start 2025-07-21 → 2025-08-08 |
| 1731 | SIT PPs E2E Sandbox Testing Start | 2025-08-08 A | 2025-08-08 A |  | 0% → 100% | 619d → none | baseline start 2025-07-21 → 2025-08-08; baseline finish 2025-07-21 → 2025-08-08 |
| 1732 | SIT PPs E2E Sandbox Testing Execution | 2025-08-08 A |  |  | 0% → 79% |  | baseline start 2025-07-21 → 2025-08-08 |
| 1734 | **Sandbox Testing Execution (UIT) - LDSO Participants** |  |  |  | 15% → 55% |  | baseline start 2025-02-07 → 2025-05-26; baseline finish 2026-04-24 → 2026-01-22 |
| 1735 | UIT E2E Sandbox Preparation Complete |  |  |  |  |  | baseline start 2025-01-31 → 2025-05-26; baseline finish 2025-01-31 → 2025-05-26 |

| ID | Task | Start | Finish | Duration | Complete | Total float | Predecessors | Other |
| --- | --- | --- | --- | --- | --- | --- | --- | --- |
| 1737 | Sandbox Testing Execution (UIT) - LDSO Participants |  |  |  | 15% → 55% |  |  |  |
| 1739 | **Sandbox Testing Execution (UIT) - Supplier & Agent Participants** | 2025-09-01 A |  |  | 0% → 11% |  |  | baseline start 2025-02-07 → 2025-09-01; baseline finish 2026-04-24 → 2026-08-28 |
| 1740 | UIT E2E Sandbox Preparation Complete - Supplier and Agent | 2025-09-01 A | 2025-09-01 A |  | 0% → 100% | 603d → none |  | baseline start none → 2025-09-01; baseline finish none → 2025-09-01 |
| 1741 | Sandbox Testing Start (UIT) - Supplier & Agent Participants | 2025-09-01 A | 2025-09-01 A |  | 0% → 100% | 603d → none |  |  |
| 1742 | Sandbox Testing Execution (UIT) - Supplier & Agent Participants | 2025-09-01 A |  |  | 0% → 11% |  |  |  |
| 1771 | **M10 Acceptance Criteria** |  | 2025-10-10 A |  | 0% → 100% | 574d → none |  |  |
| 1772 | End of SIT MVC testing | 2025-08-22 A | 2025-08-22 A |  | 0% → 100% | 609d → none |  |  |
| 1773 | IPA M10 Assurance Report developed and agreed | 2025-09-19 A | 2025-09-19 A |  | 0% → 100% | 589d → none |  |  |
| 1775 | A minimum of 1 supplier & required contracted agents are qualified and ready to operate under new MHHS arrangements | 2025-09-12 A | 2025-09-12 A |  | 0% → 100% | 594d → none |  |  |
| 1776 | All LDSOs qualified | 2025-09-10 A | 2025-09-10 A |  | 0% → 100% | 596d → none |  |  |
| 1777 | All pre-migration data cleanse activities complete | 2025-08-13 → 2025-09-22 A (+40d) | 2025-08-13 → 2025-09-22 A (+40d) |  | 0% → 100% | 616d → none |  | constraint finish no earlier than 2025-08-13 → start no earlier than 2025-09-22; baseline start 2025-08-13 → 2025-09-22; baseline finish 2025-08-13 → 2025-09-22 |
| 1778 | All data migration activities set out in the cutover plan complete | 2025-09-24 A | 2025-09-24 A |  | 0% → 100% | 586d → none |  |  |
| 1779 | ISD fully populated by Elexon | 2025-09-22 A | 2025-09-22 A |  | 0% → 100% | 588d → none |  |  |
| 1781 | Migration Schedule approved | 2025-08-19 A | 2025-08-19 A |  | 0% → 100% | 612d → none |  |  |
| 1785 | MCC tested and ready to operate | 2025-09-19 A | 2025-09-19 A |  | 0% → 100% | 589d → none |  |  |
| 1786 | Service Delivery Operating Model in place | 2025-09-19 A | 2025-09-19 A |  | 0% → 100% | 589d → none |  |  |
| 1787 | Service Delivery Operating Model in place (Self-Certification) | 2025-07-03 A | 2025-07-03 A |  | 0% → 100% | 645d → none |  |  |
| 1789 | Early Life Support Model arrangements in place and operational | 2025-09-12 A | 2025-09-12 A |  | 0% → 100% | 594d → none |  |  |
| 1790 | Early Life Support Model arrangements in place and operational (Self-Certification) | 2025-09-12 A | 2025-09-12 A |  | 0% → 100% | 594d → none |  |  |
| 1793 | Production environment in place for LDSOs and Central Parties | 2025-09-22 A | 2025-09-22 A |  | 0% → 100% | 588d → none |  |  |
| 1794 | Service activation complete to DIP Production environment for Central Parties and LDSOs | 2025-10-10 A | 2025-10-10 A |  | 0% → 100% | 574d → none |  |  |
| 1795 | Cutover Plan executed | 2025-09-23 A | 2025-09-23 A |  | 0% → 100% | 587d → none |  |  |
| 1796 | M10 Risk Assessment undertaken | 2025-09-03 A | 2025-09-03 A |  | 0% → 100% | 601d → none |  |  |
| 1797 | Roles and responsibilities post-M10 agreed and accepted | 2025-09-19 A | 2025-09-19 A |  | 0% → 100% | 589d → none |  |  |
| 1798 | M10 Work off plan agreed (if required) | 2025-09-19 A | 2025-09-19 A |  | 0% → 100% | 589d → none |  |  |
| 1799 | Qualification Operating Model in place and operational for all post-M10 activities | 2025-09-19 A | 2025-09-19 A |  | 0% → 100% | 589d → none |  |  |
| 1800 | Programme Governance updated to reflect required changes to support Programme delivery post-M10. | 2025-07-01 → 2025-09-03 A (+64d) | 2025-07-01 → 2025-09-03 A (+64d) |  | 0% → 100% | 647d → none |  | constraint finish no earlier than 2025-07-01 → start no earlier than 2025-09-03; baseline start 2025-07-01 → 2025-09-03; baseline finish 2025-07-01 → 2025-09-03 |
| 1801 | All Suppliers and Agents have made the necessary changes to support losing an MPAN via the Forward Migration Process and gaining an MPAN via the Reverse Migration Process. | 2025-09-19 A | 2025-09-19 A |  | 0% → 100% | 589d → none |  |  |
| 1802 | Performance Assurance measures are understood and in place to maintain BAU performance during the Migration period. | 2025-09-12 A | 2025-09-12 A |  | 0% → 100% | 594d → none |  |  |
| 1803 | Programme monitoring, assurance and escalation process for beyond M10 is in place and operational | 2025-09-12 A | 2025-09-12 A |  | 0% → 100% | 594d → none |  |  |
| 1804 | Central systems ready for migrating MPANs (M10) | 2025-09-22 A | 2025-09-22 A |  | 0% → 100% | 7d → none | 1674, 3178, 3163, 3198, 3134, 3141, 2309 → 1674, 3134, 3141, 2309, 3178 |  |
| 1805 | M10 Acceptance Criteria Ratification | 2025-09-24 A | 2025-09-24 A |  | 0% → 100% | 586d → none |  |  |
| 1817 | **NON SIT LDSO QUALIFICATION** |  | 2025-08-22 A |  | 99% → 100% | 609d → none |  |  |
| 1912 | **Test Window** |  | 2025-08-22 A |  | 97% → 100% | 609d → none |  |  |
| 1925 | Potential for non-SIT LDSO QT Regression for Qualification |  | 2025-08-22 A |  | 60% → 100% | 609d → none |  |  |
| 1929 | **Non-SIT LDSO Qualification Closure** |  | 2025-06-27 A |  | 94% → 100% | 649d → none |  |  |
| 1932 | Non-SIT LDSO Qualification Closure Down |  | 2025-06-27 A |  | 50% → 100% | 649d → none |  |  |
| 1933 | **HELIX / ELEXON M10 READINESS** | 2024-04-02 A → 2022-10-31 (-519d) | 2027-07-30 → 2025-12-31 (-576d) | 869d? → 828d? | 61% → 96% | 104d → 516d |  |  |
| 1934 | **Service Management - M10 Readiness** |  | 2027-07-30 → 2025-09-24 A (-674d) | 630d → 147d | 33% → 100% | 104d → none |  |  |
| 1935 | **Service Model Design (Cross Party Service Desk)** |  | 2025-08-13 → 2025-09-05 A (+23d) | 118d → 135d | 82% → 100% | 616d → none |  |  |
| 1951 | **Service Documentation** |  | 2025-08-13 A |  | 82% → 100% | 616d → none |  |  |
| 1964 | **Service Documentation V2** |  | 2025-08-13 A |  | 17% → 100% | 616d → none |  |  |
| 1967 | Operations Manual and LLSD v2 Consultation | 2025-07-17 A | 2025-07-30 A |  | 0% → 100% | 616d → none |  |  |
| 1968 | Operations Manual and LLSD v2 Consultation Completed | 2025-07-30 A | 2025-07-30 A |  | 0% → 100% | 616d → none |  |  |
| 1969 | Consultation Feedback Implemented Operations Manual and LLSD v2 | 2025-07-31 A | 2025-08-06 A |  | 0% → 100% | 616d → none |  |  |
| 1970 | Operations Manual and LLSD v2 Feedback Implemented | 2025-08-06 A | 2025-08-06 A |  | 0% → 100% | 616d → none |  |  |
| 1971 | TORWG Paper Day | 2025-08-06 A | 2025-08-06 A |  | 0% → 100% | 616d → none |  |  |
| 1972 | TORWG Operations Manual and LLSD v2 Approval | 2025-08-13 A | 2025-08-13 A |  | 0% → 100% | 616d → none |  |  |
| 1973 | Operations Manual and LLSD v2 Approved and Completed | 2025-08-13 A | 2025-08-13 A |  | 0% → 100% | 616d → none |  |  |
| 1974 | **LDSO Onboarding - Phase 1** |  | 2025-07-30 A |  | 56% → 100% | 626d → none |  | was named LDSO Onboarding |
| 1975 | LDSO Communication and Information Gathering - Phase 1 |  | 2025-07-16 A |  | 89% → 100% | 636d → none |  | was named LDSO Communication and Information Gathering |
| 1977 | LDSO ServiceNow Configuration - Phase 1/2 |  | 2025-07-23 A |  | 30% → 100% | 631d → none |  | was named LDSO ServiceNow Configuration |
| 1979 | LDSO Testing and Further Communication - Phase 1 | 2025-07-23 A | 2025-07-30 A |  | 0% → 100% | 593d → none |  | was named LDSO Testing and Further Communication |
| 1981 | LDSOs Onboarded into Elexon ServiceNow - Phase 1 | 2025-07-30 A | 2025-07-30 A |  | 0% → 100% | 593d → none |  | was named LDSOs Onboarded |
| 1987 | **Operational Readiness Testing** |  | 2025-08-29 → 2025-08-12 A (-17d) | 130d → 116d | 71% → 100% | 604d → none |  |  |
| 2022 | **ORT Exit** |  | 2025-07-31 A |  | 13% → 100% | 625d → none |  |  |
| 2023 | ORT Wrap Up |  | 2025-07-18 A |  | 20% → 100% | 600d → none |  |  |
| 2024 | ORT Exit Report |  | 2025-07-25 A |  | 10% → 100% | 625d → none |  |  |
| 2025 | ORT Exit Report Shared with Participants | 2025-07-25 A | 2025-07-25 A |  | 0% → 100% | 625d → none |  |  |
| 2026 | ORT eSITWG Exit Report Endorsement | 2025-07-31 A | 2025-07-31 A |  | 0% → 100% | 625d → none |  |  |
| 2027 | **Codification of Service** |  | 2025-08-29 → 2025-08-12 A (-17d) | 81d → 67d | 33% → 100% | 537d → none |  |  |
| 2031 | **Service Go-Live** | 2025-07-31 A | 2027-07-30 → 2025-09-15 A (-683d) | 522d → 32d | 0% → 100% | 104d → none |  |  |
| 2032 | Service Management Ready (inc. Partners) | 2025-07-31 A | 2025-07-31 A |  | 0% → 100% | 592d → none | Service Management Go/No Go Decision → none | was named Helix Service Management Live |
| 2033 | Helix Service Management Live for LDSO DIP Onboarding | 2025-08-04 A | 2025-08-04 A |  | 0% → 100% | 591d → none |  |  |
| 2034 | Helix Service Management Live for MHHS Enduring Arrangements | 2025-09-01 → 2025-09-15 A (+14d) | 2027-07-30 → 2025-09-15 A (-683d) | 500d → 0d | 0% → 100% | 104d → none |  | constraint start no earlier than 2025-09-01 → start no earlier than 2025-09-15; baseline start 2025-09-01 → 2025-09-15; baseline finish 2027-07-30 → 2025-09-15 |
| 2039 | **Business Readiness (inc DIP)** | 2024-04-02 A → 2025-04-07 A (+370d) | 2025-12-31 → 2025-10-17 (-75d) | 457d? → 140d? | 62% → 99% | 516d → 569d |  |  |
| 2041 | Elexon Leading Triage |  | 2025-08-29 → 2025-09-01 A (+3d) | 55d → 56d | 38% → 100% | 104d → none |  | baseline finish 2025-08-29 → 2025-09-01 |
| 2042 | MHHS Transition (Knowledge Transfer) |  | 2025-08-01 A |  | 78% → 100% | 624d → none |  |  |
| 2043 | Artefact Handshake with MHHS | 2025-08-01 → 2025-09-01 A (+31d) | 2025-08-01 → 2025-09-01 A (+31d) |  | 0% → 100% | 624d → none |  | constraint none → finish no earlier than 2025-09-01 |
| 2044 | Operational Control Centre (OCC) Development |  | 2025-08-01 A |  | 84% → 100% | -83d → none |  |  |

| ID | Task | Start | Finish | Duration | Complete | Total float | Predecessors | Other |
| --- | --- | --- | --- | --- | --- | --- | --- | --- |
| 2045 | Operational Control Centre (OCC) Live (Service and ULT Triage) | 2025-08-04 A | 2025-08-04 A |  | 0% → 100% | -83d → none |  |  |
| 2046 | Operational Control Centre (OCC) Live | 2025-08-29 A | 2025-08-29 A |  | 0% → 100% | 604d → none |  |  |
| 2047 | **DIP Guidance Notes** |  | 2025-07-18 A |  | 75% → 100% | 634d → none |  |  |
| 2048 | GN/LWI creation & publication |  | 2025-07-18 A |  | 75% → 100% | 634d → none |  |  |
| 2051 | Tranche 3 GN/LWI created & published | 2025-07-18 A | 2025-07-18 A |  | 0% → 100% | 601d → none |  |  |
| 2052 | DIP Reporting (M11) |  | 2025-08-08 → 2025-10-17 (+70d) | 65d → 115d | 71% → 97% | 619d → 569d |  | baseline finish 2025-08-08 → 2025-10-17 |
| 2053 | Functional Training Execution |  | 2025-08-29 → 2025-09-12 A (+14d) | 85d → 95d | 60% → 100% | 604d → none |  |  |
| 2069 | **Operational Readiness E2E Testing** |  |  |  | 76% → 100% |  |  |  |
| 2070 | Phase 1 Test Execution (Service Activation and Participant Management) |  | 2025-07-18 → 2025-08-13 A (+26d) | 48d → 66d | 92% → 100% | 634d → none |  |  |
| 2071 | Phase 2 Test Execution (S&I) |  | 2025-07-18 → 2025-08-20 A (+33d) | 22d → 45d | 82% → 100% | 634d → none |  |  |
| 2072 | Phase 3 Test Execution (Assurance & mop-up) | 2025-07-15 → 2025-07-21 A (+6d) | 2025-07-30 → 2025-08-22 A (+23d) | 12d → 25d | 0% → 100% | 626d → none |  | constraint start no earlier than 2025-07-15 → start no earlier than 2025-07-21 |
| 2073 | E2E Operational Testing Completed | 2025-07-30 → 2025-09-05 A (+37d) | 2025-07-30 → 2025-09-05 A (+37d) |  | 0% → 100% | 626d → none |  | constraint none → finish no earlier than 2025-09-05 |
| 2074 | **Service Activation Readiness** |  |  |  | 56% → 89% |  |  |  |
| 2075 | **Phase 1 - Preparation** |  | 2025-08-29 → 2025-09-05 A (+7d) | 369d? → 374d? | 85% → 100% | 604d → none |  |  |
| 2095 | **Operational Training for Service Activation** |  | 2025-08-29 → 2025-08-25 A (-4d) | 77d → 73d | 56% → 100% | 604d → none |  |  |
| 2096 | Training Execution [Placeholder] |  | 2025-08-29 → 2025-08-25 A (-4d) | 77d → 73d | 56% → 100% | 604d → none |  |  |
| 2097 | Service Activation Training Completed | 2025-08-29 → 2025-08-25 A (-4d) | 2025-08-29 → 2025-08-25 A (-4d) |  | 0% → 100% | 604d → none |  |  |
| 2098 | **Service Activation Readiness** | 2025-08-04 A | 2025-08-12 A |  | 0% → 100% | -89d → none |  |  |
| 2099 | Dress Rehearsal 1 | 2025-08-04 A | 2025-08-05 A |  | 0% → 100% | -89d → none |  |  |
| 2100 | Dress Rehearsal 1 Complete | 2025-08-05 A | 2025-08-05 A |  | 0% → 100% | -89d → none |  |  |
| 2101 | Dress Rehearsal 2 | 2025-08-11 A | 2025-08-12 A |  | 0% → 100% | -89d → none |  |  |
| 2102 | Dress Rehearsal 2 Complete | 2025-08-12 A | 2025-08-12 A |  | 0% → 100% | -89d → none |  |  |
| 2103 | **Service Activation Go / No Go** | 2025-08-22 A | 2025-08-22 A |  | 0% → 100% | -96d → none |  |  |
| 2104 | **Final Service Activation Go/No Go Decision** | 2025-08-22 A | 2025-08-22 A |  | 0% → 100% | -96d → none |  |  |
| 2105 | DIP Team Ready | 2025-08-22 A | 2025-08-22 A |  | 0% → 100% | 609d → none |  |  |
| 2106 | DIP Technical Onboarding Processes Completed | 2025-08-22 A | 2025-08-22 A |  | 0% → 100% | -96d → none |  |  |
| 2107 | PM Team Ready | 2025-08-22 A | 2025-08-22 A |  | 0% → 100% | -96d → none |  |  |
| 2108 | Operational Support Ready (Ops Control Centre, Account Managers) | 2025-08-22 A | 2025-08-22 A |  | 0% → 100% | -96d → none |  |  |
| 2109 | Service Management Activity Completed (Resolver Groups) | 2025-08-22 A | 2025-08-22 A |  | 0% → 100% | -96d → none |  |  |
| 2110 | Process 1.1.1 ISD and Related LWIs Completed | 2025-08-22 A | 2025-08-22 A |  | 0% → 100% | -96d → none |  |  |
| 2111 | **SOLR Consultation** |  | 2025-08-26 → 2025-09-05 A (+10d) | 99d? → 107d? | 77% → 100% | 607d → none |  |  |
| 2114 | **SOLR consultation** |  |  |  | 78% → 100% |  |  |  |
| 2115 | SOLR consultation |  | 2025-07-31 A |  | 78% → 100% | 625d → none |  |  |
| 2119 | GLIG (Second presentation) | 2025-07-18 A | 2025-07-18 A |  | 0% → 100% | 635d → none |  |  |
| 2122 | SOLR comms to MHHS for review | 2025-08-26 → 2025-08-27 A (+1d) | 2025-08-26 → 2025-08-27 A (+1d) |  | 0% → 100% | 607d → none |  |  |
| 2123 | **MDR Process** |  | 2025-07-31 A |  | 60% → 100% | 625d → none |  |  |
| 2128 | MDR consultation ongoing actions |  | 2025-07-31 A |  | 50% → 100% | 625d → none |  |  |
| 2129 | Service Activation Go / No Go | 2025-08-22 A | 2025-08-22 A |  | 0% → 100% | -97d → none | 2106FF, 2107FF, 2108FF, 2109FF, 2045FF, 2110FF, Service Activation Implementation, 2306 → 2106, 2107, 2108FF, 2109FF, 2045FF, 2110 | constraint finish no earlier than 2025-08-22 → none |
| 2130 | **Phase 2 - Implementation** |  |  |  | 2% → 66% |  |  |  |
| 2133 | **M10-Ready Activation Preparation Tasks** | 2025-08-25 A | 2025-09-08 → 2025-09-12 A (+4d) | 11d? → 15d? | 0% → 100% | 598d → none |  |  |
| 2134 | Identify Resources | 2025-08-25 A | 2025-08-25 A |  | 0% → 100% | 608d → none | 2129 → none |  |
| 2135 | Confirmation from Qualification of Wave Participants Complete | 2025-08-25 A | 2025-08-25 A |  | 0% → 100% | 609d → none |  |  |
| 2136 | Agree & Understand Support Model | 2025-08-26 A | 2025-08-26 A |  | 0% → 100% | 607d → none |  |  |
| 2137 | Confirm Training complete | 2025-08-27 A | 2025-08-27 A |  | 0% → 100% | 607d → none |  |  |
| 2138 | Confirm IDNOs global sign completed prior to M10 | 2025-08-28 A | 2025-08-28 → 2025-09-05 A (+8d) | 1d → 7d | 0% → 100% | 605d → none |  | was named Confirm IDNOs gobal sigin comleted prior to M10; constraint start no earlier than 2025-08-28 → finish no earlier than 2025-09-05 |
| 2139 | Engagement / Communications with Participants | 2025-08-29 A | 2025-08-29 → 2025-09-10 A (+12d) | 1d → 9d | 0% → 100% | 604d → none |  | constraint start no earlier than 2025-08-29 → finish no earlier than 2025-09-10 |
| 2140 | **Internal Communications** | 2025-09-01 A | 2025-09-01 A |  | 0% → 100% | 603d → none |  |  |
| 2141 | Agree Content for Livewire | 2025-09-01 A | 2025-09-01 A |  | 0% → 100% | 603d → none |  |  |
| 2142 | Publish Content for Livewire | 2025-09-01 A | 2025-09-01 A |  | 0% → 100% | 604d → none |  |  |
| 2143 | Validate User Access | 2025-09-02 A | 2025-09-02 A |  | 0% → 100% | 596d → none |  |  |
| 2144 | Target Systems and Environments Ready | 2025-09-03 A | 2025-09-03 A |  | 0% → 100% | 595d → none |  |  |
| 2145 | Publish the guidence with Parties | 2025-09-04 → 2025-09-12 A (+8d) | 2025-09-04 → 2025-09-12 A (+8d) |  | 0% → 100% | 592d → none |  | constraint start no earlier than 2025-09-04 → start no earlier than 2025-09-12 |
| 2146 | Provide LWIs | 2025-09-05 → 2025-09-12 A (+7d) | 2025-09-05 → 2025-09-12 A (+7d) |  | 0% → 100% | 592d → none | 2145 → none | constraint none → finish no earlier than 2025-09-12 |
| 2147 | Business Readiness Governance Approval | 2025-09-08 A | 2025-09-08 A |  | 0% → 100% | 592d → none |  |  |
| 2148 | M10-Ready Participants Service Activation Preparation Completed | 2025-09-08 A | 2025-09-08 A |  | 0% → 100% | 598d → none | 2134, 2136, 2137, 2138, 2139, 2140, 2143, 2144, 2145, 2147 → 2134, 2136, 2137, 2138, 2140, 2143, 2144, 2147 |  |
| 2149 | **M10-Ready (Inlcuding Non-SIT LDSOs) Service Activation Implementation** | 2025-09-10 A | 2025-09-19 A |  | 0% → 100% | 590d → none |  |  |
| 2150 | MHHSP Enabled Confirmation | 2025-09-10 A | 2025-09-10 A |  | 0% → 100% | 590d → none | REC Code Manager / BSC PAB Approval of Qualification, 2387, 2390 → 2387, 2390 |  |
| 2151 | Add EFD (ISD Calendar Date) to DIP | 2025-09-11 A | 2025-09-11 A |  | 0% → 100% | 590d → none |  |  |
| 2152 | Non-SIT LDSO PP DIP User Promoted to Production | 2025-09-12 A | 2025-09-12 A |  | 0% → 100% | 594d → none |  |  |
| 2153 | Create M16 in Customer Solution Started | 2025-09-11 A | 2025-09-11 A |  | 0% → 100% | 594d → none |  |  |
| 2154 | Create M16 in Customer Solution | 2025-09-11 A | 2025-09-11 A |  | 0% → 100% | 594d → none |  |  |
| 2155 | DIP Production Success Checks | 2025-09-12 A | 2025-09-12 A |  | 0% → 100% | 594d → none |  |  |
| 2156 | 1st ISD Publish Started | 2025-09-11 A | 2025-09-11 A |  | 0% → 100% | 590d → none |  |  |
| 2157 | 1st ISD Publish (7 day window for this activity is consistent with Code requirements) | 2025-09-11 A | 2025-09-18 A |  | 0% → 100% | 590d → none |  |  |
| 2158 | Go Live ISD | 2025-09-18 A | 2025-09-18 A |  | 0% → 100% | 590d → none |  |  |
| 2159 | M10-Ready Service Activation Implementation Completed | 2025-09-19 A | 2025-09-19 A |  | 0% → 100% | 590d → none |  |  |
| 2160 | **M10-Ready Service Activation Implementation MDD** | 2025-09-10 A | 2025-09-18 A |  | 0% → 100% | 590d → none |  |  |
| 2161 | MDD Final Circular Completed | 2025-09-10 A | 2025-09-10 A |  | 0% → 100% | 596d → none |  |  |
| 2162 | MDD Manual Update | 2025-09-11 A | 2025-09-15 A |  | 0% → 100% | 593d → none |  |  |
| 2163 | MDD Publish | 2025-09-11 A | 2025-09-18 A |  | 0% → 100% | 590d → none |  |  |

| ID | Task | Start | Finish | Duration | Complete | Total float | Predecessors | Other |
| --- | --- | --- | --- | --- | --- | --- | --- | --- |
| 2164 | MDD Go Live | 2025-09-18 A | 2025-09-18 A |  | 0% → 100% | 590d → none |  |  |
| 2165 | Non-SIT LDSO & SIT MVC Service Activation Implementation MDD Completed | 2025-09-18 A | 2025-09-18 A |  | 0% → 100% | 590d → none |  |  |
| 2166 | **Non-SIT LDSO & SIT Service Activation Hypercare (M10 Ready)** | 2025-09-18 A | 2025-12-02 A |  | 0% → 100% | 537d → none |  |  |
| 2167 | Monitoring | 2025-09-18 A | 2025-12-02 A |  | 0% → 100% | 537d → none |  |  |
| 2168 | Reporting | 2025-09-18 A | 2025-12-02 A |  | 0% → 100% | 537d → none |  |  |
| 2169 | Issue Management | 2025-09-18 A | 2025-12-02 A |  | 0% → 100% | 537d → none |  |  |
| 2170 | Closed Down Activities | 2025-09-19 A | 2025-09-19 A |  | 0% → 100% | 589d → none |  |  |
| 2171 | Inform MHHSP | 2025-09-19 A | 2025-09-19 A |  | 0% → 100% | 589d → none |  |  |
| 2176 | **M11-Ready Service Activation Implementation** | 2025-09-25 A |  |  | 0% → 61% |  |  |  |
| 2185 | **Pathway 5 PPs** | 2025-10-15 A | 2025-10-22 A |  | 0% → 100% | 566d → none |  |  |
| 2186 | MHHSP Enabled Confirmation | 2025-10-15 A | 2025-10-15 A |  | 0% → 100% | 566d → none |  |  |
| 2187 | Add EFD (ISD Calendar Date) to DIP | 2025-10-15 A | 2025-10-15 A |  | 0% → 100% | 570d → none |  |  |
| 2188 | Create M16 in Customer Solution | 2025-10-16 A | 2025-10-16 A |  | 0% → 100% | 570d → none |  |  |
| 2189 | DIP Production Success Checks | 2025-10-16 A | 2025-10-16 A |  | 0% → 100% | 570d → none |  |  |
| 2190 | Publish ISD | 2025-10-16 A | 2025-10-22 A |  | 0% → 100% | 566d → none |  |  |
| 2191 | Go Live ISD | 2025-10-22 A | 2025-10-22 A |  | 0% → 100% | 566d → none |  |  |
| 2192 | Publish MDD | 2025-10-16 A | 2025-10-22 A |  | 0% → 100% | 566d → none |  |  |
| 2193 | MDD Go Live | 2025-10-22 A | 2025-10-22 A |  | 0% → 100% | 566d → none |  |  |
| 2194 | Pathway 5 Service Activation Implementation Completed | 2025-10-22 A | 2025-10-22 A |  | 0% → 100% | 566d → none |  |  |
| 2213 | Publish MDD |  |  |  |  |  |  | baseline start none → 2025-10-31; baseline finish none → 2025-11-07 |
| 2214 | MDD Go Live |  |  |  |  |  |  | baseline start none → 2025-11-07; baseline finish none → 2025-11-07 |
| 2233 | **Helix Solution Build** |  | 2025-08-08 → 2025-09-18 A (+41d) | 255d? → 284d? | 91% → 100% | 619d → none |  |  |
| 2234 | M10 Build Candidate |  | 2025-07-08 → 2025-08-15 A (+38d) | 52d → 80d | 98% → 100% | 1.98d → none |  |  |
| 2235 | Helix Code Uplifts | 2025-07-09 A → 2025-08-18 A (+40d) | 2025-08-01 → 2025-09-18 A (+48d) | 18d → 24d | 11% → 100% | 624d → none |  | was named Helix Code Uplifts (TBC); baseline start 2025-07-09 → 2025-08-18; baseline finish 2025-08-08 → 2025-09-18 |
| 2236 | **Helix E2E Settlement Assurance Testing (SAT)** |  | 2025-08-07 → 2025-08-15 A (+8d) | 254d? → 260d? | 96% → 100% | 620d → none |  |  |
| 2245 | **Execution** |  | 2025-08-07 → 2025-08-15 A (+8d) | 194d → 200d | 91% → 100% | 620d → none |  |  |
| 2282 | **SAT Cycle 2** | 2025-07-17 A | 2025-08-01 A |  | 0% → 100% | -81d → none |  |  |
| 2283 | **Legacy** | 2025-07-17 A | 2025-08-01 A |  | 0% → 100% | 624d → none |  |  |
| 2284 | Pre-M10 | 2025-07-17 A | 2025-07-17 A |  | 0% → 100% | 635d → none |  |  |
| 2285 | GMT & BST & Long | 2025-07-18 A | 2025-07-25 A |  | 0% → 100% | 624d → none |  |  |
| 2286 | NESO Validation Period (GMT & BST & Long) | 2025-07-28 A | 2025-08-01 A |  | 0% → 100% | 624d → none |  |  |
| 2287 | Trading Dispute | 2025-07-28 A | 2025-07-29 A |  | 0% → 100% | 627d → none |  |  |
| 2288 | **Transition** | 2025-07-24 A | 2025-07-29 A |  | 0% → 100% | 627d → none |  |  |
| 2289 | ISD | 2025-07-24 A | 2025-07-29 A |  | 0% → 100% | 627d → none |  |  |
| 2290 | Data Agg | 2025-07-24 A | 2025-07-28 A |  | 0% → 100% | 628d → none |  |  |
| 2291 | End of Cycle 2 | 2025-08-01 A | 2025-08-01 A |  | 0% → 100% | -92d → none |  |  |
| 2292 | SAT Exit Report | 2025-08-01 A | 2025-08-07 → 2025-08-15 A (+8d) | 5d → 11d | 0% → 100% | -92d → none |  | baseline finish 2025-08-07 → 2025-08-15 |
| 2293 | SAT Complete | 2025-08-01 A | 2025-08-01 A |  | 0% → 100% | -91d → none |  |  |
| 2294 | DR Testing |  | 2025-07-31 → 2025-08-29 A (+29d) | 69d → 90d | 74% → 100% | 625d → none |  |  |
| 2296 | Production Environment Build |  | 2025-07-31 → 2025-08-15 A (+15d) | 24d → 35d | 25% → 100% | 0d → none |  |  |
| 2297 | Production Environment Base Platform Sign-off | 2025-08-08 → 2025-08-15 A (+7d) | 2025-08-08 → 2025-08-15 A (+7d) |  | 0% → 100% | -97d → none |  | baseline start 2025-07-31 → 2025-08-08; baseline finish 2025-07-31 → 2025-08-08 |
| 2298 | **Implementation (Helix & DIP)** |  | 2025-10-06 A |  | 47% → 100% | 578d → none |  |  |
| 2299 | Go / No-Go (DIP & SM) | 2025-07-31 A | 2025-07-31 A |  | 0% → 100% | 592d → none |  |  |
| 2300 | Implementation Readiness (inc Technical Readiness, Approach and Runbook, Walkthrough / Rehearsals |  | 2025-08-04 A |  | 72% → 100% | 623d → none |  | baseline finish 2025-07-31 → 2025-08-04 |
| 2303 | Final Production Deployment |  | 2025-07-31 → 2025-08-15 A (+15d) | 19d → 30d | 5% → 100% | 591d → none |  | baseline finish 2025-08-01 → 2025-07-31 |
| 2304 | DIP Portal Available | 2025-08-04 A | 2025-08-04 A |  | 0% → 100% | 590d → none |  |  |
| 2305 | Go / No-Go (Helix Central Systems) | 2025-08-08 → 2025-08-12 A (+4d) | 2025-08-08 → 2025-08-12 A (+4d) |  | 0% → 100% | -97d → none |  | constraint finish no earlier than 2025-08-08 → start no earlier than 2025-08-12; baseline start 2025-08-11 → 2025-08-08; baseline finish 2025-08-11 → 2025-08-08 |
| 2306 | ISD Data Migration | 2025-08-15 → 2025-08-18 A (+3d) | 2025-08-22 → 2025-08-29 A (+7d) | 6d → 10d | 0% → 100% | -97d → none | 2305FS+4d, 2292, ISD Dress Rehearsals → 2305, 2292 |  |
| 2307 | DAH & ISD Dark Mode | 2025-08-26 → 2025-09-01 A (+6d) | 2025-08-26 → 2025-09-01 A (+6d) |  | 0% → 100% | 24d → none | 2306FS+2d → 2306 | constraint none → start no earlier than 2025-09-01 |
| 2308 | VAS Inspection pre-prod | 2025-08-27 A | 2025-09-17 A |  | 0% → 100% | 8d → none | 2307SS-1d → none | was named Dual Run (Pre-Prod); baseline finish 2025-09-16 → 2025-09-17 |
| 2309 | M10 Cutover Weekend (20/09 and 21/09) | 2025-09-19 A | 2025-09-22 A |  | 0% → 100% | 7d → none |  |  |
| 2310 | Post Implementation Review | 2025-10-06 A | 2025-10-06 A |  | 0% → 100% | 578d → none |  |  |
| 2314 | **S & A QUALIFICATION** |  |  |  | 67% → 76% |  |  |  |
| 2315 | **MHHS Qualification - Qualification Deliverables** |  | 2025-10-17 A |  | 97% → 100% | 315d → none |  |  |
| 2343 | **Qualification Assessment Document** |  | 2025-10-17 A |  | 94% → 100% | 315d → none |  |  |
| 2362 | **Qualification Assessment Document Portal** |  | 2025-10-17 A |  | 88% → 100% | 315d → none |  |  |
| 2372 | QT Wave 3 Participant QAD Application Creation in Portal | 2025-07-28 A | 2025-08-08 A |  | 0% → 100% | 365d → none |  |  |
| 2373 | QT Wave 4 Participant QAD Application Creation in Portal | 2025-10-06 A | 2025-10-17 A |  | 0% → 100% | 235d → none |  |  |
| 2376 | **MHHS Qualification - SIT Participants** |  |  |  | 74% → 91% |  |  |  |
| 2381 | **MHHS Qualification - M10-Ready** |  | 2025-09-10 A |  | 96% → 100% | 596d → none |  |  |
| 2385 | **SIT / LDSO Pathway 2** | 2025-08-07 A | 2025-08-28 A |  | 0% → 100% | 599d → none |  |  |
| 2386 | QAD Sign Off Deadline + Test Reports | 2025-08-07 A | 2025-08-07 A |  | 0% → 100% | 599d → none |  |  |
| 2387 | REC Code Manager / BSC PAB Approval of Qualification (M10-Ready) | 2025-08-28 A | 2025-08-28 A |  | 0% → 100% | 599d → none |  |  |
| 2388 | **SIT / LDSO Pathway 3** | 2025-08-22 A | 2025-09-10 A |  | 0% → 100% | 590d → none |  |  |
| 2389 | QAD Sign Off Deadline + Test Reports | 2025-08-22 A | 2025-08-22 A |  | 0% → 100% | 590d → none |  |  |
| 2390 | REC Code Manager / BSC PAB Approval of Qualification (M10-Ready) | 2025-09-09 A | 2025-09-10 A |  | 0% → 100% | 590d → none |  |  |
| 2391 | M10-Ready SIT Participants are qualified | 2025-09-10 A | 2025-09-10 A |  | 0% → 100% | 596d → none |  |  |
| 2392 | **MHHS Qualification - M11-Ready** |  | 2025-10-15 A |  | 99% → 100% | 571d → none |  |  |
| 2396 | **SIT Pathway 4** | 2025-09-04 A | 2025-09-25 A |  | 0% → 100% | 579d → none |  |  |
| 2397 | QAD Sign Off Deadline + Test Reports | 2025-09-04 A | 2025-09-04 A |  | 0% → 100% | 579d → none |  |  |

| ID | Task | Start | Finish | Complete | Total float | Other |
| --- | --- | --- | --- | --- | --- | --- |
| 2398 | REC Code Manager / BSC PAB Approval of Qualification (M11-Ready) | 2025-09-25 A | 2025-09-25 A | 0% → 100% | 579d → none |  |
| 2399 | **SIT Pathway 5** | 2025-09-24 A | 2025-10-15 A | 0% → 100% | 566d → none |  |
| 2400 | QAD Sign Off Deadline + Test Reports | 2025-09-24 A | 2025-09-24 A | 0% → 100% | 566d → none |  |
| 2401 | REC Code Manager / BSC PAB Approval of Qualification | 2025-10-15 A | 2025-10-15 A | 0% → 100% | 566d → none |  |
| 2402 | 'M11-Ready SIT Participants are qualified' | 2025-10-15 A | 2025-10-15 A | 0% → 100% | 571d → none |  |
| 2403 | **MHHS Qualification - Not M11-Ready** |  |  | 37% → 78% |  |  |
| 2405 | SIT Not M11-Ready Participants submit Final QAD |  | 2025-09-19 A | 47% → 100% | 564d → none |  |
| 2413 | **MHHS Qualification - Non-SIT LDSO (M10-Ready)** |  | 2025-09-11 A | 97% → 100% | 595d → none |  |
| 2423 | QAD Finalisation |  | 2025-08-19 A | 90% → 100% | 599d → none |  |
| 2424 | QAD Sign Off Deadline (Non-SIT LDSOs) | 2025-08-22 A | 2025-08-22 A | 0% → 100% | 596d → none |  |
| 2425 | BSC PAB & REC Manager approval of Qualification for Non-SIT LDSOs | 2025-09-11 A | 2025-09-11 A | 0% → 100% | 595d → none |  |
| 2426 | **MHHS Qualification - Qualification Waves** |  |  | 60% → 69% |  |  |
| 2427 | **Qualification Wave Prep** |  |  | 96% → 98% | 480d → 331d |  |
| 2465 | **Qualification Testing Framework (Test Stubs and Supporting UI)** |  |  | 96% → 98% | 480d → 331d |  |
| 2531 | **MPANs, DIP Messages, Settlement, Consumption, Reference** |  |  | 88% → 94% |  |  |
| 2571 | **Wave 1 Test Data** |  |  | 4% → 100% |  |  |
| 2572 | Test Data Request + Templates Completed |  | 2025-07-15 A | 50% → 100% | 448d → none |  |
| 2573 | Test Data Generated | 2025-07-16 A | 2025-07-17 A | 0% → 100% | 448d → none |  |
| 2574 | Test Data Loaded into QP Systems | 2025-07-18 A | 2025-08-07 A | 0% → 100% | 448d → none |  |
| 2575 | Test Data Loaded into QTF + ADO | 2025-08-11 A | 2025-08-15 A | 0% → 100% | 447d → none |  |
| 2576 | **Wave 2 Test Data** |  |  | 0% → 100% |  |  |
| 2577 | Test Data Request + Templates Completed | 2025-09-17 A | 2025-09-18 A | 0% → 100% | 411d → none |  |
| 2578 | Test Data Generated | 2025-09-19 A | 2025-09-22 A | 0% → 100% | 411d → none |  |
| 2579 | Test Data Loaded into QP Systems | 2025-09-23 A | 2025-10-13 A | 0% → 100% | 411d → none |  |
| 2580 | Test Data Loaded into QTF + ADO | 2025-10-14 A | 2025-10-17 A | 0% → 100% | 411d → none |  |
| 2598 | Qualification Testing Wave Readiness Confirmed | 2025-08-21 A | 2025-08-21 A | 0% → 100% | 611d → none |  |
| 2607 | **Qualification Wave 1** |  |  | 15% → 61% |  |  |
| 2608 | **Qualification Wave 1 QAD Prep** |  | 2025-08-22 A | 31% → 100% | 441d → none |  |
| 2610 | Qualification Wave 1 Participants Submit Initial QAD |  | 2025-07-11 A | 50% → 100% | 441d → none |  |
| 2611 | Qualification Wave 1 Participants have submitted their initial QAD | 2025-07-14 A | 2025-07-14 A | 0% → 100% | 441d → none |  |
| 2612 | Code Bodies review of Wave 1 Participants Initial QAD | 2025-07-14 A | 2025-08-22 A | 0% → 100% | 441d → none |  |
| 2613 | Completion of Code Bodies review of Initial QAD | 2025-08-22 A | 2025-08-22 A | 0% → 100% | 441d → none |  |
| 2614 | **Qualification Wave 1 Test Prep** |  |  | 32% → 99% |  |  |
| 2616 | Qualification Wave 1 Participants DIP Onboarding Window |  |  | 50% → 95% | 466d → 639d |  |
| 2618 | Qualification Wave 1 Participants' to provide status of PIT completion and submit QT Test Plan | 2025-07-14 A | 2025-07-14 A | 0% → 100% | 639d → none |  |
| 2619 | Review of Participants' PIT Status and QT Test Plan |  | 2025-08-15 A | 49% → 100% | 441d → none |  |
| 2620 | Qualification Test Plans for Wave 1 Participants approved | 2025-08-15 A | 2025-08-15 A | 0% → 100% | 441d → none |  |
| 2621 | Qualification Wave 1 Participants have submitted PIT Test Completion Report and evidence for QT Entry | 2025-07-14 A | 2025-07-14 A | 0% → 100% | 2d → none |  |
| 2622 | Review of Participants PIT Test Completion Report | 2025-07-14 A | 2025-08-15 A | 0% → 100% | 2d → none |  |
| 2623 | Onboarding to QTF & ADO |  | 2025-08-15 A | 8% → 100% | 447d → none |  |
| 2624 | **Qualification Wave 1 QT Execution** | 2025-08-18 A |  | 0% → 27% | 441d → 440d |  |
| 2625 | Review Entry Criteria Evidence for each Wave 1 Participant | 2025-08-18 A | 2025-08-22 A | 0% → 100% | 441d → none |  |
| 2626 | ALL Qualification Wave 1 Participant Test Readiness Confirmed | 2025-08-22 A | 2025-08-22 A | 0% → 100% | 441d → none | was named Qualification Wave 1 Participant Test Readiness Confirmed |
| 2627 | Qualification Wave 1 QT Execution Start | 2025-08-25 A | 2025-08-25 A | 0% → 100% | 441d → none |  |
| 2628 | Qualification Wave 1 QT Execution Window | 2025-08-25 A |  | 0% → 23% | 446d → 440d |  |
| 2630 | **Qualification Wave 1 Exit** | 2025-08-25 A |  | 0% → 30% | 441d → 435d |  |
| 2631 | Final QAD Submission window opens | 2025-08-25 A | 2025-08-25 A | 0% → 100% | 441d → none |  |
| 2632 | Qualification Wave 1 Participants submit their Final QAD | 2025-08-25 A |  | 0% → 40% | 441d → 435d |  |
| 2637 | **Qualification Wave 2** |  |  | 5% → 26% |  |  |
| 2638 | **Qualification Wave 2 QAD Prep** |  |  | 22% → 74% | 410d → 569d |  |
| 2640 | Qualification Wave 2 Participants Submit Initial QAD |  |  | 30% → 89% | 410d → 8d |  |
| 2642 | Code Bodies review of Wave 2 Participants' Initial QAD | 2025-09-15 A |  | 0% → 32% | 410d → 569d |  |
| 2644 | **Qualification Wave 2 Test Prep** | 2025-07-21 A |  | 0% → 33% | 416d → 574d |  |
| 2645 | Confirmation from Qualification Wave 2 Participants that DIP Onboarding has commenced | 2025-07-21 A | 2025-07-21 A | 0% → 100% | 435d → none |  |
| 2646 | Qualification Wave 2 Participants DIP Onboarding Window | 2025-07-21 A |  | 0% → 77% | 435d → 599d |  |
| 2649 | Review of Participants' PIT Status and QT Test Plan | 2025-08-18 A |  | 0% → 13% | 435d → 599d |  |
| 2652 | Review of Participants' PIT Test Completion Report | 2025-09-08 A |  | 0% → 8% | 410d → 574d |  |
| 2653 | Onboarding to QTF & ADO | 2025-09-08 A |  | 0% → 8% | 416d → 574d |  |
| 2654 | **Qualification Wave 2 QT Execution** | 2025-10-13 A |  | 0% → 7% | 410d → 409d |  |
| 2655 | Review Entry Criteria Evidence for each Wave 2 Participant | 2025-10-13 A | 2025-10-17 A | 0% → 100% | 410d → none |  |
| 2656 | Qualification Wave 2 Participant Test Readiness Confirmed | 2025-10-17 A | 2025-10-17 A | 0% → 100% | 410d → none |  |
| 2657 | Qualification Wave 2 Execution Start | 2025-10-20 A | 2025-10-20 A | 0% → 100% | 410d → none |  |
| 2658 | Qualification Wave 2 QT Execution Window | 2025-10-20 A |  | 0% → 2% | 415d → 409d |  |
| 2660 | **Qualification Wave 2 Exit** | 2025-10-20 A |  |  | 410d → 404d |  |
| 2661 | Final QAD Submission window opens | 2025-10-20 A | 2025-10-20 A | 0% → 100% | 410d → none |  |
| 2667 | **Qualification Wave 3** | 2025-08-11 A |  | 0% → 13% | 60d → 365d |  |
| 2668 | **Qualification Wave 3 QAD Prep** | 2025-08-11 A |  | 0% → 55% | 365d → 359d |  |
| 2669 | Initial QAD Submission window opens | 2025-08-11 A | 2025-08-11 A | 0% → 100% | 365d → none |  |
| 2670 | Qualification Wave 3 Participants Submit Initial QAD | 2025-08-11 A |  | 0% → 80% | 365d → 359d |  |
| 2674 | **Qualification Wave 3 Test Prep** | 2025-09-15 A |  | 0% → 2% | 395d → 529d |  |

| ID | Task | Start | Finish | Duration | Complete | Total float | Predecessors | Other |
| --- | --- | --- | --- | --- | --- | --- | --- | --- |
| 2675 | Confirmation from Qualification Wave 3 Participants that DIP Onboarding has commenced | 2025-09-15 A | 2025-09-15 A |  | 0% → 100% | 395d → none |  |  |
| 2676 | Qualification Wave 3 Participants DIP Onboarding window | 2025-09-15 A |  |  | 0% → 6% | 395d → 389d |  |  |
| 2697 | **Qualification Wave 4** |  |  |  | 0% → 1% |  |  |  |
| 2698 | **Qualification Wave 4 QAD Prep** | 2025-10-20 A |  |  |  |  |  |  |
| 2699 | Initial QAD Submission window opens | 2025-10-20 A | 2025-10-20 A |  | 0% → 100% | 235d → none |  |  |
| 2742 | PAB299 | 2025-07-31 A | 2025-07-31 A |  | 0% → 100% | 626d → none |  |  |
| 2743 | PAB300 | 2025-08-13 A | 2025-08-13 A |  | 0% → 100% | 617d → none |  |  |
| 2744 | PAB301 | 2025-08-28 → 2025-08-27 A (-1d) | 2025-08-28 A | 0d → 2d | 0% → 100% | 606d → none |  | constraint start no earlier than 2025-08-28 → start no earlier than 2025-08-27 |
| 2745 | PAB302 | 2025-09-10 A | 2025-09-10 A |  | 0% → 100% | 597d → none |  |  |
| 2746 | PAB303 | 2025-09-25 A | 2025-09-25 A |  | 0% → 100% | 8d → none |  |  |
| 2747 | PAB304 | 2025-10-15 A | 2025-10-15 A |  | 0% → 100% | 572d → none |  |  |
| 2752 | **REGULATORY** |  | 2025-12-24 A |  | 99% → 100% | 521d → none |  |  |
| 2879 | **Deliver MHHS Code Changes** |  | 2025-12-24 A |  | 93% → 100% | 521d → none |  |  |
| 2882 | **M8 Code Change Preperation** |  | 2025-09-05 A |  | 0% → 100% | 599d → none |  |  |
| 2891 | Code Change Industry Consultation | 2025-07-29 A | 2025-07-29 A |  | 0% → 100% | 627d → none |  |  |
| 2892 | Panel Recommendation | 2025-08-14 A | 2025-08-14 A |  | 0% → 100% | 615d → none |  |  |
| 2893 | Ofgem Decision | 2025-09-05 A | 2025-09-05 A |  | 0% → 100% | 532d → none |  |  |
| 2894 | **Main Code Release** | 2025-09-15 A | 2025-12-24 A |  | 0% → 100% | 521d → none |  |  |
| 2895 | Release preparation (e.g. preparing release documentation) | 2025-09-15 A | 2025-09-22 A |  | 0% → 100% | 588d → none |  |  |
| 2896 | Implement new code on day of code release | 2025-09-22 A | 2025-09-22 A |  | 0% → 100% | 588d → none |  |  |
| 2897 | Code changes delivered (M8) | 2025-09-22 A | 2025-09-22 A |  | 0% → 100% | 521d → none | 2877, 2856, 1804SS-3d, 2893, "Codify Service Management" Decision Due (TBC and Indicitavely by End of Aug) → 2877, 2856, 1804SS-3d, 2893 |  |
| 2898 | Code changes delivered (M8*) late exit | 2025-12-24 A | 2025-12-24 A |  | 0% → 100% | 521d → none |  |  |
| 2903 | **MIGRATION** |  |  |  | 72% → 88% |  |  |  |
| 2904 | **Regulatory Governance** |  | 2025-09-26 → 2026-01-23 (+119d) | 390d → 475d | 96% → 75% | 584d → 499d |  |  |
| 2907 | Ofgem Incentives Approval | 2025-09-22 → 2025-06-13 A (-101d) | 2025-09-22 → 2026-01-23 (+123d) | 0d → 161d | 0% → 58% | 584d → 499d | none → 2906 | constraint start no earlier than 2025-09-22 → start no earlier than 2025-06-13; baseline start 2025-09-22 → 2025-06-13; baseline finish 2025-09-22 → 2026-01-23 |
| 2908 | Incentives Implementation | 2025-09-22 → 2026-01-23 (+123d) | 2025-09-26 → 2026-01-23 (+119d) | 5d → 0d |  | 584d → 499d |  | was named Incnentives Implementation; baseline start 2025-09-22 → 2026-01-23; baseline finish 2025-09-26 → 2026-01-23 |
| 2948 | **V1.0 of Migration Schedule Baseline** |  | 2025-07-22 A |  | 0% → 100% | 632d → none |  |  |
| 2950 | V1.0 of Migration Schedule Baseline Approved at MCAG | 2025-07-22 A | 2025-07-22 A |  | 0% → 100% | 632d → none |  |  |
| 2959 | **MCC Stood up** |  | 2025-11-21 A |  | 65% → 100% |  |  |  |
| 2960 | Migration Planning Management Tool Delivery |  | 2025-11-21 A |  | 63% → 100% |  |  |  |
| 2961 | **MCC Operational** |  | 2025-08-29 → 2025-09-05 A (+7d) | 93d → 98d | 99% → 100% | 604d → none |  |  |
| 2962 | **MCC Dress Rehersal 1 - Initialise Schedule (Weekly) Drop 1, 2** |  | 2025-07-22 A |  | 99% → 100% | 632d → none |  |  |
| 2972 | Test execution report (weekly) |  |  |  |  |  | Dress rehearsal startFS+56d → none |  |
| 2975 | MCAG approval of Baseline Migration schedule | 2025-07-22 A | 2025-07-22 A |  | 0% → 100% | 632d → none |  |  |
| 2976 | **MCC Dress Rehersal 2 - complete** |  | 2025-08-29 → 2025-09-05 A (+7d) | 35d → 40d | 0% → 100% | 604d → none |  |  |
| 2979 | Kestrel Webinar 2 | 2025-08-06 A | 2025-08-06 A |  | 0% → 100% | 621d → none |  |  |
| 2980 | Onboard and connectivity testing - Dress Rehearsal with Suppliers (remaining suppliers and non-supplier PPs) | 2025-07-21 → 2025-08-11 A (+21d) | 2025-07-21 → 2025-08-11 A (+21d) |  | 0% → 100% | 619d → none |  | constraint none → start no earlier than 2025-08-11; baseline start 2025-07-21 → 2025-08-11; baseline finish 2025-07-21 → 2025-08-11 |
| 2981 | **MCC Dress Rehersal 2** | 2025-08-11 A | 2025-08-11 → 2025-09-05 A (+25d) | 0d → 20d | 0% → 100% | 604d → none |  | was named Dress rehearsal start; constraint finish no earlier than 2025-08-11 → none |
| 2983 | Test execution report (weekly) | 2025-08-29 → 2025-08-11 A (-18d) | 2025-08-29 → 2025-09-05 A (+7d) | 0d → 20d | 0% → 100% | 604d → none | 2981FS+14d → none | constraint none → finish no earlier than 2025-08-11 |
| 2984 | Dress rehearsal completion report available | 2025-08-29 → 2025-09-05 A (+7d) | 2025-08-29 → 2025-09-05 A (+7d) |  | 0% → 100% | 604d → none |  | was named Dress rehearsal completion report; constraint none → finish no earlier than 2025-08-29 |
| 2986 | MCC Dress Rehearsal 2 - complete | 2025-08-29 → 2025-09-05 A (+7d) | 2025-08-29 → 2025-09-05 A (+7d) |  | 0% → 100% | 604d → none |  | was named MCC Dress Rehersal 2 - complete; constraint none → finish no earlier than 2025-09-05 |
| 2987 | MCC Operational Complete | 2025-08-29 → 2025-09-05 A (+7d) | 2025-08-29 → 2025-09-05 A (+7d) |  | 0% → 100% | 604d → none |  | constraint none → finish no earlier than 2025-08-29 |
| 2988 | **M11 Readiness Checkpoint** | 2025-07-28 → 2025-08-29 A (+32d) | 2025-08-28 → 2025-10-20 A (+53d) | 24d → 36d | 0% → 100% | 570d → none |  | constraint finish no earlier than 2025-08-28 → none; baseline start none → 2025-07-28; baseline finish none → 2025-08-28 |
| 2989 | Supplier Readiness Assessments for Sprint 0 Day 1 | 2025-08-29 A | 2025-09-25 A |  | 0% → 100% | 570d → none | 2988 → none | was named Supplier Readiness Assessments for Sprint 0; constraint none → start no earlier than 2025-08-29; baseline start none → 2025-08-29; baseline finish none → 2025-09-25 |
| 2991 | **Legacy Settlement run stability assessment** | 2025-09-25 → 2025-09-26 A (+1d) | 2025-10-16 → 2025-10-17 A (+1d) |  | 0% → 100% | 570d → none | 2989FS-1d → none | constraint start no earlier than 2025-09-25 → none; baseline start none → 2025-09-26; baseline finish none → 2025-10-17 |
| 2996 | **Migration Artefact Development and Publication** |  |  |  | 84% → 88% |  |  |  |
| 3039 | **Data Cleanse Plan** |  | 2025-09-24 A |  | 99% → 100% | 586d → none |  |  |
| 3044 | **MTDs** |  | 2025-07-18 → 2025-07-21 A (+3d) | 240d → 241d | 99% → 100% | 634d → none |  |  |
| 3051 | **Meter Location and Number of Displayed Register Digits** |  | 2025-07-18 → 2025-07-21 A (+3d) | 221d → 222d | 98% → 100% | 634d → none |  |  |
| 3055 | Suppliers complete Work Off plans |  | 2025-07-18 A |  | 98% → 100% | 634d → none |  |  |
| 3056 | Meter Location and Number of Displayed Register Digits Complete | 2025-07-18 → 2025-07-21 A (+3d) | 2025-07-18 → 2025-07-21 A (+3d) | 0d → 1d | 0% → 100% | 634d → none |  |  |
| 3057 | **Registration Data** |  | 2025-09-24 A |  | 85% → 100% | 586d → none |  |  |
| 3066 | **Domestic Premises Indicator** | 2025-09-05 A | 2025-09-24 A |  | 0% → 100% | 586d → none |  |  |
| 3067 | The DCC to extract Domestic Premises Indicator from the CSS and provide a file to each LDSO and EES. | 2025-09-05 A | 2025-09-08 A |  | 0% → 100% | 597d → none |  |  |
| 3068 | Each LDSO notifies the MHHS Programme SI of any exceptions which have occurred because of the data load and the reason for that exception | 2025-09-24 A | 2025-09-24 A |  | 0% → 100% | 586d → none |  |  |
| 3069 | Domestic Premises Indicator Complete | 2025-09-24 A | 2025-09-24 A |  | 0% → 100% | 586d → none |  |  |
| 3070 | **Connection Type and Meter Type Misalignments** |  |  |  | 67% → 76% |  |  |  |
| 3071 | **Traditional Meters installed on Current Transformers** |  |  |  | 32% → 44% |  |  |  |
| 3076 | Suppliers to have completed meter exchanges for those MPANs in pot 1 |  |  |  | 9% → 25% |  |  |  |
| 3083 | **Smart Meter Types installed on CT Connection Types** |  | 2025-07-25 A |  | 91% → 100% | 629d → none |  |  |
| 3087 | Suppliers resolve all issues |  | 2025-07-25 A |  | 80% → 100% | 629d → none |  |  |
| 3088 | Smart Meter Types installed on CT Connection Types complete | 2025-07-25 A | 2025-07-25 A |  | 0% → 100% | 629d → none |  |  |
| 3089 | **Linked Import / Export MPANs** |  | 2025-07-25 A |  | 92% → 100% | 629d → none |  |  |
| 3090 | LDSOs review and correct linked Import / Export MPANs with Different Connection Types |  | 2025-07-25 A |  | 92% → 100% | 629d → none |  |  |
| 3091 | LDSOs, Import and Export Suppliers review and correct linked Import / Export MPANs with meters in the Advanced and Traditional or Smart Meter Groups |  | 2025-07-25 A |  | 92% → 100% | 629d → none |  |  |
| 3092 | Linked Import / Export MPANs complete | 2025-07-25 A | 2025-07-25 A |  | 0% → 100% | 629d → none |  |  |
| 3093 | **Related MPANs** |  | 2025-07-25 A |  | 92% → 100% | 629d → none |  |  |
| 3095 | Suppliers unrelate any MPANs required |  | 2025-07-25 A |  | 68% → 100% | 629d → none |  |  |
| 3096 | Suppliers should investigate Related MPANs within different meter groups and verify that they are correct or request that their Meter Operators update the Meter Types where they are incorrect |  | 2025-07-25 A |  | 92% → 100% | 629d → none |  |  |
| 3097 | Related MPANs complete | 2025-07-25 A | 2025-07-25 A |  | 0% → 100% | 629d → none |  |  |

| ID | Task | Start | Finish | Duration | Complete | Total float | Predecessors | Other |
| --- | --- | --- | --- | --- | --- | --- | --- | --- |
| 3098 | **Export / Import MPANs** |  | 2025-08-13 → 2025-09-22 A (+40d) | 363d → 392d | 99% → 100% | 617d → none |  |  |
| 3105 | Pre-migration data cleanse complete | 2025-08-13 → 2025-09-22 A (+40d) | 2025-08-13 → 2025-09-22 A (+40d) |  | 0% → 100% | 617d → none |  | constraint start no earlier than 2025-08-13 → finish no earlier than 2025-09-22; baseline start 2025-08-13 → 2025-09-22; baseline finish 2025-08-13 → 2025-09-22 |
| 3106 | **Migration Period Planning** |  | 2024-11-26 → 2026-07-31 (+612d) | 367d → 805d | 83% → 98% | 678d → 240d |  |  |
| 3107 | **Migration Implementation Plan (incl. Migration Exit Criteria)** |  | 2024-11-26 → 2026-07-31 (+612d) | 367d → 805d | 83% → 98% | 678d → 240d |  |  |
| 3122 | **M16 Methodology** |  | 2024-11-26 → 2026-07-31 (+612d) | 85d → 523d | 10% → 96% | 678d → 240d |  |  |
| 3123 | Draft Document |  | 2024-10-08 → 2025-07-31 A (+296d) | 50d → 262d | 12% → 100% | 678d → none |  |  |
| 3124 | Share Document with SRO | 2024-10-09 → 2025-07-31 A (+295d) | 2024-10-09 → 2025-07-31 A (+295d) | 1d → 0d | 0% → 100% | 678d → none |  |  |
| 3125 | Industry Consultation | 2024-10-15 → 2025-08-06 (+295d) | 2024-10-29 → 2025-08-20 (+295d) |  |  | 678d → 467d |  |  |
| 3126 | Assurance Meeting | 2024-11-12 → 2025-09-03 (+295d) | 2024-11-12 → 2025-09-03 (+295d) |  |  | 678d → 467d |  |  |
| 3127 | M16 methodology approved | 2024-11-26 → 2026-07-31 (+612d) | 2024-11-26 → 2026-07-31 (+612d) |  |  | 678d → 240d |  | constraint none → finish no earlier than 2026-07-31; baseline start 2024-11-26 → 2026-07-31; baseline finish 2024-11-26 → 2026-07-31 |
| 3128 | **Preparation for Cutover to Live** | 2024-06-28 A → 2024-06-03 A (-25d) |  | 744d → 763d? | 31% → 56% |  |  |  |
| 3129 | **Central Systems Prepare for Cutover to Live** | 2024-06-28 A → 2024-06-03 A (-25d) | 2025-09-26 → 2025-10-22 A (+26d) | 326d → 363d? | 84% → 100% | 584d → none |  |  |
| 3131 | **Development of Comms Approach and Declaration Guidance** |  | 2025-08-14 A |  | 97% → 100% | 34d → none |  |  |
| 3132 | Draft Cutover Comms Approach |  | 2025-07-17 A |  | 97% → 100% | 34d → none |  |  |
| 3133 | Draft Cutover Comms Approach shared | 2025-07-17 A | 2025-07-17 A |  | 0% → 100% | 34d → none |  |  |
| 3134 | Finalised Cutover Comms Approach shared | 2025-08-14 A | 2025-08-14 A |  | 0% → 100% | 34d → none |  |  |
| 3135 | **Development of Cutover Plan requirements with Participants** |  | 2025-08-22 → 2025-10-22 A (+61d) | 96d → 139d | 81% → 100% | 609d → none |  |  |
| 3140 | LDSO Cutover Plan Assurance |  | 2025-08-01 A |  | 13% → 100% | 624d → none |  |  |
| 3141 | SIT Supplier and SIT Agent Cutover Plan Assurance |  | 2025-08-22 A |  | 7% → 100% | 28d → none |  |  |
| 3143 | **M10/M11 Cutover Activities** |  |  | 120d → 120d? | 0% → 100% |  |  |  |
| 3153 | Production DIP Portal (DIP Deployment) | 2025-09-05 → 2025-08-01 A (-35d) | 2025-09-05 → 2025-08-04 A (-32d) | 0d → 2d | 0% → 100% | 14d → none |  | constraint finish no earlier than 2025-09-05 → start no earlier than 2025-08-01; baseline start 2025-09-05 → 2025-08-01; baseline finish 2025-09-05 → 2025-08-04 |
| 3154 | Production Certificates (DIP Deployment) | 2025-09-05 → 2025-08-01 A (-35d) | 2025-09-05 → 2025-08-04 A (-32d) | 0d → 2d | 0% → 100% | 14d → none |  | constraint finish no earlier than 2025-09-05 → start no earlier than 2025-08-01; baseline start 2025-09-05 → 2025-08-01; baseline finish 2025-09-05 → 2025-08-04 |
| 3155 | Service Management Go-Live | 2025-09-19 → 2025-07-31 A (-50d) | 2025-09-19 → 2025-07-31 A (-50d) |  | 0% → 100% | 7d → none | 3198 → none | constraint none → start no earlier than 2025-07-31; baseline start 2025-09-19 → 2025-07-31; baseline finish 2025-09-19 → 2025-07-31 |
| 3162 | Completion of the pre-M10 MHHS Data Cleanse | 2025-09-24 → 2025-09-22 A (-2d) | 2025-09-24 → 2025-09-22 A (-2d) |  | 0% → 100% | 586d → none | 1804 → none | constraint finish no earlier than 2025-09-24 → finish no earlier than 2025-09-22; baseline start 2025-09-24 → 2025-09-22; baseline finish 2025-09-24 → 2025-09-22 |
| 3163 | Early Life Support Implemented | 2025-09-19 A | 2025-09-19 A |  | 0% → 100% | 8d → none | 3198 → none | constraint none → start no earlier than 2025-09-19 |
| 3164 | MCC Tested and Ready to Operate | 2025-09-19 → 2025-08-08 A (-42d) | 2025-09-19 A | 0d → 31d | 0% → 100% | 590d → none |  | constraint start no earlier than 2025-09-19 → start no earlier than 2025-08-08; baseline start 2025-09-19 → 2025-08-08 |
| 3165 | Market-wide Participant MHHS Supporting Functionality Ready - Confirmation from Code Bodies | 2025-09-15 A | 2025-09-15 A |  | 0% → 100% | 593d → none |  | constraint finish no earlier than 2025-09-15 → start no earlier than 2025-09-15 |
| 3166 | Market-wide Participant MHHS Supporting Functionality Ready | 2025-09-22 A | 2025-09-22 A |  | 0% → 100% | 588d → none | 1804 → none | constraint none → start no earlier than 2025-09-22 |
| 3178 | Central Systems live and Codes designated at 00:00 | 2025-09-22 A | 2025-09-22 A |  | 0% → 100% | 7d → none | Elexon Central Services DeploymentFS+1d, 3155FS+1d, Data Transfer Service (DTS) New Functionality DeploymentFS+1d, Electricity Enquiry Service (EES) DeploymentFS+1d, MPRS, UMSO Role, LDSO Role OperationalFS+1d, Population of Domestic Premises IndicatorFS+1d, Population of Market SegmentFS+1d, 3130FS+1d → 3130FS+1d | constraint none → finish no earlier than 2025-09-22 |
| 3185 | **Cutover Governance M10** | 2025-09-01 → 2025-08-22 A (-10d) | 2025-09-24 A | 17d → 23d | 0% → 100% | 7d → none |  |  |
| 3187 | Confirmation that all LDSOs have deployed MPRS 9 to production | 2025-09-01 A | 2025-09-01 A |  | 0% → 100% | 18d → none |  | constraint finish no earlier than 2025-09-01 → start no earlier than 2025-09-01 |
| 3188 | Confirmation that population of Domestic Premises Indicator is complete | 2025-09-08 A | 2025-09-08 A |  | 0% → 100% | 13d → none | 3187 → none | constraint finish no earlier than 2025-09-08 → start no earlier than 2025-09-08 |
| 3189 | Confirmation that Market Segment has been populated for 95% of LDSO portfolios | 2025-09-12 A | 2025-09-12 A |  | 0% → 100% | 7d → none |  | constraint finish no earlier than 2025-09-12 → start no earlier than 2025-09-12 |
| 3192 | Declaration from all Central Services and LDSOs that they are in a position to move forwards | 2025-09-15 A | 2025-09-15 A |  | 0% → 100% | 10d → none |  |  |
| 3197 | MCC Operational | 2025-09-19 A | 2025-09-19 A |  | 0% → 100% | 590d → none | 3164 → none | constraint none → start no earlier than 2025-09-19 |
| 3198 | MCAG (Confirm that the Programme can Enter M10) | 2025-09-19 A | 2025-09-19 A |  | 0% → 100% | 7d → none | TORWG (Recommendation from TORWG that the Programme should enter M10)FS+2d → none | constraint none → start no earlier than 2025-09-19 |
| 3199 | Self-Declaration from all Central Services and LDSOs that Cutover activities have been successfully carried out | 2025-09-22 A | 2025-09-22 A |  | 0% → 100% | 7d → none | 3198FS+1d → none | constraint none → start no earlier than 2025-09-22 |
| 3200 | Confirmation that DIP and ECS have been deployed, Service management is active, ISD has been populated | 2025-09-22 A | 2025-09-22 A |  | 0% → 100% | 7d → none | 3198FS+1d → none | constraint none → start no earlier than 2025-09-22 |
| 3208 | PSG (OFGEM and PSG to Approve That Conditions of M10 and M13 Have Been Met) | 2025-09-24 A | 2025-09-24 A |  | 0% → 100% | 7d → none | Recommendation from TORWG that PSG should approve M10FS+1d → none | constraint none → start no earlier than 2025-09-24 |
| 3209 | **Cutover Governance M11** | 2025-09-26 → 2025-10-14 A (+18d) | 2025-10-22 A | 19d → 6d | 0% → 100% | 5d → none |  |  |
| 3210 | Self-Declaration that MHHS Functionality will be deployed to Production by Qualified parties | 2025-10-14 A | 2025-10-14 A |  | 0% → 100% | 7d → none | 3208FS+12d → none | constraint finish no earlier than 2025-10-14 → start no earlier than 2025-10-14 |
| 3215 | PSG (OFGEM and PSG Decision to Confirm M11 and M12) | 2025-10-22 A | 2025-10-22 A |  | 0% → 100% | 5d → none | MCAG (Provide recommendation to PSG on M11 decision)FS+2d → none | constraint none → start no earlier than 2025-10-22 |
| 3216 | **Migration Sprints** | 2025-09-25 → 2025-09-24 A (-1d) |  | 420d → 421d | 0% → 1% |  |  |  |
| 3217 | **Migration Sprint 0** | 2025-09-25 → 2025-09-24 A (-1d) |  | 94d → 95d | 0% → 7% |  |  |  |
| 3218 | Sprint 0 Planning start date | 2025-09-25 → 2025-09-24 A (-1d) | 2025-10-02 → 2025-10-01 A (-1d) |  | 0% → 100% | 492d → none |  | constraint start no earlier than 2025-09-25 → start no earlier than 2025-09-24 |
| 3219 | Issue Envelope | 2025-10-02 → 2025-10-01 A (-1d) | 2025-10-02 → 2025-10-01 A (-1d) |  | 0% → 100% | 492d → none |  |  |
| 3220 | Supplier Submission Deadline | 2025-10-09 → 2025-10-08 A (-1d) | 2025-10-09 → 2025-10-08 A (-1d) |  | 0% → 100% | 492d → none |  |  |
| 3221 | Baseline Schedule Publication | 2025-10-16 → 2025-10-15 A (-1d) | 2025-10-16 → 2025-10-15 A (-1d) |  | 0% → 100% | 492d → none |  |  |
| 3222 | Migration Sprint 0 Schedule Baselined | 2025-10-16 A | 2025-10-16 A |  | 0% → 100% | 492d → none |  | constraint none → finish no earlier than 2025-10-16 |
| 3223 | Sprint Execution Start | 2025-10-23 → 2025-10-22 (-1d) | 2025-10-23 → 2025-10-22 (-1d) |  |  | 492d → 566d | 3222FS+5d, 3315 → 3222FS+4d, 3315 |  |
| 3224 | Sprint Execution | 2025-10-24 → 2025-10-22 (-2d) |  | 73d → 75d |  |  | 3223 → none | constraint none → start no earlier than 2025-10-22 |
| 3299 | **External Programme Dependency Management** |  | 2025-08-29 A |  | 66% → 100% | 604d → none |  |  |
| 3303 | **BSC Mod P434** |  | 2025-07-23 A |  | 57% → 100% | 631d → none |  |  |
| 3305 | Monitor progress and await implementation date |  | 2025-07-23 A |  | 52% → 100% | 631d → none |  |  |
| 3306 | **Elexon System Capacity Upgrade** |  | 2025-07-01 A |  | 58% → 100% | 647d → none |  |  |
| 3307 | Monitor progress to implementation |  | 2025-07-01 A |  | 58% → 100% | 647d → none |  |  |
| 3308 | Implementation date | 2025-07-01 A | 2025-07-01 A |  | 0% → 100% | 647d → none |  |  |
| 3309 | **DCC System Capacity Upgrade** | 2025-07-28 A | 2025-08-29 A |  | 0% → 100% | 604d → none |  |  |
| 3310 | Assurance of DCC capacity upgrade to ensure suitability to support migration | 2025-07-28 A | 2025-08-22 A |  | 0% → 100% | 604d → none |  |  |
| 3311 | DCC Capacity Upgrade Operational | 2025-08-29 A | 2025-08-29 A |  | 0% → 100% | 604d → none |  |  |
| 3312 | **Migration - Tier 1 Milestones** | 2025-09-22 A |  |  |  | 27d → 98d |  |  |
| 3313 | Load Shaping Service switched on (M13) | 2025-09-22 A | 2025-09-22 A |  | 0% → 100% | 27d → none |  | baseline start 2025-09-24 → 2025-09-22; baseline finish 2025-09-24 → 2025-09-22 |
| 3315 | Start of 18-month migration for UMS / Advanced (M11) | 2025-10-22 A | 2025-10-22 A |  | 0% → 100% | 5d → none | 3313, MCAG (Provide recommendation to PSG on M11 decision), 3215, 1804FS+20d → 3313, 1804FS+22d, 2991 |  |
| 3317 | Start of 18-month migration for Smart / Non-smart (M12) | 2025-10-22 A | 2025-10-22 A |  | 0% → 100% | 501d → none |  |  |
| 3321 | **BUSINESS & OPERATIONAL READINESS** |  |  | 1344d → 1344d? | 41% → 63% |  |  |  |
| 3322 | **Service Management** |  | 2026-10-23 → 2026-11-14 (+22d) | 1040d → 1055d? | 28% → 69% | 304d → 289d |  |  |
| 3333 | **Service Management Arrangements Implementation** | 2022-10-31 A |  |  | 0% → 84% |  |  |  |
| 3335 | Monitor Elexon implementation of Service Management arrangements | 2022-10-31 A | 2024-07-01 A |  | 0% → 100% | 908d → none |  |  |
| 3336 | **Wave 1** | 2022-10-31 → 2025-08-25 (+1029d) | 2026-05-12 → 2026-05-22 (+10d) | 922d → 195d? |  | 422d → 156d |  |  |
| 3353 | **Wave 1 - Service Activation Implementation** | 2026-04-14 → 2026-04-02 (-12d) | 2026-04-24 → 2026-05-08 (+14d) | 9d → 27d? |  | 434d → 424d |  |  |

| ID | Task | Start | Finish | Duration | Complete | Total float | Predecessors | Other |
| --- | --- | --- | --- | --- | --- | --- | --- | --- |
| 3355 | PP is Qualified by Code Bodies | 2026-04-14 → 2026-04-15 (+1d) | 2026-04-14 → 2026-04-15 (+1d) | 1d → 0d |  | 442d → 435d | none → 2636 | was named MHHSP Enabled Confirmation; baseline start 2026-04-14 → 2026-04-15; baseline finish 2026-04-14 → 2026-04-15 |
| 3356 | DIP Promoted to Production | 2026-04-20 → 2026-04-16 (-4d) | 2026-04-24 → 2026-04-22 (-2d) |  |  | 434d → 436d | Add EFD to DIP → 3355 | constraint finish no earlier than 2026-04-24 → start no earlier than 2026-04-16 |
| 3357 | Create M16 in Customer Solution | 2026-04-17 → 2026-04-16 (-1d) | 2026-04-17 → 2026-04-16 (-1d) |  |  | 439d → 440d |  | constraint finish no earlier than 2026-04-17 → start no earlier than 2026-04-16 |
| 3358 | MDD & ISD Publish |  | 2026-04-24 → 2026-04-17 (-7d) | 6d → 1d |  |  | none → 3355, 3365 | was named Publish ISD; constraint finish no earlier than 2026-04-24 → start no earlier than 2026-04-17 |
| 3360 | Wave 1 - Service Activation Implementation Complete (M) |  |  |  |  |  | 3358 → 3359 |  |
| 3363 | **Wave 1 - Service Activation Implementation MDD** | 2026-04-17 → 2026-04-15 (-2d) | 2026-05-11 → 2026-04-16 (-25d) | 17d → 2d |  | 423d → 434d |  |  |
| 3366 | **Wave 1 - Service Activation Hypercare** | 2026-04-16 → 2025-08-25 (-234d) |  | 19d → 187d |  |  |  |  |
| 3367 | Service& Process Monitoring | 2026-04-16 → 2025-08-25 (-234d) | 2026-05-12 → 2025-09-18 (-236d) |  |  | 422d → 590d | Add EFD to DIPSS → none |  |
| 3368 | Daily Reporting | 2026-04-16 → 2025-08-25 (-234d) | 2026-05-12 → 2025-09-18 (-236d) |  |  | 422d → 590d | Add EFD to DIPSS → none |  |
| 3369 | Issue Management | 2026-04-16 → 2025-08-25 (-234d) | 2026-05-12 → 2025-09-18 (-236d) |  |  | 422d → 590d | Add EFD to DIPSS → none |  |
| 3377 | **Wave 2** |  | 2026-06-08 → 2026-06-19 (+11d) | 941d → 950d |  | 403d → 0d |  |  |
| 3378 | **Wave 2 - Service Activation Implementation** | 2026-05-27 → 2026-05-15 (-12d) |  | 8d → 16d |  |  |  | baseline start 2026-05-27 → 2026-05-15 |
| 3380 | PP is Qualified by Code Bodies | 2026-05-27 → 2026-05-28 (+1d) | 2026-05-27 → 2026-05-28 (+1d) | 1d → 0d |  | 407d → 404d | none → 2666 | was named MHHSP Enabled Confirmation; baseline start 2026-05-27 → 2026-05-28; baseline finish 2026-05-27 → 2026-05-28 |
| 3381 | PAB Approval | 2026-05-28 → 2026-05-29 (+1d) | 2026-05-28 → 2026-05-29 (+1d) |  |  | 407d → 408d |  | baseline start 2026-05-28 → 2026-05-29; baseline finish 2026-05-28 → 2026-05-29 |
| 3382 | Add EFD to DIP | 2026-05-29 → 2026-06-01 (+3d) | 2026-05-29 → 2026-06-01 (+3d) |  |  | 407d → 408d |  | baseline start 2026-05-29 → 2026-06-01; baseline finish 2026-05-29 → 2026-06-01 |
| 3383 | DIP Promoted to Production | 2026-06-01 → 2026-05-29 (-3d) | 2026-06-01 → 2026-06-04 (+3d) | 1d → 5d |  | 407d → 405d | 3382 → 3380 | baseline start 2026-06-01 → 2026-05-29; baseline finish 2026-06-01 → 2026-06-04 |
| 3384 | Create M16 in Customer Solution | 2026-06-02 → 2026-05-29 (-4d) | 2026-06-02 → 2026-05-29 (-4d) |  |  | 407d → 409d | 3383 → 3380 | baseline start 2026-06-02 → 2026-05-29; baseline finish 2026-06-02 → 2026-05-29 |
| 3385 | MDD & ISD Publish |  | 2026-06-05 → 2026-05-29 (-7d) | 6d → 1d |  |  | none → 3380 | was named Publish ISD; baseline finish 2026-06-05 → 2026-05-29 |
| 3388 | **Wave 2 - Service Activation Implementation MDD** | 2025-06-12 → 2022-10-31 (-955d) | 2025-11-19 → 2022-11-24 (-1091d) | 115d → 19d |  | 546d → none |  | baseline start 2025-06-12 → 2022-10-31; baseline finish 2025-11-19 → 2022-11-24 |
| 3402 | **Wave 3** |  | 2026-08-21 → 2026-08-14 (-7d) | 995d → 990d? |  | 349d → 0d |  |  |
| 3419 | **Wave 3 - Service Activation Implementation** | 2026-07-29 → 2022-10-31 (-1367d) | 2026-08-10 → 2022-11-21 (-1358d) | 8d → 16d |  | 359d → none |  | baseline start 2026-07-29 → 2022-10-31; baseline finish 2026-08-10 → 2022-11-21 |
| 3421 | PP Qualified by Code Bodies | 2026-07-29 → 2026-07-30 (+1d) | 2026-07-29 → 2026-07-30 (+1d) | 1d → 0d |  | 364d → 359d | none → 2696 | was named MHHSP Enabled Confirmation; baseline start 2026-07-29 → 2026-07-30; baseline finish 2026-07-29 → 2026-07-30 |
| 3422 | DIP Promoted to Production | 2026-08-03 → 2026-07-31 (-3d) | 2026-08-03 → 2026-08-06 (+3d) | 1d → 5d |  | 363d → 360d | Add EFD to DIP → 3421 | baseline start 2026-08-03 → 2026-07-31; baseline finish 2026-08-03 → 2026-08-06 |
| 3423 | Create M16 in Customer Solution |  |  |  |  | 359d → 364d | none → 3421 |  |
| 3424 | MDD & ISD Publish |  | 2026-08-07 → 2026-07-31 (-7d) | 6d → 1d |  |  | 3423SS → 3421 | was named Publish ISD; baseline finish 2026-08-07 → 2026-07-31 |
| 3425 | MDD & ISD Go-Live | 2026-08-10 → 2026-08-07 (-3d) | 2026-08-10 → 2026-08-07 (-3d) |  |  |  | 3424 → 3424FS+5d | was named Wave 3 - Service Activation Implementation Complete (M); constraint start no earlier than 2026-08-10 → none; baseline start 2026-08-10 → 2026-08-07; baseline finish 2026-08-10 → 2026-08-07 |
| 3426 | **Wave 3 - Service Activation Implementation MDD** | 2026-08-14 → 2026-07-30 (-15d) | 2026-08-21 → 2026-08-14 (-7d) | 6d → 12d? |  | 349d → 354d |  | baseline start 2026-08-14 → 2026-07-30 |
| 3440 | **Wave 4** |  | 2026-10-23 → 2026-11-14 (+22d) | 1040d → 1055d? |  | 304d → 0d |  |  |
| 3457 | **Wave 4 - Service Activation Implementation** | 2026-09-23 → 2022-10-31 (-1423d) | 2026-10-05 → 2022-11-21 (-1414d) | 8d → 16d |  | 319d → none |  | baseline start 2026-09-23 → 2022-10-31; baseline finish 2026-10-05 → 2022-11-21 |
| 3459 | MHHSP Enabled Confirmation | 2026-09-23 → 2026-09-24 (+1d) | 2026-09-23 → 2026-09-24 (+1d) | 1d → 0d |  | 323d → 319d | none → 2726 | baseline start 2026-09-23 → 2026-09-24; baseline finish 2026-09-23 → 2026-09-24 |
| 3460 | DIP Promoted to Production | 2026-09-28 → 2026-09-25 (-3d) | 2026-09-28 → 2026-10-01 (+3d) | 1d → 5d |  | 323d → 320d | Add EFD to DIP → 3459 | baseline start 2026-09-28 → 2026-09-25; baseline finish 2026-09-28 → 2026-10-01 |
| 3461 | Create M16 in Customer Solution |  |  |  |  |  | none → 3459 |  |
| 3462 | MDD & ISD Publish |  | 2026-10-02 → 2026-09-25 (-7d) | 6d → 1d |  |  |  | was named Publish ISD; baseline finish 2026-10-02 → 2026-09-25 |
| 3465 | **Wave 4 - Service Activation Implementation MDD** | 2026-10-16 → 2026-09-24 (-22d) | 2026-10-23 → 2026-10-16 (-7d) | 6d → 17d? |  | 304d → 309d |  | baseline start 2026-10-16 → 2026-09-24 |
| 3468 | **Wave 4 - Service Activation Hypercare** |  | 2026-10-05 → 2026-11-14 (+40d) | 9d → 38d |  | 318d → 289d |  |  |
| 3480 | **Implement Early Life Support Plan** | 2025-07-07 A |  |  | 0% → 76% |  |  |  |
| 3481 | Implement Early Life Support Plan | 2025-07-07 A |  |  | 0% → 76% |  |  |  |
| 3482 | **Business Continuity and Disaster Recovery Plan** | 2025-07-31 A | 2025-09-24 A |  | 0% → 100% | 586d → none |  |  |
| 3483 | Central Parties BCDRs in Place | 2025-07-31 A | 2025-08-27 A |  | 0% → 100% | 586d → none |  |  |
| 3484 | Risk Based Assurance of Cental Party BCDRs | 2025-08-28 A | 2025-09-24 A |  | 0% → 100% | 586d → none |  |  |
| 3485 | **Training and Support Materials** | 2025-08-21 A |  |  | 0% → 13% |  |  |  |
| 3486 | Develop document | 2025-08-21 A |  |  | 0% → 25% |  |  |  |
| 3593 | **CONTROL POINTS** |  |  |  | 51% → 79% |  |  |  |
| 3600 | **Control Point 3/4 - Readiness for Migration** | 2025-08-21 A | 2025-09-18 → 2025-09-24 A (+6d) | 20d → 25d | 0% → 100% | 591d → none |  |  |
| 3601 | Control Point 3/4 Preparation (incl. Control Point Report development and review) | 2025-08-21 A | 2025-09-09 → 2025-09-24 A (+15d) | 14d → 25d | 0% → 100% | 597d → none |  |  |
| 3602 | Control Point 3/4 - Readiness for Migration (incl. Control Point Report approval) | 2025-09-18 → 2025-09-24 A (+6d) | 2025-09-18 → 2025-09-24 A (+6d) |  | 0% → 100% | 591d → none |  | constraint none → finish no earlier than 2025-09-24 |
| 3609 | Control Point 3/4 - Readiness for Migration (incl. Control Point Report approval) | 2025-09-18 → 2025-09-24 A (+6d) | 2025-09-18 → 2025-09-24 A (+6d) |  | 0% → 100% | 591d → none |  |  |
| 3611 | **MILESTONE RANGE CHECKPOINTS** | 2025-07-31 A |  |  |  |  |  |  |
| 3612 | **M10, M11, M12 and M13 milestone checkpoint** | 2025-07-31 A | 2025-07-31 A |  | 0% → 100% | 626d → none |  |  |
| 3613 | M10, M11, M12, and M13 milestone checkpoint - date approval | 2025-07-31 A | 2025-07-31 A |  | 0% → 100% | 626d → none |  |  |

## Version 15 (data date 2025-11-05, saved 2025-11-05, file MHHS-DEL1139 - MHHS Plan v6.37.mpp)

Last finish stays 2027-12-23. Complete tasks 2442 → 2472.

Added:

| ID | Task | Duration | Start | Finish | Predecessors |
| --- | --- | --- | --- | --- | --- |
| 3480 | **Early Life Support Phase** | 66d | 2025-10-23 A | 2026-01-22 |  |
| 3481 | Phase 1 End | 21d | 2025-10-23 A | 2025-11-20 | 3315 |
| 3482 | Phase 2 End | 20d | 2025-11-21 | 2025-12-18 | 3481 |
| 3483 | Phase 3 End/Early Life Exit | 25d | 2025-12-19 | 2026-01-22 | 3482 |

Removed: 3381 PAB Approval; 3382 Add EFD to DIP

Changed:

| ID | Task | Start | Finish | Duration | Complete | Total float | Predecessors | Other |
| --- | --- | --- | --- | --- | --- | --- | --- | --- |
| 466 | **DBT Progress Monitoring of Consequential Change** |  |  |  | 90% → 93% |  |  |  |
| 467 | Monitor & report data cleanse progress |  |  |  | 90% → 93% |  |  |  |
| 1675 | **UIT Environment Preparation** |  |  |  | 89% → 90% |  |  |  |
| 1726 | **Onboarding and Test Data (Sandbox UIT)** |  |  |  | 28% → 38% |  |  |  |
| 1727 | LDSO Onboarding and Test Data Creation and Support |  |  |  | 55% → 67% |  |  |  |
| 1728 | Supplier & Agent Onboarding and Test Data Creation and Support |  |  |  | 11% → 18% |  |  |  |
| 1729 | **Sandbox Execution** |  |  |  | 34% → 41% |  |  |  |
| 1730 | **SIT PPs Early Sandbox Testing Execution (SIT-A)** |  | 2025-10-24 A |  | 79% → 100% | 564d → none |  |  |
| 1732 | SIT PPs E2E Sandbox Testing Execution |  | 2025-10-24 A |  | 79% → 100% | 564d → none |  |  |
| 1733 | SIT PPs E2E Sandbox Testing End | 2025-10-24 A | 2025-10-24 A |  | 0% → 100% | 564d → none |  |  |
| 1739 | **Sandbox Testing Execution (UIT) - Supplier & Agent Participants** |  |  |  | 11% → 18% |  |  |  |
| 1742 | Sandbox Testing Execution (UIT) - Supplier & Agent Participants |  |  |  | 11% → 18% |  |  |  |
| 1933 | **HELIX / ELEXON M10 READINESS** |  |  |  | 96% → 98% |  |  |  |
| 2039 | **Business Readiness (inc DIP)** |  | 2025-10-17 A |  | 99% → 100% | 569d → none |  |  |
| 2052 | DIP Reporting (M11) |  | 2025-10-17 A |  | 97% → 100% | 569d → none |  |  |
| 2054 | **DIP UIT Onboarding** |  |  |  | 90% → 94% |  |  |  |
| 2074 | **Service Activation Readiness** |  |  |  | 89% → 94% |  |  |  |
| 2130 | **Phase 2 - Implementation** |  |  |  | 66% → 81% |  |  |  |
| 2172 | **M11-Ready Activation Preparation Tasks** | 2025-10-09 A | 2025-10-13 A |  | 0% → 100% | 573d → none |  |  |
| 2173 | Engagement / Communications with Participants | 2025-10-09 A | 2025-10-09 A |  | 0% → 100% | 575d → none |  |  |
| 2174 | Validate User Access | 2025-10-13 A | 2025-10-13 A |  | 0% → 100% | 573d → none |  |  |
| 2175 | M11-Ready Participants Service Activation Preparation Completed | 2025-10-13 A | 2025-10-13 A |  | 0% → 100% | 573d → none |  |  |
| 2176 | **M11-Ready Service Activation Implementation** |  | 2025-10-22 A |  | 61% → 100% | 566d → none |  |  |
| 2177 | **Pathway 4 PPs** | 2025-09-25 A | 2025-10-03 A |  | 0% → 100% | 579d → none |  |  |
| 2178 | MHHSP Enabled Confirmation | 2025-09-25 A | 2025-09-25 A |  | 0% → 100% | 579d → none |  |  |
| 2179 | Add EFD (ISD Calendar Date) to DIP | 2025-09-25 A | 2025-09-25 A |  | 0% → 100% | 584d → none |  |  |
| 2180 | Create M16 in Customer Solution | 2025-09-25 A | 2025-09-25 A |  | 0% → 100% | 584d → none |  |  |
| 2181 | DIP Production Success Checks | 2025-09-26 A | 2025-09-26 A |  | 0% → 100% | 584d → none |  |  |
| 2182 | Publish ISD | 2025-09-26 A | 2025-10-03 A |  | 0% → 100% | 579d → none |  |  |
| 2183 | Go Live ISD | 2025-10-03 A | 2025-10-03 A |  | 0% → 100% | 579d → none |  |  |
| 2184 | Pathway 4 Service Activation Implementation Completed | 2025-10-03 A | 2025-10-03 A |  | 0% → 100% | 579d → none |  |  |
| 2195 | **M11-Ready Service Activation Hypercare** | 2025-10-15 A | 2025-11-05 A |  | 0% → 100% | 556d → none |  |  |
| 2196 | Monitoring | 2025-10-15 A | 2025-10-29 A |  | 0% → 100% | 561d → none |  |  |
| 2197 | Reporting | 2025-10-15 A | 2025-10-29 A |  | 0% → 100% | 561d → none |  |  |
| 2198 | Issue Management | 2025-10-15 A | 2025-10-29 A |  | 0% → 100% | 556d → none |  |  |
| 2199 | Closed Down Activities | 2025-10-30 A | 2025-11-03 A |  | 0% → 100% | 556d → none |  |  |
| 2200 | Inform MHHSP | 2025-11-04 A | 2025-11-05 A |  | 0% → 100% | 556d → none |  |  |
| 2201 | M11-Ready Service Activation Hypercare Completed | 2025-11-05 A | 2025-11-05 A |  | 0% → 100% | 556d → none |  |  |
| 2202 | **Not M11-Ready Service Activation Preparation Tasks** | 2025-10-13 A | 2025-10-16 A |  | 0% → 100% | 570d → none |  |  |
| 2203 | Engagement / Communications with Participants | 2025-10-16 A | 2025-10-16 A |  | 0% → 100% | 570d → none |  |  |
| 2204 | Validate User Access | 2025-10-13 A | 2025-10-13 A |  | 0% → 100% | 573d → none |  |  |
| 2205 | **Not M11-Ready Service Activation Implementation** | 2025-10-30 A |  | 43d? → 43d |  |  |  |  |
| 2206 | **First Pathway 6 PAB** | 2025-10-30 A | 2025-12-23 → 2025-11-21 (-32d) | 38d? → 16d |  | 522d → 544d |  |  |
| 2207 | MHHSP Enabled Confirmation | 2025-10-30 A | 2025-10-30 A |  | 0% → 100% | 554d → none |  |  |
| 2208 | Add EFD (ISD Calendar Date) to DIP | 2025-10-30 A | 2025-10-30 A |  | 0% → 100% | 559d → none |  |  |
| 2209 | Create M16 in Customer Solution | 2025-12-19 → 2025-10-31 A (-49d) | 2025-12-19 → 2025-10-31 A (-49d) |  | 0% → 100% | 524d → none | 2211SS → 2207FS+1d | constraint start no earlier than 2025-12-19 → finish no earlier than 2025-10-31 |
| 2210 | DIP Production Success Checks | 2025-12-23 → 2025-10-31 A (-53d) | 2025-12-23 → 2025-10-31 A (-53d) | 1d? → 0d | 0% → 100% | 522d → none | 2208, 2209 → 2209 | constraint start no earlier than 2025-12-23 → finish no earlier than 2025-10-31 |
| 2211 | Publish ISD | 2025-10-31 → 2025-11-14 (+14d) | 2025-11-07 → 2025-11-21 (+14d) |  |  | 554d → 544d | 2207 → none | constraint none → start no earlier than 2025-11-14; baseline start 2025-12-22 → 2025-11-14; baseline finish 2025-12-26 → 2025-11-21 |
| 2212 | Go Live ISD | 2025-11-07 → 2025-11-21 (+14d) | 2025-11-07 → 2025-11-21 (+14d) |  |  | 554d → 544d |  | baseline start 2025-12-26 → 2025-11-21; baseline finish 2025-12-26 → 2025-11-21 |
| 2213 | Publish MDD | 2025-10-31 → 2025-11-14 (+14d) | 2025-11-07 → 2025-11-21 (+14d) |  |  | 554d → 544d | 2207 → none | constraint none → start no earlier than 2025-11-14; baseline start 2025-10-31 → 2025-11-14; baseline finish 2025-11-07 → 2025-11-21 |
| 2214 | MDD Go Live | 2025-11-07 → 2025-11-21 (+14d) | 2025-11-07 → 2025-11-21 (+14d) |  |  | 554d → 544d |  | baseline start 2025-11-07 → 2025-11-21; baseline finish 2025-11-07 → 2025-11-21 |
| 2215 | Service Activation Implementation Completed | 2025-11-07 → 2025-11-21 (+14d) | 2025-11-07 → 2025-11-21 (+14d) |  |  | 554d → 544d |  | baseline start 2025-12-31 → 2025-11-21; baseline finish 2025-12-31 → 2025-11-21 |
| 2216 | **Final Pathway 6 PAB** |  |  | 9d? → 9d |  |  |  |  |
| 2219 | Create M16 in Customer Solution | 2025-12-22 → 2025-12-18 (-4d) | 2025-12-22 → 2025-12-18 (-4d) |  |  | 523d → 525d | 2221SS → 2217FS+1d | constraint start no earlier than 2025-12-19 → start no earlier than 2025-12-17 |
| 2220 | DIP Production Success Checks | 2025-12-23 → 2025-12-18 (-5d) | 2025-12-23 → 2025-12-18 (-5d) | 1d? → 0d |  | 522d → 525d |  | constraint start no earlier than 2025-12-23 → none |
| 2314 | **S & A QUALIFICATION** |  |  |  | 76% → 77% |  |  |  |
| 2426 | **MHHS Qualification - Qualification Waves** |  |  |  | 69% → 71% |  |  |  |
| 2607 | **Qualification Wave 1** |  |  |  | 61% → 70% | 441d → 435d |  |  |
| 2614 | **Qualification Wave 1 Test Prep** |  | 2025-08-15 A |  | 99% → 100% | 614d → none |  |  |
| 2616 | Qualification Wave 1 Participants DIP Onboarding Window |  | 2025-07-11 A |  | 95% → 100% | 639d → none |  |  |
| 2617 | Confirmation from Qualification Wave 1 Participants that DIP onboarding has completed | 2025-07-11 A | 2025-07-11 A |  | 0% → 100% | 639d → none |  |  |
| 2624 | **Qualification Wave 1 QT Execution** |  |  |  | 27% → 55% |  |  |  |
| 2628 | Qualification Wave 1 QT Execution Window |  |  |  | 23% → 53% |  |  |  |
| 2630 | **Qualification Wave 1 Exit** |  |  |  | 30% → 38% |  |  |  |
| 2632 | Qualification Wave 1 Participants submit their Final QAD |  |  |  | 40% → 50% |  |  |  |
| 2637 | **Qualification Wave 2** |  |  |  | 26% → 31% |  |  |  |
| 2654 | **Qualification Wave 2 QT Execution** |  |  |  | 7% → 17% |  |  |  |
| 2658 | Qualification Wave 2 QT Execution Window |  |  |  | 2% → 13% |  |  |  |
| 2660 | **Qualification Wave 2 Exit** |  |  |  | 0% → 9% |  |  |  |
| 2662 | Qualification Wave 2 Participants submit their Final QAD | 2025-10-20 A |  |  | 0% → 12% |  |  |  |

| ID | Task | Start | Finish | Duration | Complete | Total float | Other |
| --- | --- | --- | --- | --- | --- | --- | --- |
| 2684 | **Qualification Wave 3 QT Execution** | 2025-11-03 → 2025-12-15 (+42d) | 2026-03-24 → 2026-05-15 (+52d) | 102d → 110d |  |  |  |
| 2748 | PAB305 | 2025-10-30 A | 2025-10-30 A |  | 0% → 100% | 561d → none |  |
| 2903 | **MIGRATION** |  |  |  | 88% → 89% |  |  |
| 2904 | **Regulatory Governance** |  |  |  | 75% → 85% |  |  |
| 2907 | Ofgem Incentives Approval |  |  |  | 58% → 75% |  |  |
| 2996 | **Migration Artefact Development and Publication** |  |  |  | 88% → 89% |  |  |
| 3070 | **Connection Type and Meter Type Misalignments** |  |  |  | 76% → 78% |  |  |
| 3071 | **Traditional Meters installed on Current Transformers** |  |  |  | 44% → 48% |  |  |
| 3076 | Suppliers to have completed meter exchanges for those MPANs in pot 1 |  |  |  | 25% → 31% |  |  |
| 3128 | **Preparation for Cutover to Live** |  |  |  | 56% → 57% |  |  |
| 3216 | **Migration Sprints** |  |  |  | 1% → 4% |  | baseline start none → 2025-09-24; baseline finish none → 2027-05-05 |
| 3217 | **Migration Sprint 0** |  |  |  | 7% → 20% |  |  |
| 3223 | Sprint Execution Start | 2025-10-22 A | 2025-10-22 A |  | 0% → 100% | 566d → none |  |
| 3224 | Sprint Execution | 2025-10-22 A |  |  | 0% → 13% |  |  |
| 3336 | **Wave 1** | 2025-08-25 → 2026-03-31 (+218d) |  | 195d? → 39d? |  | 156d → 0d |  |
| 3359 | MDD & ISD Go-Live |  |  |  |  |  | baseline start none → 2026-04-24; baseline finish none → 2026-04-24 |
| 3361 | Seondary Publish ISD |  |  |  |  |  | baseline start none → 2026-05-01; baseline finish none → 2026-05-01 |
| 3362 | Secondary Go Live ISD |  |  |  |  |  | baseline start none → 2026-05-08; baseline finish none → 2026-05-08 |
| 3364 | MDD Final Circular Completed |  |  |  |  |  | baseline start none → 2026-04-15; baseline finish none → 2026-04-15 |
| 3365 | MDD Manual Update |  |  |  |  |  | baseline start none → 2026-04-15; baseline finish none → 2026-04-16 |
| 3366 | **Wave 1 - Service Activation Hypercare** | 2025-08-25 → 2026-04-16 (+234d) |  | 187d → 19d |  |  |  |
| 3367 | Service& Process Monitoring | 2025-08-25 → 2026-04-16 (+234d) | 2025-09-18 → 2026-05-12 (+236d) |  |  | 590d → 422d | constraint finish no earlier than 2025-09-18 → start no earlier than 2026-04-16 |
| 3368 | Daily Reporting | 2025-08-25 → 2026-04-16 (+234d) | 2025-09-18 → 2026-05-12 (+236d) |  |  | 590d → 422d | constraint finish no earlier than 2025-09-18 → start no earlier than 2026-04-16 |
| 3369 | Issue Management | 2025-08-25 → 2026-04-16 (+234d) | 2025-09-18 → 2026-05-12 (+236d) |  |  | 590d → 422d | constraint finish no earlier than 2025-09-18 → start no earlier than 2026-04-16 |
| 3372 | Non-SIT LDSO Service Activation Hypercare Complete (M) |  |  |  |  |  | constraint none → finish no earlier than 2026-05-12 |
| 3454 | Wave 4 - Service Activation Preparation Tasks Completed |  |  |  |  |  | baseline start 2022-10-31 → 2026-09-18; baseline finish 2022-11-21 → 2026-09-18 |
| 3478 | **Implement Early Life Support Plan** |  | 2025-09-19 A |  | 76% → 100% | 589d → none |  |
| 3479 | Implement Early Life Support Plan |  | 2025-09-19 A |  | 76% → 100% | 589d → none |  |

## Version 16 (data date 2025-11-19, saved 2025-11-21, file MHHS-DEL1139 - MHHS Plan v6.38.mpp)

Last finish stays 2027-12-23. Complete tasks 2472 → 2523.

Added:

| ID | Task | Duration | Start | Finish | Predecessors | Constraint |
| --- | --- | --- | --- | --- | --- | --- |
| 2312 | Post-M11 Settlement Checks | 262d | 2025-11-07 | 2026-11-09 |  | finish no earlier than 2026-11-09 |
| 2313 | **Solution Build Sprints** | 150d | 2025-09-03 A | 2026-03-31 |  |  |
| 2314 | 25.18 | 10d | 2025-09-03 A | 2025-09-16 A |  | finish no earlier than 2025-09-16 |
| 2315 | 25.19 | 10d | 2025-09-17 A | 2025-09-30 A |  | finish no earlier than 2025-09-30 |
| 2316 | 25.20 | 10d | 2025-10-01 A | 2025-10-14 A |  | finish no earlier than 2025-10-14 |
| 2317 | 25.21 | 10d | 2025-10-15 A | 2025-10-28 A |  | finish no earlier than 2025-10-28 |
| 2318 | 25.22 | 10d | 2025-10-29 A | 2025-11-11 A |  | finish no earlier than 2025-11-11 |
| 2319 | 25.23 | 10d | 2025-11-12 A | 2025-11-25 |  | finish no earlier than 2025-11-25 |
| 2320 | 25.24 | 10d | 2025-12-03 | 2025-12-16 |  | finish no earlier than 2025-12-16 |
| 2321 | 26.1 | 10d | 2026-01-07 | 2026-01-20 |  | finish no earlier than 2026-01-20 |
| 2322 | 26.2 | 10d | 2026-01-21 | 2026-02-03 |  | finish no earlier than 2026-02-03 |
| 2323 | 26.3 | 10d | 2026-02-04 | 2026-02-17 |  | finish no earlier than 2026-02-17 |
| 2324 | 26.4 | 10d | 2026-02-18 | 2026-03-03 |  | finish no earlier than 2026-03-03 |
| 2325 | 26.5 | 10d | 2026-03-04 | 2026-03-17 |  | finish no earlier than 2026-03-17 |
| 2326 | 26.6 | 10d | 2026-03-18 | 2026-03-31 |  | finish no earlier than 2026-03-31 |
| 2327 | **Release management schedule** | 321d | 2025-09-17 A | 2026-12-09 |  |  |
| 2328 | 25.14.5 | 1d | 2025-10-20 A | 2025-10-20 A |  |  |
| 2329 | 25.14.6 | 1d | 2025-11-04 A | 2025-11-04 A |  |  |
| 2330 | 25.14.7 | 1d | 2025-11-19 A | 2025-11-19 A |  |  |
| 2331 | 25.14.8 | 1d | 2025-12-02 | 2025-12-02 |  | start no earlier than 2025-12-02 |
| 2332 | 25.14.9 | 1d | 2025-12-11 | 2025-12-11 |  | start no earlier than 2025-12-11 |
| 2333 | 26.1.0 | 1d | 2026-01-22 | 2026-01-22 |  | start no earlier than 2026-01-22 |
| 2334 | 26.2.0 | 1d | 2026-02-05 | 2026-02-05 |  | start no earlier than 2026-02-05 |
| 2335 | 26.3.0 | 1d | 2026-02-19 | 2026-02-19 |  | start no earlier than 2026-02-19 |
| 2336 | 26.4.0 | 1d | 2026-03-05 | 2026-03-05 |  | start no earlier than 2026-03-05 |
| 2337 | 26.5.0 | 1d | 2026-03-19 | 2026-03-19 |  | start no earlier than 2026-03-19 |
| 2338 | **Work Package Development** | 321d | 2025-09-17 A | 2026-12-09 |  |  |
| 2339 | **DAH** | 140d | 2025-09-17 A | 2026-03-31 |  |  |
| 2340 | MSID Counts and Missing DA files (Bronze to Silver) | 10d | 2025-09-17 A | 2025-09-30 A |  |  |
| 2341 | P0276 & P0277 Reports | 10d | 2025-10-01 A | 2025-10-14 A |  |  |
| 2342 | Throughput monitoring for DIP ingestion | 30d | 2025-09-17 A | 2025-10-28 A |  |  |
| 2343 | P0213 Report | 10d | 2025-10-29 A | 2025-11-11 A |  |  |
| 2344 | P0214 Report | 10d | 2025-10-29 A | 2025-11-11 A |  |  |
| 2345 | P0275 Report | 10d | 2025-10-29 A | 2025-11-11 A |  |  |
| 2346 | Errors & warnings in new DAH table | 20d | 2025-10-15 A | 2025-11-11 A |  |  |
| 2347 | Electralink | 70d | 2025-11-12 A | 2026-02-17 |  |  |
| 2348 | CP1607 IF-51 Data Refresh (CR44) | 120d | 2025-10-15 A | 2026-03-31 |  |  |
| 2349 | CP1606 Supplier Start Date Correction Tools (CR45) | 90d | 2025-11-26 | 2026-03-31 |  | start no earlier than 2025-11-26 |
| 2350 | **WP2 (LSS/MDS/VAS/OP)** | 321d | 2025-09-17 A | 2026-12-09 |  |  |
| 2351 | Implementation of P0275 | 45d | 2025-10-15 A | 2025-12-16 |  |  |
| 2352 | SCCS Technial Work | 10d | 2025-10-29 A | 2025-11-11 A |  |  |
| 2353 | SCCS Report | 10d | 2025-11-12 A | 2025-11-25 |  |  |
| 2354 | LSS Publishing Load Shapes | 35d | 2025-10-29 A | 2025-12-16 |  |  |
| 2355 | Update configuration parameters into Operator Portal for LSS / VAS | 10d | 2025-09-17 A | 2025-09-30 A |  |  |
| 2356 | Operator Portal Configuration Parameters (part 1) | 20d | 2025-09-17 A | 2025-10-14 A |  |  |
| 2357 | **Settlement Checks** | 318d | 2025-09-22 A | 2026-12-09 |  |  |
| 2358 | **M10** | 296d | 2025-09-22 A | 2026-11-09 |  |  |
| 2359 | M10 Settlement Start Date | 1d | 2025-09-22 A | 2025-09-22 A | 1804 |  |
| 2360 | R1 | 1d | 2025-10-06 A | 2025-10-06 A | 2359FS+9d |  |
| 2361 | R2 | 1d | 2026-01-14 | 2026-01-14 | 2359FS+81d |  |
| 2362 | R3 | 1d | 2026-04-24 | 2026-04-24 | 2359FS+153d |  |
| 2363 | RF | 1d | 2026-11-09 | 2026-11-09 | 2359FS+294d |  |
| 2364 | **M11** | 296d | 2025-10-22 A | 2026-12-09 |  |  |
| 2365 | M11 Settlement Start Date | 1d | 2025-10-22 A | 2025-10-22 A | 3396 |  |
| 2366 | II | 1d | 2025-10-28 A | 2025-10-28 A | 2365FS+3d |  |
| 2367 | SF | 1d | 2025-11-12 A | 2025-11-12 A | 2365FS+14d |  |
| 2368 | R1 | 1d | 2025-12-09 | 2025-12-09 | 2365FS+33d |  |
| 2369 | R2 | 1d | 2026-02-13 | 2026-02-13 | 2365FS+81d |  |
| 2370 | R3 | 1d | 2026-05-28 | 2026-05-28 | 2365FS+155d |  |
| 2371 | RF | 1d | 2026-12-09 | 2026-12-09 | 2365FS+294d |  |
| 2672 | All Qualification Wave 1 Participants have submitted their initial QAD | 0d | 2025-07-14 A | 2025-07-14 A | 2671 | start no earlier than 2025-07-14 |
| 2680 | All Qualification Wave 1 Participants' to provide status of PIT completion and submit QT Test Plan | 0d | 2025-07-14 A | 2025-07-14 A | 2679 | start no earlier than 2025-07-14 |
| 2683 | All Qualification Test Plans for Wave 1 Participants approved | 0d | 2025-08-15 A | 2025-08-15 A | 2682 | start no earlier than 2025-08-15 |
| 2684 | Minimum threshold of Qualification Wave 1 Participants required for QT start have submitted PIT Test Completion Report and evidence for QT Entry | 0d | 2025-07-14 A | 2025-07-14 A |  | start no earlier than 2025-07-14 |
| 2691 | All Qualification Wave 1 Participant Test Readiness Confirmed | 0d | 2025-08-22 A | 2025-08-22 A | 2690 | start no earlier than 2025-08-22 |
| 2699 | All Qualification Wave 1 Participants have submitted their final QAD | 0d | 2026-01-16 | 2026-01-16 | 2698 | start no earlier than 2026-01-16 |
| 2702 | 80% of M14 Critical Wave 1 Participants Qualification approved by BSC PAB and REC Manager | 0d | 2026-04-15 | 2026-04-15 |  | finish no earlier than 2026-04-15 |
| 2709 | All Qualification Wave 2 Participants have submitted their initial QAD | 0d | 2025-09-12 | 2025-09-12 | 2708 | start no earlier than 2025-09-12 |
| 2717 | All Qualification Wave 2 Participants' to provide status of PIT completion and submit QT Test Plan | 0d | 2025-08-18 A | 2025-08-18 A | 2716 |  |
| 2720 | All Qualification Test Plans for Wave 2 Participants approved | 0d | 2025-09-05 A | 2025-09-05 A | 2719 |  |
| 2722 | All Qualification Wave 2 Participants have submitted PIT Test Completion Report and evidence for QT entry | 0d | 2025-09-08 A | 2025-09-08 A | 2721 |  |
| 2728 | All Qualification Wave 2 Participant Test Readiness Confirmed | 0d | 2025-10-17 A | 2025-10-17 A | 2727 |  |
| 2736 | All Qualification Wave 2 Participants have submitted their final QAD | 0d | 2026-03-06 | 2026-03-06 | 2735 |  |
| 2739 | 80% of M14 Critical Wave 2 Participants Qualification approved by BSC PAB and REC Manager | 0d | 2026-05-28 | 2026-05-28 |  | start no earlier than 2026-05-28 |
| 2746 | All Qualification Wave 3 Participants have submitted their initial QAD | 0d | 2025-11-07 | 2025-11-07 | 2745 | start no earlier than 2025-11-07 |
| 2754 | All Qualification Wave 3 Participants' to provide status of PIT completion and submit QT Test Plan | 0d | 2025-10-20 A | 2025-10-20 A | 2753 | start no earlier than 2025-10-20 |
| 2757 | All Qualification Test Plans for Wave 3 Participants approved | 0d | 2025-11-07 | 2025-11-07 | 2756 | start no earlier than 2025-11-07 |
| 2759 | All Qualification Wave 3 Participants have submitted PIT Test Completion Report and evidence for QT Entry | 0d | 2025-11-10 | 2025-11-10 | 2758 | start no earlier than 2025-11-10 |
| 2765 | All Qualification Wave 3 Participant Test Readiness confirmed | 0d | 2025-12-19 | 2025-12-19 | 2764 |  |
| 2773 | All Qualification Wave 3 Participants have submitted their Final QAD | 0d | 2026-05-22 | 2026-05-22 | 2772 | finish no earlier than 2026-05-22 |
| 2776 | 80% of M14 Critical Wave 3 Participants Qualification approved by BSC PAB and REC Manager | 0d | 2026-07-30 | 2026-07-30 |  | start no earlier than 2026-07-30 |

Removed: 3487 Training and Support Materials; 3488 Develop document; 3489 Document review and update; 3490 Training and Support Materials approved

Changed:

| ID | Task | Start | Finish | Duration | Complete | Total float | Predecessors | Other |
| --- | --- | --- | --- | --- | --- | --- | --- | --- |
| 2311 | **ELEXON / HELIX M10 - M16** | 2026-04-08 → 2025-09-03 A (-217d) | 2026-07-30 → 2026-12-09 (+132d) | 81d → 331d | 0% → 30% | 365d → 271d |  | baseline start 2026-07-01 → 2025-09-03; baseline finish 2026-07-30 → 2026-12-09 |
| 2374 | **S & A QUALIFICATION** |  |  |  | 77% → 81% |  |  |  |
| 2486 | **MHHS Qualification - Qualification Waves** |  |  |  | 71% → 76% |  |  |  |
| 2667 | **Qualification Wave 1** |  |  |  | 70% → 72% | 435d → 441d |  |  |
| 2671 | Minimum threshold of Qualification Wave 1 Participants required for QT start have submitted their initial QAD |  |  |  |  |  |  | was named Qualification Wave 1 Participants have submitted their initial QAD |
| 2679 | Minimum threshold of Qualification Wave 1 Participants' required for QT start to provide status of PIT completion and submit QT Test Plan |  |  |  |  |  |  | was named Qualification Wave 1 Participants' to provide status of PIT completion and submit QT Test Plan |
| 2682 | Minimum threshold of Qualification Test Plans for Wave 1 Participants required for QT start approved |  |  |  |  |  |  | was named Qualification Test Plans for Wave 1 Participants approved |
| 2685 | Qualification Wave 1 Participants have submitted PIT Test Completion Report and evidence for QT Entry |  |  |  |  |  | none → 2684 |  |
| 2686 | Review of Participants PIT Test Completion Report |  |  |  |  |  | 2685 → 2684 |  |
| 2688 | **Qualification Wave 1 QT Execution** |  |  |  | 55% → 64% |  |  |  |
| 2690 | Minimum threshold of Qualification Wave 1 Participant Test required for QT start Readiness Confirmed |  |  |  |  |  |  | was named ALL Qualification Wave 1 Participant Test Readiness Confirmed |
| 2693 | Qualification Wave 1 QT Execution Window |  |  |  | 53% → 62% |  |  |  |
| 2698 | 80% of M14 Critical Qualification Wave 1 Participants have submitted their final QAD |  |  |  |  |  |  | was named Qualification Wave 1 Participants have submitted their final QAD |
| 2703 | All M14 Critical Wave 1 Participants Qualification approved by BSC PAB and REC Manager |  |  |  |  |  | 2701FS+18d → 2701FS+18d, 2672, 2691, 2699 | was named Qualification Wave 1 Participants Qualification approved by BSC PAB and REC Manager |
| 2704 | **Qualification Wave 2** |  |  |  | 31% → 55% |  |  |  |
| 2705 | **Qualification Wave 2 QAD Prep** |  |  |  | 74% → 87% |  |  |  |
| 2707 | Qualification Wave 2 Participants Submit Initial QAD |  |  |  | 89% → 95% | 8d → 594d |  |  |
| 2708 | Minimum threshold of Qualification Wave 2 Participants required for QT start have submitted their initial QAD | 2025-09-12 A | 2025-09-12 A |  | 0% → 100% | 8d → none |  | was named Qualification Wave 2 Participants have submitted their initial QAD |
| 2710 | Code Bodies review of Wave 2 Participants' Initial QAD |  |  |  | 32% → 63% |  |  |  |
| 2712 | **Qualification Wave 2 Test Prep** |  | 2025-10-10 A |  | 33% → 100% | 574d → none |  |  |
| 2714 | Qualification Wave 2 Participants DIP Onboarding Window |  | 2025-09-05 A |  | 77% → 100% | 599d → none |  |  |
| 2715 | Confirmation from Qualificiation Wave 2 Participants that DIP onboarding has completed | 2025-09-05 A | 2025-09-05 A |  | 0% → 100% | 599d → none |  |  |
| 2716 | Minimum threshold of Qualification Wave 2 Participants' required for QT start to provide status of PIT completion and submit QT Test Plan | 2025-08-18 A | 2025-08-18 A |  | 0% → 100% | 2d → none |  | was named Qualification Wave 2 Participants' to provide status of PIT completion and submit QT Test Plan |
| 2718 | Review of Participants' PIT Status and QT Test Plan |  | 2025-09-05 A |  | 13% → 100% | 599d → none |  |  |
| 2719 | Minimum threshold of Qualification Test Plans for Wave 2 Participants required for QT start approved | 2025-09-05 A | 2025-09-05 A |  | 0% → 100% | 599d → none |  | was named Qualification Test Plans for Wave 2 Participants approved |
| 2721 | Minimum threshold of Qualification Wave 2 Participants required for QT start have submitted PIT Test Completion Report and evidence for QT entry | 2025-09-08 A | 2025-09-08 A |  | 0% → 100% | 2d → none |  | was named Qualification Wave 2 Participants have submitted PIT Test Completion Report and evidence for QT entry |
| 2723 | Review of Participants' PIT Test Completion Report |  | 2025-10-10 A |  | 8% → 100% | 574d → none |  |  |
| 2724 | Onboarding to QTF & ADO |  | 2025-10-10 A |  | 8% → 100% | 574d → none |  |  |
| 2725 | **Qualification Wave 2 QT Execution** |  |  |  | 17% → 27% |  |  |  |
| 2727 | Minimum threshold of Qualification Wave 2 Participant required for QT start Test Readiness Confirmed |  |  |  |  |  |  | was named Qualification Wave 2 Participant Test Readiness Confirmed |
| 2730 | Qualification Wave 2 QT Execution Window |  |  |  | 13% → 23% |  |  |  |
| 2732 | **Qualification Wave 2 Exit** |  |  |  | 9% → 17% | 404d → 410d |  |  |
| 2734 | Qualification Wave 2 Participants submit their Final QAD |  |  |  | 12% → 22% |  |  |  |
| 2735 | 80% of M14 Critical Qualification Wave 2 Participants have submitted their final QAD |  |  |  |  |  |  | was named Qualification Wave 2 Participants have submitted their final QAD |
| 2740 | All M14 Critical Wave 2 Participants Qualification approved by BSC PAB and REC Manager |  |  |  |  |  | 2738FS+28d → 2738FS+28d, 2709, 2717, 2722, 2728, 2736 | was named Qualification Wave 2 Participants Qualification approved by BSC PAB and REC Manager |
| 2741 | **Qualification Wave 3** |  |  | 254d → 254d? | 13% → 30% |  |  |  |
| 2742 | **Qualification Wave 3 QAD Prep** |  |  |  | 55% → 65% | 359d → 524d |  |  |
| 2744 | Qualification Wave 3 Participants Submit Initial QAD |  |  |  | 80% → 90% | 359d → 554d |  |  |
| 2745 | Minimum threshold of Qualification Wave 3 Participants required for QT start have submitted their initial QAD | 2025-11-07 A | 2025-11-07 A |  | 0% → 100% | 359d → none |  | was named Qualification Wave 3 Participants have submitted their initial QAD |
| 2747 | Code Bodies review of Wave 3 Participants' Initial QAD | 2025-11-10 A |  |  | 0% → 10% |  |  |  |
| 2749 | **Qualification Wave 3 Test Prep** |  |  |  | 2% → 60% |  |  |  |
| 2751 | Qualification Wave 3 Participants DIP Onboarding window |  | 2025-10-31 A |  | 6% → 100% | 389d → none |  |  |
| 2752 | Confirmation from Qualification Wave 3 Participants that DIP onboarding has completed | 2025-10-31 A | 2025-10-31 A |  | 0% → 100% | 389d → none |  |  |
| 2753 | Minimum threshold of Qualification Wave 3 Participants' required for QT start to provide status of PIT completion and submit QT Test Plan | 2025-10-20 A | 2025-10-20 A |  | 0% → 100% | 554d → none |  | was named Qualification Wave 3 Participants' to provide status of PIT completion and submit QT Test Plan |
| 2755 | Review of Participants' PIT Status and QT Test Plan | 2025-10-20 A |  |  | 0% → 75% |  |  |  |
| 2756 | Minimum threshold of Qualification Test Plans for Wave 3 Participants required for QT start approved | 2025-11-07 A | 2025-11-07 A |  | 0% → 100% | 554d → none |  | was named Qualification Test Plans for Wave 3 Participants approved |
| 2758 | Minimum threshold of Qualification Wave 3 Participants required for QT start have submitted PIT Test Completion Report and evidence for QT Entry | 2025-11-10 A | 2025-11-10 A |  | 0% → 100% | 359d → none |  | was named Qualification Wave 3 Participants have submitted PIT Test Completion Report and evidence for QT Entry |
| 2760 | Review of Participants' PIT Test Completion Report | 2025-11-10 A |  |  | 0% → 28% | 359d → 529d |  |  |
| 2761 | Onboarding to QTF & ADO | 2025-11-10 A |  |  | 0% → 28% |  |  |  |
| 2762 | **Qualification Wave 3 QT Execution** |  |  | 110d → 110d? |  |  |  |  |
| 2764 | Minimum threshold of Qualification Wave 3 Participant required for QT start Test Readiness confirmed |  |  |  |  |  |  | was named Qualification Wave 3 Participant Test Readiness confirmed |
| 2772 | 80% of M14 Critical Qualification Wave 3 Participants have submitted their Final QAD |  |  |  |  |  |  | was named Qualification Wave 3 Participants have submitted their Final QAD |
| 2777 | All M14 Critical Wave 3 Participants Qualification approved by BSC PAB and REC Manager |  |  |  |  |  | 2775FS+24d → 2775FS+24d, 2746, 2754, 2759, 2765, 2773 | was named Qualification Wave 3 Participants Qualification approved by BSC PAB and REC Manager |
| 2778 | **Qualification Wave 4** |  |  |  | 1% → 8% |  |  |  |
| 2779 | **Qualification Wave 4 QAD Prep** |  |  |  | 0% → 19% |  |  |  |
| 2781 | Qualification Wave 4 Participants Submit Initial QAD | 2025-10-20 A |  |  | 0% → 28% |  |  |  |
| 2785 | **Qualification Wave 4 Test Prep** | 2025-11-03 A |  |  | 0% → 11% |  |  |  |
| 2786 | Confirmation from Qualification 4 Participants that DIP Onboarding has commenced | 2025-11-03 A | 2025-11-03 A |  | 0% → 100% | 285d → none |  |  |
| 2787 | Qualification Wave 4 Participants DIP Onboarding Window | 2025-11-03 A |  |  | 0% → 34% |  |  |  |
| 2811 | **PAB dates** |  |  |  |  |  |  | baseline start none → 2025-01-23; baseline finish none → 2025-12-18 |
| 2830 | PAB306 | 2025-11-12 A | 2025-11-12 A |  | 0% → 100% | 552d → none |  |  |
| 3209 | **Preparation for Cutover to Live** |  |  |  | 57% → 58% |  |  |  |
| 3297 | **Migration Sprints** |  |  |  | 4% → 5% |  |  |  |
| 3298 | **Migration Sprint 0** |  |  |  | 20% → 28% |  |  |  |
| 3305 | Sprint Execution |  |  |  | 13% → 23% |  |  |  |
| 3402 | **BUSINESS & OPERATIONAL READINESS** |  |  |  | 63% → 64% |  |  |  |
| 3561 | **Early Life Support Phase** |  |  |  | 14% → 29% |  |  |  |
| 3562 | Phase 1 End |  | 2025-11-20 → 2025-11-27 (+7d) | 21d → 26d | 43% → 80% | 500d → 540d |  |  |
| 3563 | Phase 2 End |  |  |  |  |  | 3562 → 3562SS | constraint none → start no earlier than 2025-11-21 |
| 3564 | Phase 3 End/Early Life Exit |  |  |  |  |  |  | constraint none → start no earlier than 2025-12-19 |

| ID | Task | Start | Finish | Complete | Total float |
| --- | --- | --- | --- | --- | --- |
| 3575 | **Transition to New Settlement Timetable (M16)** | 2025-10-22 A |  |  |  |
| 3576 | Elexon to produce Settlement Calendar for Settlement Year 2025/2026 | 2025-10-22 A | 2025-10-22 A | 0% → 100% | 5d → none |

## Version 17 (data date 2025-12-03, saved 2025-12-03, file MHHS-DEL1139 - MHHS Plan v6.39.mpp)

Last finish stays 2027-12-23. Complete tasks 2523 → 2533.

Added:

| ID | Task | Duration | Start | Finish | Constraint |
| --- | --- | --- | --- | --- | --- |
| 2833 | PAB2026/01 | 0d | 2026-01-29 | 2026-01-29 | finish no earlier than 2026-01-29 |
| 2834 | PAB2026/02 | 0d | 2026-02-11 | 2026-02-11 | finish no earlier than 2026-02-11 |
| 2835 | PAB2026/03 | 0d | 2026-02-26 | 2026-02-26 | finish no earlier than 2026-02-26 |
| 2836 | PAB2026/04 | 0d | 2026-03-11 | 2026-03-11 | finish no earlier than 2026-03-11 |
| 2837 | PAB2026/05 | 0d | 2026-03-26 | 2026-03-26 | finish no earlier than 2026-03-26 |
| 2838 | PAB2026/06 | 0d | 2026-04-15 | 2026-04-15 | finish no earlier than 2026-04-15 |
| 2839 | PAB2026/07 | 0d | 2026-04-30 | 2026-04-30 | finish no earlier than 2026-04-30 |
| 2840 | PAB2026/08 | 0d | 2026-05-13 | 2026-05-13 | finish no earlier than 2026-05-13 |
| 2841 | PAB2026/09 | 0d | 2026-05-28 | 2026-05-28 | finish no earlier than 2026-05-28 |
| 2842 | PAB2026/10 | 0d | 2026-06-10 | 2026-06-10 | finish no earlier than 2026-06-10 |
| 2843 | PAB2026/11 | 0d | 2026-06-25 | 2026-06-25 | finish no earlier than 2026-06-25 |
| 2844 | PAB2026/12 | 0d | 2026-07-15 | 2026-07-15 | finish no earlier than 2026-07-15 |
| 2845 | PAB2026/13 | 0d | 2026-07-30 | 2026-07-30 | finish no earlier than 2026-07-30 |
| 2846 | PAB2026/14 | 0d | 2026-08-12 | 2026-08-12 | finish no earlier than 2026-08-12 |
| 2847 | PAB2026/15 | 0d | 2026-08-27 | 2026-08-27 | finish no earlier than 2026-08-27 |
| 2848 | PAB2026/16 | 0d | 2026-09-09 | 2026-09-09 | finish no earlier than 2026-09-09 |
| 2849 | PAB2026/17 | 0d | 2026-09-24 | 2026-09-24 | finish no earlier than 2026-09-24 |
| 2850 | PAB2026/18 | 0d | 2026-10-14 | 2026-10-14 | finish no earlier than 2026-10-14 |
| 2851 | PAB2026/19 | 0d | 2026-10-29 | 2026-10-29 | finish no earlier than 2026-10-29 |
| 2852 | PAB2026/20 | 0d | 2026-11-11 | 2026-11-11 | finish no earlier than 2026-11-11 |
| 2853 | PAB2026/21 | 0d | 2026-11-26 | 2026-11-26 | finish no earlier than 2026-11-26 |
| 2854 | PAB2026/22 | 0d | 2026-12-09 | 2026-12-09 | finish no earlier than 2026-12-09 |

Changed:

| ID | Task | Start | Finish | Duration | Complete | Total float | Predecessors | Other |
| --- | --- | --- | --- | --- | --- | --- | --- | --- |
| 4 | **Programme Management** |  |  |  | 67% → 69% |  |  |  |
| 5 | Sprint-based prioritisation planning and execution |  |  |  | 67% → 74% |  |  |  |
| 8 | Tracking against Programme outcomes and KPIs |  |  |  | 67% → 73% |  |  |  |
| 187 | **PP Design, Build & Test (DBT)** |  | 2025-02-21 A |  | 99% → 100% | 739d → none |  |  |
| 291 | **SIT Participants DBT** |  | 2025-02-21 A |  | 99% → 100% | 739d → none |  |  |
| 326 | **All SIT Programme Participants PIT (SIT Functional)** |  | 2025-02-21 A |  | 99% → 100% | 739d → none |  |  |
| 378 | **SIT Programme Participants PIT (SIT Operational Theme 1, 2, 3 (Batch 2))** |  | 2025-01-31 A |  | 99% → 100% | 754d → none |  |  |
| 390 | **PIT execution** |  | 2025-01-31 A |  | 99% → 100% | 754d → none |  |  |
| 394 | SIT Operational Theme 1, 2, 3 (Batch 2) PIT Completion Report MHHS Review Completed | 2025-01-31 A | 2025-01-31 A |  | 0% → 100% | 754d → none |  |  |
| 463 | **DBT Monitoring and Assurance** |  |  |  | 98% → 99% |  |  |  |
| 466 | **DBT Progress Monitoring of Consequential Change** |  |  |  | 93% → 96% |  |  |  |
| 467 | Monitor & report data cleanse progress |  |  |  | 93% → 96% |  |  |  |
| 509 | **SYSTEMS INTEGRATION TESTING (SIT)** |  |  |  | 96% → 97% |  |  |  |
| 1675 | **UIT Environment Preparation** |  |  |  | 90% → 92% |  |  |  |
| 1726 | **Onboarding and Test Data (Sandbox UIT)** |  |  |  | 38% → 47% |  |  |  |
| 1727 | LDSO Onboarding and Test Data Creation and Support |  |  |  | 67% → 79% |  |  |  |
| 1728 | Supplier & Agent Onboarding and Test Data Creation and Support |  |  |  | 18% → 26% |  |  |  |
| 1729 | **Sandbox Execution** |  |  |  | 41% → 45% |  |  |  |
| 1739 | **Sandbox Testing Execution (UIT) - Supplier & Agent Participants** |  |  |  | 18% → 26% |  |  |  |
| 1742 | Sandbox Testing Execution (UIT) - Supplier & Agent Participants |  |  |  | 18% → 26% |  |  |  |
| 2054 | **DIP UIT Onboarding** |  |  |  | 94% → 95% |  |  |  |
| 2074 | **Service Activation Readiness** |  |  |  | 94% → 95% |  |  |  |
| 2130 | **Phase 2 - Implementation** |  |  |  | 81% → 85% |  |  |  |
| 2205 | **Not M11-Ready Service Activation Implementation** |  |  |  | 0% → 46% |  |  |  |
| 2206 | **First Pathway 6 PAB** |  | 2025-11-21 A |  | 0% → 100% | 544d → none |  |  |
| 2211 | Publish ISD | 2025-11-14 A | 2025-11-21 A |  | 0% → 100% | 544d → none |  |  |
| 2212 | Go Live ISD | 2025-11-21 A | 2025-11-21 A |  | 0% → 100% | 544d → none |  |  |
| 2213 | Publish MDD | 2025-11-14 A | 2025-11-21 A |  | 0% → 100% | 544d → none |  |  |
| 2214 | MDD Go Live | 2025-11-21 A | 2025-11-21 A |  | 0% → 100% | 544d → none |  |  |
| 2215 | Service Activation Implementation Completed | 2025-11-21 A | 2025-11-21 A |  | 0% → 100% | 544d → none |  |  |
| 2311 | **ELEXON / HELIX M10 - M16** |  |  |  | 30% → 34% |  |  |  |
| 2313 | **Solution Build Sprints** |  |  |  | 43% → 49% |  |  |  |
| 2315 | 25.19 |  |  |  |  |  |  | constraint finish no earlier than 2025-09-30 → none |
| 2316 | 25.20 |  |  |  |  |  | none → 2315 | constraint finish no earlier than 2025-10-14 → none |
| 2317 | 25.21 |  |  |  |  |  | none → 2316 | constraint finish no earlier than 2025-10-28 → none |
| 2318 | 25.22 |  |  |  |  |  | none → 2317 | constraint finish no earlier than 2025-11-11 → none |
| 2319 | 25.23 |  | 2025-11-25 A |  | 60% → 100% | 542d → none | none → 2318 | constraint finish no earlier than 2025-11-25 → none |
| 2320 | 25.24 | 2025-12-03 → 2025-11-26 A (-7d) |  | 10d → 15d | 0% → 40% | 527d → 452d | none → 2319 | constraint finish no earlier than 2025-12-16 → none; baseline start 2025-12-03 → 2025-11-26 |
| 2321 | 26.1 |  |  |  |  | 502d → 452d | none → 2320FS+15d | constraint finish no earlier than 2026-01-20 → none |
| 2322 | 26.2 |  |  |  |  | 492d → 452d | none → 2321 | constraint finish no earlier than 2026-02-03 → none |
| 2323 | 26.3 |  |  |  |  | 482d → 452d | none → 2322 | constraint finish no earlier than 2026-02-17 → none |
| 2324 | 26.4 |  |  |  |  | 472d → 452d | none → 2323 | constraint finish no earlier than 2026-03-03 → none |
| 2325 | 26.5 |  |  |  |  | 462d → 452d | none → 2324 | constraint finish no earlier than 2026-03-17 → none |
| 2326 | 26.6 |  |  |  |  |  | none → 2325 | constraint finish no earlier than 2026-03-31 → none |
| 2327 | **Release management deployment schedule** |  |  |  | 43% → 48% |  |  | was named Release management schedule |
| 2338 | **Work Package Development** |  |  |  | 43% → 48% |  |  |  |
| 2339 | **DAH** |  |  |  | 35% → 40% |  |  |  |
| 2347 | Electralink |  |  |  | 9% → 23% |  |  |  |
| 2348 | CP1607 IF-51 Data Refresh (CR044) |  |  |  | 22% → 30% |  |  | was named CP1607 IF-51 Data Refresh (CR44) |
| 2349 | CP1606 Supplier Start Date Correction Tools (CR045) |  |  |  |  |  |  | was named CP1606 Supplier Start Date Correction Tools (CR45) |
| 2350 | **WP2 (LSS/MDS/VAS/OP)** |  |  |  | 65% → 71% |  |  |  |
| 2352 | SCCS Technical Work |  |  |  |  |  |  | was named SCCS Technial Work |
| 2353 | SCCS Report |  | 2025-11-25 A |  | 60% → 100% | 542d → none |  |  |
| 2354 | LSS Publishing Load Shapes |  |  |  | 46% → 57% |  |  |  |
| 2374 | **S & A QUALIFICATION** |  |  |  | 81% → 82% |  |  |  |
| 2486 | **MHHS Qualification - Qualification Waves** |  |  |  | 76% → 77% |  |  |  |
| 2667 | **Qualification Wave 1** |  |  |  | 72% → 78% |  |  |  |
| 2688 | **Qualification Wave 1 QT Execution** |  |  |  | 64% → 88% |  |  |  |
| 2693 | Qualification Wave 1 QT Execution Window |  |  |  | 62% → 87% |  |  |  |
| 2704 | **Qualification Wave 2** |  |  |  | 55% → 64% |  |  |  |
| 2725 | **Qualification Wave 2 QT Execution** |  |  |  | 27% → 68% |  |  |  |
| 2730 | Qualification Wave 2 QT Execution Window |  |  |  | 23% → 66% |  |  |  |
| 2778 | **Qualification Wave 4** |  |  |  | 8% → 9% |  |  |  |
| 2779 | **Qualification Wave 4 QAD Prep** |  |  |  | 19% → 14% |  |  |  |
| 2781 | Qualification Wave 4 Participants Submit Initial QAD |  |  |  | 28% → 20% |  |  |  |
| 2785 | **Qualification Wave 4 Test Prep** |  |  |  | 11% → 19% |  |  |  |
| 2787 | Qualification Wave 4 Participants DIP Onboarding Window |  |  |  | 34% → 60% |  |  |  |
| 2811 | **PAB dates** |  | 2025-12-18 → 2026-12-09 (+356d) | 235d → 490d |  | 526d → 271d |  |  |
| 2831 | PAB307 | 2025-11-27 A | 2025-11-27 A |  | 0% → 100% | 541d → none |  |  |
| 3006 | **MIGRATION** |  |  |  | 89% → 90% |  |  |  |

| ID | Task | Start | Finish | Duration | Complete | Total float | Other |
| --- | --- | --- | --- | --- | --- | --- | --- |
| 3007 | **Regulatory Governance** |  |  |  | 85% → 86% |  |  |
| 3010 | Ofgem Incentives Approval |  |  |  | 75% → 77% |  |  |
| 3099 | **Migration Artefact Development and Publication** |  |  |  | 89% → 90% |  |  |
| 3173 | **Connection Type and Meter Type Misalignments** |  |  |  | 78% → 79% |  |  |
| 3174 | **Traditional Meters installed on Current Transformers** |  |  |  | 48% → 52% |  |  |
| 3179 | Suppliers to have completed meter exchanges for those MPANs in pot 1 |  |  |  | 31% → 36% |  |  |
| 3231 | **Preparation for Cutover to Live** |  |  |  | 58% → 59% |  |  |
| 3319 | **Migration Sprints** |  |  |  | 5% → 8% |  |  |
| 3320 | **Migration Sprint 0** |  |  |  | 28% → 46% |  |  |
| 3327 | Sprint Execution |  |  |  | 23% → 41% |  |  |
| 3424 | **BUSINESS & OPERATIONAL READINESS** |  |  |  | 64% → 66% |  |  |
| 3425 | **Service Management** |  |  |  | 69% → 74% |  |  |
| 3436 | **Service Management Arrangements Implementation** |  |  |  | 84% → 94% |  |  |
| 3437 | Hypercare post M10 | 2025-09-23 A |  |  | 0% → 63% |  |  |
| 3576 | **Service Activation Transition Completion** |  |  |  |  |  | baseline start none → 2026-10-12; baseline finish none → 2026-10-16 |
| 3577 | Lessons Learnt Review |  |  |  |  |  | baseline start none → 2026-10-19; baseline finish none → 2026-11-06 |
| 3578 | Document and circulate Lessons Learnt |  |  |  |  |  | baseline start none → 2026-11-09; baseline finish none → 2026-11-14 |
| 3579 | Handover to Elexon |  |  |  |  |  | baseline start none → 2026-11-14; baseline finish none → 2026-11-14 |
| 3580 | Service Activation Transition Completed |  |  |  |  |  | baseline start none → 2026-11-14; baseline finish none → 2026-11-14 |
| 3583 | **Early Life Support Phase** |  | 2026-01-22 → 2026-01-27 (+5d) | 66d → 69d | 29% → 46% | 500d → 497d |  |
| 3584 | Phase 1 End |  | 2025-11-27 A |  | 80% → 100% | 540d → none |  |
| 3585 | Phase 2 End | 2025-11-21 A |  |  | 0% → 40% | 500d → 497d |  |
| 3586 | Phase 3 End/Early Life Exit |  | 2026-01-22 → 2026-01-27 (+5d) | 25d → 28d |  | 500d → 497d | baseline finish 2026-01-22 → 2026-01-27 |

## Version 18 (data date 2025-12-17, saved 2025-12-17, file MHHS-DEL1139 - MHHS Plan v6.40.mpp)

Last finish stays 2027-12-23. Complete tasks 2533 → 2550.

Removed: 2312 Post-M11 Settlement Checks

Changed:

| ID | Task | Start | Finish | Duration | Complete | Total float | Predecessors | Other |
| --- | --- | --- | --- | --- | --- | --- | --- | --- |
| 1 | **PROGRAMME PLAN.** |  |  |  | 83% → 86% |  |  |  |
| 3 | **PROGRAMME MANAGEMENT** |  |  |  | 68% → 75% |  |  |  |
| 4 | **Programme Management** |  |  |  | 69% → 75% |  |  |  |
| 5 | Sprint-based prioritisation planning and execution |  |  |  | 74% → 75% |  |  |  |
| 6 | Programme governance secretariat |  |  |  | 67% → 75% |  |  |  |
| 7 | RAID management and reporting |  |  |  | 67% → 75% |  |  |  |
| 8 | Tracking against Programme outcomes and KPIs |  |  |  | 73% → 75% |  |  |  |
| 9 | Change control and reporting |  |  |  | 67% → 75% |  |  |  |
| 10 | Ongoing identification of lessons learned relating to the PMO and implementation of improvements |  |  |  | 67% → 75% |  |  |  |
| 11 | **Programme Internal Assurance Reviews** |  |  |  | 67% → 75% |  |  |  |
| 12 | Programme Internal Assurance Reviews |  |  |  | 67% → 75% |  |  |  |
| 13 | **Engagement with PPs** |  |  |  | 67% → 75% |  |  |  |
| 14 | Ongoing PP liaison activities |  |  |  | 67% → 75% |  |  |  |
| 15 | Milestone and Control Point objective setting |  |  |  | 67% → 75% |  |  |  |
| 16 | Reporting |  |  |  | 67% → 75% |  |  |  |
| 17 | **PP Engagement Events** |  |  |  | 67% → 75% |  |  |  |
| 18 | Bilateral meetings |  |  |  | 67% → 75% |  |  |  |
| 19 | Monthly webinars |  |  |  | 67% → 75% |  |  |  |
| 20 | Open days |  |  |  | 67% → 75% |  |  |  |
| 21 | **PP Communications** |  |  |  | 67% → 75% |  |  |  |
| 22 | The Clock updates (weekly) |  |  |  | 67% → 75% |  |  |  |
| 23 | Maintain and update content on public-facing Portal (and ongoing feedback reviews to identify and implement Portal improvements) |  |  |  | 67% → 75% |  |  |  |
| 24 | **Code Change Support / Other Programme Alignment** |  |  |  | 67% → 75% |  |  |  |
| 25 | Support DCC/BEIS on SEC change |  |  |  | 67% → 75% |  |  |  |
| 26 | Support on Smart Meters Act changes |  |  |  | 67% → 75% |  |  |  |
| 27 | Support DCC/RECCo on CSS change |  |  |  | 67% → 75% |  |  |  |
| 28 | Support Elexon on BSC change |  |  |  | 67% → 75% |  |  |  |
| 29 | Support code change inside & outside CCIAG |  |  |  | 67% → 75% |  |  |  |
| 30 | Support code change inside & outside CCAG |  |  |  | 67% → 75% |  |  |  |
| 45 | **DESIGN, BUILD & TEST (PIT)** |  |  |  | 96% → 97% |  |  |  |
| 46 | **Design Baseline & Enduring PP Support** |  |  |  | 85% → 88% |  |  |  |
| 56 | **Establish Design Change Management Processes** |  |  |  | 68% → 73% |  |  |  |
| 61 | Maintain E2E MHHS Design (post-M5 design change management processes operational) |  |  |  | 66% → 72% |  |  |  |
| 1675 | **UIT Environment Preparation** |  |  |  | 92% → 93% |  |  |  |
| 1726 | **Onboarding and Test Data (Sandbox UIT)** |  |  |  | 47% → 52% |  |  |  |
| 1727 | LDSO Onboarding and Test Data Creation and Support |  |  |  | 79% → 85% |  |  |  |
| 1728 | Supplier & Agent Onboarding and Test Data Creation and Support |  |  |  | 26% → 30% |  |  |  |
| 1933 | **HELIX / ELEXON M10 READINESS** |  | 2025-12-31 → 2026-01-13 (+13d) | 828d? → 837d? |  | 516d → 507d |  |  |
| 2054 | **DIP UIT Onboarding** |  | 2025-12-31 → 2026-01-13 (+13d) | 828d? → 837d? |  | 516d → 507d |  |  |
| 2074 | **Service Activation Readiness** |  | 2025-12-31 → 2026-01-13 (+13d) | 457d? → 466d? |  | 516d → 507d |  |  |
| 2130 | **Phase 2 - Implementation** |  | 2025-12-31 → 2026-01-13 (+13d) | 409d? → 418d? |  | 516d → 507d |  |  |
| 2205 | **Not M11-Ready Service Activation Implementation** |  | 2025-12-30 → 2026-01-13 (+14d) | 43d → 53d |  | 517d → 507d |  |  |
| 2216 | **Final Pathway 6 PAB** | 2025-12-17 → 2025-12-18 (+1d) | 2025-12-30 → 2026-01-13 (+14d) | 9d → 19d |  | 517d → 507d |  |  |
| 2217 | MHHSP Enabled Confirmation | 2025-12-17 → 2025-12-18 (+1d) | 2025-12-17 → 2025-12-18 (+1d) |  |  | 517d → 507d |  | constraint start no earlier than 2025-09-08 → start no earlier than 2025-12-18; baseline start 2025-12-17 → 2025-12-18; baseline finish 2025-12-17 → 2025-12-18 |
| 2218 | Add EFD (ISD Calendar Date) to DIP | 2025-12-17 → 2025-12-18 (+1d) | 2025-12-17 → 2025-12-18 (+1d) |  |  |  |  | baseline start 2025-12-17 → 2025-12-18; baseline finish 2025-12-17 → 2025-12-18 |
| 2221 | Publish ISD | 2025-12-22 → 2026-01-05 (+14d) | 2025-12-30 → 2026-01-13 (+14d) |  |  | 517d → 507d | 2217FS+2d → 2217FS+12d | baseline start 2025-12-22 → 2026-01-05; baseline finish 2025-12-30 → 2026-01-13 |
| 2222 | Go Live ISD | 2025-12-30 → 2026-01-13 (+14d) | 2025-12-30 → 2026-01-13 (+14d) |  |  | 517d → 507d |  | baseline start 2025-12-30 → 2026-01-13; baseline finish 2025-12-30 → 2026-01-13 |
| 2225 | Service Activation Implementation Completed | 2025-12-30 → 2026-01-13 (+14d) | 2025-12-30 → 2026-01-13 (+14d) |  |  | 517d → 507d |  | baseline start 2025-12-30 → 2026-01-13; baseline finish 2025-12-30 → 2026-01-13 |
| 2311 | **ELEXON / HELIX M10 - M16** |  |  |  | 34% → 68% |  |  |  |
| 2312 | **Solution Build Sprints** |  |  |  | 49% → 55% |  |  |  |
| 2319 | 25.24 |  | 2025-12-16 → 2025-12-19 (+3d) | 15d → 18d | 40% → 89% |  |  | baseline finish 2025-12-16 → 2025-12-19 |
| 2320 | 26.1 |  |  |  |  |  | 2319FS+15d → 2319FS+12d |  |
| 2326 | **Release management deployment schedule** |  |  |  | 48% → 75% |  |  |  |
| 2330 | 25.14.8 | 2025-12-02 → 2025-12-03 A (+1d) | 2025-12-02 → 2025-12-03 A (+1d) |  | 0% → 100% | 537d → none |  | constraint start no earlier than 2025-12-02 → finish no earlier than 2025-12-03 |
| 2331 | 25.14.9 | 2025-12-11 A | 2025-12-11 A |  | 0% → 100% | 530d → none |  |  |
| 2337 | **Work Package Development** |  |  |  | 48% → 75% |  |  |  |
| 2338 | **DAH** |  |  |  | 40% → 67% |  |  |  |
| 2346 | Electralink |  |  |  | 23% → 29% |  |  |  |
| 2347 | CP1607 IF-51 Data Refresh (CR044) |  | 2026-03-31 A |  | 30% → 100% | 452d → none |  |  |
| 2348 | CP1606 Supplier Start Date Correction Tools (CR045) | 2025-11-26 A |  |  | 0% → 18% |  |  |  |
| 2349 | **WP2 (LSS/MDS/VAS/OP)** |  |  |  | 71% → 96% |  |  |  |
| 2350 | Implementation of P0275 |  | 2025-12-16 A |  | 58% → 100% | 527d → none |  |  |
| 2353 | LSS Publishing Load Shapes |  | 2025-12-16 A |  | 57% → 100% | 527d → none |  |  |
| 2356 | **Settlement Checks** |  |  |  | 42% → 50% |  |  |  |
| 2363 | **M11** |  |  |  | 43% → 57% |  |  |  |
| 2367 | R1 | 2025-12-09 A | 2025-12-09 A |  | 0% → 100% | 532d → none |  |  |
| 2373 | **S & A QUALIFICATION** |  |  |  | 82% → 84% |  |  |  |
| 2435 | **MHHS Qualification - SIT Participants** |  | 2025-12-17 → 2026-07-30 (+225d) | 248d? → 408d? | 91% → 99% | 526d → 366d |  |  |
| 2462 | **MHHS Qualification - Not M11-Ready** |  | 2025-12-17 → 2026-07-30 (+225d) | 153d → 313d | 78% → 99% | 526d → 366d |  |  |
| 2465 | Completion of Code Bodies review of Final QAD (Not M11-Ready) | 2025-09-22 A | 2025-10-24 A |  | 0% → 100% | 564d → none |  |  |

| ID | Task | Start | Finish | Complete | Total float | Other |
| --- | --- | --- | --- | --- | --- | --- |
| 2466 | **SIT Pathway 6** | 2025-10-09 A | 2025-12-17 → 2025-12-18 (+1d) |  | 526d → 507d |  |
| 2467 | QAD Sign Off Deadline + Test Reports | 2025-10-09 A | 2025-10-09 A | 0% → 100% | 560d → none |  |
| 2468 | REC Code Manager / BSC PAB Approval of Qualification (first Pathway 6 PAB) | 2025-10-30 A | 2025-10-30 A | 0% → 100% | 560d → none |  |
| 2469 | QAD Sign Off Deadline + Test Reports | 2025-11-26 A | 2025-11-26 A | 0% → 100% | 517d → none |  |
| 2470 | REC Code Manager / BSC PAB Approval of Qualification (final Pathway 6 PAB) | 2025-12-17 → 2025-12-18 (+1d) | 2025-12-17 → 2025-12-18 (+1d) |  | 517d → 507d | constraint none → start no earlier than 2025-12-18 |
| 2471 | SIT Participants are Qualified | 2025-12-17 → 2026-07-30 (+225d) | 2025-12-17 → 2026-07-30 (+225d) |  | 526d → 366d | constraint finish no earlier than 2025-12-17 → start no earlier than 2026-07-30; baseline start 2025-12-17 → 2026-07-30; baseline finish 2025-12-17 → 2026-07-30 |
| 2485 | **MHHS Qualification - Qualification Waves** |  |  | 77% → 79% |  |  |
| 2486 | **Qualification Wave Prep** |  |  | 98% → 99% | 331d → 247d |  |
| 2524 | **Qualification Testing Framework (Test Stubs and Supporting UI)** |  |  | 98% → 99% | 331d → 247d |  |
| 2590 | **MPANs, DIP Messages, Settlement, Consumption, Reference** |  |  | 94% → 97% |  |  |
| 2640 | **Wave 3 Test Data** |  |  | 0% → 100% |  |  |
| 2641 | Test Data Request + Templates Completed | 2025-11-10 A | 2025-11-11 A | 0% → 100% | 381d → none |  |
| 2642 | Test Data Generated | 2025-11-12 A | 2025-11-13 A | 0% → 100% | 381d → none |  |
| 2643 | Test Data Loaded into QP Systems | 2025-11-14 A | 2025-12-04 A | 0% → 100% | 381d → none |  |
| 2644 | Test Data Loaded into QTF + ADO | 2025-12-05 A | 2025-12-11 A | 0% → 100% | 381d → none |  |
| 2666 | **Qualification Wave 1** |  |  | 78% → 76% |  |  |
| 2687 | **Qualification Wave 1 QT Execution** |  |  | 88% → 98% | 440d → 11.3d |  |
| 2692 | Qualification Wave 1 QT Execution Window |  |  | 87% → 98% | 440d → 11.3d |  |
| 2694 | **Qualification Wave 1 Exit** |  |  | 38% → 23% |  |  |
| 2696 | Qualification Wave 1 Participants submit their Final QAD |  |  | 50% → 25% | 435d → 6.3d |  |
| 2699 | Completion of Code Bodies review of Final QAD | 2026-01-19 A |  | 0% → 18% |  |  |
| 2703 | **Qualification Wave 2** |  |  | 64% → 69% |  |  |
| 2704 | **Qualification Wave 2 QAD Prep** |  |  | 87% → 91% |  |  |
| 2706 | Qualification Wave 2 Participants Submit Initial QAD |  | 2025-09-12 A | 95% → 100% | 594d → none |  |
| 2708 | All Qualification Wave 2 Participants have submitted their initial QAD | 2025-09-12 A | 2025-09-12 A | 0% → 100% | 588d → none |  |
| 2709 | Code Bodies review of Wave 2 Participants' Initial QAD |  |  | 63% → 67% |  |  |
| 2724 | **Qualification Wave 2 QT Execution** |  |  | 68% → 84% |  |  |
| 2729 | Qualification Wave 2 QT Execution Window |  |  | 66% → 83% |  |  |
| 2740 | **Qualification Wave 3** |  |  | 30% → 37% |  |  |
| 2741 | **Qualification Wave 3 QAD Prep** |  |  | 65% → 93% |  |  |
| 2743 | Qualification Wave 3 Participants Submit Initial QAD |  |  | 90% → 93% |  |  |
| 2746 | Code Bodies review of Wave 3 Participants' Initial QAD |  |  | 10% → 93% |  |  |
| 2748 | **Qualification Wave 3 Test Prep** |  |  | 60% → 63% |  |  |
| 2754 | Review of Participants' PIT Status and QT Test Plan |  |  | 75% → 95% |  |  |
| 2777 | **Qualification Wave 4** |  |  | 9% → 11% |  |  |
| 2778 | **Qualification Wave 4 QAD Prep** |  |  | 14% → 11% |  |  |
| 2780 | Qualification Wave 4 Participants Submit Initial QAD |  |  | 20% → 16% |  |  |
| 2784 | **Qualification Wave 4 Test Prep** |  |  | 19% → 31% |  |  |
| 2786 | Qualification Wave 4 Participants DIP Onboarding Window |  |  | 60% → 83% |  |  |
| 2789 | Review of Participants' PIT Status and QT Test Plan | 2025-12-08 A |  | 0% → 20% |  |  |
| 3006 | **Regulatory Governance** |  |  | 86% → 90% |  |  |
| 3009 | Ofgem Incentives Approval |  |  | 77% → 83% |  |  |
| 3230 | **Preparation for Cutover to Live** |  |  | 59% → 60% |  |  |
| 3318 | **Migration Sprints** |  |  | 8% → 10% |  |  |
| 3319 | **Migration Sprint 0** |  |  | 46% → 58% |  |  |
| 3326 | Sprint Execution |  |  | 41% → 55% |  |  |
| 3423 | **BUSINESS & OPERATIONAL READINESS** |  |  | 66% → 68% |  |  |
| 3582 | **Early Life Support Phase** |  |  | 46% → 62% |  |  |
| 3584 | Phase 2 End |  | 2025-12-18 A | 40% → 100% | 497d → none |  |
| 3596 | **Transition to New Settlement Timetable (M16)** |  |  | 0% → 7% |  |  |
| 3598 | Elexon monitor settlement data of migrated MPANs | 2025-10-23 A |  | 0% → 9% |  |  |

## Version 19 (data date 2026-01-13, saved 2026-01-14, file MHHS-DEL1139 - MHHS Plan v6.41.mpp)

Last finish stays 2027-12-23. Complete tasks 2550 → 2577.

Added:

| ID | Task | Duration | Start | Finish | Predecessors | Constraint |
| --- | --- | --- | --- | --- | --- | --- |
| 2349 | MDS Annual Consumption | 10d | 2026-01-07 A | 2026-01-20 | 2319FS+12d |  |
| 2350 | Missing Parms report | 30d | 2026-01-07 A | 2026-02-17 | 2319FS+12d |  |
| 2358 | MDS Annual Consumption | 10d | 2026-01-07 A | 2026-01-20 | 2319FS+12d, 2349SF | start no earlier than 2026-01-07 |
| 2359 | Missing Parms report | 20d | 2026-01-21 | 2026-02-17 | 2319FS+12d, 2350SS+10d |  |

Changed:

| ID | Task | Start | Finish | Duration | Complete | Total float | Other |
| --- | --- | --- | --- | --- | --- | --- | --- |
| 1 | **PROGRAMME PLAN.** |  |  |  | 86% → 87% |  |  |
| 1744 | **System Integration Testing - Tier 1 Milestones** |  | 2025-12-24 A |  | 99% → 100% | 521d → none |  |
| 1806 | Central systems ready for migrating MPANs (M10*) - Late Exit | 2025-12-24 A | 2025-12-24 A |  | 0% → 100% | 521d → none |  |
| 1933 | **HELIX / ELEXON M10 READINESS** |  | 2026-01-13 A |  | 98% → 100% | 507d → none |  |
| 2054 | **DIP UIT Onboarding** |  | 2026-01-13 A |  | 95% → 100% | 507d → none |  |
| 2074 | **Service Activation Readiness** |  | 2026-01-13 A |  | 95% → 100% | 507d → none |  |
| 2130 | **Phase 2 - Implementation** |  | 2026-01-13 A |  | 85% → 100% | 507d → none |  |
| 2205 | **Not M11-Ready Service Activation Implementation** |  | 2026-01-13 A |  | 46% → 100% | 507d → none |  |
| 2216 | **Final Pathway 6 PAB** | 2025-12-18 A | 2026-01-13 A |  | 0% → 100% | 507d → none |  |
| 2217 | MHHSP Enabled Confirmation | 2025-12-18 A | 2025-12-18 A |  | 0% → 100% | 507d → none |  |
| 2218 | Add EFD (ISD Calendar Date) to DIP | 2025-12-18 A | 2025-12-18 A |  | 0% → 100% | 526d → none |  |
| 2219 | Create M16 in Customer Solution | 2025-12-18 A | 2025-12-18 A |  | 0% → 100% | 525d → none |  |
| 2220 | DIP Production Success Checks | 2025-12-18 A | 2025-12-18 A |  | 0% → 100% | 525d → none |  |
| 2221 | Publish ISD | 2026-01-05 A | 2026-01-13 A |  | 0% → 100% | 507d → none |  |
| 2222 | Go Live ISD | 2026-01-13 A | 2026-01-13 A |  | 0% → 100% | 507d → none |  |
| 2223 | Publish MDD | 2025-12-22 A | 2025-12-30 A |  | 0% → 100% | 517d → none |  |
| 2224 | MDD Go Live | 2025-12-30 A | 2025-12-30 A |  | 0% → 100% | 517d → none |  |
| 2225 | Service Activation Implementation Completed | 2026-01-13 A | 2026-01-13 A |  | 0% → 100% | 507d → none |  |
| 2226 | **Not M11-Ready Service Activation Hypercare** | 2025-12-17 A | 2025-12-31 A |  | 0% → 100% | 516d → none |  |
| 2227 | Monitoring | 2025-12-17 A | 2025-12-31 A |  | 0% → 100% | 516d → none |  |
| 2228 | Reporting | 2025-12-17 A | 2025-12-31 A |  | 0% → 100% | 516d → none |  |
| 2229 | Issue Management | 2025-12-17 A | 2025-12-31 A |  | 0% → 100% | 516d → none |  |
| 2230 | Closed Down Activities | 2025-12-29 A | 2025-12-31 A |  | 0% → 100% | 516d → none |  |
| 2231 | Inform MHHSP | 2025-12-30 A | 2025-12-31 A |  | 0% → 100% | 516d → none |  |
| 2232 | Not M11-Ready Service Activation Hypercare Completed | 2025-12-31 A | 2025-12-31 A |  | 0% → 100% | 516d → none |  |
| 2311 | **ELEXON / HELIX M10 - M16** |  |  |  | 68% → 77% |  |  |
| 2312 | **Solution Build Sprints** |  |  |  | 55% → 59% |  |  |
| 2319 | 25.24 |  | 2025-12-19 A |  | 89% → 100% | 452d → none |  |
| 2320 | 26.1 | 2026-01-07 A |  |  | 0% → 30% |  |  |
| 2326 | **Release management deployment schedule** |  |  |  | 75% → 84% |  |  |
| 2337 | **Work Package Development** |  |  |  | 75% → 85% |  |  |
| 2338 | **DAH** |  |  |  | 67% → 88% |  |  |
| 2346 | Electralink |  | 2026-02-17 → 2026-02-03 (-14d) | 70d → 60d | 29% → 72% | 482d → 492d | baseline finish 2026-02-17 → 2026-02-03 |
| 2348 | CP1606 Supplier Start Date Correction Tools (CR045) |  | 2026-03-31 A |  | 18% → 100% | 452d → none |  |
| 2351 | **WP2 (LSS/MDS/VAS/OP)** |  |  |  | 96% → 80% |  |  |
| 2355 | LSS Publishing Load Shapes |  | 2025-12-16 A → 2026-01-20 (+35d) | 35d → 60d | 100% → 88% | none → 502d | constraint none → start no earlier than 2025-10-29; baseline finish 2025-12-16 → 2026-01-20 |
| 2377 | **S & A QUALIFICATION** |  |  |  | 84% → 86% |  |  |
| 2470 | **SIT Pathway 6** |  | 2025-12-18 A |  | 0% → 100% | 507d → none |  |
| 2474 | REC Code Manager / BSC PAB Approval of Qualification (final Pathway 6 PAB) | 2025-12-18 A | 2025-12-18 A |  | 0% → 100% | 507d → none |  |
| 2489 | **MHHS Qualification - Qualification Waves** |  |  |  | 79% → 82% |  |  |
| 2670 | **Qualification Wave 1** |  |  |  | 76% → 92% |  |  |
| 2691 | **Qualification Wave 1 QT Execution** |  | 2026-01-09 A |  | 98% → 100% | 11.3d → none |  |
| 2696 | Qualification Wave 1 QT Execution Window |  | 2026-01-09 A |  | 98% → 100% | 11.3d → none |  |
| 2697 | Qualification Wave 1 QT Projected Execution End | 2026-01-09 A | 2026-01-09 A |  | 0% → 100% | 11.3d → none |  |
| 2698 | **Qualification Wave 1 Exit** |  |  |  | 23% → 75% |  |  |
| 2700 | Qualification Wave 1 Participants submit their Final QAD |  |  |  | 25% → 94% | 6.3d → 7d |  |
| 2703 | Completion of Code Bodies review of Final QAD |  |  |  | 18% → 20% |  |  |
| 2707 | **Qualification Wave 2** |  |  |  | 69% → 74% |  |  |
| 2708 | **Qualification Wave 2 QAD Prep** |  |  |  | 91% → 92% |  |  |
| 2713 | Code Bodies review of Wave 2 Participants' Initial QAD |  |  |  | 67% → 70% |  |  |
| 2728 | **Qualification Wave 2 QT Execution** |  |  |  | 84% → 67% |  |  |
| 2733 | Qualification Wave 2 QT Execution Window |  |  |  | 83% → 65% |  |  |
| 2735 | **Qualification Wave 2 Exit** |  |  |  | 17% → 46% |  |  |
| 2737 | Qualification Wave 2 Participants submit their Final QAD |  |  |  | 22% → 59% |  |  |
| 2744 | **Qualification Wave 3** |  |  |  | 37% → 39% |  |  |
| 2765 | **Qualification Wave 3 QT Execution** | 2025-12-15 A |  |  | 0% → 7% |  |  |
| 2766 | Review Entry Criteria Evidence for each Wave 3 Participant | 2025-12-15 A |  |  | 0% → 90% | 359d → 17d |  |
| 2767 | Minimum threshold of Qualification Wave 3 Participant required for QT start Test Readiness confirmed | 2025-12-19 A | 2025-12-19 A |  | 0% → 100% | 359d → none |  |
| 2768 | All Qualification Wave 3 Participant Test Readiness confirmed | 2025-12-19 A | 2025-12-19 A |  | 0% → 100% | 518d → none |  |
| 2769 | Qualification Wave 3 Execution Start | 2026-01-12 A | 2026-01-12 A |  | 0% → 100% | 359d → none |  |
| 2770 | Qualification Wave 3 QT Execution Window | 2026-01-12 A |  |  | 0% → 2% |  |  |
| 2772 | **Qualification Wave 3 Exit** | 2026-01-12 A |  |  | 0% → 2% | 359d → 365d |  |
| 2773 | Final QAD Submission window opens | 2026-01-12 A | 2026-01-12 A |  | 0% → 100% | 359d → none |  |
| 2774 | Qualification Wave 3 Participants submit their Final QAD | 2026-01-12 A |  |  | 0% → 2% |  |  |
| 2781 | **Qualification Wave 4** |  |  |  | 11% → 13% |  |  |
| 2782 | **Qualification Wave 4 QAD Prep** |  |  |  | 11% → 18% |  |  |
| 2784 | Qualification Wave 4 Participants Submit Initial QAD |  |  |  | 16% → 26% |  |  |
| 2835 | PAB308 | 2025-12-18 A | 2025-12-18 A |  | 0% → 100% | 526d → none |  |
| 3010 | **Regulatory Governance** |  |  |  | 90% → 96% |  |  |
| 3013 | Ofgem Incentives Approval |  |  |  | 83% → 93% |  |  |

| ID | Task | Start | Finish | Duration | Complete | Total float |
| --- | --- | --- | --- | --- | --- | --- |
| 3234 | **Preparation for Cutover to Live** |  |  |  | 60% → 61% |  |
| 3322 | **Migration Sprints** |  |  |  | 10% → 11% |  |
| 3332 | **Migration Sprint 1** | 2026-01-07 A |  |  | 0% → 4% |  |
| 3333 | Sprint 1 Planning start date | 2026-01-07 A |  |  | 0% → 33% |  |
| 3420 | Load Shaping Service switched on (M13*) - Late Exit | 2025-12-24 A | 2025-12-24 A |  | 0% → 100% | 521d → none |
| 3422 | Start of 18-month migration for UMS / Advanced (M11*) - Late Exit | 2026-01-21 A | 2026-01-21 A |  | 0% → 100% | 501d → none |
| 3427 | **BUSINESS & OPERATIONAL READINESS** |  |  |  | 68% → 69% |  |
| 3586 | **Early Life Support Phase** |  |  |  | 62% → 80% |  |
| 3589 | Phase 3 End/Early Life Exit | 2025-12-19 A |  |  | 0% → 46% |  |
| 3715 | **MILESTONE RANGE CHECKPOINTS** | 2025-07-31 A → 2022-10-31 A (-1004d) |  | 442d → 1160d? |  |  |
| 3722 | **M16 milestone checkpoint** | 2027-04-12 → 2022-10-31 (-1624d) |  | 0d → 1160d? |  |  |

## Version 20 (data date 2026-01-26, saved 2026-01-28, file MHHS-DEL1139 - MHHS Plan v6.42.mpp)

Last finish stays 2027-12-23. Complete tasks 2577 → 2596.

Added:

| ID | Task | Duration | Start | Finish | Predecessors | Constraint |
| --- | --- | --- | --- | --- | --- | --- |
| 3322 | **Migration Exclusion PPIR** | 20d | 2026-02-16 | 2026-03-13 |  |  |
| 3323 | Publication of migration exclusion PPIR | 0d | 2026-02-16 | 2026-02-16 |  | start no earlier than 2026-02-16 |
| 3324 | Participant response window for PPIR | 20d | 2026-02-16 | 2026-03-13 | 3323 |  |
| 3325 | PPIR consultation window closed | 0d | 2026-03-13 | 2026-03-13 | 3324 |  |

Changed:

| ID | Task | Start | Finish | Duration | Complete | Total float | Other |
| --- | --- | --- | --- | --- | --- | --- | --- |
| 1 | **PROGRAMME PLAN.** |  |  |  | 87% → 88% |  |  |
| 3 | **PROGRAMME MANAGEMENT** |  |  |  | 75% → 78% |  |  |
| 4 | **Programme Management** |  |  |  | 75% → 78% |  |  |
| 5 | Sprint-based prioritisation planning and execution |  |  |  | 75% → 78% |  |  |
| 6 | Programme governance secretariat |  |  |  | 75% → 78% |  |  |
| 7 | RAID management and reporting |  |  |  | 75% → 78% |  |  |
| 8 | Tracking against Programme outcomes and KPIs |  |  |  | 75% → 78% |  |  |
| 9 | Change control and reporting |  |  |  | 75% → 78% |  |  |
| 10 | Ongoing identification of lessons learned relating to the PMO and implementation of improvements |  |  |  | 75% → 78% |  |  |
| 11 | **Programme Internal Assurance Reviews** |  |  |  | 75% → 78% |  |  |
| 12 | Programme Internal Assurance Reviews |  |  |  | 75% → 78% |  |  |
| 13 | **Engagement with PPs** |  |  |  | 75% → 78% |  |  |
| 14 | Ongoing PP liaison activities |  |  |  | 75% → 78% |  |  |
| 15 | Milestone and Control Point objective setting |  |  |  | 75% → 78% |  |  |
| 16 | Reporting |  |  |  | 75% → 78% |  |  |
| 17 | **PP Engagement Events** |  |  |  | 75% → 78% |  |  |
| 18 | Bilateral meetings |  |  |  | 75% → 78% |  |  |
| 19 | Monthly webinars |  |  |  | 75% → 78% |  |  |
| 20 | Open days |  |  |  | 75% → 78% |  |  |
| 21 | **PP Communications** |  |  |  | 75% → 78% |  |  |
| 22 | The Clock updates (weekly) |  |  |  | 75% → 78% |  |  |
| 23 | Maintain and update content on public-facing Portal (and ongoing feedback reviews to identify and implement Portal improvements) |  |  |  | 75% → 78% |  |  |
| 24 | **Code Change Support / Other Programme Alignment** |  |  |  | 75% → 78% |  |  |
| 25 | Support DCC/BEIS on SEC change |  |  |  | 75% → 78% |  |  |
| 26 | Support on Smart Meters Act changes |  |  |  | 75% → 78% |  |  |
| 27 | Support DCC/RECCo on CSS change |  |  |  | 75% → 78% |  |  |
| 28 | Support Elexon on BSC change |  |  |  | 75% → 78% |  |  |
| 29 | Support code change inside & outside CCIAG |  |  |  | 75% → 78% |  |  |
| 30 | Support code change inside & outside CCAG |  |  |  | 75% → 78% |  |  |
| 1726 | **Onboarding and Test Data (Sandbox UIT)** |  |  |  | 52% → 58% |  |  |
| 1727 | LDSO Onboarding and Test Data Creation and Support |  | 2026-01-22 A |  | 85% → 100% | 500d → none |  |
| 1729 | **Sandbox Execution** |  |  |  | 45% → 60% |  |  |
| 1734 | **Sandbox Testing Execution (UIT) - LDSO Participants** |  | 2026-01-22 A |  | 55% → 100% | 500d → none |  |
| 1737 | Sandbox Testing Execution (UIT) - LDSO Participants |  | 2026-01-22 A |  | 55% → 100% | 500d → none |  |
| 1738 | Sandbox Testing End (UIT) - LDSO Participants | 2026-01-22 A | 2026-01-22 A |  | 0% → 100% | 500d → none |  |
| 2377 | **S & A QUALIFICATION** |  |  |  | 86% → 88% |  |  |
| 2489 | **MHHS Qualification - Qualification Waves** |  |  |  | 82% → 84% |  |  |
| 2670 | **Qualification Wave 1** |  |  |  | 92% → 95% |  |  |
| 2698 | **Qualification Wave 1 Exit** |  |  |  | 75% → 84% |  |  |
| 2700 | Qualification Wave 1 Participants submit their Final QAD |  | 2026-01-16 A |  | 94% → 100% | 7d → none |  |
| 2701 | 80% of M14 Critical Qualification Wave 1 Participants have submitted their final QAD | 2026-01-16 A | 2026-01-16 A |  | 0% → 100% | 7d → none |  |
| 2702 | All Qualification Wave 1 Participants have submitted their final QAD | 2026-01-16 A | 2026-01-16 A |  | 0% → 100% | 498d → none |  |
| 2703 | Completion of Code Bodies review of Final QAD |  |  |  | 20% → 40% |  |  |
| 2707 | **Qualification Wave 2** |  |  |  | 74% → 75% |  |  |
| 2728 | **Qualification Wave 2 QT Execution** |  |  |  | 67% → 99% |  |  |
| 2733 | Qualification Wave 2 QT Execution Window |  |  |  | 65% → 99% |  |  |
| 2735 | **Qualification Wave 2 Exit** |  |  |  | 46% → 24% |  |  |
| 2737 | Qualification Wave 2 Participants submit their Final QAD |  |  |  | 59% → 30% |  |  |
| 2744 | **Qualification Wave 3** |  |  |  | 39% → 48% |  |  |
| 2745 | **Qualification Wave 3 QAD Prep** |  |  |  | 93% → 98% |  |  |
| 2747 | Qualification Wave 3 Participants Submit Initial QAD |  | 2025-11-07 A |  | 93% → 100% | 554d → none |  |
| 2749 | All Qualification Wave 3 Participants have submitted their initial QAD | 2025-11-07 A | 2025-11-07 A |  | 0% → 100% | 548d → none |  |
| 2752 | **Qualification Wave 3 Test Prep** |  |  |  | 63% → 82% |  |  |
| 2758 | Review of Participants' PIT Status and QT Test Plan |  | 2025-11-07 A |  | 95% → 100% | 554d → none |  |
| 2760 | All Qualification Test Plans for Wave 3 Participants approved | 2025-11-07 A | 2025-11-07 A |  | 0% → 100% | 554d → none |  |
| 2764 | Onboarding to QTF & ADO |  | 2025-12-12 A |  | 28% → 100% | 4.5d → none |  |
| 2765 | **Qualification Wave 3 QT Execution** |  |  |  | 7% → 19% |  |  |
| 2766 | Review Entry Criteria Evidence for each Wave 3 Participant |  | 2025-12-19 A |  | 90% → 100% | 17d → none |  |
| 2770 | Qualification Wave 3 QT Execution Window |  |  |  | 2% → 14% |  |  |
| 2781 | **Qualification Wave 4** |  |  |  | 13% → 26% |  |  |
| 2782 | **Qualification Wave 4 QAD Prep** |  |  |  | 18% → 69% |  |  |
| 2784 | Qualification Wave 4 Participants Submit Initial QAD |  |  |  | 26% → 90% | 235d → 7.5d |  |
| 2786 | Code Bodies review of Wave 4 Participants' Initial QAD | 2026-01-19 A |  |  | 0% → 25% |  |  |
| 2788 | **Qualification Wave 4 Test Prep** |  |  |  | 31% → 38% |  |  |
| 2793 | Review of Participants' PIT Status and QT Test Plan |  |  |  | 20% → 50% |  |  |
| 3009 | **MIGRATION** |  |  |  | 90% → 91% |  |  |
| 3010 | **Regulatory Governance** |  | 2026-01-23 → 2026-02-27 (+35d) | 475d → 500d | 96% → 88% | 499d → 474d |  |
| 3013 | Ofgem Incentives Approval |  | 2026-01-23 → 2026-02-27 (+35d) | 161d → 186d | 93% → 81% | 499d → 474d | constraint start no earlier than 2025-06-13 → finish no earlier than 2026-02-27; baseline finish 2026-01-23 → 2026-02-27 |
| 3014 | Incentives Implementation | 2026-01-23 → 2026-02-27 (+35d) | 2026-01-23 → 2026-02-27 (+35d) |  |  | 499d → 474d | constraint none → finish no earlier than 2026-02-27; baseline finish 2026-01-23 → 2026-02-27 |
| 3102 | **Migration Artefact Development and Publication** |  |  |  | 90% → 91% |  |  |

| ID | Task | Start | Finish | Complete | Total float |
| --- | --- | --- | --- | --- | --- |
| 3176 | **Connection Type and Meter Type Misalignments** |  |  | 79% → 82% |  |
| 3177 | **Traditional Meters installed on Current Transformers** |  |  | 52% → 58% |  |
| 3182 | Suppliers to have completed meter exchanges for those MPANs in pot 1 |  |  | 36% → 44% |  |
| 3234 | **Preparation for Cutover to Live** |  |  | 61% → 62% |  |
| 3326 | **Migration Sprints** |  |  | 11% → 18% |  |
| 3327 | **Migration Sprint 0** |  |  | 58% → 93% |  |
| 3334 | Sprint Execution |  |  | 55% → 92% |  |
| 3336 | **Migration Sprint 1** |  |  | 4% → 13% |  |
| 3337 | Sprint 1 Planning start date |  | 2026-01-14 A | 33% → 100% | 452d → none |
| 3338 | Issue Envelope | 2026-01-14 A | 2026-01-14 A | 0% → 100% | 452d → none |
| 3339 | Supplier Submission Deadline | 2026-01-21 A | 2026-01-21 A | 0% → 100% | 452d → none |
| 3340 | Baseline Schedule Publication | 2026-01-28 A | 2026-01-28 A | 0% → 100% | 452d → none |
| 3341 | Migration Sprint 1 Schedule Baselined | 2026-01-28 A | 2026-01-28 A | 0% → 100% | 452d → none |
| 3428 | Start of 18-month migration for Smart / Non-smart (M12*) - Late Exit | 2026-01-21 A | 2026-01-21 A | 0% → 100% | 501d → none |
| 3431 | **BUSINESS & OPERATIONAL READINESS** |  |  | 69% → 70% |  |
| 3432 | **Service Management** |  |  | 74% → 76% |  |
| 3443 | **Service Management Arrangements Implementation** |  | 2026-01-14 A | 94% → 100% | 506d → none |
| 3444 | Hypercare post M10 |  | 2026-01-14 A | 63% → 100% | 506d → none |

## Version 21 (data date 2026-02-11, saved 2026-02-11, file MHHS-DEL1139 - MHHS Plan v6.43.mpp)

Last finish 2027-12-23 → 2148-12-31 (+44203d). Complete tasks 2596 → 2620.

Added:

| ID | Task | Duration | Start | Finish | Predecessors | Constraint |
| --- | --- | --- | --- | --- | --- | --- |
| 2349 | Trading Disputes | 20d | 2026-01-21 A | 2026-02-17 | 2318 |  |
| 2350 | Business Validations | 10d | 2026-01-21 A | 2026-02-03 A | 2318 |  |
| 2351 | Merge IF51 into main | 10d | 2026-01-07 A | 2026-01-20 A | 2317FS+12d |  |
| 2352 | Upload 350K MPANs | 10d | 2026-02-04 A | 2026-02-17 A | 2319 |  |
| 2353 | Enable batching to DIP | 10d | 2026-02-04 A | 2026-02-17 | 2319 |  |
| 2354 | Trading disputes test suite | 40d | 2026-02-04 A | 2026-03-31 | 2319 |  |
| 2355 | Data lifecycle | 40d | 2026-02-04 A | 2026-03-31 | 2319 |  |
| 2365 | LSS Threshold | 10d | 2026-01-21 A | 2026-02-03 A | 2318 |  |
| 2366 | Errors and Warnings / Business Validation | 10d | 2026-01-21 A | 2026-02-03 A | 2318 |  |
| 2367 | Operator portal override functionality | 10d | 2026-02-04 A | 2026-02-17 | 2319 |  |
| 2368 | **ISD** | 110d | 2025-10-01 A | 2026-03-03 |  |  |
| 2369 | **ISD Asure** | 70d | 2025-11-12 A | 2026-02-17 |  |  |
| 2370 | Validation error messages (RT and CSAD) | 70d | 2025-11-12 A | 2026-02-17 | 2315 |  |
| 2371 | LLF publication and filter | 30d | 2026-01-07 A | 2026-02-17 | 2317FS+12d |  |
| 2372 | DTID Data to EIS | 30d | 2026-01-07 A | 2026-02-17 | 2317FS+12d |  |
| 2373 | **ISD Salesforce** | 110d | 2025-10-01 A | 2026-03-03 |  |  |
| 2374 | ISD UI Alignment | 110d | 2025-10-01 A | 2026-03-03 | 2312 |  |
| 2714 | Assurance on PP Test Completion Report | 10d | 2026-01-05 A | 2026-01-16 A | 2712 |  |
| 2752 | Assurance on PP Test Completion Report | 10d | 2026-02-23 A | 2026-03-06 A | 2750 |  |
| 2790 | Assurance on PP Test Completion Report | 10d | 2026-05-11 | 2026-05-22 | 2788 |  |
| 2823 | Assurance on PP Test Completion Report | 10d | 2026-07-13 | 2026-07-24 | 2821 |  |
| 3355 | Sprint 0 Retro | 10d | 2026-02-04 A | 2026-02-17 | 3354 | start no earlier than 2026-02-04 |
| 3365 | Sprint 1 Retro | 10d | 2026-04-01 | 2026-04-14 | 3364 | start no earlier than 2026-04-01 |
| 3376 | Sprint 2 Retro | 10d | 2026-06-03 | 2026-06-16 | 3375 |  |
| 3386 | Sprint 3 Retro | 10d | 2026-08-05 | 2026-08-18 | 3385 |  |
| 3396 | Sprint 4 Retro | 10d | 2026-10-07 | 2026-10-20 | 3395 |  |
| 3406 | Sprint 5 Retro | 10d | 2026-12-02 | 2026-12-15 | 3405 |  |
| 3416 | Sprint 6 Retro | 10d | 2027-02-03 | 2027-02-16 | 3415 |  |
| 3426 | Sprint 7 Retro | 10d | 2027-04-07 | 2027-04-20 | 3425 |  |
| 3436 | Sprint 8 Retro | 10d | 2027-05-07 | 2027-05-20 | 3435 | start no earlier than 2027-05-07 |
| 3709 | **Readiness Assessment 7 - Migration Checkpoint** | 23d | 2026-03-02 | 2026-04-01 |  |  |
| 3710 | Readiness Assessment 7 survey issued | 0d | 2026-03-02 | 2026-03-02 |  | start no earlier than 2026-03-02 |
| 3711 | Draft response review point | 3d | 2026-03-06 | 2026-03-10 | 3710FS+4d |  |
| 3712 | Evidence asessment | 19d | 2026-03-06 | 2026-04-01 |  | start no earlier than 2026-03-06 |
| 3713 | Readiness Assessment 7 survey closes | 0d | 2026-03-16 | 2026-03-16 | 3710FS+11d | start no earlier than 2026-03-11 |
| 3714 | Report on Readiness Assessment 7 findings at PSG | 0d | 2026-04-01 | 2026-04-01 | 3713FS+12d |  |

Removed: 466 DBT Progress Monitoring of Consequential Change; 467 Monitor & report data cleanse progress

Changed:

| ID | Task | Start | Finish | Duration | Complete | Total float | Predecessors | Other |
| --- | --- | --- | --- | --- | --- | --- | --- | --- |
| 1 | **PROGRAMME PLAN.** |  |  |  | 88% → 87% |  |  |  |
| 3 | **PROGRAMME MANAGEMENT** |  | 2026-12-31 → 2148-12-31 (+44560d) | 1089d → 32917d | 78% → 74% | 255d → 0d |  |  |
| 4 | **Programme Management** |  |  |  | 78% → 79% | 255d → 31828d |  |  |
| 5 | Sprint-based prioritisation planning and execution |  |  |  | 78% → 79% | 255d → 31828d |  |  |
| 6 | Programme governance secretariat |  |  |  | 78% → 79% | 255d → 31828d |  |  |
| 7 | RAID management and reporting |  |  |  | 78% → 79% | 255d → 31828d |  |  |
| 8 | Tracking against Programme outcomes and KPIs |  |  |  | 78% → 79% | 255d → 31828d |  |  |
| 9 | Change control and reporting |  |  |  | 78% → 79% | 255d → 31828d |  |  |
| 10 | Ongoing identification of lessons learned relating to the PMO and implementation of improvements |  |  |  | 78% → 79% | 255d → 31828d |  |  |
| 11 | **Programme Internal Assurance Reviews** |  |  |  | 78% → 79% | 255d → 31828d |  |  |
| 12 | Programme Internal Assurance Reviews |  |  |  | 78% → 79% | 255d → 31828d |  |  |
| 13 | **Engagement with PPs** |  | 2026-12-31 → 2148-12-31 (+44560d) | 1089d → 32917d | 78% → 67% | 255d → 0d |  |  |
| 14 | Ongoing PP liaison activities |  |  |  | 78% → 79% | 255d → 31828d |  |  |
| 15 | Milestone and Control Point objective setting |  |  |  | 78% → 79% | 255d → 31828d |  |  |
| 16 | Reporting |  |  |  | 78% → 79% | 255d → 31828d |  |  |
| 17 | **PP Engagement Events** |  |  |  | 78% → 79% | 255d → 31828d |  |  |
| 18 | Bilateral meetings |  |  |  | 78% → 79% | 255d → 31828d |  |  |
| 19 | Monthly webinars |  |  |  | 78% → 79% | 255d → 31828d |  |  |
| 20 | Open days |  |  |  | 78% → 79% | 255d → 31828d |  |  |
| 21 | **PP Communications** |  | 2026-12-30 → 2148-12-31 (+44561d) | 1088d → 32917d | 78% → 46% | 256d → 0d |  |  |
| 22 | The Clock updates (weekly) |  | 2026-12-30 → 2148-12-31 (+44561d) | 1088d → 2654d | 78% → 32% | 256d → 0d |  |  |
| 23 | Maintain and update content on public-facing Portal (and ongoing feedback reviews to identify and implement Portal improvements) |  |  |  | 78% → 79% | 256d → 31829d |  |  |
| 24 | **Code Change Support / Other Programme Alignment** |  |  |  | 78% → 79% | 255d → 31828d |  |  |
| 25 | Support DCC/BEIS on SEC change |  |  |  | 78% → 79% | 255d → 31828d |  |  |
| 26 | Support on Smart Meters Act changes |  |  |  | 78% → 79% | 255d → 31828d |  |  |
| 27 | Support DCC/RECCo on CSS change |  |  |  | 78% → 79% | 255d → 31828d |  |  |
| 28 | Support Elexon on BSC change |  |  |  | 78% → 79% | 255d → 31828d |  |  |
| 29 | Support code change inside & outside CCIAG |  |  |  | 78% → 79% | 255d → 31828d |  |  |
| 30 | Support code change inside & outside CCAG |  |  |  | 78% → 79% | 255d → 31828d |  |  |
| 46 | **Design Baseline & Enduring PP Support** |  |  |  | 88% → 90% | 243d → 31816d |  |  |
| 56 | **Establish Design Change Management Processes** |  |  |  | 73% → 77% | 243d → 31816d |  |  |
| 61 | Maintain E2E MHHS Design (post-M5 design change management processes operational) |  |  |  | 72% → 76% | 243d → 31816d |  |  |
| 463 | **DBT Monitoring and Assurance** |  | 2026-01-20 → 2025-08-06 A (-167d) | 842d → 723d | 99% → 100% | 502d → none |  |  |
| 507 | **SYSTEMS INTEGRATION TESTING (SIT)** |  |  |  | 97% → 98% |  |  |  |
| 1673 | **UIT Environment Preparation** |  |  |  | 93% → 95% | 344d → 31917d |  |  |
| 1724 | **Onboarding and Test Data (Sandbox UIT)** |  |  |  | 58% → 67% | 344d → 31917d |  |  |
| 1726 | Supplier & Agent Onboarding and Test Data Creation and Support |  |  |  | 30% → 45% | 344d → 31917d |  |  |
| 1727 | **Sandbox Execution** |  |  |  | 60% → 71% | 344d → 31917d |  |  |
| 1737 | **Sandbox Testing Execution (UIT) - Supplier & Agent Participants** |  |  |  | 26% → 45% | 344d → 31917d |  |  |
| 1740 | Sandbox Testing Execution (UIT) - Supplier & Agent Participants |  |  |  | 26% → 45% | 344d → 31917d |  |  |
| 2309 | **ELEXON / HELIX M10 - M16** |  |  |  | 77% → 84% | 271d → 31844d |  |  |
| 2310 | **Solution Build Sprints** |  |  |  | 59% → 75% | 452d → 32025d |  |  |
| 2318 | 26.1 |  | 2026-01-20 A |  | 30% → 100% | 452d → none |  |  |
| 2319 | 26.2 | 2026-01-21 A | 2026-02-03 A |  | 0% → 100% | 452d → none |  |  |
| 2320 | 26.3 | 2026-02-04 A |  |  | 0% → 60% | 452d → 32025d |  |  |
| 2324 | **Release management deployment schedule** |  |  |  | 84% → 87% | 271d → 31844d |  |  |
| 2330 | 26.1.0 | 2026-01-22 → 2026-01-28 A (+6d) | 2026-01-22 → 2026-01-28 A (+6d) |  | 0% → 100% | 500d → none |  | constraint start no earlier than 2026-01-22 → finish no earlier than 2026-01-28 |
| 2331 | 26.2.0 | 2026-02-05 A | 2026-02-05 A |  | 0% → 100% | 490d → none |  |  |
| 2335 | **Work Package Development** |  |  |  | 85% → 87% | 271d → 31844d |  |  |
| 2336 | **DAH** |  |  |  | 88% → 85% | 452d → 32025d |  |  |
| 2344 | Electralink |  | 2026-02-03 A |  | 72% → 100% | 492d → none |  |  |
| 2347 | MDS Annual Consumption |  | 2026-01-20 A |  | 30% → 100% | 502d → none |  |  |
| 2348 | Missing Parms report |  | 2026-02-17 A |  | 10% → 100% | 482d → none |  |  |
| 2356 | **WP2 (LSS/MDS/VAS/OP)** |  | 2026-12-09 → 2026-02-17 (-295d) | 321d → 110d | 80% → 97% | 271d → 32055d |  |  |
| 2360 | LSS Publishing Load Shapes |  | 2026-01-20 A |  | 88% → 100% | 502d → none |  |  |
| 2363 | MDS Annual Consumption |  | 2026-01-20 A |  | 30% → 100% | 502d → none |  |  |
| 2364 | Missing Parms report | 2026-01-21 → 2026-01-22 A (+1d) | 2026-02-17 → 2026-02-04 A (-13d) | 20d → 10d | 0% → 100% | 482d → none |  | constraint none → finish no earlier than 2026-02-04 |
| 2375 | **Settlement Checks** |  |  |  | 50% → 58% | 271d → 31844d |  |  |
| 2376 | **M10** |  |  |  | 40% → 60% | 293d → 31866d |  |  |
| 2379 | R2 | 2026-01-14 A | 2026-01-14 A |  | 0% → 100% | 506d → none |  |  |
| 2504 | **MHHS Qualification - Qualification Waves** |  |  |  | 84% → 85% | 235d → 31808d |  |  |
| 2664 | **Wave 4 Test Data** | 2025-11-06 → 2026-01-19 A (+74d) | 2026-01-08 → 2026-02-19 (+42d) | 45d → 24d | 0% → 8% |  |  |  |
| 2665 | Test Data Request + Templates Completed | 2026-01-19 A |  |  | 0% → 50% | 247d → 1d |  |  |
| 2666 | Test Data Generated | 2026-01-21 A |  |  | 0% → 50% | 247d → 31820d |  |  |
| 2685 | **Qualification Wave 1** |  |  |  | 95% → 96% | 441d → 32014d |  |  |
| 2706 | **Qualification Wave 1 QT Execution** |  | 2026-01-09 A → 2026-01-02 A (-7d) | 105d → 100d |  |  |  |  |
| 2711 | Qualification Wave 1 QT Execution Window |  | 2026-01-09 A → 2026-01-02 A (-7d) | 100d → 95d |  |  |  |  |
| 2712 | Qualification Wave 1 QT Projected Execution End | 2026-01-09 A → 2026-01-02 A (-7d) | 2026-01-09 A → 2026-01-02 A (-7d) |  |  |  |  |  |
| 2713 | **Qualification Wave 1 Exit** |  |  |  | 84% → 89% | 441d → 32014d |  |  |
| 2716 | Qualification Wave 1 Participants submit their Final QAD |  |  |  |  |  | 2715FS-1d → 2715FS-1d, 2714FF |  |

| ID | Task | Start | Finish | Duration | Complete | Total float | Predecessors | Other |
| --- | --- | --- | --- | --- | --- | --- | --- | --- |
| 2719 | Completion of Code Bodies review of Final QAD |  |  |  | 40% → 55% | 435d → 0.3d |  |  |
| 2720 | QAD Sign Off deadline | 2026-03-20 A |  |  | 0% → 30% | 435d → 32008d |  |  |
| 2723 | **Qualification Wave 2** |  |  |  | 75% → 78% | 410d → 31983d |  |  |
| 2724 | **Qualification Wave 2 QAD Prep** |  |  |  | 92% → 97% | 569d → 32142d |  |  |
| 2729 | Code Bodies review of Wave 2 Participants' Initial QAD |  |  |  | 70% → 90% | 569d → 32142d |  |  |
| 2744 | **Qualification Wave 2 QT Execution** |  | 2026-02-27 → 2026-02-20 (-7d) | 100d → 95d |  | 409d → 31987d |  |  |
| 2749 | Qualification Wave 2 QT Execution Window |  | 2026-02-27 → 2026-02-20 (-7d) | 95d → 90d |  | 409d → 31987d |  |  |
| 2750 | Qualfication Wave 2 QT Execution End | 2026-02-27 → 2026-02-20 (-7d) | 2026-02-27 → 2026-02-20 (-7d) |  |  | 409d → 31987d |  |  |
| 2751 | **Qualification Wave 2 Exit** |  |  |  | 24% → 33% | 410d → 31983d |  |  |
| 2754 | Qualification Wave 2 Participants submit their Final QAD |  |  |  | 30% → 35% | 404d → 31977d | 2753FS-1d → 2753FS-1d, 2752FF |  |
| 2761 | **Qualification Wave 3** |  |  |  | 48% → 52% | 365d → 31938d |  |  |
| 2779 | All Qualification Wave 3 Participants have submitted PIT Test Completion Report and evidence for QT Entry | 2025-11-10 A | 2025-11-10 A |  | 0% → 100% | 548d → none |  |  |
| 2782 | **Qualification Wave 3 QT Execution** |  |  |  | 19% → 41% |  |  |  |
| 2787 | Qualification Wave 3 QT Execution Window |  | 2026-05-15 → 2026-05-08 (-7d) | 90d → 85d | 14% → 38% | 364d → 31932d |  |  |
| 2788 | Qualification Wave 3 Projected Execution End | 2026-05-15 → 2026-05-08 (-7d) | 2026-05-15 → 2026-05-08 (-7d) |  |  | 364d → 31932d |  |  |
| 2792 | Qualification Wave 3 Participants submit their Final QAD |  |  |  |  | 359d → 31932d | 2791FS-1d → 2791FS-1d, 2790FF |  |
| 2799 | **Qualification Wave 4** |  |  |  | 26% → 29% | 235d → 31808d |  |  |
| 2800 | **Qualification Wave 4 QAD Prep** |  |  |  | 69% → 83% | 235d → 31808d |  |  |
| 2802 | Qualification Wave 4 Participants Submit Initial QAD |  |  |  | 90% → 98% | 7.5d → 15d |  |  |
| 2804 | Code Bodies review of Wave 4 Participants' Initial QAD |  |  |  | 25% → 50% | 235d → 31808d |  |  |
| 2806 | **Qualification Wave 4 Test Prep** |  |  |  | 38% → 41% | 251d → 31824d |  |  |
| 2808 | Qualification Wave 4 Participants DIP Onboarding Window |  |  |  | 83% → 81% | 285d → 31858d |  |  |
| 2811 | Review of Participants' PIT Status and QT Test Plan |  |  |  | 50% → 69% | 251d → 31824d |  |  |
| 2816 | **Qualification Wave 4 QT Execution** |  | 2026-07-17 → 2026-07-10 (-7d) | 100d → 95d |  | 235d → 31808d |  |  |
| 2820 | Qualification Wave 4 QT Execution Window |  | 2026-07-17 → 2026-07-10 (-7d) | 95d → 90d |  | 240d → 31808d |  |  |
| 2821 | Qualification Wave 4 Projected Execution End | 2026-07-17 → 2026-07-10 (-7d) | 2026-07-17 → 2026-07-10 (-7d) |  |  | 240d → 31808d |  |  |
| 2825 | Qualification Wave 4 Participants submit their Final QAD |  |  |  |  | 235d → 31808d | 2824FS-1d → 2824FS-1d, 2823FF |  |
| 2855 | PAB2026/01 | 2026-01-29 A | 2026-01-29 A |  | 0% → 100% | 495d → none |  |  |
| 2856 | PAB2026/02 | 2026-02-11 A | 2026-02-11 A |  | 0% → 100% | 486d → none |  |  |
| 3028 | **MIGRATION** |  |  |  | 91% → 90% | 98d → 31671d |  |  |
| 3029 | **Regulatory Governance** |  |  |  | 88% → 96% | 474d → 32047d |  |  |
| 3032 | Ofgem Incentives Approval |  |  |  | 81% → 94% | 474d → 32047d |  |  |
| 3121 | **Migration Artefact Development and Publication** |  |  |  | 91% → 92% | 301d → 31874d |  |  |
| 3195 | **Connection Type and Meter Type Misalignments** |  |  |  | 82% → 84% | 301d → 31874d |  |  |
| 3196 | **Traditional Meters installed on Current Transformers** |  |  |  | 58% → 63% | 301d → 31874d |  |  |
| 3201 | Suppliers to have completed meter exchanges for those MPANs in pot 1 |  |  |  | 44% → 50% | 301d → 31874d |  |  |
| 3253 | **Preparation for Cutover to Live** |  | 2027-05-05 → 2027-05-20 (+15d) | 763d? → 774d? | 62% → 59% | 166d → 31728d |  |  |
| 3345 | **Migration Sprints** |  | 2027-05-05 → 2027-05-20 (+15d) | 421d → 432d |  | 166d → 31728d |  |  |
| 3346 | **Migration Sprint 0** |  | 2026-02-03 → 2026-02-17 (+14d) | 95d → 105d | 93% → 95% | 492d → 32055d |  |  |
| 3353 | Sprint Execution |  | 2026-02-03 A |  | 92% → 100% | 492d → none |  |  |
| 3354 | Sprint Execution End | 2026-02-03 A | 2026-02-03 A |  | 0% → 100% | 492d → none |  |  |
| 3356 | **Migration Sprint 1** |  | 2026-03-31 → 2026-04-14 (+14d) | 60d → 70d | 13% → 18% | 452d → 32015d |  |  |
| 3362 | Sprint Execution Start | 2026-02-04 A | 2026-02-04 A |  | 0% → 100% | 452d → none |  |  |
| 3363 | Sprint Execution | 2026-02-05 A |  |  | 0% → 10% | 452d → 32015d |  |  |
| 3366 | **Migration Sprint 2** |  | 2026-06-02 → 2026-06-16 (+14d) | 65d → 75d |  | 407d → 31970d |  |  |
| 3377 | **Migration Sprint 3** |  | 2026-08-04 → 2026-08-18 (+14d) | 65d → 75d |  | 362d → 31925d |  |  |
| 3387 | **Migration Sprint 4** |  | 2026-10-06 → 2026-10-20 (+14d) | 65d → 75d |  | 317d → 31880d |  |  |
| 3397 | **Migration Sprint 5** |  | 2026-12-01 → 2026-12-15 (+14d) | 60d → 70d |  | 277d → 31840d |  |  |
| 3407 | **Migration Sprint 6** |  | 2027-02-02 → 2027-02-16 (+14d) | 65d → 75d |  | 232d → 31795d |  |  |
| 3417 | **Migration Sprint 7** |  | 2027-04-06 → 2027-04-20 (+14d) | 65d → 75d |  | 187d → 31750d |  |  |
| 3427 | **Migration Sprint 8** |  | 2027-05-05 → 2027-05-20 (+15d) | 48d → 59d |  | 0d → 31573d |  |  |
| 3618 | **Early Life Support Phase** |  | 2026-01-27 → 2026-02-12 (+16d) | 69d → 81d | 80% → 99% | 497d → 32058d |  |  |
| 3621 | Phase 3 End/Early Life Exit |  | 2026-01-27 → 2026-02-12 (+16d) | 28d → 40d | 46% → 98% | 497d → 32058d |  | constraint start no earlier than 2025-12-19 → finish no earlier than 2026-02-12; baseline finish 2026-01-27 → 2026-02-12 |
| 3688 | **READINESS ASSESSMENTS** | 2023-09-05 A → 2022-10-31 A (-309d) |  | 988d → 1209d | 47% → 44% | 135d → 31708d |  |  |
| 3703 | **Readiness Assessment 7 - Migration Checkpoint** |  | 2026-03-19 → 2026-03-13 (-6d) | 49d → 45d |  | 460d → 32037d |  |  |
| 3715 | Readiness Assessment 7 - Migration Checkpoint - Completed (incl. Readiness Assessment Report approval) | 2026-03-19 → 2026-04-01 (+13d) | 2026-03-19 → 2026-04-01 (+13d) |  |  | 460d → 32024d | 3708FS+4d → 3714 | baseline start 2026-03-19 → 2026-04-01; baseline finish 2026-03-19 → 2026-04-01 |
| 3730 | **Readiness Assessments - Tier 1 Milestones** | 2025-07-01 A → 2022-10-31 A (-974d) |  | 512d → 1209d |  | 135d → 31708d |  |  |
| 3732 | Readiness Assessment 7 - Migration Checkpoint - Completed (incl. Readiness Assessment Report approval) | 2026-03-19 → 2022-10-31 (-1235d) | 2026-03-19 → 2022-10-31 (-1235d) |  |  | 460d → 32917d | 3715 → none |  |
| 3753 | **MILESTONE RANGE CHECKPOINTS** | 2022-10-31 A → 2025-07-31 A (+1004d) |  | 1160d? → 442d |  | 184d → 31757d |  |  |
| 3760 | **M16 milestone checkpoint** | 2022-10-31 → 2027-04-12 (+1624d) |  | 1160d? → 0d |  | 184d → 31757d |  |  |
